# 3GPP_Release-2000

Schedule from MS Project, 1999-01-01 to 2012-09-17, A marks actual dates.

## Calendars

- Standard: Mon-Fri 08:00-12:00, 13:00-17:00; Sat-Sun off. Exceptions (off unless hours are given): 2000-01-15 08:00-12:00, 13:00-17:00, 2009-05-30 08:00-12:00, 13:00-17:00.

## Resources

| Resource |
| --- |
| NP |
| N1 |
| N2 |
| N3 |
| N4 |
| N5 |
| TP |
| T1 |
| T2 |
| T3 |
| RP |
| R1 |
| R2 |
| R3 |
| R4 |
| SP |
| S1 |
| S2 |
| S3 |
| S4 |
| S5 |
| PCG |
| GP |
| No |
| CN4 |
| ? |
| WG G2 |
| G2 |
| G1 |
| G4 |
| G3 |
| All |
| Generic |
| MLST |
| G5 |
| S3, G2 |
| WG T2 |
| GP,G1 |
| G4,G5 |
| OMA |
| GP-G2 |
| Yes |
| GP, |
| N4, |
| GP, N1 |
| CT5 |
| C5 |
| C1 |
| C4 |
| C3 |
| C6 |
| G1, |
| 4 |
| ct |
| c,s,r |
| CT,RAN,SA |
| G2, |
| G1, G3 |
| CT6 |
| CT1 |
| CT1, CT3, CT4 |
| C1, C3, C4 |
| CP |
| R5 |
| C |
| Rel-8 |
| GP, G2 |
| R1,R4 |
| S5,C1 |
| CT,RAN,SA,GERAN |
| S3,C1,C4 |
| 5 |
| S1,C1,C3,C4,S5 |
| S1,C1,C3,C5 |
| S1,C1,C3,C4 |
| S1,S5 |
| S2,S3 |
| RAN,SA |
| RP,S5 |
| S2,CT |
| S1,CT |
| S1,CT,GERAN |
| S1,C5 |
| S3,CT |
| S4,CT |
| C1,SA |
| S1,S2 |
| S1,S4 |
| S2,S2,S3,CT |
| S2,S3,CT |
| S1,CT,GX |
| S1,S4,CT |
| S2,S2,S3,S5,CT |
| S1,S2,CT |
| S1,S2,S3,CT |
| S1,S2,S3,S5CT |
| S1,S2,S3,S5,CT |
| S2,S5,CT |
| S4,S3 |
| S1,C1 |
| CP,C1 |
| C1,C3 |
| C1,C3,C4 |
| S1,S5,CT |
| C4,C3 |
| CP,RAN,SA,GERAN |
| S1,S2,S3,S5,CP |
| S2,S3,CP |
| S2,CP |
| S1,CP,GX |
| S1,CP |
| S1,S4,CP |
| S1,S2,CP |
| S1,S2,S3,CP |
| S2,S5,CP |
| S3,CP |
| S1,S5,CP |
| RAN,SA,GERAN |
| S1,S2,S3,S5,C1,C3,C4,C6 |
| S2,S3,C1,C3,C4 |
| S2,C4 |
| S2,C1,C3,C4 |
| S2,C1,C4 |
| S2,S3,C1,C4 |
| S1,C1,C4,G2 |
| C1,C4 |
| S1,C1,C3 |
| S1,S4,C1,C3,C4 |
| S1,S2,S3,C1,C3,C4 |
| S2,S5,C3 |
| S1,S2,C1,C4 |
| S2,C1 |
| S2,C1,C3 |
| S3,C1,C3,C4 |
| S1,S5,C1,C3,C4 |
| S2,C3,C4 |
| C3,C1 |
| R2,R4 |
| R2,R5 |
| RP,R5 |
| RP,S5,R5 |
| R1,R5 |
| S1,C1,R5 |
| S1,C1,S4,R5 |
| GERAN |
| G3new |
| G1, G3new |
| C4,C1,C3 |
| R1.R4 |
| R1, R4 |
| R2,R3 |
| C3,C4 |
| S4,C3 |
| S4,C3,C1,C4 |
| S1,S2,C1 |
| S1,S2<C1,C3,C4 |
| S1,S2,C1,C3,C4 |
| S5,C1,C3,C4 |
| GP,C4 |
| C4,C1 |
| S2,S1 |
| RP,SP,GP |
| RP,SP,CP,GP |
| CP,GP,RP,SP |
| GP,C4,S4 |
| S1,C1,C4 |
| S1,S2,C3,C1 |
| R2,R4,R3 |
| CP,GP, RP,SP |
| S2,S1,C1,S5 |
| S2,S1,C1 |
| S1,C1,S4 |
| S1,S2,GP,C4,R2 |
| S1,GP,R2 |
| S1,C6 |
| S1,S2,C1,S4 |
| S2,S3,S5,C1,C3,C4 |
| S2,S5,C1 |
| S2,S3,S5 |
| CP,GP, RP,SP,TP |
| S2,C4,C1 |
| S1,C1,C4,S3 |
| S2,S5 |
| S3,C1 |
| S3,C4 |
| S1,C4 |
| S2,S5,C3,C1 |
| S2,S1,S5,C1,C4 |
| S1,R1,C3 |
| S1,C1,R2 |
| S2,S1,C1,C4 |
| S1,C1,C6 |
| GP,S4,C4,C1,C3 |
| C3,C1,C4 |
| S1,C4,C1 |
| S1,S3 |
| S1,S2,S5,C3,C4 |
| R4,G1 |
| G1,R4 |
| RP,GP |
| R4,GP |
| R3,R2 |
| C6,RP,SP |
| R5,C6 |
| CP,RP,SP |
| RP,SP,CP |
| R3,S5 |
| S1,S2,RP |
| S1,S2,S5,RP |
| S2,S1,RP |
| Rel-9 |
| S3,C6 |
| S1,S2,S3,S5,RP |
| S2,S1,S3 |
| S1,S2,S3 |
| S1,S2,S3,S5 |
| C6,R5 |
| S1,S2,RP,GP |
| S1,S2,S4,S5,RP,GP |
| GP,G2 |
| GP,GP, N1 |
| GP,S2,G1,G2 |
| GP,R2,R3,S2,G1,G2 |
| GP,S2,S5,R2,R3,G2,G1 |
| GP,R3 |
| N4,S2 |
| GP,RP |
| GP,S2,RP |
| G5,G4 |
| G4,R3 |
| S2,R2,R4 |
| S1,S2,R2,R4 |
| GP,S5 |
| S1,S2,S5 |
| R4,R5 |
| R4,R2,R3,R5 |
| S2,S5,N4,RP |
| S1,S2,S3,S5,NP |
| S2,S4,S5 |
| T2,S1,S4,S5 |
| SP,RP |
| S2,RP |
| S1,S2,CP,G2 |
| CP,SP |
| S1,G2 |
| SP,CP |
| S1,S2,S5,C3 |
| S1,C1,S3 |
| G1,G3new |
| C4, C3, C1C4 |
| C4,C3,C1 |
| S1,S2,S3,S5,R2,R3,R4 |
| S1,S2,S3,R2 |
| S2,S3,S5,C4,R2 |
| S1,S5,C1 |
| S1,S2,S3,C1,C3,C4,R2 |
| Ggp |
| S3,S2,C1,C4,G2 G3new |
| R1,R2,R3,R4 |
| R4,R1,R2,R3 |
| R4,R2,R3 |
| S1,C1,C4,R2 |
| R4,R2 |
| S2,C4,R2,R4 |
| S2,C4,R2 |
| S2,S3,S5,C3,C4,R2 |
| S1,S2,S4,T2 |
| S1,S2,S4 |
| S1,S2,S4,R5 |
| S3,S2,C1,C4,G2,G3new |
| GP,C1 |
| S1,S5,C4 |
| S1,S2,S3,S5,R2,R3,R4,GP |
| GP,C4,C3,C1 |
| SMG9 |
| SMG1 |
| SMG2 |
| N3,R5 |
| N1, N2, N4, G1, G2, R3, S1, SMG2 |
| S1,SMG1 |
| SMG1,N4 |
| N1,C1,N4,S1,T2,G2,SMG1,SMG2,SMG3,SMG7,SMG9 |
| SMG1,N2 |
| S1,S2,N2,N4 |
| N4,N2 |
| G1,G2 |
| G1,G2,C1 |
| G1,G2,N1 |
| SMG2, SMG1, SMG3, SMG4, SMG7, SMG9, SMG10, G1, G2, G3, N1, N3, T2 |
| SMG2,G1 |
| S1,G1,G2 |
| SMG1,N1,G1,G2 |
| G2,G1 |
| G1,G2,G3,S1,S2,SMG1,SMG2,SMG7,N1,N2,N3,N4,T2 |
| 23.003, 23.008, 29.060 |
| S1, S2, SMG1, SMG2, SMG12, G2, N1, N2, N4 |
| S1,S2,SMG1,SMG2,SMG12,G2,N1,N2,N4 |
| S1,SMG2,N1,N2,N4 |
| SMG1,T2 |
| S1,N1,N2,N4 |
| S1,S2,N5 |
| SMG2,SMG7,G2,T2 |
| S3,N1,N2,N3 |
| S3,N1,N2,N4 |
| SMG9,T3 |
| SMG2,SMG3,SMG7,G2,N2 |
| SMG2,N1,G1,G2 |
| S1,N2 |
| N1,N3 |
| S2,N1 |
| N1,N2,N4 |
| N2,N1,N4 |
| N2,N4 |
| S1,T3 |
| T2,N3 |
| S3,N2 |
| T2,S1 |
| S1,N4 |
| SMG1,SMG2,SMG7 |
| N1,S1,T1 |
| SMG1,SMG3 |
| N4,S2,N1 |
| S1,S2,SMG1,SMG2,SMG7,G1,G2,G3,N1,N2,N3,N4,T2 |
| SMG1,N3 |
| S1,N3 |
| CP,SP,SMG |
| CP,SP,TP,GP,SMG |
| NP,SP,TP,GP,SMG |
| NP,GP, RP,SP,TP |
| SMG2,SMG1,SMG3,SMG4,SMG7,SMG9,SMG10,G1,G2,G3,N1,N3,T2 |
| S1,N2,N4 |
| S1,S2,S3,C1,C3,C4,R2,R3 |
| R2,R3,R1,R4 |
| R2,R3,R4 |
| R2,R1,R3,R4 |
| S2,C4,R2,R3,R4 |
| S2,C4,R2,R1,R3,R4 |
| S2,S3,S5,C3,C4,R2,R3,R4 |
| R1,R2,R4 |
| R3,R1,R4 |
| S2, |
| S2,G2, |
| S1,S2,G2, |
| S1,S2,G2,R2,R3, |
| S1,S2,C4,G2,R2,R3 |
| S1,S2,N4,G2,R2,R3 |
| S1,S2,SMG1,SMG2,SMG12,G2,N1,N2,N4,R2,R3 |
| S1,SMG1,T2 |
| S1,SMG1,S2 |
| S1,N4,N2 |
| T2,N1,N3 |
| S3,N2,N4 |
| SMG1,SMG2,SMG3,SMG7,SMG9,N1,C1,N4,S1,T2,G2 |
| SMG1,N2,N4 |
| S2,T2,N1,N2,N4 |
| S1,T2 |
| S1,S2,C4 |
| S1,S2,N4,RP |
| S2,N4 |
| S1,S2,N3,N4,RP |
| S1,S2,SMG1,SMG2,SMG12,T2,G2,N1,N2,N4,R2,R3 |
| S1,T2,N1,N3 |
| S1,S2,SMG1,SMG2,SMG12,T2,G2,N1,N2,N3,N4,R2,R3 |
| S1,S2,S3,SMG1,SMG2,SMG12,G2,N1,N2,N4,R2,R3 |
| S1,S2,SMG,G1,G2,G3,N1,N2,N3,N4,T2 |
| S1,S2,SMG,T2,G2,N1,N2,N3,N4,R2,R3 |
| S1,S3,SMG,G1,G2,G3,N1,N2,N3,N4,T2 |
| S1,S3,T2,N2,N4 |
| S1,S2,SMG,T2,G1,G2,G3,N1,N2,N3,N4 |
| G2,S2 |
| T1,R5 |
| R5,T1 |
| S1,S2,S4,T1,R5 |
| S1,S2,S4,S5,T1,RP,GP |
| S1,S2,S3,S5,R2,R3,R4,GP,C1 |
| S1,S2,S3,SMG1,SMG2,SMG12,N1,N2,N4,R2,R3 |
| S1,S2,SMG,T2,N1,N2,N3,N4,R2,R3 |
| NP,SP,TP,SMG |
| S1,S2,SMG,T2,N1,N2,N3,N4 |
| SMG,N1 |
| SMG |
| S1,S2,SMG1,SMG2,SMG7,N1,N2,N3,N4,T2 |
| SMG2,SMG1,SMG3,SMG4,SMG7,SMG9,SMG10,N1,N3,T2 |
| S1,SMG |
| SMG2,SMG7,T2 |
| SMG2,S2 |
| N1,N2,N4,R3,S1,SMG |
| SMG2,SMG3,SMG7,N2 |
| SMG1,SMG2,SMG3,SMG7,SMG9,N1,C1,N4,S1,T2 |
| S1,S2,SMG,N3,N4,RP |
| S1,S2,S4,SMG,N3,N4,RP |
| S2,C1,C4,R2,R1,R3,R4 |
| R2,S2,S4 |
| G3new,R5 |
| GP,R4 |
| S2,S4,R2 |
| SP,GP |
| RP,SP |
| S2,S1,S3,S5 |
| S3,S1 |
| N4,N1,N2,S2 |
| S2,G1,G2,R2,R3 |
| S2,G1,G2 |
| G1,G2,R2,R3 |
| N4,T3 |
| S3,S2,N1,N4,T3,OMA |
| T2,S1,S4,S5,OMA |
| S2,N3 |
| S4,S1 |
| N4,N3,S1 |
| R5,G3new |
| R4,R2,R1 |
| S2,R2 |
| C3, C4,C1 |
| S3,C1,C4,C3 |
| C1,C4,C3 |
| S2,C1,C4,C3 |
| R3,R5 |
| S1,S2,C3 |
| R1,R2 |

## Schedule

| ID | WBS | Task | Type | Duration | Start | Finish | Complete | Remaining | Baseline start | Baseline finish | Baseline duration | Total slack | Constraint | Resources | Work | Actual work | Text6 | Text1 | Text2 | Text4 | Text5 | Text7 | Text8 | Text9 | Text12 |
| --- | --- | --- | --- | --- | --- | --- | --- | --- | --- | --- | --- | --- | --- | --- | --- | --- | --- | --- | --- | --- | --- | --- | --- | --- | --- |
| 1 | 1 | Version 2009 Dec 08 |  | 3318d? | 2000-01-03 | 2012-09-17 |  |  | 2000-01-03 | 2012-09-17 | 3318d? | 0d |  |  |  |  |  |  |  |  |  |  |  |  |  |
| 2 | 2 | SA3 Rel-9 Stage 2 exceptions to 03/2010 |  | 1d? | 2000-01-03 | 2000-01-03 |  |  | 2000-01-03 | 2000-01-03 | 1d? | 3317d |  |  |  |  |  |  |  |  |  |  |  |  |  |
| 3 | 3 | Rel-9 Stage 3 exceptions to 03/2010 |  | 1d | 2000-01-03 | 2000-01-03 |  |  | 2000-01-03 | 2000-01-03 | 1d | 3317d |  |  |  |  |  |  |  |  |  |  |  |  |  |
| 4 | 4 | "CTRL + a" to display all the 3GPP fields |  | 1d | 2000-01-03 | 2000-01-03 |  |  | 2000-01-03 | 2000-01-03 | 1d | 3317d |  |  |  |  |  |  |  |  |  |  |  |  |  |
| 5 | 5 | Gantt: dark blue=done; light blue=to be done; grey: previous values; black=summary |  | 1d? | 2000-01-03 | 2000-01-03 |  |  | 2000-01-03 | 2000-01-03 | 1d? | 3317d | start no earlier than 2000-01-01 |  |  |  |  |  |  |  |  |  |  |  |  |
| 7 | 6 | Release 10 Features | milestone | 0d? | 2000-01-01 | 2000-01-01 |  |  | 2000-01-01 | 2000-01-01 | 0d? | 3318d |  | RP,SP |  |  | Rel-10 |  |  |  |  |  |  |  |  |
| 8 | 7 | **Enhanced Home NodeB / eNodeB continuation of Rel-9** |  | 467d? | 2008-12-11 A | 2010-09-23 | 40% | 280.2d? | 2008-12-11 | 2010-09-23 | 467d? | 517d |  | S2 | 7464h | 2985.6h | Rel-10 | eEHNB | PCG-23 | Alcatel-Lucent | Nicolas Drevon | SP-44 | Maurice |  |  |
| 9 | 7.1 | IMS aspects of Architecture for Home NodeB |  | 466d? | 2008-12-11 A | 2010-09-23 | 40% | 279.6d? | 2008-12-11 | 2010-09-23 | 466d? | 517d | finish no earlier than 2010-09-23 | S2 | 3728h | 1491.2h | Rel-10 | EHNB-IMS | PCG-22 | Alcatel-Lucent | Nicolas Drevon | SP-42 | Maurice |  |  |
| 10 | 8 | **H(e)NB enhancements** |  | 131d? | 2009-09-24 A | 2010-03-25 | 5% | 124.7d? | 2009-09-24 | 2010-03-25 | 131d? | 647d |  | S1 | 2096h | 100.8h | Rel-10 | EHNBF | PCG-23 | NEC | joerg.swetina@nw.neclab.eu | SP-45 | Alain |  |  |
| 11 | 8.1 | H(e)NB enhancements |  | 131d? | 2009-09-24 A | 2010-03-25 | 5% | 124.7d? | 2009-09-24 | 2010-03-25 | 131d? | 647d | finish no earlier than 2010-03-25 | S1 | 1048h | 50.4h | Rel-10 | EHNBF | PCG-23 | NEC | joerg.swetina@nw.neclab.eu | SP-45 | Alain |  |  |
| 12 | 9 | **Deleted - Registration in Densely-populated area (RED)** |  | 665d? | 2007-03-12 A | 2009-09-24 A | 100% |  | 2007-03-12 | 2009-09-24 | 665d? |  |  | S1 | 9544h | 9544h | Rel-10 | RED |  | NTT DoCoMo | tanakai@nttdocomo.co.jp | SP-35 | Alain | PCG-24 | SP-46 |
| 13 | 9.1 | Deleted - Stage 1 for RED |  | 4d? | 2007-03-12 A | 2007-03-15 A | 100% |  | 2007-03-12 | 2007-03-15 | 4d? |  | start no earlier than 2007-03-12 | S1 | 32h | 32h | Rel-10 | RED |  | NTT DoCoMo | takakurat@s1.nttdocomo.co.jp | SP-35 | Alain | PCG-24 | SP-46 |
| 14 | 9.2 | Deleted - Stage 2 for RED |  | 524d? | 2007-09-25 A | 2009-09-24 A | 100% |  | 2007-09-25 | 2009-09-24 | 524d? |  | finish no earlier than 2009-09-24 | S2 | 4192h | 4192h | Rel-10 | RED |  | NTT DoCoMo | tanakai@nttdocomo.co.jp | SP-37 | Maurice | PCG-23 | SP-45 |
| 15 | 10 | **Network Improvements for Machine-Type Communications** |  | 523d? | 2008-09-18 A | 2010-09-17 | 39% | 320.49d? | 2008-09-18 | 2010-09-17 | 523d? | 521d |  | S1,S2 | 10929.2h | 4231.94h | Rel-10 | NIMTC | PCG-21 | KPN | Toon Norp (toon.norp AT tno.nl) | SP-41 | Alain |  |  |
| 16 | 10.1 | Stage 1 for NIMTC |  | 397d? | 2008-09-18 A | 2010-03-25 | 79% | 83.37d? | 2008-09-18 | 2010-03-25 | 397d? | 647d | finish no earlier than 2009-12-10 | S1 | 3176h | 2509.04h | Rel-10 | NIMTC | PCG-21 | KPN | Toon Norp (toon.norp AT tno.nl) | SP-41 | Alain |  |  |
| 17 | 10.2 | Stage 2 for NIMTC |  | 257d? | 2009-09-24 A | 2010-09-17 | 5% | 244.15d? | 2009-09-24 | 2010-09-17 | 257d? | 521d | finish no earlier than 2010-09-17 | S2 | 2056h | 102.8h | Rel-10 | NIMTC | PCG-23 | Samsung | Erik Guttman (erik.guttman@partner.samsung.com) | SP-45 | Maurice |  |  |
| 18 | 10.3 | Security for NIMTC |  | 189.15d? | 2009-12-10 | 2010-09-17 |  |  | 2009-12-10 | 2010-09-17 | 189.15d? | 521d | start no earlier than 2009-12-10 | S3 | 1513.2h |  | Rel-10 | NIMTC | PCG-24 | Samsung | Rajavelsamy R (rajvel@samsung.com) | SP-46 | Dionisio |  |  |
| 19 | 11 | **GTP-based S8 chaining** |  | 327d? | 2008-12-11 A | 2010-03-11 | 35% | 212.55d? | 2008-12-11 | 2010-03-11 | 327d? | 657d |  | S2 | 5232h | 1831.2h | Rel-10 | GTPchaining | PCG-22 | Huawei | Haining Wang (wanghaining@huawei.com) | SP-42 | Maurice |  |  |
| 20 | 11.1 | Stage 2 for GTPchaining |  | 327d? | 2008-12-11 A | 2010-03-11 | 35% | 212.55d? | 2008-12-11 | 2010-03-11 | 327d? | 657d | finish no earlier than 2010-03-11 | S2 | 2616h | 915.6h | Rel-10 | GTPchaining | PCG-22 | Huawei | Haining Wang (wanghaining@huawei.com) | SP-42 | Maurice |  |  |
| 21 | 12 | Multi Access PDN Connectivity |  | 261d? | 2009-03-13 A | 2010-03-11 | 75% | 65.25d? | 2009-03-13 | 2010-03-11 | 261d? | 657d | finish no earlier than 2010-03-11 | S2 | 2088h | 1566h | Rel-10 | MAPCON | PCG-22 | Telecom Italia | ivano.guardini@telecomitalia.it | SP-43 | Maurice |  |  |
| 22 | 13 | **IMS Service Continuity – Inter Device Transfer enhancements** |  | 266d? | 2009-06-04 A | 2010-06-10 | 58% | 113d? | 2009-06-04 | 2010-06-10 | 266d? | 592d |  | S1,S2 | 5304h | 2466.8h | Rel-10 | IMS_SC_eIDT | PCG-23 | Huawei | Amar Deol (adeol@huawei.com) | SP-44 | Alain |  |  |
| 23 | 13.1 | Stage 1 for IMS_SC_eIDT |  | 211d? | 2009-06-04 A | 2010-03-25 | 95% | 10.55d? | 2009-06-04 | 2010-03-25 | 211d? | 647d | finish no earlier than 2010-03-25 | S1 | 1688h | 1603.6h | Rel-10 | IMS_SC_eIDT | PCG-23 | Huawei | Amar Deol (adeol@huawei.com) | SP-44 | Alain |  |  |
| 24 | 13.2 | IMS Inter-UE Transfer enhancements (Stage 2) |  | 186d? | 2009-09-24 A | 2010-06-10 | 15% | 158.1d? | 2009-09-24 | 2010-06-10 | 186d? | 592d | finish no earlier than 2010-06-10 | S2 | 1488h | 223.2h | Rel-10 | IMS_SC_eIDT | PCG-23 | Huawei | HengLiang Zhang (hl_zhang@huawei.com) | SP-45 | Maurice |  |  |
| 25 | 14 | **IP-Short-Message-Gateway enhancements for CPM-SMS Interworking** |  | 192d? | 2009-09-24 A | 2010-06-18 | 52% | 93.08d? | 2009-09-24 | 2010-06-18 | 192d? | 586d |  | S1,S2,C3 | 5192.8h | 2242.48h | Rel-10 | CPM-SMS | PCG-23 | China Mobile | Qing Huang | SP-45 | Alain |  |  |
| 26 | 14.1 | Stage 1 for CPM-SMS |  | 131d? | 2009-09-24 A | 2010-03-25 | 95% | 6.55d? | 2009-09-24 | 2010-03-25 | 131d? | 647d | finish no earlier than 2010-03-25 | S1 | 1048h | 995.6h | Rel-10 | CPM-SMS | PCG-23 | China Mobile | Qing Huang | SP-45 | Alain |  |  |
| 27 | 14.2 | Stage 2 for CPM-SMS |  | 185.1d? | 2009-09-24 A | 2010-06-10 | 60% | 74.04d? | 2009-09-24 | 2010-06-10 | 185.1d? | 592d | finish no earlier than 2010-06-10 | S2 | 1480.8h | 888.48h | Rel-10 | CPM-SMS | PCG-23 | Orange | Antoine Mouquet | SP-45 | Maurice |  |  |
| 28 | 14.3 | Stage 3 for CPM-SMS |  | 141d? | 2009-12-04 | 2010-06-18 |  |  | 2009-12-04 | 2010-06-18 | 141d? | 586d | finish no earlier than 2010-06-18 | C3 | 1128h |  | Rel-10 | CPM-SMS | PCG-24 | Ericsson | Jan Holm | CP-46 | Gwiho |  |  |

Notes:
- 2: -
- 3: -
- 4: -
- 5: -
- 7: -
- 8: SP#44 Umbrella Feature created to host WIs moved out of Rel-9
- 9: SP#46 completion 06/10 (was 12/09)=>09/10 / Text3: 23.832, 23.232
- 10: Items beyond Rel-9 UID_400035 Enhanced Home NodeB / eNodeB (EHNB)
- 11: Items beyond Rel-9 UID_400035 Enhanced Home NodeB / eNodeB (EHNB) / Text3: 22.220
- 12: SP#35 Stage 1 completed. SP#45 Stage 2 work stopped. SP#46 work stopped/abandoned / Text3: WID identifies also impacted CT1 24.008, RAN2 25.331
- 13: SP#35 completed. SP#46 work stopped/abandoned / Text3: 22.101 CR#0207
- 14: SP#45 Stage 2 work stopped / Text3: draft TR 23.880 withdrawn, 23.002, 23.060, 23.221, 23.236
- 15: SP#46 updated WID SP-090831=>SP-090658 (added SA3 part). Stage 2 completion 06/10=>09/10. Triggered by Rel-8 UID_7027 Study on Facilitating Machine to Machine Communication in GSM and UMTS (FS_M2M) TR 22.868
- 16: Text3: new 22.368
- 17: SP#46 Stage 2 completion 06/10=>09/10. SP#45 updated WID SP-080649=>SP-090658 (added SA2 part) / Text3: new 23.888 (Architectural Enhancements for machine-type communications)
- 18: SP#46 updated WID SP-090658=>SP-090831 (added SA3 part) / Text3: new TR 33.8xx Security aspects of Machine-Type Communications
- 19: Stage 1 in UID_320022 Rel-8 Requirements for evolution of the 3GPP system architecture (AIPN-SAE): 22.278, 22.011, 22.246
- 20: SP#46 completion 12/09=>09/10 / Text3: 23.402 (Chaining GTP-S8 based architecture and procedures)
- 21: SP#45 WID updated SP-090100=>SP-090659. Triggered by TR 23.861 UID_410043 FS_MAPIM. Stage 1 in Rel-9 22.278 (6.2 - IP session control) / Text3: 23.401, 23.402, 23.237
- 22: Rel-9 set Inter-Device Transfer requirements UID_410033 (IMS_SCC-IDT). Add additional scenarios and requirements for IDT.
- 23: - / Text3: 22.228
- 24: - / Text3: 23.237, 23.292, new TR 23.8ab (IMS Inter-UE transfer enhancements)
- 25: IP-SM-GW enhancements for interworking with OMA CPM. External requirements (Stage 1 in OMA-RD-CPM-V1_0-20090310-C)
- 26: External requirements (Stage 1 in OMA-RD-CPM-V1_0-20090310-C) / Text3: 22.340 (IMS messaging)
- 27: SP#46 TR 23.824v100 for Information / Text3: 23.204 (Support of SMS over generic 3GPP IP access), new TR 23.824 (IP-SM-GW enhancements for interworking with OMA CPM)
- 28: Linked to Rel-8 UID_340031 Service-Level Interworking for Messaging Services (MESSIW) 23.204 / Text3: 29.311

| ID | WBS | Task | Duration | Start | Finish | Complete | Remaining | Baseline start | Baseline finish | Baseline duration | Total slack | Constraint | Resources | Work | Actual work | Text1 | Text2 | Text4 | Text6 | Text7 | Text8 | Text11 |
| --- | --- | --- | --- | --- | --- | --- | --- | --- | --- | --- | --- | --- | --- | --- | --- | --- | --- | --- | --- | --- | --- | --- |
| 29 | 15 | **Completion of Communications on Not Logged-in** | 1d? | 2009-09-24 A | 2009-09-24 A | 100% |  | 2009-09-24 | 2009-09-24 | 1d? |  |  | S1 | 16h | 16h | CCNL | PCG-23 | Deutsche Telekom | Rel-10 | SP-45 | Alain |  |
| 30 | 15.1 | Stage 1 for CCNL | 1d? | 2009-09-24 A | 2009-09-24 A | 100% |  | 2009-09-24 | 2009-09-24 | 1d? |  | start no earlier than 2009-09-24 | S1 | 8h | 8h | CCNL | PCG-23 | Deutsche Telekom | Rel-10 | SP-45 | Alain |  |
| 31 | 16 | **Local IP Access and Selected Internet IP Traffic Offload** | 327d? | 2009-09-24 A | 2010-12-24 | 13% | 283.19d? | 2009-09-24 | 2010-12-24 | 327d? | 451d |  | S2,S1,S3,S5 | 13480h | 1455.6h | LIPA_SIPTO | PCG-23 | Huawei, China Mobile | Rel-10 | SP-45 | Maurice |  |
| 32 | 16.1 | TR on LIPA_SIPTO | 186d? | 2009-09-24 A | 2010-06-10 | 45% | 102.3d? | 2009-09-24 | 2010-06-10 | 186d? | 592d | finish no earlier than 2010-06-10 | S2 | 1488h | 669.6h | LIPA_SIPTO | PCG-23 | Huawei, China Mobile | Rel-10 | SP-45 | Maurice |  |
| 33 | 16.2 | Stage 1 for LIPA_SIPTO | 131d? | 2009-09-24 A | 2010-03-25 | 75% | 32.75d? | 2009-09-24 | 2010-03-25 | 131d? | 647d | finish no earlier than 2010-03-25 | S1 | 1048h | 786h | LIPA_SIPTO | PCG-23 | Huawei, China Mobile | Rel-10 | SP-45 | Alain |  |
| 34 | 16.3 | Stage 2 for LIPA_SIPTO | 257d? | 2009-09-24 | 2010-09-17 |  |  | 2009-09-24 | 2010-09-17 | 257d? | 521d | finish no earlier than 2010-09-17 | S2 | 2056h |  | LIPA_SIPTO | PCG-23 | Huawei, China Mobile | Rel-10 | SP-45 | Maurice |  |
| 35 | 16.4 | Security for LIPA_SIPTO | 256d? | 2009-09-24 | 2010-09-16 |  |  | 2009-09-24 | 2010-09-16 | 256d? | 522d | finish no earlier than 2010-09-16 | S3 | 2048h |  | LIPA_SIPTO | PCG-23 | Huawei, Qualcomm Europe | Rel-10 | SP-45 | Dionisio |  |
| 36 | 16.5 | OAM&P for LIPA_SIPTO | 256d? | 2009-09-24 | 2010-09-16 |  |  | 2009-09-24 | 2010-09-16 | 256d? | 522d | finish no earlier than 2010-09-16 | S5 | 2048h |  | LIPA_SIPTO | PCG-23 | Huawei, China Mobile | Rel-10 | SP-45 | Dionisio |  |
| 37 | 16.6 | Charging for LIPA_SIPTO | 272d? | 2009-12-10 | 2010-12-24 |  |  | 2009-09-24 | 2010-12-24 | 327d? | 451d | start no earlier than 2009-12-10 | S5 | 2176h |  | LIPA_SIPTO | PCG-24 | Huawei, China Mobile | Rel-10 | SP-46 | Dionisio |  |
| 38 | 17 | **IP Flow Mobility and seamless WLAN offload** | 186d? | 2009-09-24 A | 2010-06-10 | 46% | 100.07d? | 2009-09-24 | 2010-06-10 | 186d? | 592d |  | S2,S1 | 3424h | 1581.83h | IFOM | PCG-23 | Qualcomm Europe | Rel-10 | SP-45 | Maurice |  |
| 39 | 17.1 | Stage 1 for IFOM | 56d? | 2009-09-24 A | 2009-12-10 A | 100% |  | 2009-09-24 | 2009-12-10 | 56d? |  | finish no earlier than 2009-12-10 | S1 | 448h | 448h | IFOM | PCG-23 | Qualcomm Europe | Rel-10 | SP-45 | Alain |  |
| 40 | 17.2 | Stage 2 for IFOM | 186d? | 2009-09-24 A | 2010-06-10 | 30% | 130.2d? | 2009-09-24 | 2010-06-10 | 186d? | 592d | finish no earlier than 2010-06-10 | S2 | 1488h | 446.4h | IFOM | PCG-23 | Qualcomm Europe | Rel-10 | SP-45 | Maurice |  |
| 41 | 18 | **Enabling Coder Selection and Rate Adaptation for UTRAN and E-UTRAN for Load Adaptive Applications** | 257d? | 2009-09-24 A | 2010-09-17 | 2% | 251.6d? | 2009-09-24 | 2010-09-17 | 257d? | 521d |  | S2,S4,R2 | 5600h | 117.56h | ECSRA_LAA | PCG-23 | Qualcomm Europe | Rel-10 | SP-45 | Maurice |  |
| 42 | 18.1 | TR on ECSRA_LAA | 186d? | 2009-09-24 A | 2010-06-10 | 5% | 176.7d? | 2009-09-24 | 2010-06-10 | 186d? | 592d | finish no earlier than 2010-06-10 | S2,S4,R2 | 1488h | 74.4h | ECSRA_LAA | PCG-23 | Qualcomm Europe | Rel-10 | SP-45 | Maurice |  |
| 43 | 18.2 | Stage 2 for ECSRA_LAA | 257d? | 2009-09-24 | 2010-09-17 |  |  | 2009-09-24 | 2010-09-17 | 257d? | 521d | finish no earlier than 2010-09-17 | S2 | 2056h |  | ECSRA_LAA | PCG-23 | Qualcomm Europe | Rel-10 | SP-45 | Maurice |  |
| 44 | 19 | EEA3 and EIA3 (new Encryption & Integrity EPS security algorithms) | 266d? | 2009-06-04 | 2010-06-10 |  |  | 2009-06-04 | 2010-06-10 | 266d? | 592d | finish no earlier than 2010-06-10 | S3 | 2128h |  | EEA3_EIA3 | PCG-23 | CATR | Rel-10 | SP-44 | Dionisio |  |
| 45 | 20 | Definition of 3GPP UICC services over the new high-speed interface | 796d? | 2007-12-10 A | 2010-12-24 | 15% | 676.6d? | 2007-12-10 | 2010-12-24 | 796d? | 451d | finish no earlier than 2010-12-24 | C6 | 6368h | 955.2h | UICCHS | PCG-21 | Gemalto | Rel-10 | CP-38 | Xavier |  |
| 46 | 21 | 1.28 Mcps TDD Repeater | 654d? | 2007-12-04 A | 2010-06-04 | 85% | 98.1d? | 2007-12-04 | 2010-06-04 | 654d? | 596d | finish no earlier than 2010-06-04 | R4 | 5232h | 4447.2h | RANimp-Repeaters1.28TDD | PCG-21 | RITT | Rel-10 | RP-38 | Issam | RP-091053 |
| 47 | 22 | UTRAN 2 ms TTI uplink range improvement | 402d? | 2009-03-06 A | 2010-09-17 | 10% | 361.8d? | 2009-03-06 | 2010-09-17 | 402d? | 521d | finish no earlier than 2010-09-17 | R1,R2,R3,R4 | 3216h | 321.6h | RANimp-2mTTI_ULimp | PCG-22 | Nokia Siemens Networks | Rel-10 | RP-43 | Patrick | RP-091054 |
| 48 | 23 | 1.28 Mcps TDD Multi-carrier HSUPA | 316d? | 2009-09-18 A | 2010-12-03 | 5% | 300.2d? | 2009-09-18 | 2010-12-03 | 316d? | 466d | finish no earlier than 2010-12-03 | R1,R2,R3,R4 | 2528h | 126.4h | TDD_MC_HSUPA | PCG-23 | CATR | Rel-10 | RP-45 | Patrick | RP-091056 |
| 49 | 24 | A-GNSS Minimum Performance for UTRAN | 261d? | 2009-09-18 | 2010-09-17 |  |  | 2009-09-18 | 2010-09-17 | 261d? | 521d | finish no earlier than 2010-09-17 | R4 | 2088h |  | AGNSSPerf_UTRAN | PCG-23 | Thales | Rel-10 | RP-45 | Issam | RP-091055 |
| 50 | 25 | UE Over The Air (Antenna) conformance testing methodology - Laptop mounted equipment Free Space test | 521d? | 2009-09-18 A | 2011-09-16 | 5% | 494.95d? | 2009-09-18 | 2011-09-16 | 521d? | 261d | finish no earlier than 2011-09-16 | R4 | 4168h | 208.4h | UEAnt_FSTest | PCG-23 | CATR | Rel-10 | RP-45 | Issam | RP-091057 |
| 51 | 26 | (Small) Technical Enhancements and Improvements for Rel-10 | 136d? | 2009-06-04 | 2009-12-10 |  |  | 2009-06-04 | 2009-12-10 | 136d? | 722d | finish no earlier than 2009-12-10 | All | 1088h |  | TEI10 | PCG-23 | ALL | Rel-10 | SP-44 |  |  |
| 52 | 27 | **Uplink Multiple Antenna Transmission for LTE** | 400d? | 2009-12-04 | 2011-06-16 |  |  | 2009-12-04 | 2011-06-16 | 400d? | 327d |  | R1,R2,R4 | 8608h |  | LTE_UL_MIMO | PCG-24 | Huawei | Rel-10 | RP-46 | Patrick |  |
| 53 | 27.1 | Core - UL Multiple Antenna Transmission for LTE | 276d? | 2009-12-04 | 2010-12-24 |  |  | 2009-12-04 | 2010-12-24 | 276d? | 451d | finish no earlier than 2010-12-24 | R1,R2,R4 | 2208h |  | LTE_UL_MIMO-Core | PCG-24 | Huawei | Rel-10 | RP-46 | Patrick |  |
| 54 | 27.2 | Perf - UL Multiple Antenna Transmission for LTE | 400d? | 2009-12-04 | 2011-06-16 |  |  | 2009-12-04 | 2011-06-16 | 400d? | 327d | finish no earlier than 2011-06-16 | R4 | 3200h |  | LTE_UL_MIMO-Perf | PCG-24 | Huawei | Rel-10 | RP-46 | Issam |  |

Notes:
- 29: SP#45 WID approved. Stage 1 completed / Text5: Kurt Bischinger
- 30: SP#45 WID approved. Stage 1 completed / Text3: 22.173 CR#0056r1 Call Completion on Not Logged in (CCNL) / Text5: Kurt Bischinger
- 31: SP#46 updated WID SP-090618=>SP-090761 (added SA5 aspects). UID_400035 Enhanced Home NodeB/eNodeB (EHNB) formerly covered Local IP Access to Internet and Local access to Home Network from the Home NodeB/eNodeB Features now covered by this WI / Text5: patrice.hede@huawei.com, Tao Sun (suntao@chinamobile.com)
- 32: SP#46 completion 03/10=>06/10 / Text3: 23.829 (Local IP Access & Selected IP Traffic Offload) / Text5: patrice.hede@huawei.com, Tao Sun (suntao@chinamobile.com)
- 33: - / Text3: 22.101, 22.220 / Text5: Amar Deol (adeolf@huawei.com), Gang Li (ligangyf@chinamobile.com)
- 34: SP#46 completion 06/10=>09/10 / Text3: 23.060, 23.203, 23.401 / Text5: patrice.hede@huawei.com, Tao Sun (suntao@chinamobile.com)
- 35: - / Text3: 33.102, 33.107, 33.108, 33.320, 33.401 / Text5: Marcus Wong (mwong@huawei.com), Brian Rosenberg (bmr@qualcomm.com)
- 36: SP#46 updated WID SP-090618=>SP-090761 (added SA5 aspects) / Text3: 32.101, 32.102, 32.405, 32.425, 32.452, 32.453, 32.581, 32.582, 32.583, 32.584, 32.591, 32.592, 32.593, 32.594, 32.64x, 32.76x / Text5: Zou Lan (zlan@huawei.com), Chen Gang (chengang@chinamobile.com)
- 37: SP#46 updated WID SP-090618=>SP-090761 (added SA5 aspects) / Text3: 32.240, 32.251, 32.298, 32.299 / Text5: shan.mingjun@huawei.com, Ai Chen (chenai@chinamobile.com)
- 38: SP#46 WID nupdated SP-090616=>SP-090804. Triggered by Rel-10 TR 23.861 (UID_410043 Study on Multi Access PDN connectivity and IP flow mobility - MAPIM). Charging aspects are to be considered for IP Flow Mobility and WLAN offloading. / Text5: Gerardo Giaretta (gerardo@qualcomm.com)
- 39: SP#46 completed. Service requirements for IP Flow Mobility partially in 22.278 and additional aspects in TR 23.861. 22.278 needs updating to capture aspects currently only in TR 23.861. / Text3: 22.278 / Text5: David Williams (dwilliam@qualcomm.com)
- 40: SP#46 WID nupdated SP-090616=>SP-090804. / Text3: 23.203, 23.402, new TS 23.261 (IP Flow Mobility and Seamless WLAN Offload) / Text5: Gerardo Giaretta (gerardo@qualcomm.com)
- 41: Rel-10 Rate Adaptation. Triggered by Rel-9 RAN2 (UID_440013 Vocoder rate adaptation for LTE (LTEimp-Vocoder). Enhance existing (pre Rel-10) codec selection/rate adaptation based on network loading conditions and operator policies over UTRA/E-UTRA / Text5: AC Mahendran (ac@qualcomm.com)
- 42: Needs Liaison with SA4, RAN2 / Text3: 23.860 (Enabling Encoder Selection and Rate Adaptation for UTRAN and E-UTRAN) / Text5: AC Mahendran (ac@qualcomm.com)
- 43: SP#46 completion 06/10=>09/10 / Text3: 23.060, 23.203, 23.228, 23.401 / Text5: AC Mahendran (ac@qualcomm.com)
- 44: develop new EPS algorithms acceptable to regions such as China / Text3: 35.xxx (EEA3 & EIA3 Algorithm Specification, Implementers’ test data, Design and evaluation report, Final project report), 33.401 (SAE Security Architecture) / Text5: Yuan Qi, yuanqi@mail.ritt.com.cn
- 45: CP#46 moved to Rel-10. Provide updated WID at CP#47. CP#42 moved to Rel-9 / Text3: 31.xyz / Text5: Denis L'Heriteau
- 46: RP#45 completion 12/09=>06/10 / Text3: 25.113, new 25.116, 25.153 (testing) / Text5: qinyan@chinattl.com
- 47: RP#46 moved to Rel-10 (No activity in WGs=>RP#47 to decide a way forward). Cell sets the TTI (Transmission Time Interval) to 2 ms / Text3: 25.133, 25.212, 25.214, 25.321, 25.331 / Text5: Karri Ranta-aho (karri.ranta-aho@nsn.com)
- 48: - / Text3: 25.102, 25.105, 25.123, 25.221, 25.222, 25.223, 25.224, 25.225, 25.306, 25.319, 25.321, 25.331, 25.423, 25.427, 25.433 / Text5: Aihui Song (songaihui@mail.ritt.com.cn)
- 49: RP#46 definition of GNSS min performance reqs in GERAN delayed. Triggered by Rel-7 UID_20050 (GNSS in UTRAN) and Rel-8 UID_400051 (Support for Additional NSS). Linked to GERAN Rel-9 UID_38002 (A-GNSS Performances and Testing Procedures) / Text3: 25.171, 34.108, 34.123, 34.171, 34.109 / Text5: Michel.monnerat@thalesaleniaspace.com
- 50: - / Text3: 25.144, 25.914, 34.114 / Text5: Guo Lin (guolin@emcite.com)
- 51: -
- 52: Triggered by FS_RAN_LTEA (Study on LTE-Advanced) 36.912, 36. 814 / Text5: Mattias Wennström
- 53: - / Text3: 36.101, 36.104, 36.133, 36.201, 36.211, 36.212, 36.213, 36.300, 36.306, 36.321, 36.331 / Text5: Mattias Wennström
- 54: - / Text3: 36.101, 36.104, 36.133, 36.141 / Text5: Mattias Wennström

| ID | WBS | Task | Duration | Start | Finish | Baseline start | Baseline finish | Baseline duration | Total slack | Constraint | Resources | Work | Text1 | Text2 | Text4 | Text5 | Text6 | Text7 | Text8 |
| --- | --- | --- | --- | --- | --- | --- | --- | --- | --- | --- | --- | --- | --- | --- | --- | --- | --- | --- | --- |
| 55 | 28 | **Enhanced Downlink Multiple Antenna Transmission for LTE** | 400d? | 2009-12-04 | 2011-06-16 | 2009-12-04 | 2011-06-16 | 400d? | 327d |  | R1,R2,R4 | 8608h | LTE_eDL_MIMO | PCG-24 | NTT DoCoMo | Hidekazu Taoka | Rel-10 | RP-46 | Patrick |
| 56 | 28.1 | Core - Enhanced Downlink Multiple Antenna Transmission for LTE | 276d? | 2009-12-04 | 2010-12-24 | 2009-12-04 | 2010-12-24 | 276d? | 451d | finish no earlier than 2010-12-24 | R1,R2,R4 | 2208h | LTE_eDL_MIMO-Core | PCG-24 | NTT DoCoMo | Hidekazu Taoka | Rel-10 | RP-46 | Patrick |
| 57 | 28.2 | Perf - Enhanced Downlink Multiple Antenna Transmission for LTE | 400d? | 2009-12-04 | 2011-06-16 | 2009-12-04 | 2011-06-16 | 400d? | 327d | finish no earlier than 2011-06-16 | R4 | 3200h | LTE_eDL_MIMO-Perf | PCG-24 | NTT DoCoMo | Hidekazu Taoka | Rel-10 | RP-46 | Issam |
| 58 | 29 | **Relays for LTE** | 336d? | 2009-12-04 | 2011-03-18 | 2009-12-04 | 2011-03-18 | 336d? | 391d |  | R1,R2,R4 | 7584h | LTE_Relay | PCG-24 | Ericsson | Christian Hoymann | Rel-10 | RP-46 | Patrick |
| 59 | 29.1 | Core - Relays for LTE | 276d? | 2009-12-04 | 2010-12-24 | 2009-12-04 | 2010-12-24 | 276d? | 451d | finish no earlier than 2010-12-24 | R1,R2,R4 | 2208h | LTE_Relay-Core | PCG-24 | Ericsson | Christian Hoymann | Rel-10 | RP-46 | Patrick |
| 60 | 29.2 | Perf - Relays for LTE | 336d? | 2009-12-04 | 2011-03-18 | 2009-12-04 | 2011-03-18 | 336d? | 391d | finish no earlier than 2011-03-18 | R4 | 2688h | LTE_Relay-Perf | PCG-24 | Ericsson | Christian Hoymann | Rel-10 | RP-46 | Issam |
| 61 | 30 | **Carrier Aggregation for LTE** | 400d? | 2009-12-04 | 2011-06-16 | 2009-12-04 | 2011-06-16 | 400d? | 327d |  | R1,R2,R3,R4 | 8608h | LTE_CA | PCG-24 | Nokia | Asbjørn Grøvlen | Rel-10 | RP-46 | Patrick |
| 62 | 30.1 | Core - Carrier Aggregation for LTE | 276d? | 2009-12-04 | 2010-12-24 | 2009-12-04 | 2010-12-24 | 276d? | 451d | finish no earlier than 2010-12-24 | R1,R2,R3,R4 | 2208h | LTE_CA-Core | PCG-24 | Nokia | Asbjørn Grøvlen | Rel-10 | RP-46 | Patrick |
| 63 | 30.2 | Perf - Carrier Aggregation for LTE | 400d? | 2009-12-04 | 2011-06-16 | 2009-12-04 | 2011-06-16 | 400d? | 327d | finish no earlier than 2011-06-16 | R4 | 3200h | LTE_CA-Perf | PCG-24 | Nokia | Asbjørn Grøvlen | Rel-10 | RP-46 | Issam |
| 64 | 31 | **Enhanced Network Transmission Reduction for LTE** | 276d? | 2009-12-04 | 2010-12-24 | 2009-12-04 | 2010-12-24 | 276d? | 451d |  | R1,R4 | 4416h | LTE_NTR | PCG-24 | Ericsson | Muhammad Kazmi | Rel-10 | RP-46 | Patrick |
| 65 | 31.1 | Core - Enhanced Network Transmission Reduction for LTE | 276d? | 2009-12-04 | 2010-12-24 | 2009-12-04 | 2010-12-24 | 276d? | 451d | finish no earlier than 2010-12-24 | R1,R4 | 2208h | LTE_NTR | PCG-24 | Ericsson | Muhammad Kazmi | Rel-10 | RP-46 | Patrick |
| 66 | 32 | **Latency reductions for LTE** | 276d? | 2009-12-04 | 2010-12-24 | 2009-12-04 | 2010-12-24 | 276d? | 451d |  | R1,R2 | 4416h | LTE_LATRED | PCG-24 | Ericsson | Henrik Enbuske | Rel-10 | RP-46 | Patrick |
| 67 | 32.1 | Core - Latency reductions for LTE | 276d? | 2009-12-04 | 2010-12-24 | 2009-12-04 | 2010-12-24 | 276d? | 451d | finish no earlier than 2010-12-24 | R1,R2 | 2208h | LTE_LATRED-Core | PCG-24 | Ericsson | Henrik Enbuske | Rel-10 | RP-46 | Patrick |
| 68 | 33 | **Inclusion of “RF Pattern Matching Technologies” as positioning method in the UTRAN** | 141d? | 2009-12-04 | 2010-06-18 | 2009-12-04 | 2010-06-18 | 141d? | 586d |  | R2,R3 | 2256h | LCS_UMTS_RFPMT | PCG-24 | Polaris Wireless | Norman Shaw | Rel-10 | RP-46 | Joern |
| 69 | 33.1 | Core - Inclusion of “RF Pattern Matching Technologies” as positioning method in the UTRAN | 141d? | 2009-12-04 | 2010-06-18 | 2009-12-04 | 2010-06-18 | 141d? | 586d | finish no earlier than 2010-06-18 | R2,R3 | 1128h | LCS_UMTS_RFPMT | PCG-24 | Polaris Wireless | Norman Shaw | Rel-10 | RP-46 | Joern |
| 70 | 34 | **1.28 Mcps TDD Home NodeB RF requirements** | 276d? | 2009-12-04 | 2010-12-24 | 2009-12-04 | 2010-12-24 | 276d? | 451d |  | R4 | 5544h | HNB_LCRTDD_RF | PCG-24 | TD Tech | Li Rong (lirong@td-tech.com) | Rel-10 | RP-46 | Issam |
| 71 | 34.1 | Core - 1.28 Mcps TDD Home NodeB RF requirements | 141d? | 2009-12-04 | 2010-06-18 | 2009-12-04 | 2010-06-18 | 141d? | 586d | finish no earlier than 2010-06-18 | R4 | 1128h | HNB_LCRTDD_RF-Core | PCG-24 | TD Tech | Li Rong (lirong@td-tech.com) | Rel-10 | RP-46 | Issam |
| 72 | 34.2 | Perf - 1.28 Mcps TDD Home NodeB RF requirements | 276d? | 2009-12-04 | 2010-12-24 | 2009-12-04 | 2010-12-24 | 276d? | 451d | finish no earlier than 2010-12-24 | R4 | 2208h | HNB_LCRTDD_RF-Perf | PCG-24 | TD Tech | Li Rong (lirong@td-tech.com) | Rel-10 | RP-46 | Issam |
| 73 | 35 | **Minimization of Drive Tests for E-UTRAN and UTRAN** | 276d? | 2009-12-04 | 2010-12-24 | 2009-12-04 | 2010-12-24 | 276d? | 451d |  | R2,R4,R3 | 4416h | MDT_UMTSLTE | PCG-24 | Nokia Siemens Networks | Malgorzata Tomala | Rel-10 | RP-46 | Joern |
| 74 | 35.1 | Core - MDT for E-UTRAN and UTRAN | 276d? | 2009-12-04 | 2010-12-24 | 2009-12-04 | 2010-12-24 | 276d? | 451d | finish no earlier than 2010-12-24 | R2,R4,R3 | 2208h | MDT_UMTSLTE-Core | PCG-24 | Nokia Siemens Networks | Malgorzata Tomala | Rel-10 | RP-46 | Joern |
| 75 | 36 | **Fixed Wireless Customer-Premises Equipment (CPE) RF Requirements** | 276d? | 2009-12-04 | 2010-12-24 | 2009-12-04 | 2010-12-24 | 276d? | 451d |  | R4,R5 | 6104h | FW_CPE_RF | PCG-24 | Verizon Wireless | zheng.zhao@verizonwireless.com | Rel-10 | RP-46 | Issam |
| 76 | 36.1 | Core - Fixed Wireless CPE RF Requirements | 211d? | 2009-12-04 | 2010-09-24 | 2009-12-04 | 2010-09-24 | 211d? | 516d | finish no earlier than 2010-09-24 | R4 | 1688h | FW_CPE_RF-Core | PCG-24 | Verizon Wireless | zheng.zhao@verizonwireless.com | Rel-10 | RP-46 | Issam |
| 77 | 36.2 | Test - Fixed Wireless CPE RF Requirements | 276d? | 2009-12-04 | 2010-12-24 | 2009-12-04 | 2010-12-24 | 276d? | 451d | finish no earlier than 2010-12-24 | R5 | 2208h | FW_CPE_RF-Test | PCG-24 | Verizon Wireless | zheng.zhao@verizonwireless.com | Rel-10 | RP-46 | Ingbert |
| 78 | 37 | **Four carrier HSDPA** | 400d? | 2009-12-04 | 2011-06-16 | 2009-12-04 | 2011-06-16 | 400d? | 327d |  | R1,R2,R3,R4 | 8608h | 4C_HSDPA | PCG-24 | Qualcomm Europe | Arjun Bharadwaj (arjunb@qualcomm.com) | Rel-10 | RP-46 | Patrick |
| 79 | 37.1 | Core - Four carrier HSDPA | 276d? | 2009-12-04 | 2010-12-24 | 2009-12-04 | 2010-12-24 | 276d? | 451d | finish no earlier than 2010-12-24 | R1,R2,R3,R4 | 2208h | 4C_HSDPA-Core | PCG-24 | Qualcomm Europe | Arjun Bharadwaj (arjunb@qualcomm.com) | Rel-10 | RP-46 | Patrick |
| 80 | 37.2 | Perf - Four carrier HSDPA | 400d? | 2009-12-04 | 2011-06-16 | 2009-12-04 | 2011-06-16 | 400d? | 327d | finish no earlier than 2011-06-16 | R4 | 3200h | 4C_HSDPA-Perf | PCG-24 | Qualcomm Europe | Arjun Bharadwaj (arjunb@qualcomm.com) | Rel-10 | RP-46 | Issam |
| 81 | 38 | Study on Solutions for energy saving within UTRA Node B | 141d? | 2009-12-04 | 2010-06-18 | 2009-12-04 | 2010-06-18 | 141d? | 586d | finish no earlier than 2010-06-18 | R1 | 1128h | FS_Energy_UMTS | PCG-24 | Vodafone | Prakash Bhat | Rel-10 | RP-46 | Patrick |
| 82 | 39 | Study on Non Voice Emergency Services | 206d? | 2009-12-10 | 2010-09-23 | 2009-12-10 | 2010-09-23 | 206d? | 517d | start no earlier than 2009-12-10 | S1 | 1648h | FS_NOVES | PCG-24 | Qualcomm Europe | dwilliams@qualcomm.com | Rel-11 | SP-46 | Alain |
| 83 | 40 | Study on UICC/USIM enhancements | 206d? | 2009-12-10 | 2010-09-23 | 2009-12-10 | 2010-09-23 | 206d? | 517d | start no earlier than 2009-12-10 | S1 | 1648h | FS_U2e | PCG-24 | Giesecke & Devrient | Ilario Macchi | Rel-11 | SP-46 | Alain |
| 84 | 41 | Support BroadBand Forum (BBF) Accesses Interworking | 76d? | 2009-12-10 | 2010-03-25 | 2009-12-10 | 2010-03-25 | 76d? | 647d | start no earlier than 2009-12-10 | S1 | 608h | BBAI | PCG-24 | Ericsson | Peter Bleckert | Rel-10 | SP-46 | Alain |
| 85 | 42 | Enhancements to EPS for E-UTRA-based Heterogeneous Networks | 76d? | 2009-12-10 | 2010-03-25 | 2009-12-10 | 2010-03-25 | 76d? | 647d | start no earlier than 2009-12-10 | S1 | 608h | E3HN | PCG-24 | Alcatel-Lucent | Betsy.Covell@alcatel-lucent.com | Rel-10 | SP-46 | Alain |
| 86 | 43 | Optimal Media Routeing | 76d? | 2009-12-10 | 2010-03-25 | 2009-12-10 | 2010-03-25 | 76d? | 647d | finish no earlier than 2010-03-25 | S2 | 608h | OMR | PCG-24 | Alcatel-Lucent | andy.bennett@alcatel-lucent.com | Rel-10 | SP-46 | Maurice |
| 87 | 44 | Enhanced Multimedia Priority Service - Phase 2 | 137d? | 2009-12-10 | 2010-06-18 | 2009-12-10 | 2010-06-18 | 137d? | 586d | finish no earlier than 2010-06-18 | S2 | 1096h | PRIOR2 | PCG-24 |  |  | Rel-10 | SP-46 | Maurice |
| 88 | 45 | Study on SR-VCC from UTRAN/GERAN to E-UTRAN/HSPA | 137d? | 2009-12-10 | 2010-06-18 | 2009-12-10 | 2010-06-18 | 137d? | 586d | finish no earlier than 2010-06-18 | S2 | 1096h | FS_SRVCC1 | PCG-24 | Orange | delphin.barankanira@orange-ftgroup.com | Rel-10 | SP-46 | Maurice |

Notes:
- 55: Triggered by FS_RAN_LTEA (Study on LTE-Advanced) 36.912, 36. 814
- 56: - / Text3: 36.101, 36.104, 36.133, 36.201, 36.211, 36.212, 36.213, 36.300, 36.306, 36.321, 36.331
- 57: - / Text3: 36.101, 36.104, 36.133, 36.141
- 58: Triggered by FS_RAN_LTEA (Study on LTE-Advanced) 36.912, 36. 814
- 59: - / Text3: 36.133, 36.201, 36.211, 36.212, 36.213, 36.300, 36.321, 36.323, 36.331
- 60: - / Text3: 36.133
- 61: Triggered by FS_RAN_LTEA (Study on LTE-Advanced) 36.912, 36. 814
- 62: - / Text3: 36.101, 36.104, 36.133, 36.211, 36.212, 36.213, 36.300, 36.302, 36.306, 36.321, 36.331, 36.413, 36.423
- 63: - / Text3: 36.101, 36.104, 36.133, 36.141, 36.211, 36.212, 36.213, 36.300, 36.302, 36.306, 36.321, 36.331, 36.413, 36.423
- 64: Triggered by FS_RAN_LTEA (Study on LTE-Advanced) 36.912, 36. 814
- 65: - / Text3: 36.133, 36.214
- 66: Triggered by FS_RAN_LTEA (Study on LTE-Advanced) 36.912, 36. 814
- 67: - / Text3: 36.213, 36.300, 36.306, 36.321, 36.331
- 68: Triggered by Study UID_380079 Evaluation of the inclusion of Path Loss Based Technology in the UTRAN (25.907)
- 69: - / Text3: 25.305, 25.453
- 70: Triggered by FS_RAN-HNBLCRTDD UID_410016 Study on 1.28 Mcps TDD Home NodeB (TR 25.866)
- 71: - / Text3: 25.105
- 72: - / Text3: 25.142
- 73: Triggered by UID_430021 TR 36.805 (Study on Minimization of drive-tests in NGN)
- 74: - / Text3: 25.133, 25.215, 25.304, 25.331, 25.423, 36.133, 36.214, 36.300, 36.304, 36.331, 36.413, 36.423
- 75: Add new power classes in E-UTRAN UL to allow CPE type applications to be operated at higher max output power
- 76: - / Text3: 36.101
- 77: - / Text3: 36.521-1
- 78: -
- 79: - / Text3: 25.101, 25.104, 25.133, 25.211, 25.212, 25.213, 25.214, 25.215, 25.308, 25.331, 25.423, 25.433, 26.306
- 80: - / Text3: 25.101, 25.104, 25.133, 25.141
- 81: Linked to SA5 Rel-9 UID_430044 TR 32.826 (Study on Telecommunication Management; Energy Savings Management) / Text3: 25.8xx Energy-saving enhancements for UTRA Node B
- 82: Text3: 22.8xx Study on Non Voice Emergency Services
- 83: Triggered by GSMA Smart SIM and 3GNBK projects, and to evolve from traditional USAT to multimedia USIM toolkit support, particularly to Smart Card Web Server / Text3: 22.8xx Study on UICC/USIM enhancements
- 84: Triggered by BBF WT 203. Interworking between the 3GPP EPS and the fixed broadband accesses as defined by BBF / Text3: 22.278
- 85: Text3: 21.905, 22.278
- 86: Triggered by UID_370050 Study on System enhancements for the use of IMS services in local breakout (TR 23.894) / Text3: 23.228 (IMS Stage 2)
- 87: Text3: TR 23.8yz Enhanced Multimedia Priority Service for E-UTRAN
- 88: Investigate solution for seamless service continuity when UE handovers from UTRAN/GERAN CS access to E-UTRAN/HSPA for voice call initiated in LTE and handed over to 2G/3G CS access + for voice call directly initiated in 2G/3G CS / Text3: 23.8ab Study on SR-VCC for UTRAN/GERAN to E-UTRAN/HSPA service continuity

| ID | WBS | Task | Type | Duration | Start | Finish | Complete | Remaining | Baseline start | Baseline finish | Baseline duration | Total slack | Constraint | Resources | Work | Actual work | Text1 | Text2 | Text6 | Text7 | Text8 | Text4 | Text9 | Text12 | Text11 |
| --- | --- | --- | --- | --- | --- | --- | --- | --- | --- | --- | --- | --- | --- | --- | --- | --- | --- | --- | --- | --- | --- | --- | --- | --- | --- |
| 89 | 46 | **OAM&P 10** |  | 332d? | 2009-12-10 | 2011-03-18 |  |  | 2009-12-10 | 2011-03-18 | 332d? | 391d |  | S5 | 14496h |  | OAM10 | PCG-24 | Rel-10 | SP-46 | Dionisio |  |  |  |  |
| 90 | 46.1 | **Network Infrastructure Management** |  | 332d? | 2009-12-10 | 2011-03-18 |  |  | 2009-12-10 | 2011-03-18 | 332d? | 391d |  | S5 | 5312h |  | OAM10-NIM | PCG-24 | Rel-10 | SP-46 | Dionisio |  |  |  |  |
| 91 | 46.1.1 | Common RAT Network Resource Model (NRM) |  | 332d? | 2009-12-10 | 2011-03-18 |  |  | 2009-12-10 | 2011-03-18 | 332d? | 391d | finish no earlier than 2011-03-18 | S5 | 2656h |  | RAT_NRM_common | PCG-24 | Rel-10 | SP-46 | Dionisio | Ericsson |  |  |  |
| 92 | 46.2 | **Self-Organizing Networks (SON) - OAM aspects** |  | 272d? | 2009-12-10 | 2010-12-24 |  |  | 2009-12-10 | 2010-12-24 | 272d? | 451d |  | S5 | 6528h |  | OAM10-SON | PCG-24 | Rel-10 | SP-46 | Dionisio |  |  |  |  |
| 93 | 46.2.1 | SON Self-optimization management continuation |  | 272d? | 2009-12-10 | 2010-12-24 |  |  | 2009-12-10 | 2010-12-24 | 272d? | 451d | finish no earlier than 2010-12-24 | S5 | 2176h |  | LTE-SON-OAM_SO | PCG-24 | Rel-10 | SP-46 | Dionisio | Huawei |  |  |  |
| 94 | 46.2.2 | SON Self-healing management |  | 272d? | 2009-12-10 | 2010-12-24 |  |  | 2009-12-10 | 2010-12-24 | 272d? | 451d | finish no earlier than 2010-12-24 | S5 | 2176h |  | LTE-SON-OAM_SH | PCG-24 | Rel-10 | SP-46 | Dionisio | ZTE |  |  |  |
| 95 | 47 | Study on Alignment of 3GPP Generic NRM IRP and TMF Shared Information Data (SID) model |  | 131d? | 2000-01-03 | 2000-06-30 |  |  | 2000-01-03 | 2000-06-30 | 131d? | 3187d |  | S5 | 1048h |  | FS_3GNRM_TMFSID | PCG-24 | Rel-10 | SP-46 | Dionisio | Nokia Siemens Networks |  |  |  |
| 96 | 48 | Study on Harmonization of 3GPP Alarm IRP and TMF Interface Program (TIP) Fault Management |  | 131d? | 2009-12-10 | 2010-06-10 |  |  | 2009-12-10 | 2010-06-10 | 131d? | 592d | finish no earlier than 2010-06-10 | S5 | 1048h |  | FS_3G_TMF_FM | PCG-24 | Rel-10 | SP-46 | Dionisio | Nokia Siemens Networks, Alcatel-Lucent |  |  |  |
| 97 | 49 | **Deleted - Network Selection for non-3GPP Access** |  | 471d? | 2007-12-07 A | 2009-09-24 A | 100% |  | 2007-12-07 | 2009-09-24 | 471d? |  |  | S1,C6 | 10452.8h | 10452.8h | N3GtoNSP | PCG-21 | Rel-10 | SP-38 | Alain | Telefonica O2 | PCG-23 | SP-45 |  |
| 98 | 49.1 | Deleted - Stage 1 for N3GtoNSP |  | 471d? | 2007-12-07 A | 2009-09-24 A | 100% |  | 2007-12-07 | 2009-09-24 | 471d? |  | finish no earlier than 2009-12-10 | S1 | 3768h | 3768h | N3GtoNSP | PCG-21 | Rel-10 | SP-38 | Alain | Telefonica O2 | PCG-23 | SP-45 |  |
| 99 | 49.2 | Deleted - CT6 issues for N3GtoNSP |  | 471d? | 2007-12-07 A | 2009-09-24 A | 100% |  | 2007-12-07 | 2009-09-24 | 471d? |  | finish no earlier than 2009-12-04 | C6 | 3768h | 3768h | N3GtoNSP | PCG-21 | Rel-10 | CP-38 | Xavier | Telefonica O2 | PCG-23 | CP-45 |  |
| 100 | 50 | Release 10 Studies | milestone | 0d? | 2000-01-01 | 2000-01-01 |  |  | 2000-01-01 | 2000-01-01 | 0d? | 3318d | start no earlier than 2000-01-01 | RP,SP |  |  |  |  | Rel-10 |  |  |  |  |  |  |
| 101 | 51 | Study on Haptic Services |  | 272d? | 2009-03-12 A | 2010-03-25 | 80% | 54.4d? | 2009-03-12 | 2010-03-25 | 272d? | 647d | finish no earlier than 2010-03-25 | S1 | 2168h | 1732.8h | FS_Haptics | PCG-22 | Rel-10 | SP-43 | Alain | SK Telecom |  |  |  |
| 102 | 52 | Study on advanced requirements for IP interconnect |  | 528d? | 2007-12-04 A | 2009-12-10 A | 100% |  | 2007-12-04 | 2009-12-10 | 528d? |  | finish no earlier than 2009-12-10 | S1 | 4224h | 4224h | FS_IPXS | PCG-21 | Rel-10 | SP-38 | Alain | Telefonica O2 |  |  |  |
| 103 | 53 | Study on Unauthenticated PS Emergency Calls |  | 471d? | 2008-06-05 A | 2010-03-25 | 20% | 376.8d? | 2008-06-05 | 2010-03-25 | 471d? | 647d | finish no earlier than 2010-03-25 | S1 | 3768h | 753.6h | FS_UAPSEC | PCG-21 | Rel-10 | SP-40 | Alain | Nokia Siemens Networks |  |  |  |
| 104 | 54 | Study on Personal Broadcast Service |  | 397d? | 2008-09-18 A | 2010-03-25 | 90% | 39.7d? | 2008-09-18 | 2010-03-25 | 397d? | 647d | finish no earlier than 2010-03-25 | S1 | 3168h | 2850.4h | FS_PBS | PCG-21 | Rel-10 | SP-41 | Alain | ETRI |  |  |  |
| 105 | 55 | Study on LCS support in SAE for non-3GPP accesses |  | 397d? | 2008-09-18 A | 2010-03-25 | 70% | 119.1d? | 2008-09-18 | 2010-03-25 | 397d? | 647d | finish no earlier than 2010-03-25 | S1 | 3168h | 2215.2h | FS_LCS_n3GPP | PCG-21 | Rel-10 | SP-41 | Alain | SK Telecom |  |  |  |
| 106 | 56 | Study on IMS based Peer-to-Peer Content Distribution Services |  | 196d? | 2009-09-24 A | 2010-06-24 | 50% | 98d? | 2009-09-24 | 2010-06-24 | 196d? | 582d | finish no earlier than 2010-06-24 | S1,S2 | 1568h | 784h | FS_IMS_P2P | PCG-23 | Rel-10 | SP-45 | Alain | China Mobile |  |  |  |
| 107 | 57 | Study on System enhancements for the use of IMS services in Local BreakOut and Optimal Routing of Media |  | 575d? | 2007-10-01 A | 2009-12-10 A | 100% |  | 2007-10-01 | 2009-12-10 | 575d? |  | finish no earlier than 2009-12-10 | S2 | 4600h | 4600h | FS_IMS_LBO_ORM |  | Rel-10 | SP-37 | Maurice | Telecom Italia, BT |  |  |  |
| 108 | 58 | Study on Intra Domain Connection of RAN Nodes to Multiple CN Nodes |  | 523d? | 2008-03-12 A | 2010-03-11 | 70% | 156.9d? | 2008-03-12 | 2010-03-11 | 523d? | 657d | finish no earlier than 2010-03-11 | S2 | 4184h | 2928.8h | FS_IDC | PCG-21 | Rel-10 | SP-39 | Maurice | China Mobile |  |  |  |
| 109 | 59 | Study on IMS Evolution |  | 387d? | 2008-09-18 A | 2010-03-11 | 70% | 116.1d? | 2008-09-18 | 2010-03-11 | 387d? | 657d | finish no earlier than 2010-03-11 | S2 | 3096h | 2167.2h | FS_eIMS | PCG-21 | Rel-10 | SP-41 | Maurice | China Mobile |  |  |  |
| 110 | 60 | Study on enhancements to IMS border functions for IMS Interconnection of services |  | 452d? | 2008-09-18 A | 2010-06-10 | 30% | 315.5d? | 2008-09-18 | 2010-06-10 | 452d? | 592d | finish no earlier than 2010-06-10 | S2 | 3616h | 1092h | FS_eIMS_IBCF | PCG-21 | Rel-10 | SP-41 | Maurice | Starent Networks |  |  |  |
| 111 | 61 | Study on Multi Access PDN connectivity and IP flow Mobility |  | 387d? | 2008-09-18 A | 2010-03-11 | 75% | 95.25d? | 2008-09-18 | 2010-03-11 | 387d? | 657d | finish no earlier than 2010-03-11 | S2,S1 | 3096h | 2334h | FS_MAPIM | PCG-21 | Rel-10 | SP-41 | Maurice | Qualcomm Europe |  |  |  |
| 112 | 62 | Study on Policy solutions and enhancements |  | 407d? | 2009-06-04 A | 2010-12-24 | 15% | 345.95d? | 2009-06-04 | 2010-12-24 | 407d? | 451d | finish no earlier than 2010-12-24 | S2,S1 | 3256h | 488.4h | FS_PP | PCG-23 | Rel-10 | SP-44 | Maurice | AT&T |  |  |  |
| 113 | 63 | Study on IPv6 Migration |  | 266d? | 2009-06-04 A | 2010-06-10 | 25% | 198.75d? | 2009-06-04 | 2010-06-10 | 266d? | 592d | finish no earlier than 2010-06-10 | S2 | 2128h | 538h | FS_IP6M | PCG-23 | Rel-10 | SP-44 | Maurice | China Mobile |  |  |  |
| 114 | 64 | Study on SR-VCC Enhancements |  | 337d? | 2009-06-04 A | 2010-09-17 | 20% | 269.4d? | 2009-06-04 | 2010-09-17 | 337d? | 521d | finish no earlier than 2010-09-17 | S2 | 2696h | 540.8h | FS_eSRVCC | PCG-23 | Rel-10 | SP-44 | Maurice | China Mobile |  |  |  |
| 115 | 65 | Study on UTRAN key management enhancements |  | 588d? | 2007-12-20 A | 2010-03-19 | 30% | 411.6d? | 2007-12-20 | 2010-03-19 | 588d? | 651d | finish no earlier than 2010-03-19 | S3 | 4704h | 1411.2h | FS_UKM | PCG-21 | Rel-10 | SP-38 | Dionisio | Ericsson |  |  |  |
| 116 | 66 | Study on Rc Reference Point Functionalities and Message Flows |  | 593d? | 2008-09-18 A | 2010-12-24 | 90% | 59.3d? | 2008-09-18 | 2010-12-24 | 593d? | 451d | finish no earlier than 2010-12-24 | S5 | 4736h | 4261.6h | FS_OAM_Rc | PCG-21 | Rel-10 | SP-41 | Dionisio | Huawei |  |  |  |
| 117 | 67 | Study on Telecommunication Management; Energy Savings Management (ESM) |  | 467d? | 2009-03-12 A | 2010-12-24 | 60% | 186.8d? | 2009-03-12 | 2010-12-24 | 467d? | 451d | finish no earlier than 2010-12-24 | S5 | 3736h | 2241.6h | FS_OAM_ESM | PCG-22 | Rel-10 | SP-43 | Dionisio | Orange, Vodafone |  |  |  |
| 118 | 68 | Study on Integration of Device Management Information with Itf-N |  | 407d? | 2009-06-04 A | 2010-12-24 | 40% | 244.2d? | 2009-06-04 | 2010-12-24 | 407d? | 451d | finish no earlier than 2010-12-24 | S5 | 3256h | 1302.4h | FS_IDMI_Itf-N | PCG-23 | Rel-10 | SP-44 | Dionisio | Motorola |  |  |  |
| 119 | 69 | Study on EPC Charging enhancement |  | 407d? | 2009-06-04 A | 2010-12-24 | 5% | 386.65d? | 2009-06-04 | 2010-12-24 | 407d? | 451d | finish no earlier than 2010-12-24 | S5 | 3256h | 162.8h | FS_EPCcharg | PCG-23 | Rel-10 | SP-44 | Dionisio | Nokia Siemens Networks |  |  |  |
| 120 | 70 | Study on Policy and Charging Rules Function (PCRF) failure and restoration |  | 186d? | 2009-08-18 A | 2010-06-04 | 50% | 93d? | 2009-08-18 | 2010-06-04 | 186d? | 596d | finish no earlier than 2010-06-04 | C3 | 1488h | 744h | FS_PCRF-FR | PCG-23 | Rel-10 | CP-45 | Gwiho | NEC |  |  |  |
| 121 | 71 | Study on Measurement of Radiated Performance for MIMO and multi-antenna reception for HSPA and LTE terminals |  | 256.8d? | 2009-03-06 A | 2010-06-04 | 35% | 166.92d? | 2009-03-06 | 2010-06-04 | 256.8d? | 596d | finish no earlier than 2010-06-04 | R4 | 2054.4h | 719.03h | FS_HSPA_LTE_measRP_MIMO_multi-antenna | PCG-22 | Rel-10 | RP-43 | Issam | Vodafone |  |  | RP-091083 |
| 122 | 72 | Study on Extending 850 MHz |  | 266d? | 2009-05-30 A | 2010-06-04 | 5% | 252.7d? | 2009-05-30 | 2010-06-04 | 266d? | 596d | finish no earlier than 2010-06-04 | R4 | 2128h | 106.4h | FS_e850 | PCG-23 | Rel-10 | RP-44 | Issam | Ericsson |  |  | RP-091085 |
| 123 | 73 | Study on Uplink Tx Diversity for HSPA |  | 208.4d? | 2009-08-18 A | 2010-06-04 | 20% | 166.72d? | 2009-08-18 | 2010-06-04 | 208.4d? | 596d | finish no earlier than 2010-06-04 | R4 | 1667.2h | 333.43h | FS_UL-TxDiv-HSPA | PCG-23 | Rel-10 | RP-45 | Issam | Qualcomm Europe |  |  | RP-091086 |
| 124 | 74 | Study on RAN improvements for Machine-Type Communications |  | 186d? | 2009-09-18 | 2010-06-04 |  |  | 2009-09-18 | 2010-06-04 | 186d? | 596d | finish no earlier than 2010-06-04 | R2,R1,R3,R4 | 1488h |  | FS_NIMTC-RAN | PCG-23 | Rel-10 | RP-45 | Joern | Huawei |  |  | RP-091087 |
| 125 | 75 | Study on GERAN improvements for Machine-Type Communications |  | 206d? | 2009-11-20 | 2010-09-03 |  |  | 2009-11-20 | 2010-09-03 | 206d? | 531d | finish no earlier than 2010-09-03 | GP | 1648h |  | FS_GERANIMTC | PCG-24 | Rel-10 | GP-44 | Paolo | Ericsson |  |  |  |
| 126 | 76 | Release 9 Features | milestone | 0d? | 2000-01-01 | 2000-01-01 |  |  | 2000-01-01 | 2000-01-01 | 0d? | 3318d |  | CP,GP,RP,SP |  |  |  |  | Rel-9 |  |  |  |  |  |  |

Notes:
- 91: To reduce costs, some equipment can be shared between several RATs, e.g. RET, TMA and repeaters. With existing modelling it is very difficult for an operator to see that several cells are affected when an antenna tilt is changed etc / Text3: new (TR 32.9xx, TSs 32.7x1, 32.7x2, 32.7x3, 32.7x5), 32.615, 32.642, 32.643, 32.645, 32.652, 32.653, 32.655, 32.762, 32.763, 32.765 / Text5: Robert Petersen
- 92: umbrella BB
- 93: Continuation of Rel-9 work UID_390007 SON self-optimization management / Text3: 32.425, 32.521, 32.522, 32.752, 32.753, 32.755, 32.762, 32.763, 32.765 / Text5: Lan Zou (zlan@huawei.com)
- 94: Work moved to Rel-10 after split of the Rel-9 UID_390007 SON self-optimization (removed Self-Healing handling) / Text3: new TS (32.541, 32.542, 32.543), 32.752, 32.753, 32.755, 32.762, 32.763, 32.765 / Text5: zhu.weihong@zte.com.cn
- 95: Text3: 32.8xy Alignment 3GPP Generic NRM IRP and TMF SID / Text5: Olaf Pollakowski
- 96: Text3: 32.8xy Study on 3GPP Alarm IRP and TMF TIP FM harmonization / Text5: Olaf Pollakowski, Padma Sudarsan
- 97: SP#45 work stopped/abandoned / Text5: chris.friel@O2.com
- 98: SP#45 work stopped/abandoned / Text3: 22.011 / Text5: chris.friel@O2.com
- 99: SP#45 work stopped/abandoned / Text3: 36.300 / Text5: chris.friel@O2.com
- 100: - / Text3: 36.306
- 101: SP#46 TR 22.987 for Information. Covers Mobile/Fixed/Cordless/etc terminals. Haptic (human-machine tactile communication) extend service offering & richness of user experience beyond current visual & auditory senses / Text3: 22.987 / Text5: Jinhan Song
- 102: SP#46 completed. Linked to Rel-8 Feature UID_380060 IP Interconnection of Services (IPinterc) / Text3: 22.893 / Text5: chris.friel@O2.com
- 103: SP#44/45 stagnating at 20% / Text3: 22.984 / Text5: Juergen Merkel
- 104: SP#45 TR 22.947 for Information / Text3: 22.947 / Text5: Jaihyung Cho
- 105: SP#44 TR 22.913 for Information / Text3: 22.913 / Text5: Donghee Shim
- 106: Linked to OMA work? / Text3: 22.8xy / Text5: Li Gang (ligangyf@chinamobile.com)
- 107: SP#46 completed TR 23.894 (Common and IP-CAN aspects). Spin-off Feature OMR. Linked to Study on Multimedia Session Continuity UID_350051, Study on Centralized IMS Service Control UID_330012, IMS inter-operator service interconnection interface UID_360011 / Text3: 23.894 / Text5: mario.madella@telecomitalia.it, victor.kueh@bt.com
- 108: SP#45 TR 23.823 for Information. Completion 12/09=>03/10. Linked to 23.236 / Text3: 23.823 / Text5: LIU HONG (liuhongyfw@chinamobile.com)
- 109: - / Text3: 23.812 / Text5: Li Gang (ligangyf@chinamobile.com), Yu Qing (yuqing@chinamobile.com)
- 110: SP#46 updated WID SP-080559=>SP-090809 (extended scope to include the IMS AGW) / Text3: 23.848 / Text5: Rajat Ghai (rghai@starentnetworks.com)
- 111: SP#45 completion 09/09=>03/10 (SA1 completed). Spin-off UID_430035 MAPCON and UID_450041 IFOM / Text3: 23.861 / Text5: Gerardo Giaretta (gerardog@qualcomm.com)
- 112: SP#46 updated WID SP-090361=>SP-090805. Study an evolved policy solution through enhancement of 3GPP policy framework (Stage 2). Consider aspects such as DPI, traffic steering, enhancing service policies / Text3: 23.813 / Text5: farooq.bari@att.com
- 113: Study how to migrate from IPv4 to IPv6-only with the help of transition mechanisms defined in IETF, and how to handle scenarios where not all services are provided via IPv6. Some of these solutions may have impacts on 3GPP network elements and terminals. / Text3: 23.975 / Text5: Li Lianyuan (lilianyuan@chinamobile.com), Liu Hong (liuhongyfw@chinamobile.com)
- 114: SP#45 completion 03/10=>09/10. Analyze current performance of SR-VCC solution in Rel-8 from E-UTRAN/HSPA to UTRAN/GERAN, and then evaluate additional mechanisms to improve user experience. Study if SR-VCC performance needs to be enhanced. / Text3: 23.856 / Text5: Hou zhiqiang (houzhiqiang@chinamobile.com), Jiang Yi (jiangyi@chinamobile.com)
- 115: SP#44 SID updated SP-070782=>SP-090283 (removed UTRAN/E-UTRAN IRAT signalling cases from Study scope (while IRAT handling is left as specified by 33.401). Study also focuses on support for a key hierarchy locally in UTRAN and intra-UTRAN mobility cases.) / Text3: 33.8xy / Text5: Karl Norrman
- 116: SP#44 for SA Information / Text3: 32.825 / Text5: shan.mingjun@huawei.com
- 117: Study result might impact Feature UID_420011 Self Organising Networks (SON) / Text3: 32.826 / Text5: Jean-Michel Cornilly (Orange)
- 118: Study the missing Itf-N part in the Framework. Study changes to Itf-N to utilize UE based measurements / Text3: 32.827 / Text5: Yizhi Yao (yzyao@motorola.com)
- 119: Study grouping the investigation of various minor EPC charging enhancements / Text3: It has to be decided whether it will be a new TR or Rel-9 CRs on TR 32.820 / Text5: Gerald.Goermer@nsn.com
- 120: CP#46 completion 03/10=>06/10. WID updated CP-090588=>CP-090861 / Text3: 29.816 / Text5: gottfried.punz@nw.neclab.eu
- 121: RP#46 completion 12/09=>06/10 / Text3: New TR (25/36) on Measurements of radiated performance for MIMO and multi-antenna reception for HSPA and LTE terminals / Text5: soonleh.ling@vodafone.com
- 122: RP#46 completion 12/09=>06/10 / Text3: TR xx.yyy (Extending 850 study Item Technical report) / Text5: Christian Bergljung (christian.bergljung@stericsson.com)
- 123: - / Text3: 25.8xx / Text5: Heechoon Lee (heechoon@qualcomm.com)
- 124: Triggered by UID_7027 Study on Facilitating Machine to Machine Communication in GSM and UMTS (M2M) TR 22.868 and Rel-10 UID_410030 Network Improvements for Machine-Type Communications (NIMTC) / Text3: TR on RAN Improvements for Machine-type Communications / Text5: arnaud.meylan@huawei.com
- 125: SA1 TS 22.36 (Stage 1) to be approved before GERAN work starts / Text3: TR on GERAN Improvements for Machine-type Communications / Text5: Paul Schliwa-Bertling
- 126: -

| ID | WBS | Task | Duration | Start | Finish | Complete | Remaining | Baseline start | Baseline finish | Baseline duration | Total slack | Constraint | Resources | Work | Actual work | Text1 | Text2 | Text4 | Text5 | Text6 | Text7 | Text8 | Text11 |
| --- | --- | --- | --- | --- | --- | --- | --- | --- | --- | --- | --- | --- | --- | --- | --- | --- | --- | --- | --- | --- | --- | --- | --- |
| 127 | 77 | **Enhanced Home NodeB / eNodeB** | 513d? | 2008-06-05 A | 2010-05-21 | 79% | 108.37d? | 2008-06-05 | 2010-05-21 | 513d? | 606d |  | S1,S2,S3,S5,R2,R3,R4,GP,C1 | 29896h | 23579.1h | EHNB | PCG-21 | T-Mobile | michael.kurz@t-mobile.at | Rel-9 | SP-40 | Alain |  |
| 128 | 77.1 | Stage 1 for EHNB | 261d? | 2008-06-05 A | 2009-06-04 A | 100% |  | 2008-06-05 | 2009-06-04 | 261d? |  | finish no earlier than 2009-06-04 | S1 | 2088h | 2088h | EHNB | PCG-21 | T-Mobile | michael.kurz@t-mobile.at | Rel-9 | SP-40 | Alain |  |
| 129 | 77.2 | Architecture aspects of EHNB | 266d? | 2008-09-18 A | 2009-09-24 A | 100% |  | 2008-09-18 | 2009-09-24 | 266d? |  | finish no earlier than 2009-09-22 | S2 | 2128h | 2128h | EHNB | PCG-21 | T-Mobile | Sebastian Speicher | Rel-9 | SP-41 | Maurice |  |
| 130 | 77.3 | Security aspects of Enhanced Home NodeB / eNodeB | 262d? | 2008-12-11 A | 2009-12-10 A | 100% |  | 2008-12-11 | 2009-12-10 | 262d? |  | finish no earlier than 2009-12-10 | S3 | 2096h | 2096h | EHNB-Sec | PCG-22 | Huawei | Marcus Wong (mwong@huawei.com) | Rel-9 | SP-42 | Dionisio |  |
| 131 | 77.4 | CT1 aspects - Support of Home NB and Home eNB enhancements | 131d? | 2009-09-18 A | 2010-03-19 | 95% | 6.55d? | 2009-09-18 | 2010-03-19 | 131d? | 651d | finish no earlier than 2010-03-19 | C1 | 1048h | 995.6h | EHNB-CT1 | PCG-23 | Qualcomm Europe | Ramachandran Subramanian (rsubrama@qualcomm.com) | Rel-9 | CP-45 | Frederic |  |
| 132 | 77.5 | CT6 aspects - Support of Home NB and Home eNB enhancements | 131d? | 2009-09-18 A | 2010-03-19 | 90% | 13.1d? | 2009-09-18 | 2010-03-19 | 131d? | 651d | finish no earlier than 2010-03-19 | C6 | 1048h | 943.2h | EHNB-CT6 | PCG-23 | Qualcomm Europe | Alfredo Ruvacalba | Rel-9 | CP-45 | Xavier |  |
| 133 | 77.6 | 3G HNB Gateway and LTE HeNB Gateway OAM&P | 336d? | 2008-12-11 A | 2010-03-25 | 60% | 134.4d? | 2008-12-11 | 2010-03-25 | 336d? | 647d | finish no earlier than 2010-03-25 | S5 | 2688h | 1612.8h | HNB-OAM_GW | PCG-22 | China Mobile | GangChen (chengang@chinamobile.com) | Rel-9 | SP-42 | Dionisio | SP-090743 |
| 134 | 77.7 | 3G HNB and LTE HeNB OAM&P Type 1 Interface | 272d? | 2009-03-12 A | 2010-03-25 | 60% | 108.8d? | 2009-03-12 | 2010-03-25 | 272d? | 647d | finish no earlier than 2010-03-25 | S5 | 2168h | 1297.6h | HNB_eHNB-OAM_Type1 | PCG-22 | Huawei | Zou Lan (zlan@huawei.com) | Rel-9 | SP-43 | Dionisio | SP-090744 |
| 135 | 77.8 | 3G HNB and LTE HeNB OAM&P Type 2 Interface | 225d? | 2009-05-15 A | 2010-03-25 | 60% | 90d? | 2009-05-15 | 2010-03-25 | 225d? | 647d | finish no earlier than 2010-03-25 | S5 | 1800h | 1080h | HNB_eHNB-OAM_Type2 | PCG-23 | Ericsson | edwin.tse@ericsson.com | Rel-9 | SP-44 | Dionisio | SP-090751 |
| 136 | 77.9 | LTE FDD Home eNodeB RF Requirements | 336d? | 2008-12-05 A | 2010-03-19 | 70% | 100.8d? | 2008-12-05 | 2010-03-19 | 336d? | 651d | finish no earlier than 2010-03-19 | R4 | 2688h | 1881.6h | HeNB-RF_FDD | PCG-22 | Motorola | Ying Cai (yingcai@motorola.com) | Rel-9 | RP-42 | Issam | RP-091047 |
| 137 | 77.10 | LTE TDD Home eNodeB RF Requirements | 271d? | 2009-03-06 A | 2010-03-19 | 80% | 54.2d? | 2009-03-06 | 2010-03-19 | 271d? | 651d | finish no earlier than 2010-03-19 | R4 | 2168h | 1734.4h | HeNB-RF_TDD | PCG-22 | China Mobile | Nan Li (linan@chinamobile.com) | Rel-9 | RP-43 | Issam | RP-091048 |
| 138 | 77.11 | Home NB and Home eNB enhancements - RAN3 aspects | 197d? | 2009-03-06 A | 2009-12-04 A | 100% |  | 2009-03-06 | 2009-12-04 | 197d? |  | finish no earlier than 2009-12-04 | R3 | 1576h | 1576h | EHNB-RAN3 | PCG-22 | Alcatel-Lucent | Martin Warner (mw15@alcatel-lucent.com) | Rel-9 | RP-43 | Juha | RP-091050 |
| 139 | 77.12 | Home NB and Home eNB enhancements - RAN2 aspects | 271d? | 2009-03-06 A | 2010-03-19 | 90% | 27.1d? | 2009-03-06 | 2010-03-19 | 271d? | 651d | finish no earlier than 2010-03-19 | R2 | 2168h | 1951.2h | EHNB-RAN2 | PCG-22 | Huawei | Yang Xudong (yangxudong@huawei.com) | Rel-9 | RP-43 | Joern | RP-091361 |
| 140 | 77.13 | Home NB and Home eNB enhancements - GERAN aspects | 266d? | 2009-05-18 A | 2010-05-21 | 45% | 146.3d? | 2009-05-18 | 2010-05-21 | 266d? | 606d | finish no earlier than 2010-05-21 | GP | 2128h | 957.6h | EHNB-GERAN | PCG-23 | Nokia Siemens Networks | Leonardo Provvedi | Rel-9 | GP-42 | Paolo |  |
| 141 | 78 | **Services Alignment and Migration** | 467d? | 2006-12-06 A | 2008-09-18 A | 100% |  | 2006-12-06 | 2008-09-18 | 467d? |  |  | S1 | 7472h | 7472h | ServAl |  | China Mobile | fenglingjuan@chinamobile.com | Rel-9 | SP-33 | Alain |  |
| 142 | 78.1 | Stage 1 for ServAl | 467d? | 2006-12-06 A | 2008-09-18 A | 100% |  | 2006-12-06 | 2008-09-18 | 467d? |  | finish no earlier than 2008-12-11 | S1 | 3736h | 3736h | ServAl | PCG-21 | China Mobile | fenglingjuan@chinamobile.com | Rel-9 | SP-33 | Alain |  |
| 143 | 79 | **Value-Added Services for Short Message Service** | 586d? | 2007-09-10 A | 2009-12-04 A | 100% |  | 2007-09-10 | 2009-12-04 | 586d? |  |  | S1,C4,C1 | 10888h | 10888h | VAS4SMS |  | China Mobile | Wu Bin (wubin@chinamobile.com) | Rel-9 | SP-37 | Alain |  |
| 144 | 79.1 | Stage 1 for VAS4SMS | 133d? | 2007-09-10 A | 2008-03-12 A | 100% |  | 2007-09-10 | 2008-03-12 | 133d? |  | finish no earlier than 2008-03-21 | S1 | 1064h | 1064h | VAS4SMS |  | China Mobile | Wu Bin (wubin@chinamobile.com) | Rel-9 | SP-37 | Alain |  |
| 145 | 79.2 | VAS4SMS Interface and Signalling Flow - CT4 aspects | 322d? | 2008-09-12 A | 2009-12-04 A | 100% |  | 2008-09-12 | 2009-12-04 | 322d? |  | finish no earlier than 2009-12-04 | C4 | 2568h | 2568h | VAS4SMS | PCG-21 | China Mobile | Wu Bin (wubin@chinamobile.com) | Rel-9 | CP-41 | Kimmo |  |
| 146 | 79.3 | VAS4SMS Interface and Signalling Flow - CT1 aspects | 321d? | 2008-09-09 A | 2009-12-04 A | 100% |  | 2008-09-09 | 2009-12-04 | 321d? |  | finish no earlier than 2009-12-04 | C1 | 2568h | 2568h | VAS4SMS | PCG-21 | China Mobile | Wu Bin (wubin@chinamobile.com) | Rel-9 | CP-41 | Frederic |  |
| 147 | 80 | **End-User Identity** | 334d? | 2007-09-03 A | 2008-12-11 A | 100% |  | 2007-09-03 | 2008-12-11 | 334d? |  |  | S1 | 5344h | 5344h | EUI |  | Nokia Siemens Networks | Juergen.Merkel@NSN.com | Rel-9 | SP-38 | Alain |  |
| 148 | 80.1 | Definition of EUI | 334d? | 2007-09-03 A | 2008-12-11 A | 100% |  | 2007-09-03 | 2008-12-11 | 334d? |  | finish no earlier than 2008-12-11 | S1 | 2672h | 2672h | EUI | PCG-21 | Nokia Siemens Networks | Juergen.Merkel@NSN.com | Rel-9 | SP-38 | Alain |  |
| 149 | 81 | **Customized Ringing Signal** | 598d? | 2007-12-06 A | 2010-03-19 | 93% | 39.78d? | 2007-12-06 | 2010-03-19 | 598d? | 651d |  | S1,C1 | 7728h | 4908.8h | CRS | PCG-21 | SK Telecom, China Mobile | Donghee Shim (SK Telecom), Jianping Zheng (China Mobile) | Rel-9 | SP-38 | Alain |  |
| 150 | 81.1 | Stage 1 for CRS | 266d? | 2007-12-06 A | 2008-12-11 A | 100% |  | 2007-12-06 | 2008-12-11 | 266d? |  | finish no earlier than 2008-12-11 | S1 | 2128h | 2128h | CRS | PCG-21 | SK Telecom, China Mobile | Donghee Shim (SK Telecom), Jianping Zheng (China Mobile) | Rel-9 | SP-38 | Alain |  |
| 151 | 81.2 | Stage 3 for IMS CRS Service | 212d? | 2009-05-29 A | 2010-03-19 | 85% | 31.8d? | 2009-05-29 | 2010-03-19 | 212d? | 651d | finish no earlier than 2010-03-19 | C1 | 816h | 652.8h | CRS | PCG-23 | China Mobile | wangzhao | Rel-9 | CP-44 | Frederic | CP-090868 |

Notes:
- 127: SP#43 WID updated SP-080791=>SP-090197 to include RAN items/BBs
- 128: SP#44 completed / Text3: 22.220, 22.011
- 129: SP#45 completed. TR 23.830 for Approval / Text3: 23.830, 23.401, 23.402, 23.060
- 130: SP#46 completed. TS 33.320 for Approval / Text3: new 33.320
- 131: CP#46 completion 12/09=>03/10. Roaming aspects for manual CSG selection, Support of temporary users and CSG membership changes, Support of user controlled and operator controlled lists / Text3: 23.122, 24.008, 24.285, 24.301
- 132: CP#46 completion 12/09=>03/10. Storing of CSG related data items on the USIM / Text3: 31.102
- 133: SP#46 exception to 03/10 in SP-090743. TS 32.771 & 32.781 v200 for Approval / Text3: 32.771, 32.772, 32.773, 32.775, 32.781, 32.782, 32.783, 32.785, 32.452, 32.453, 32.632, 32.633, 32.635
- 134: SP#46 exception to 03/10 in SP-090744. TS 32.593 v200 for Approval / Text3: 32.591, 32.592, 32.593, 32.594, 32.581, 32.582, 32.583, 32.584
- 135: SP#46 exception to 03/10 in SP-090751. SP#46 32.571 v100 for Information / Text3: new 32.571, 32.572
- 136: RP#46 exception to 03/10 in RP-091108. WID updated RP-081080=>RP-091300 / Text3: new TR 36.921, 36.104, 36.141
- 137: RP#46 exception to 03/10 in RP-091148. WID updated RP-090160=>RP-091301 / Text3: new TR 36.922, 36.104, 36.141, 36.300, 36.331, 36.413
- 138: RP#46 completed (based on high priority items specified in RP-090995) / Text3: 25.413, 25.467, 25.467, 25.468, 25.469, 25.469, 36.401, 36.413, new 25.444
- 139: RP#46 exception to 03/10 in RP-091393. WID updated RP-090351=>RP-091219 / Text3: 25.304, 25.331, 25.367, 36.300, 36.304, 36.331
- 140: GP#44 exception to 05/10 in GP-092474. GP#42 WID approved / Text3: 43.055, 43.129, 44.018, 44.060, 45.008, 48.008, 48.018
- 141: SP#41 Stage 1 completed. Triggered by Study UID_370086 (FSServAl).
- 142: SP#41 completed / Text3: 22.182
- 143: CP#46 completed. SP#43 Feature moved to Rel-9. Stage 1 TS 22.142 promoted to Rel-9 and dismissed the Rel-8 version.
- 144: SP#39 completed. SP#43 Feature moved to Rel-9. Stage 1 TS 22.142 promoted to Rel-9 and dismissed the Rel-8 version. / Text3: 22.142
- 145: CP#46 completed. WID updated CP-090021=>CP-090813 / Text3: new 23.142
- 146: CP#46 completed. WID updated CP-090021=>CP-090813 / Text3: 23.040
- 147: SP#44 WID updated SP-070651=>SP-090380 (reduced scope of the work)
- 148: SP#44 WID updated SP-070651=>SP-090380 (reduced scope of the work) / Text3: 21.905
- 149: SP#42 Stage 1 completed (need for Input in SA2). SP#41 WID updated SP-070875=>SP-080502
- 150: SP#42 completed. / Text3: 22.183, 22.173
- 151: CP#46 exception to 03/10 in CP-090868 / Text3: 24.173, new 24.183

| ID | WBS | Task | Type | Duration | Start | Finish | Complete | Remaining | Baseline start | Baseline finish | Baseline duration | Total slack | Constraint | Resources | Work | Actual work | Text1 | Text2 | Text4 | Text6 | Text7 | Text8 | Text3 | Text11 |
| --- | --- | --- | --- | --- | --- | --- | --- | --- | --- | --- | --- | --- | --- | --- | --- | --- | --- | --- | --- | --- | --- | --- | --- | --- |
| 152 | 82 | **Public Warning System** |  | 523d? | 2007-12-06 A | 2009-12-04 A | 100% |  | 2007-12-06 | 2009-12-04 | 523d? |  |  | S1,C1,C4,R2 | 10232h | 10232h | PWS | PCG-21 | T-Mobile | Rel-9 | SP-38 | Alain |  |  |
| 153 | 82.1 | Stage 1 for PWS |  | 266d? | 2007-12-06 A | 2008-12-11 A | 100% |  | 2007-12-06 | 2008-12-11 | 266d? |  | finish no earlier than 2008-12-11 | S1 | 2128h | 2128h | PWS | PCG-21 | T-Mobile | Rel-9 | SP-38 | Alain | 22.268 |  |
| 154 | 82.2 | **Stage 3 for PWS** |  | 137d? | 2009-05-29 A | 2009-12-04 A | 100% |  | 2009-05-29 | 2009-12-04 | 137d? |  |  | C1,C4 | 3272h | 3272h | PWS-St3 | PCG-23 | Qualcomm Europe | Rel-9 | CP-44 | Frederic |  |  |
| 155 | 82.2.1 | CT1 aspects of PWS-St3 |  | 137d? | 2009-05-29 A | 2009-12-04 A | 100% |  | 2009-05-29 | 2009-12-04 | 137d? |  | finish no earlier than 2009-12-04 | C1 | 1088h | 1088h | PWS-St3 | PCG-23 | Qualcomm Europe | Rel-9 | CP-44 | Frederic | 23.041 |  |
| 156 | 82.2.2 | CT4 aspects of PWS-St3 |  | 136d? | 2009-05-30 A | 2009-12-04 A | 100% |  | 2009-05-30 | 2009-12-04 | 136d? |  | finish no earlier than 2009-12-04 | C4 | 1088h | 1088h | PWS-St3 | PCG-23 | Qualcomm Europe | Rel-9 | CP-44 | Kimmo | 29.168 |  |
| 157 | 82.3 | Public Warning System (PWS) – RAN aspects |  | 81d? | 2009-05-30 A | 2009-12-04 A | 100% |  | 2009-05-30 | 2009-12-04 | 81d? |  | finish no earlier than 2009-12-04 | R2,R3 | 648h | 648h | PWS-RAN | PCG-23 | AT&T | Rel-9 | RP-44 | Joern | 36.300, 36.302, 36.331, 36.413 | RP-091052 |
| 158 | 83 | **Enhancements to Multimedia Priority Service** |  | 584d? | 2006-03-13 A | 2008-06-05 A | 100% |  | 2006-03-13 | 2008-06-05 | 584d? |  |  | S1 | 4672h | 4672h | ePRIOR | PCG-21 | Telcordia | Rel-9 | SP-39 | Alain |  |  |
| 159 | 83.1 | Stage 1 for ePRIOR |  | 584d? | 2006-03-13 A | 2008-06-05 A | 100% |  | 2006-03-13 | 2008-06-05 | 584d? |  | start no earlier than 2006-03-12 | S1 | 4672h | 4672h | ePRIOR | PCG-21 | Telcordia | Rel-9 | SP-39 | Alain | 22.153, 22.278 |  |
| 160 | 84 | **Support of Personal Area Networks and Enhancements to Personal Network Management** |  | 468d? | 2008-06-05 A | 2010-03-19 | 83% | 81.47d? | 2008-06-05 | 2010-03-19 | 468d? | 651d |  | S1,C1 | 7480h | 6177.81h | PAN_EPNM | PCG-21 | Vodafone | Rel-9 | SP-40 | Alain |  |  |
| 161 | 84.1 | Stage 1 for PAN_EPNM | milestone | 0d? | 2008-06-05 A | 2008-06-05 A | 100% |  | 2008-06-05 | 2008-06-05 | 0d? |  | finish no earlier than 2008-06-05 | S1 |  |  | PAN_EPNM | PCG-21 | Vodafone | Rel-9 | SP-40 | Alain | 22.259 |  |
| 162 | 84.2 | Stage 2 for PAN_EPNM |  | 196d? | 2009-03-06 A | 2009-12-04 A | 100% |  | 2009-03-06 | 2009-12-04 | 196d? |  | finish no earlier than 2009-12-04 | C1 | 1568h | 1568h | PAN_EPNM | PCG-22 | Huawei | Rel-9 | CP-43 | Frederic | 23.259 |  |
| 163 | 84.3 | Stage 3 for PAN_EPNM |  | 271d? | 2009-03-09 A | 2010-03-19 | 70% | 81.3d? | 2009-03-09 | 2010-03-19 | 271d? | 651d | finish no earlier than 2010-03-19 | C1 | 2168h | 1517.6h | PAN_EPNM | PCG-22 | Huawei | Rel-9 | CP-43 | Frederic | 24.259 | CP-090879 |
| 164 | 85 | **Multi-Media Telephony Service enhancements** |  | 472d? | 2008-06-05 A | 2010-03-25 | 87% | 62.87d? | 2008-06-05 | 2010-03-25 | 472d? | 647d |  | S1,S5,C1 | 10288h | 8916.67h | eMMTel | PCG-21 | France Telecom | Rel-9 | SP-40 | Alain |  |  |
| 165 | 85.1 | Stage 1 for eMMTel |  | 136d? | 2008-06-05 A | 2008-12-11 A | 100% |  | 2008-06-05 | 2008-12-11 | 136d? |  | start no earlier than 2008-06-05 | S1 | 1088h | 1088h | eMMTel | PCG-21 | France Telecom | Rel-9 | SP-40 | Alain | 22.173 |  |
| 166 | 85.2 | Multimedia Telephony (MMTel) Service and Supplementary Services - Online Charging and completion for Offline Charging (all supplementary services) |  | 272d? | 2009-03-12 A | 2010-03-25 | 85% | 40.8d? | 2009-03-12 | 2010-03-25 | 272d? | 647d | finish no earlier than 2010-03-25 | S5 | 2168h | 1841.6h | eMMTel-SS-CH | PCG-22 | Alcatel-Lucent | Rel-9 | SP-43 | Dionisio | 32.275, 32.298, 32.299 | SP-090753 |
| 167 | 85.3 | Support of Real-time Transfer of Tariff Information (RTTI) in IMS charging |  | 271d? | 2009-03-12 A | 2010-03-25 | 75% | 67.75d? | 2009-03-12 | 2010-03-25 | 271d? | 647d | finish no earlier than 2010-03-25 | S5 | 2168h | 1626h | IMSTSS-RTTI-CH | PCG-22 | Orange | Rel-9 | SP-43 | Dionisio | 32.27x, 32.240, 32.280, 32.298, 32.299 | SP-090754 |
| 168 | 85.4 | Stage 3 - Enhancements for Completion of Communications Supplementary service |  | 136d? | 2009-05-30 A | 2009-12-04 A | 100% |  | 2009-05-30 | 2009-12-04 | 136d? |  | finish no earlier than 2009-12-04 | C1 | 1088h | 1088h | eMMTel-CC | PCG-23 | France Telecom | Rel-9 | CP-44 | Frederic | 24.642 |  |
| 169 | 86 | **User Data Convergence** |  | 472d? | 2008-06-05 A | 2010-03-25 | 60% | 188.65d? | 2008-06-05 | 2010-03-25 | 472d? | 647d |  | S1,S5,C4 | 13136h | 7716.38h | UDC | PCG-21 | China Mobile | Rel-9 | SP-40 | Alain |  |  |
| 170 | 86.1 | Stage 1 for UDC |  | 136d? | 2008-06-05 A | 2008-12-11 A | 100% |  | 2008-06-05 | 2008-12-11 | 136d? |  | start no earlier than 2008-06-05 | S1 | 1088h | 1088h | UDC | PCG-21 | China Mobile | Rel-9 | SP-40 | Alain | 22.985, 22.101 |  |
| 171 | 86.2 | UDC Technical Realization (Stage 2) |  | 271d? | 2009-03-06 A | 2010-03-19 | 70% | 81.3d? | 2009-03-06 | 2010-03-19 | 271d? | 651d | finish no earlier than 2010-03-19 | C4 | 2168h | 1517.6h | UDC-CN | PCG-22 | Ericsson | Rel-9 | CP-43 | Kimmo | new 23.335 | CP-090805 |
| 172 | 86.3 | UDC Protocol Description |  | 130d? | 2009-09-18 A | 2010-03-19 | 30% | 91d? | 2009-09-18 | 2010-03-19 | 130d? | 651d | finish no earlier than 2010-03-19 | C4 | 1040h | 312h | UDC-CN | PCG-23 | China Mobile, Ericsson | Rel-9 | CP-45 | Kimmo | 29.335 | CP-090805 |
| 173 | 86.4 | **User Data Convergence - Modelling and Management** |  | 211d? | 2009-06-04 A | 2010-03-25 | 50% | 105.5d? | 2009-06-04 | 2010-03-25 | 211d? | 647d |  | S5 | 5064h | 2532h | UDC-MMAN | PCG-23 | T-Mobile, China Mobile, Ericsson | Rel-9 | SP-44 | Dionisio |  |  |
| 174 | 86.4.1 | UDC – Framework for Model Handling and Management |  | 211d? | 2009-06-04 A | 2010-03-25 | 30% | 147.7d? | 2009-06-04 | 2010-03-25 | 211d? | 647d | finish no earlier than 2010-03-25 | S5 | 1688h | 506.4h | UDC-MMAN-MFRM | PCG-23 | T-Mobile | Rel-9 | SP-44 | Dionisio | 32.172, new 32.181 | SP-090748 |
| 175 | 86.4.2 | UDC – Common Baseline Information Model |  | 211d? | 2009-06-04 A | 2010-03-25 | 70% | 63.3d? | 2009-06-04 | 2010-03-25 | 211d? | 647d | finish no earlier than 2010-03-25 | S5 | 1688h | 1181.6h | UDC-MMAN-CBIM | PCG-23 | China Mobile, Ericsson | Rel-9 | SP-44 | Dionisio | 32.172, new 32.182 | SP-090747 |

Notes:
- 152: TSG#46 completed. Larger scope than Rel-8 Feature UID_370051 (ETWS). Triggered by TR 22.968 Study UID_320025 (FS_PWS) / Text5: Mark.Younge@t-mobile.com
- 153: SP#42 completed / Text5: Mark.Younge@t-mobile.com
- 154: RP#46 completed / Text5: Ramachandran Subramanian (rsubrama@qualcomm.com)
- 155: CP#46 completed / Text5: Ramachandran Subramanian (rsubrama@qualcomm.com)
- 156: CP#46 completed / Text5: Ramachandran Subramanian (rsubrama@qualcomm.com)
- 157: RP#46 completed / Text5: don.zelmer@att.com
- 158: SP#40 Stage 1 completed. Continuation of Rel-8 Feature PRIOR UID_340044. / Text5: jgarraha@telcordia.com
- 159: SP#40 completed / Text5: jgarraha@telcordia.com
- 160: SP#40 WID approved & Stage 1 completed / Text5: armin.toepfer@vodafone.com
- 161: SP#40 Stage 1 completed / Text5: armin.toepfer@vodafone.com
- 162: CP#46 completed. CP#44 WID updated CP-090113=>CP-090435 Removed: Mechanism for a PNE without a (U)SIM capable of discovering PNEs with a (U)SIM in its proximity / Text5: Lili Yang (kadyyang@huawei.com)
- 163: CP#46 exception to 03/10 in CP-090879 / Text5: Lili Yang (kadyyang@huawei.com)
- 164: SP#42 Stage 1 completed. SP#41 WID updated SP-080324=>SP-080503 / Text5: Philippe Lottin
- 165: SP#42 completed. SP#41 WID updated SP-080324=>SP-080503 / Text5: Philippe Lottin
- 166: SP#46 exception to 03/10 in SP-090753 / Text5: Maryse.Gardella@alcatel-lucent.fr
- 167: SP#46 exception to 03/10 in SP-090754. SP#44 WID updated SP-090055=>SP-090306. Linked to SA5 Rel-8 UID_380042 AoC support in IMS Charging (IMSTSS) / Text5: Jean-Luc Garcia (jl.garcia@orange-ftgroup.com)
- 168: CP#46 completed / Text5: Youssef.chadli@orange-ftgroup.com
- 169: SP#42 Stage 1 completed / Text5: lansizhong@chinamobile.com
- 170: SP#42 completed / Text5: lansizhong@chinamobile.com
- 171: CP#46 exception to 03/10 in CP-090805 / Text5: Emiliano Merino (emiliano.merino@ericsson.com)
- 172: CP#46 exception to 03/10 in CP-090805 / Text5: Lan Si Zhong (lansizhong@chinamobile.com), emiliano.merino@ericsson.com
- 173: SP#46 exception to 03/10 / Text5: Istvan Aba, Lan Si Zhong, Miguel Garcia
- 174: SP#46 exception to 03/10 in SP-090748 / Text5: istvan.aba <at> t-mobile.at
- 175: SP#46 exception to 03/10 in SP-090747. 32.182 v100 for Information / Text5: Istvan Aba, Lan Si Zhong, Miguel Garcia

| ID | WBS | Task | Duration | Start | Finish | Complete | Remaining | Baseline start | Baseline finish | Baseline duration | Total slack | Constraint | Resources | Work | Actual work | Text1 | Text2 | Text4 | Text5 | Text6 | Text7 | Text8 | Text11 |
| --- | --- | --- | --- | --- | --- | --- | --- | --- | --- | --- | --- | --- | --- | --- | --- | --- | --- | --- | --- | --- | --- | --- | --- |
| 176 | 87 | **IMS Services Centralization and Continuity** | 393d? | 2008-09-18 A | 2010-03-19 | 91% | 35.13d? | 2008-09-18 | 2010-03-19 | 393d? | 651d |  | S1,S2,C1 | 12160h | 8522.88h | IMS_SCC | PCG-21 | NEC | Joerg Swetina (joerg.swetina@nw.neclab.eu) | Rel-9 | SP-41 | Alain |  |
| 177 | 87.1 | Stage 1 - Inter-Device Transfer – Requirements | 61d? | 2008-09-18 A | 2008-12-11 A | 100% |  | 2008-09-18 | 2008-12-11 | 61d? |  | finish no earlier than 2009-06-18 | S1 | 488h | 488h | IMS_SCC-IDT | PCG-21 | NEC | Joerg Swetina (joerg.swetina@nw.neclab.eu) | Rel-9 | SP-41 | Alain |  |
| 178 | 87.2 | Stage 2 - IMS Service Continuity Enhancements: Service, Policy and Interactions | 186d? | 2008-09-18 A | 2009-06-04 A | 100% |  | 2008-09-18 | 2009-06-04 | 186d? |  | finish no earlier than 2009-06-04 | S2 | 1488h | 1488h | IMS_SCC-SPI | PCG-21 | Huawei | HengLiang Zhang (hl_zhang@huawei.com) | Rel-9 | SP-41 | Maurice |  |
| 179 | 87.3 | Stage 3 - IMS Service Continuity Enhancements: Service, Policy, Interactions and Inter UE Transfer | 212d? | 2009-05-29 A | 2010-03-19 | 80% | 42.4d? | 2009-05-29 | 2010-03-19 | 212d? | 651d | finish no earlier than 2010-03-19 | C1 | 1696h | 1356.8h | IMS_SCC-SPI | PCG-23 | Qualcomm Europe | Roozbeh Atarius (ratarius@qualcomm.com) | Rel-9 | CP-44 | Frederic | CP-090875 |
| 180 | 87.4 | Stage 2 - IMS Centralized Services | 186d? | 2008-09-18 A | 2009-06-04 A | 100% |  | 2008-09-18 | 2009-06-04 | 186d? |  | finish no earlier than 2009-06-04 | S2 | 1488h | 1488h | IMS_SCC-ICS | PCG-21 | Alcatel-Lucent | Andy Bennett (andybennett@alcatel-lucent.com) | Rel-9 | SP-41 | Maurice |  |
| 181 | 87.5 | Stage 3 - Enhancements to IMS Centralized Services | 212d? | 2009-05-29 A | 2010-03-19 | 98% | 4.24d? | 2009-05-29 | 2010-03-19 | 212d? | 651d | finish no earlier than 2010-03-19 | C1 | 1688h | 1654.08h | IMS_SCC-ICS | PCG-23 | Nokia Siemens Networks | Peter.Leis@nsn.com | Rel-9 | CP-44 | Frederic |  |
| 182 | 87.6 | Stage 3 - IMS Centralized Services support via I1 interface | 271d? | 2009-03-06 A | 2010-03-19 | 80% | 54.2d? | 2009-03-06 | 2010-03-19 | 271d? | 651d | finish no earlier than 2010-03-19 | C1 | 2168h | 1734.4h | IMS_SCC-ICS_I1 | PCG-22 | Huawei | Lili Yang(kadyyang@huawei.com) | Rel-9 | CP-43 | Frederic | CP-090874 |
| 183 | 88 | **Service Specific Access Control in EPS** | 333d? | 2008-12-11 A | 2010-03-19 | 85% | 49.72d? | 2008-12-11 | 2010-03-19 | 333d? | 651d |  | S1,C1 | 4368h | 1457.6h | SSAC | PCG-22 | NTT DoCoMo | Frederic Thepot (thepot@docomolab-euro.com) | Rel-9 | SP-42 | Alain |  |
| 184 | 88.1 | Stage 1 for SSAC | 1d? | 2008-12-11 A | 2008-12-11 A | 100% |  | 2008-12-11 | 2008-12-11 | 1d? |  | start no earlier than 2008-12-11 | S1 | 8h | 8h | SSAC | PCG-22 | NTT DoCoMo | Frederic Thepot (thepot@docomolab-euro.com) | Rel-9 | SP-42 | Alain |  |
| 185 | 88.2 | Stage 3 for SSAC | 212d? | 2009-05-29 A | 2010-03-19 | 85% | 31.8d? | 2009-05-29 | 2010-03-19 | 212d? | 651d | finish no earlier than 2010-03-19 | C1 | 1696h | 1441.6h | SSAC | PCG-23 | NTT DoCoMo | Hideyuki Yamashita (yamashitahi@s1.nttdocomo.co.jp) | Rel-9 | CP-44 | Frederic | CP-090880 |
| 186 | 89 | **Support for IMS Emergency Calls over GPRS and EPS** | 575d? | 2008-01-14 A | 2010-03-25 | 96% | 20.59d? | 2008-01-14 | 2010-03-19 | 571d? | 647d |  | S1,S2,S3,C1,C3,C4,R2,R3 | 24771.7h | 19801.5h | IMS_EMER_GPRS_EPS | PCG-21 | Alcatel-Lucent | Deborah Barclay | Rel-9 | SP-38 | Maurice |  |
| 187 | 89.1 | Stage 1 of IMS_EMER_GPRS_EPS | 239d? | 2008-01-14 A | 2008-12-11 A | 100% |  | 2008-01-14 | 2008-12-11 | 239d? |  | finish no earlier than 2008-12-11 | S1 | 1912h | 1912h | IMS_EMER_GPRS_EPS | PCG-21 | Alcatel-Lucent | Deborah Barclay | Rel-9 | SP-38 | Alain |  |
| 188 | 89.2 | Stage 2 of IMS_EMER_GPRS_EPS | 364d? | 2008-01-14 A | 2009-06-04 A | 100% |  | 2008-01-14 | 2009-06-04 | 364d? |  | finish no earlier than 2009-06-04 | S2 | 2912h | 2912h | IMS_EMER_GPRS_EPS | PCG-21 | Alcatel-Lucent | Deborah Barclay | Rel-9 | SP-38 | Maurice |  |
| 189 | 89.3 | Security aspects of IMS_EMER_GPRS_EPS | 336d? | 2008-12-12 A | 2010-03-25 | 80% | 67.2d? | 2008-12-12 | 2009-12-10 | 261d? | 647d | finish no earlier than 2010-03-25 | S3 | 2688h | 2150.4h | IMS_EMER_GPRS_EPS-Sec | PCG-22 | Alcatel-Lucent | Deborah Barclay | Rel-9 | SP-42 | Dionisio |  |
| 190 | 89.4 | **Stage 3 of IMS_EMER_GPRS_EPS** | 212d? | 2009-05-29 A | 2010-03-19 | 98% | 5.21d? | 2009-05-29 | 2010-03-19 | 212d? | 651d |  | C1,C3,C4 | 5139.68h | 3395.15h | IMS_EMER_GPRS_EPS | PCG-23 | Alcatel-Lucent | Frank Alfano (falfano@alcatel-lucent.com) | Rel-9 | CP-44 | Frederic |  |
| 191 | 89.4.1 | CT1 aspects - Stage 3 of IMS_EMER_GPRS_EPS | 212d? | 2009-05-29 A | 2010-03-19 | 95% | 10.6d? | 2009-05-29 | 2010-03-19 | 212d? | 651d | finish no earlier than 2010-03-19 | C1 | 1696h | 1611.2h | IMS_EMER_GPRS_EPS | PCG-23 | Alcatel-Lucent | Frank Alfano (falfano@alcatel-lucent.com) | Rel-9 | CP-44 | Frederic | CP-090873 |
| 192 | 89.4.2 | CT3 aspects - Stage 3 of IMS_EMER_GPRS_EPS | 82d? | 2009-05-29 A | 2009-09-18 A | 100% |  | 2009-05-29 | 2009-09-18 | 82d? |  | start no earlier than 2009-05-29 | C3 | 651.68h | 651.68h | IMS_EMER_GPRS_EPS | PCG-23 | Alcatel-Lucent | Frank Alfano (falfano@alcatel-lucent.com) | Rel-9 | CP-44 | Gwiho |  |
| 193 | 89.4.3 | CT4 aspects - Stage 3 of IMS_EMER_GPRS_EPS | 137d? | 2009-05-29 A | 2009-12-04 A | 100% |  | 2009-05-29 | 2009-12-04 | 137d? |  | finish no earlier than 2009-12-04 | C4 | 1096h | 1096h | IMS_EMER_GPRS_EPS | PCG-23 | Alcatel-Lucent | Frank Alfano (falfano@alcatel-lucent.com) | Rel-9 | CP-44 | Kimmo |  |
| 194 | 89.5 | Support for IMS Emergency Calls over LTE | 206d? | 2008-12-05 A | 2009-09-18 A | 100% |  | 2008-12-05 | 2009-09-18 | 206d? |  |  | R2,R3 | 1648h | 1648h | IMS_EMER_LTE | PCG-22 | Alcatel-Lucent | Sudeep Palat (spalat@alcatel-lucent.com) | Rel-9 | RP-42 | Joern | RP-090698 |
| 195 | 89.6 | **SRVCC support for IMS Emergency Calls** | 322d? | 2008-09-18 A | 2009-12-10 A | 100% |  | 2008-09-18 | 2009-12-10 | 322d? |  |  | S2,C1,C4,C3 | 5872h | 5872h | IMS_EMER_GPRS_EPS-SRVCC | PCG-21 | China Mobile | Yu Qing (Yuqing@chinamobile.com) | Rel-9 | SP-41 | Maurice |  |
| 196 | 89.6.1 | SRVCC support for IMS Emergency Calls | 322d? | 2008-09-18 A | 2009-12-10 A | 100% |  | 2008-09-18 | 2009-12-10 | 322d? |  | finish no earlier than 2009-12-10 | S2 | 2576h | 2576h | IMS_EMER_GPRS_EPS-SRVCC | PCG-21 | China Mobile | Yu Qing (Yuqing@chinamobile.com) | Rel-9 | SP-41 | Maurice |  |
| 197 | 89.6.2 | **CT aspects of SRVCC support for IMS Emergency Calls** | 137d? | 2009-05-29 A | 2009-12-04 A | 100% |  | 2009-05-29 | 2009-12-04 | 137d? |  |  | C1,C4,C3 | 3296h | 3296h | IMS_EMER_GPRS_EPS-SRVCC | PCG-24 | China Mobile | jiangyi@chinamobile.com | Rel-9 | CP-46 | Frederic |  |
| 198 | 89.6.2.1 | CT1 aspects of SRVCC support for IMS Emergency Calls | 137d? | 2009-05-29 A | 2009-12-04 A | 100% |  | 2009-05-29 | 2009-12-04 | 137d? |  | finish no earlier than 2009-12-04 | C1 | 1096h | 1096h | IMS_EMER_GPRS_EPS-SRVCC | PCG-23 | China Mobile | jiangyi@chinamobile.com | Rel-9 | CP-44 | Frederic |  |
| 199 | 89.6.2.2 | CT4 aspects of SRVCC support for IMS Emergency Calls | 137d? | 2009-05-29 A | 2009-12-04 A | 100% |  | 2009-05-29 | 2009-12-04 | 137d? |  | finish no earlier than 2009-12-04 | C4 | 1096h | 1096h | IMS_EMER_GPRS_EPS-SRVCC | PCG-23 | China Mobile | jiangyi@chinamobile.com | Rel-9 | CP-44 | Kimmo |  |
| 200 | 89.6.2.3 | CT3 aspects of SRVCC support for IMS Emergency Calls | 1d? | 2009-12-04 A | 2009-12-04 A | 100% |  | 2009-05-29 | 2009-12-04 | 137d? |  | finish no earlier than 2009-12-04 | C3 | 8h | 8h | IMS_EMER_GPRS_EPS-SRVCC | PCG-24 | China Mobile | jiangyi@chinamobile.com | Rel-9 | CP-46 | Kimmo |  |

Notes:
- 176: SP#42 Stage 1 completed.
- 177: SP#42 completed / Text3: 22.101, 22.228
- 178: SP#44 completed. TR 23.838 for Approval / Text3: 23.838, 23.237, 23.292, 23.216
- 179: CP#46 exception to 03/10 in CP-090875 / Text3: 24.216, 24.229, 24.237
- 180: SP#44 completed. TR 23.883 for Information + Approval / Text3: 23.883, 23.292
- 181: CP#46 completion 12/09=>03/10. WID updated CP-090439=>CP-090883 (added ICS support of video media over CS bearer) / Text3: 24.292, 24.604, 24.607, 24.608, 24.611, 24.623
- 182: CP#46 exception to 03/10 in CP-090874 / Text3: 24.237, 24.292, new 24.294
- 183: SP#42 Stage 1 completed (need for SA2 input). Triggered by Study UID_400036 on Service Specific Access Control in EPS (FS_SSAC)
- 184: SP#42 completed / Text3: 22.011 CR0136
- 185: CP#46 exception to 03/10 in CP-090880. WID updated CP-090443=>CP-090885 / Text3: 24.173, 27.007
- 186: SP#42 Stage 1 completed. WID updated SP-070820=>SP-080352=>SP-080844 (Add SA3 task).
- 187: SP#42 completed / Text3: 22.101
- 188: SP#44 completed / Text3: 23.869, 23.060, 23.167, 23.203, 23.221, 23.228, 23.271, 23.401, 23.402
- 189: SP#46 completion 12/09=>03/10 (no extension requested !?). SP#42 WID updated SP-080352=>SP-080844 (Added SA3 task) / Text3: 33.401, 33.402
- 190: CP#45 WID updated CP-090441=>CP-090564
- 191: CP#46 exception to 03/10 in CP-090873 / Text3: 23.122, 24.008, 24.229, 24.301, 24.302
- 192: CP#45 completed / Text3: 29.212, 29.213, 29.214, 29.215
- 193: CP#46 completed / Text3: 23.003, 23.008, 29.060, 29.272, 29.273, 29.274, 29.275, 29.276
- 194: RP#45 completed / Text3: 36.331, 36.413
- 195: CP/SP#46 completed
- 196: SP#46 completed. SP#43 WID updated SP-080562=>SP-090099 (added location continuity aspects) / Text3: 23.870, 23.216, 23.237
- 197: CP#46 completed. WID updated CP-090436=>CP-090882 (added CT3 part)
- 198: CP#46 completed / Text3: 24.229, 24.237
- 199: CP#46 completed / Text3: 29.205, 29.280
- 200: CP#46 completed / Text3: 29.163

| ID | WBS | Task | Duration | Start | Finish | Complete | Remaining | Baseline start | Baseline finish | Baseline duration | Total slack | Constraint | Resources | Work | Actual work | Text1 | Text2 | Text6 | Text7 | Text8 | Text4 | Text5 | Text11 |
| --- | --- | --- | --- | --- | --- | --- | --- | --- | --- | --- | --- | --- | --- | --- | --- | --- | --- | --- | --- | --- | --- | --- | --- |
| 201 | 90 | **LCS for LTE and EPS** | 468d? | 2008-06-05 A | 2010-03-19 | 73% | 126.9d? | 2008-06-05 | 2010-03-19 | 468d? | 651d |  | S2,C1,C4,R2,R1,R3,R4 | 17832h | 13316.8h | LCS_LTE_EPS | PCG-22 | Rel-9 | SP-43 | Maurice |  |  |  |
| 202 | 90.1 | **LCS Control Plane Solution for EPS** | 468d? | 2008-06-05 A | 2010-03-19 | 81% | 86.9d? | 2008-06-05 | 2010-03-19 | 468d? | 651d |  | S2,C4,C1 | 9224h | 7511.16h | LCS_EPS-CPS | PCG-21 | Rel-9 | SP-40 | Maurice | Polaris Wireless | Robert Gross |  |
| 203 | 90.1.1 | Stage 2 for LCS_CPS_EPS | 261d? | 2008-06-05 A | 2009-06-04 A | 100% |  | 2008-06-05 | 2009-06-04 | 261d? |  | finish no earlier than 2009-06-04 | S2 | 2088h | 2088h | LCS_EPS-CPS | PCG-21 | Rel-9 | SP-40 | Maurice | Polaris Wireless | Robert Gross |  |
| 204 | 90.1.2 | CT4 aspects - Control Plane LCS in the EPC | 212d? | 2009-05-29 A | 2010-03-19 | 80% | 42.4d? | 2009-05-29 | 2010-03-19 | 212d? | 651d | finish no earlier than 2010-03-19 | C4 | 1696h | 1356.8h | LCS_EPS-CPS | PCG-23 | Rel-9 | CP-44 | Kimmo | Polaris Wireless | Robert Gross | CP-090808 |
| 205 | 90.1.3 | CT1 aspects - Control Plane LCS in the EPC | 212d? | 2009-05-29 A | 2010-03-19 | 60% | 84.8d? | 2009-05-29 | 2010-03-19 | 212d? | 651d | finish no earlier than 2010-03-19 | C1 | 1696h | 1017.6h | LCS_EPS-CPS | PCG-23 | Rel-9 | CP-44 | Frederic | Polaris Wireless | Robert Gross | CP-090876 |
| 206 | 90.2 | Positioning Support for LTE | 337d? | 2008-12-05 A | 2010-03-19 | 90% | 33.7d? | 2008-12-05 | 2010-03-19 | 337d? | 651d | finish no earlier than 2010-03-19 | R2,R1,R3,R4 | 2696h | 2426.4h | LCS_LTE | PCG-22 | Rel-9 | RP-42 | Joern | Qualcomm Europe | Nathan Tenny (ntenny@qualcomm.com) | RP-091042 |
| 207 | 90.3 | Network-Based Positioning Support in LTE | 271d? | 2009-03-06 A | 2010-03-19 | 30% | 189.7d? | 2009-03-06 | 2010-03-19 | 271d? | 651d | finish no earlier than 2010-03-19 | R2,R3,R4 | 2168h | 650.4h | LCS_LTE-NBPS | PCG-22 | Rel-9 | RP-43 | Joern | TruePosition | terri.brooks@trueposition.com | RP-091043 |
| 208 | 91 | **MBMS support in EPS** | 472d? | 2008-06-05 A | 2010-03-25 | 86% | 63.81d? | 2008-06-05 | 2010-03-19 | 468d? | 647d |  | S2,S3,S5,C3,C4,R2,R3,R4 | 14512h | 12549.1h | MBMS_EPS | PCG-21 | Rel-9 | SP-40 | Maurice | China Mobile | Liu Hong (liuhongyfw@chinamobile.com) |  |
| 209 | 91.1 | Stage 2 for MBMS_EPS | 261d? | 2008-06-05 A | 2009-06-04 A | 100% |  | 2008-06-05 | 2009-06-04 | 261d? |  | finish no earlier than 2009-06-04 | S2 | 2088h | 2088h | MBMS_EPS | PCG-21 | Rel-9 | SP-40 | Maurice | China Mobile | Liu Hong (liuhongyfw@chinamobile.com) |  |
| 210 | 91.2 | Security for MBMS_EPS | 336d? | 2008-12-11 A | 2010-03-25 | 50% | 168d? | 2008-12-11 | 2009-12-10 | 261d? | 647d | finish no earlier than 2010-03-25 | S3 | 2688h | 1344h | MBMS_EPS | PCG-22 | Rel-9 | SP-42 | Dionisio | China Mobile | Liu Hong (liuhongyfw@chinamobile.com) |  |
| 211 | 91.3 | MBMS Charging in EPS | 201d? | 2009-03-06 A | 2009-12-10 A | 100% |  | 2009-03-06 | 2009-12-10 | 201d? |  | finish no earlier than 2009-12-10 | S5 | 1600h | 1600h | MBMS_EPS | PCG-22 | Rel-9 | SP-43 | Dionisio | ZTE | guo.wenjie1@zte.com.cn |  |
| 212 | 91.4 | CT4 aspects of MBMS support in EPS (Stage 3) | 137d? | 2009-05-29 A | 2009-12-04 A | 100% |  | 2009-05-29 | 2009-12-04 | 137d? |  | finish no earlier than 2009-12-04 | C4 | 1096h | 1096h | MBMS_EPS | PCG-23 | Rel-9 | CP-44 | Kimmo | China Mobile, ZTE | wangjingyf@chinamobile.com, lu.fei1@zte.com.cn |  |
| 213 | 91.5 | CT3 aspects of MBMS support in EPS (Stage 3) | 137d? | 2009-05-29 A | 2009-12-04 A | 100% |  | 2009-05-29 | 2009-12-03 | 136d? |  | start no earlier than 2009-05-29 | C3 | 1096h | 1096h | MBMS_EPS | PCG-23 | Rel-9 | CP-44 | Gwiho | ZTE, China Mobile | zhou.xiaoyun@zte.com.cn, wangjingyf@chinamobile.com |  |
| 214 | 91.6 | MBMS support in LTE | 271d? | 2009-03-06 A | 2010-03-19 | 95% | 13.55d? | 2009-03-06 | 2010-03-19 | 271d? | 651d | finish no earlier than 2010-03-19 | R2,R3,R4 | 2168h | 2059.6h | MBMS_LTE | PCG-22 | Rel-9 | RP-43 | Joern | Huawei | arnaud.meylan@huawei.com | RP-091044 |
| 215 | 92 | **Access Network Discovery and Selection Function enhancements** | 333d? | 2008-12-11 A | 2010-03-19 | 85% | 50.92d? | 2008-12-11 | 2010-03-19 | 333d? | 651d |  | S2,S1 | 3704h | 1741.6h | eANDSF | PCG-22 | Rel-9 | SP-42 | Maurice | Motorola | Apostolis Salkintzis (salki@motorola.com) |  |
| 216 | 92.1 | Stage 2 for eANDSF | 126d? | 2008-12-11 A | 2009-06-04 A | 100% |  | 2008-12-11 | 2009-06-04 | 126d? |  | finish no earlier than 2009-06-04 | S2 | 1008h | 1008h | eANDSF | PCG-22 | Rel-9 | SP-42 | Maurice | Motorola | Apostolis Salkintzis (salki@motorola.com) |  |
| 217 | 92.2 | CT1 aspects - eANDSF | 131d? | 2009-09-18 A | 2010-03-19 | 70% | 39.3d? | 2009-09-18 | 2010-03-19 | 131d? | 651d | finish no earlier than 2010-03-19 | C1 | 1048h | 733.6h | eANDSF | PCG-23 | Rel-9 | CP-45 | Frederic | Panasonic | benjamin.limck@sg.panasonic.com | CP-090869 |
| 218 | 93 | **Multiple PDN Connection to the Same APN for PMIP-based Interfaces** | 267d? | 2009-03-13 A | 2010-03-19 | 95% | 14.1d? | 2009-03-13 | 2010-03-19 | 267d? | 651d |  | S2,C4,C1 | 4120h | 2367.2h | MUPSAP | PCG-22 | Rel-9 | SP-43 | Maurice | Samsung | erik.guttman@partner.samsung.com |  |
| 219 | 93.1 | Stage 2 for MUPSAP | 61d? | 2009-03-13 A | 2009-06-04 A | 100% |  | 2009-03-13 | 2009-06-04 | 61d? |  | finish no earlier than 2009-06-04 | S2 | 488h | 488h | MUPSAP | PCG-22 | Rel-9 | SP-43 | Maurice | Samsung | erik.guttman@partner.samsung.com |  |
| 220 | 93.2 | MUPSAP - CT4 aspects | 56d? | 2009-09-18 A | 2009-12-04 A | 100% |  | 2009-09-18 | 2009-12-04 | 56d? |  | finish no earlier than 2009-12-04 | C4 | 448h | 448h | MUPSAP | PCG-23 | Rel-9 | CP-45 | Kimmo | Samsung | Surjyakanta Mohapatra (surjya.kanta@samsung.com) |  |
| 221 | 93.3 | MUPSAP - CT1 aspects | 131d? | 2009-09-18 A | 2010-03-19 | 90% | 13.1d? | 2009-09-18 | 2010-03-19 | 131d? | 651d | finish no earlier than 2010-03-19 | C1 | 1048h | 943.2h | MUPSAP | PCG-23 | Rel-9 | CP-45 | Frederic | Samsung | Surjyakanta Mohapatra (surjya.kanta@samsung.com) | CP-090878 |
| 222 | 94 | Access Security Enhancements | 505d? | 2007-07-02 A | 2009-06-04 A | 100% |  | 2007-07-02 | 2009-06-04 | 505d? |  | finish no earlier than 2009-06-03 | S3 | 4040h | 4040h | ACCSEC2 |  | Rel-9 | SP-26 | Dionisio | Ericsson | Bengt.Sahlin@ericsson.com |  |
| 223 | 95 | **Protection against Unsolicited Communication for IMS (PUCI)** | 322d? | 2008-09-18 A | 2009-12-10 A | 100% |  | 2008-09-18 | 2009-12-10 | 322d? |  |  | S3,S1 | 5640h | 5640h | PUCI | PCG-21 | Rel-9 | SP-41 | Alain | NEC | Anand R. Prasad (anand@bq.jp.nec.com) |  |
| 224 | 95.1 | Stage 1 for PUCI | 61d? | 2008-09-18 A | 2008-12-11 A | 100% |  | 2008-09-18 | 2008-12-11 | 61d? |  | finish no earlier than 2009-06-18 | S1 | 488h | 488h | PUCI | PCG-21 | Rel-9 | SP-41 | Alain | NEC | Anand R. Prasad (anand@bq.jp.nec.com) |  |
| 225 | 95.2 | SA3 work on PUCI | 322d? | 2008-09-18 A | 2009-12-10 A | 100% |  | 2008-09-18 | 2009-12-10 | 322d? |  | finish no earlier than 2009-12-10 | S3 | 2576h | 2576h | PUCI | PCG-21 | Rel-9 | SP-41 | Dionisio | NEC | Anand R. Prasad (anand@bq.jp.nec.com) |  |

Notes:
- 201: -
- 202: Triggered by abandoned Study UID_380068 (FS_LCS_EPS). Linked to UID_380064 Feature IMS_EMER_GPRS_EPS.
- 203: SP#44 completed (Some alignments might be needed later on based on RAN progress) / Text3: 23.891, 23.271, 23.401, 23.402
- 204: CP#46 extension to 03/10 in CP-090808. WID updated CP-090518=>CP-090811. Stage 3 SLs and SLg interfaces & transport of positioning messages between E-SMLC and MME in the scope of UID_420006 (Positioning Support for LTE) / Text3: 24.080, 29.002 new 24.171, 29.171, 29.172, 29.173
- 205: CP#46 exception to 03/10 in CP-090876 / Text3: 24.301
- 206: RP#46 exception to 03/10 in RP-091390. WID updated RP-080995=>RP-091348. UID_400038 (LCS Control Plane Solution for EPS) depends on this WI / Text3: 36.133, 36.214, 36.300, 36.331, 36.413, new 36.171, 36.305, 36.355, 36.455
- 207: RP#46 exception to 03/10 in RP-091391 / Text3: 36.305, 36.455
- 208: SP#42 WID updated SP-080442=>SP-080737 (add SA3 task)
- 209: SP#44 completed / Text3: 23.246
- 210: SP#46 completion 12/09=>03/10 (no extension requested !?). SP#45 completion 09/09=>12/09 / Text3: 33.246
- 211: SP#46 completed / Text3: 32.273, 32.251, 32.298, 32.299
- 212: CP#46 completed / Text3: 29.274, 29.281, 23.007, 23.008
- 213: CP#46 completed / Text3: 29.061
- 214: RP#46 exception to 03/10 in RP-091221. WID updated RP-090619=>RP-091396 / Text3: 25.446, 36.101, 36.104, 36.141, 36.300, 36.304, 36.321, 36.322, 36.323, 36.331, 36.440, 36.441, 36.442, 36.444, 36.445
- 215: SP#44 Stage 2 completed. No new Rel-9 use cases defined. Implement service requirements not covered in Rel-8 / Text3: SA1 22.278, SA3 33.402 CR#0055
- 216: SP#44 completed / Text3: 23.402, 23.002
- 217: CP#46 exception to 03/10 in CP-090869 / Text3: 24.302, 24.312
- 218: SP#44 Stage 2 completed. Continues Rel-8 SAES Stage 2 UID_320005. Stage 1 in 22.278 (EPS Service requirements) / Text3: 23.060, 23.203, 23.401, 23.402
- 219: SP#44 completed. Continues Rel-8 SAES Stage 2 UID_320005. Stage 1 in 22.278 (EPS Service requirements) / Text3: 23.060, 23.203, 23.401, 23.402
- 220: CP#46 completed / Text3: 29.275, 23.008, 29.282
- 221: CP#46 exception to 03/10 in CP-090878 / Text3: 24.302
- 222: SP#44 completed. Stopped TR 33.801. CRs 33.102,43.020 on A5/2 removal done long time ago. A5/4 introduction CRs will be done under UID_440057 128 bit encryption for GSM and GPRS. SP#26 approved WID (improved GERAN security) / Text3: 33.102, 43.020, Stopped TR 33.801 “Access security review” (Reason: draft contained useful material for planning A5/2 removal and A5/4 introduction. Completion would require significant effort)
- 223: SP#46 SA3 completed TR but no specification work done in Rel-9. SP#42 Stage 1 completed. Related work in OMA Categorization Based Content Screening
- 224: SP#42 completed / Text3: 22.228
- 225: SP#46 completed. TR 33.837 converted to 33.937. No SA3 normative work done in Rel-9 / Text3: new 33.937 (was 33.837)

| ID | WBS | Task | Duration | Start | Finish | Complete | Remaining | Baseline start | Baseline finish | Baseline duration | Total slack | Constraint | Resources | Work | Actual work | Text1 | Text2 | Text4 | Text5 | Text6 | Text7 | Text8 | Text11 | Text9 | Text12 |
| --- | --- | --- | --- | --- | --- | --- | --- | --- | --- | --- | --- | --- | --- | --- | --- | --- | --- | --- | --- | --- | --- | --- | --- | --- | --- |
| 226 | 96 | **IMS Media Plane Security** | 271d? | 2009-03-13 A | 2010-03-25 | 52% | 130.97d? | 2009-03-13 | 2010-03-25 | 271d? | 647d |  | S3,C1,C4,C3 | 6467.2h | 2118.21h | MEDIASEC | PCG-22 | Vodafone | Peter.Howard@vodafone.com | Rel-9 | SP-43 | Dionisio |  |  |  |
| 227 | 96.1 | SA3 aspects - MEDIASEC | 271d? | 2009-03-13 A | 2010-03-25 | 95% | 13.55d? | 2009-03-13 | 2010-03-25 | 271d? | 647d | finish no earlier than 2010-03-25 | S3 | 2168h | 2059.6h | MEDIASEC | PCG-22 | Vodafone | Peter.Howard@vodafone.com | Rel-9 | SP-43 | Dionisio |  |  |  |
| 228 | 96.2 | **CN aspects of IMS Media Plane Security** | 131d? | 2009-09-18 A | 2010-03-19 | 3% | 127.4d? | 2009-09-18 | 2010-03-19 | 131d? | 651d |  | C1,C4,C3 | 2131.2h | 58.61h | MEDIASEC_CORE | PCG-23 | Vodafone | peter.dawes@vodafone.com | Rel-9 | CP-45 | Frederic | CP-090877 |  |  |
| 229 | 96.2.1 | CT1 aspects - MEDIASEC | 33d? | 2009-09-18 A | 2010-03-19 | 20% | 26.4d? | 2009-09-18 | 2010-03-19 | 33d? | 651d | finish no earlier than 2010-03-19 | C1 | 264h | 52.8h | MEDIASEC_CORE | PCG-23 | Vodafone | peter.dawes@vodafone.com | Rel-9 | CP-45 | Frederic | CP-090877 |  |  |
| 230 | 96.2.2 | CT4 aspects - MEDIASEC | 131d? | 2009-09-18 | 2010-03-19 |  |  | 2009-09-18 | 2010-03-19 | 131d? | 651d | finish no earlier than 2010-03-19 | C4 | 1048h |  | MEDIASEC_CORE | PCG-23 | Vodafone | peter.dawes@vodafone.com | Rel-9 | CP-45 | Kimmo | CP-090809 |  |  |
| 231 | 96.2.3 | CT3 aspects - MEDIASEC | 76d? | 2009-12-04 | 2010-03-19 |  |  | 2009-12-04 | 2010-03-19 | 76d? | 651d | finish no earlier than 2010-03-19 | C3 | 608h |  | MEDIASEC_CORE | PCG-24 | Vodafone | peter.dawes@vodafone.com | Rel-9 | CP-46 |  | CP-091022 |  |  |
| 232 | 97 | **GBAPush enhancements (Generic push layer)** | 533d? | 2008-03-12 A | 2010-03-25 | 85% | 79.95d? | 2008-03-12 | 2009-12-10 | 458d? | 647d |  | S3 | 8528h | 7248.8h | eGBAPush | PCG-23 | Ericsson | Rolf Blom | Rel-9 | SP-44 | Dionisio |  |  |  |
| 233 | 97.1 | SA3 part of eGBAPush (Generic push layer) | 533d? | 2008-03-12 A | 2010-03-25 | 85% | 79.95d? | 2008-03-12 | 2009-12-10 | 458d? | 647d | finish no earlier than 2010-03-25 | S3 | 4264h | 3624.4h | eGBAPush | PCG-21 | Ericsson | Rolf Blom | Rel-9 | SP-39 | Dionisio |  |  |  |
| 234 | 98 | Extended Identity Management | 136d? | 2009-06-04 A | 2009-12-10 A | 100% |  | 2009-06-04 | 2009-12-10 | 136d? |  | finish no earlier than 2009-12-10 | S3 | 1088h | 1088h | GBA-IdM | PCG-23 | Nokia | Silke.Holtmanns at nokia.com | Rel-9 | SP-44 | Dionisio |  |  |  |
| 235 | 99 | **Network Domain Security (NDS) enhancements to support backhaul security** | 211d? | 2009-06-04 A | 2010-03-25 | 57% | 90.86d? | 2009-06-04 | 2010-03-25 | 211d? | 647d |  | S3,C4 | 4432h | 2523.53h | NDS_Backhaul | PCG-23 | Vodafone | Peter Howard | Rel-9 | SP-44 | Dionisio |  |  |  |
| 236 | 99.1 | SA3 part of NDS_Backhaul | 211d? | 2009-06-04 A | 2010-03-25 | 30% | 147.7d? | 2009-06-04 | 2010-03-25 | 211d? | 647d | finish no earlier than 2010-03-25 | S3 | 1688h | 506.4h | NDS_Backhaul | PCG-23 | Vodafone | Peter Howard | Rel-9 | SP-44 | Dionisio | SP-090834 |  |  |
| 237 | 99.2 | CT4 part of NDS_Backhaul | 132d? | 2009-06-04 A | 2009-12-04 A | 100% |  | 2009-06-04 | 2009-12-04 | 132d? |  | finish no earlier than 2009-12-04 | C4 | 1056h | 1056h | NDS_Backhaul | PCG-23 | Vodafone | Peter Howard | Rel-9 | SP-44 | Kimmo |  |  |  |
| 238 | 100 | **128 bit encryption for GSM and GPRS** | 211d? | 2009-06-04 A | 2010-03-25 | 94% | 12.83d? | 2009-06-04 | 2009-12-10 | 136d? | 647d |  | S3,S2,C1,C4,G2,G3new | 7240h | 6799.76h | A5/4-GEA4 | PCG-23 | Ericsson | Karl Norrman | Rel-9 | SP-44 | Dionisio |  |  |  |
| 239 | 100.1 | SA3 part of A5/4-GEA4 | 211d? | 2009-06-04 A | 2010-03-25 | 80% | 42.2d? | 2009-06-04 | 2009-12-10 | 136d? | 647d | finish no earlier than 2010-03-25 | S3 | 1688h | 1350.4h | A5/4-GEA4 | PCG-23 | Ericsson | Karl Norrman | Rel-9 | SP-44 | Dionisio |  |  |  |
| 240 | 100.2 | CT1 part of A5/4-GEA4 | 77d? | 2009-06-04 A | 2009-09-18 A | 100% |  | 2009-06-04 | 2009-09-18 | 77d? |  | start no earlier than 2009-06-04 | C1 | 616h | 616h | A5/4-GEA4 | PCG-23 | Ericsson | Karl Norrman | Rel-9 | SP-44 | Frederic |  |  |  |
| 241 | 100.3 | CT4 part of A5/4-GEA4 | 136d? | 2009-06-04 A | 2009-12-10 A | 100% |  | 2009-06-04 | 2009-12-10 | 136d? |  | start no earlier than 2009-06-04 | C4 | 1088h | 1088h | A5/4-GEA4 | PCG-23 | Ericsson | Karl Norrman | Rel-9 | SP-44 | Kimmo |  |  |  |
| 242 | 100.4 | GERAN2 part of A5/4-GEA4 | 67d? | 2009-06-04 A | 2009-09-04 A | 100% |  | 2009-06-04 | 2009-09-04 | 67d? |  | finish no earlier than 2009-09-04 | G2 | 536h | 536h | A5/4-GEA4 | PCG-23 | Ericsson | Karl Norrman | Rel-9 | SP-44 | Gert |  |  |  |
| 243 | 100.5 | GERAN3new (testing) part of A5/4-GEA4 | 122d? | 2009-06-04 A | 2009-11-20 A | 100% |  | 2009-06-04 | 2009-11-20 | 122d? |  | finish no earlier than 2009-11-20 | G3new | 976h | 976h | A5/4-GEA4 | PCG-23 | Ericsson | Karl Norrman | Rel-9 | SP-44 | Ingbert |  |  |  |
| 244 | 100.6 | Deleted - SA2 part of A5/4-GEA4 | 81d? | 2009-06-04 A | 2009-09-24 A | 100% |  | 2009-06-04 | 2009-09-24 | 81d? |  | finish no earlier than 2009-09-24 | S2 | 648h | 648h | A5/4-GEA4 | PCG-23 | Ericsson | Karl Norrman | Rel-9 | SP-44 | Maurice |  | PCG-23 | SP-45 |
| 245 | 101 | Lawful Interception in the 3GPP Rel-9 | 211d? | 2009-06-04 A | 2010-03-25 | 30% | 147.7d? | 2009-06-04 | 2010-03-25 | 211d? | 647d | finish no earlier than 2010-03-25 | S3 | 1688h | 506.4h | LI9 | PCG-23 | PIDS, Nortel | Koen Jaspers, Ronald Ryan | Rel-9 | SP-44 | Dionisio | SP-090833 |  |  |
| 246 | 102 | Timed Graphics | 337d? | 2008-12-11 A | 2010-03-25 | 60% | 134.8d? | 2008-12-11 | 2010-03-25 | 337d? | 647d | finish no earlier than 2010-03-25 | S4 | 2696h | 1617.6h | TG | PCG-22 | Ericsson | clinton.priddle@ericsson.com | Rel-9 | SP-42 | Paolo | SP-090715 |  |  |
| 247 | 103 | Managing MTSI Media Adaptation | 196d? | 2009-03-12 A | 2009-12-10 A | 100% |  | 2009-03-12 | 2009-12-10 | 196d? |  | finish no earlier than 2009-12-10 | S4 | 1568h | 1568h | M3A | PCG-22 | Samsung | kyunghun.jung@samsung.com | Rel-9 | SP-43 | Paolo |  |  |  |
| 248 | 104 | **PSS and MBMS Aspects** | 272d? | 2009-03-12 A | 2010-03-25 | 57% | 115.6d? | 2009-03-12 | 2010-03-25 | 272d? | 647d |  | S4 | 6512h | 3744.4h | PMA | PCG-23 | Ericsson, Nokia | Clinton.Priddle@ericsson.com, imed.bouazizi@nokia.com | Rel-9 | SP-44 | Paolo |  |  |  |
| 249 | 104.1 | PSS and MBMS extensions | 271d? | 2009-03-12 A | 2010-03-25 | 45% | 149.05d? | 2009-03-12 | 2010-03-25 | 271d? | 647d | finish no earlier than 2010-03-25 | S4 | 2168h | 975.6h | PMA-MBS_Ext | PCG-22 | Ericsson | Clinton.Priddle@ericsson.com | Rel-9 | SP-43 | Paolo | SP-090712 |  |  |
| 250 | 104.2 | Improved Video Support for PSS and MBMS | 271d? | 2009-03-12 A | 2010-03-25 | 70% | 81.3d? | 2009-03-12 | 2010-03-25 | 271d? | 647d | finish no earlier than 2010-03-25 | S4 | 2168h | 1517.6h | PMA-IVS | PCG-22 | Nokia | imed.bouazizi@nokia.com | Rel-9 | SP-43 | Paolo | SP-090712 |  |  |
| 251 | 105 | IMS based PSS and MBMS User Service extensions | 197d? | 2009-03-12 A | 2009-12-10 A | 100% |  | 2009-03-12 | 2009-12-10 | 197d? |  | finish no earlier than 2009-12-10 | S4 | 1576h | 1576h | IMS_PSS_MBMS_US_EXT | PCG-22 | Ericsson | Markus Kampmann | Rel-9 | SP-43 | Paolo |  |  |  |
| 252 | 106 | Syndicated Feed Reception within 3GPP environments | 136d? | 2009-06-04 A | 2009-12-10 A | 100% |  | 2009-06-04 | 2009-12-10 | 136d? |  | start no earlier than 2009-06-04 | S4 | 1088h | 1088h | SFR | PCG-23 | Ericsson | Thorsten.Lohmar@ericsson.com | Rel-9 | SP-44 | Paolo |  |  |  |
| 253 | 107 | Distortion Measurement Test Methods and Requirements | 131d? | 2009-09-24 A | 2010-03-25 | 55% | 58.95d? | 2009-09-24 | 2010-03-25 | 131d? | 647d | finish no earlier than 2010-03-25 | S4 | 1048h | 576.4h | DTMR | PCG-23 | Motorola | Stephen Kendall (wcsk01@motorola.com) | Rel-9 | SP-45 | Paolo | SP-090706 |  |  |

Notes:
- 226: CP#46 Stage 3 exception to 03/10
- 227: SP#46 completion 12/09=>03/10. TR 33.828 3rd time for Information. TS 33.328 for Approval / Text3: new 33.828, 33.328
- 228: CP#46 exception to 03/10. WID updated CP-090740=>CP-090884
- 229: CP#46 exception to 03/10 in CP-090877 / Text3: 23.218, 24.229
- 230: CP#46 exception to 03/10 in CP-090809 / Text3: 29.238, 23.334, 29.334
- 231: CP#46 exception to 03/10 in CP-091022 / Text3: 29.162
- 232: SP#45 TS 33.224 for Approval. Completion 09/09=>12/09. SP#44 WID approved. Develop a generic push layer using GAA protection. SP#43 Umbrella Feature created to host 33.224, moved from Rel-8 to Rel-9 / Text3: 33.224
- 233: SP#46 completion 12/09=>03/10 (no extension requested !?). SP#45 TS 33.224 for Approval. Completion 09/09=>12/09 / Text3: 33.224
- 234: SP#46 completed. TR 33.924 (Stage 2) for Approval. Stage 1 not identified: GBA Liberty Interworking has been outlined and GBAOpenID interworking is analogous / Text3: new 33.924, CP#45 CT4 completed (Added service code in 29.109)
- 235: SP#46 further Stage 2 exception to 03/10 (was 12/09). Continuation of Rel-8 UID_390044 SAE security architecture. Covers gaps in backhaul security in SAE (also applicable to UTRAN and GERAN backhaul)
- 236: SP#46 further Stage 2 exception to 03/10 (was 12/09) in SP-090834. [Identity Management and 3GPP Security Interworking (Interworking of GAA and OpenID)] / Text3: 33.102, 33.210, 33.310, 33.401, 33.402
- 237: CP#46 completed. No impact on CT4 specs
- 238: Allow 128 as an alternative to 64 bit keys (Stage 2/3 + Test spec)
- 239: SP#46 completion 12/09=>03/10 (no extension requested !?). SP#45 TS 55.226v100 for Information+Approval / Text3: 33.102,43.020, new 55.226 (A5/4 encryption algorithms for GSM and ECSD, and GEA4 encryption algorithm for GPRS)
- 240: CP#45 completed / Text3: 24.008,44.064
- 241: CP#46 completed. Kc128 enhancements are carried as UMTS keys => no CT4 impact / Text3: 29.002, 29.060
- 242: GP#43 WID approved / Text3: 44.018,48.008,48.018,48.058
- 243: GP#44 completed. GP#43 WID approved / Text3: 51.010
- 244: SP#45 work stopped/abandoned / Text3: 23.060
- 245: SP#46 further Stage 2 exception to 03/10 (was 12/09) in SP-090833. WID updated SP-090532=>SP-090832 / Text3: 33.106 (LI requirements), 33.107 (LI architecture and functions), 33.108 (Handover interface for LI)
- 246: SP#46 exception to 03/10 in SP-090715. TS 26.430 v.100 forInformation / Text3: 26.114, 26.140, 26.234, 26.244, 26.245, 26.346, new 26.430
- 247: SP#46 completed. Work extending Rel-8 UID_34041 MTSI Video - Dynamic Rate Adaptation/Signalling of Image Size. Update speech/video adaptation algorithms used by network to control MTSI client terminal in congestion or poor transmission conditions. / Text3: 26.114
- 248: Umbrella WI
- 249: SP#46 exception to 03/10 in SP-090712. Work extending Rel-8 UID_34043 PSS_MBMS_OMTV & ensure compatibility with UID_34046 (IMS_PSS_MBMS_US) / Text3: 26.234, 26.346
- 250: SP#46 exception to 03/10 in SP-090712. TR 26.903 for Information / Text3: 26.234, 26.244, 26.346, new 26.903
- 251: SP#46 completed. Work extending Rel-8 UID_34046 (IMS_PSS_MBMS_US), SA2 UID_410034 IMSSCC-SPI (IMS Service Continuity Enhancements: Service, Policy and Interactions) / Text3: 26.237
- 252: SP#46 completed. TS 26.150v100 for Approval. RSS optimized for mobile use. Reuse/reference OMA's enabler DCD. / Text3: 26.150
- 253: SP#46 exception to 03/10 in SP-090706 / Text3: 26.131, 26.132

| ID | WBS | Task | Duration | Start | Finish | Complete | Remaining | Baseline start | Baseline finish | Baseline duration | Total slack | Constraint | Resources | Work | Actual work | Text1 | Text2 | Text6 | Text7 | Text8 | Text4 | Text11 | Text9 | Text12 |
| --- | --- | --- | --- | --- | --- | --- | --- | --- | --- | --- | --- | --- | --- | --- | --- | --- | --- | --- | --- | --- | --- | --- | --- | --- |
| 254 | 108 | **OAM&P 9** | 546d? | 2008-02-22 A | 2010-03-25 | 60% | 216.47d? | 2008-02-22 | 2010-03-25 | 546d? | 647d |  | S5 | 33810.4h | 20486h | OAM9 | PCG-22 | Rel-9 | SP-42 | Dionisio |  |  |  |  |
| 255 | 108.1 | **Network Infrastructure Management** | 337d? | 2008-12-11 A | 2010-03-25 | 44% | 187.44d? | 2008-12-11 | 2010-03-25 | 337d? | 647d |  | S5 | 8760h | 3887.68h | OAM9-NIM | PCG-22 | Rel-9 | SP-42 | Dionisio |  |  |  |  |
| 256 | 108.1.1 | Software Management for Network Elements | 336d? | 2008-12-11 A | 2010-03-25 | 75% | 84d? | 2008-12-11 | 2010-03-25 | 336d? | 647d | finish no earlier than 2010-03-25 | S5 | 2688h | 2016h | OAM9-NE_SWM | PCG-22 | Rel-9 | SP-42 | Dionisio | Huawei, Nokia Siemens Networks | SP-090742 |  |  |
| 257 | 108.1.2 | Service Oriented Architecture (SOA) for IRP | 211d? | 2009-06-04 A | 2010-03-25 | 20% | 168.8d? | 2009-06-04 | 2010-03-25 | 211d? | 647d | finish no earlier than 2010-03-25 | S5 | 1688h | 337.6h | OAM9 | PCG-23 | Rel-9 | SP-44 | Dionisio | Ericsson, Nokia Siemens Networks | SP-090749 |  |  |
| 258 | 108.1.3 | IRP SOAP Solution Sets continuation from Rel-8 | 211d? | 2009-06-04 A | 2010-03-25 | 20% | 168.8d? | 2009-06-04 | 2010-03-25 | 211d? | 647d | finish no earlier than 2010-03-25 | S5 | 1688h | 337.6h | OAM9 | PCG-23 | Rel-9 | SP-44 | Dionisio | Ericsson | SP-090750 |  |  |
| 259 | 108.2 | **Performance Management** | 272d? | 2009-03-12 A | 2010-03-25 | 69% | 85.6d? | 2009-03-12 | 2010-03-25 | 272d? | 647d |  | S5 | 7010.41h | 4802.4h | OAM9-PM | PCG-22 | Rel-9 | SP-42 | Dionisio |  |  |  |  |
| 260 | 108.2.1 | Enhancement of E-UTRAN Performance Measurements | 272d? | 2009-03-12 A | 2010-03-25 | 30% | 190.4d? | 2009-03-12 | 2010-03-25 | 272d? | 647d | finish no earlier than 2010-03-25 | S5 | 2176h | 652.8h | OAM9 | PCG-22 | Rel-9 | SP-43 | Dionisio | Motorola, Huawei | SP-090745 |  |  |
| 261 | 108.2.2 | Enhancement of EPC Performance Measurements | 197d? | 2009-03-12 A | 2009-12-10 A | 100% |  | 2009-03-12 | 2009-12-10 | 197d? |  | finish no earlier than 2010-03-25 | S5 | 1570.41h | 1570.41h | OAM9 | PCG-22 | Rel-9 | SP-43 | Dionisio | China Mobile |  |  |  |
| 262 | 108.2.3 | Enhancement of UTRAN Performance Measurements | 136d? | 2009-06-04 A | 2009-12-10 A | 100% |  | 2009-06-04 | 2009-12-10 | 136d? |  | start no earlier than 2009-06-04 | S5 | 1088h | 1088h | OAM9 | PCG-23 | Rel-9 | SP-44 | Dionisio | China Mobile |  |  |  |
| 263 | 108.3 | Deleted - Trace | 196d? | 2009-03-13 A | 2009-12-10 A | 100% |  | 2009-03-13 | 2009-12-10 | 196d? |  | finish no earlier than 2009-12-10 | S5 | 1568h | 1568h | OAM9-Trace | PCG-22 | Rel-9 | SP-42 | Dionisio |  |  | PCG-24 | SP-46 |
| 264 | 108.4 | **Self-Organizing Networks (SON) - OAM aspects** | 546d? | 2008-02-22 A | 2010-03-25 | 68% | 174.6d? | 2008-02-22 | 2010-03-25 | 546d? | 647d |  | S5 | 10416h | 7085.22h | OAM9-SON | PCG-22 | Rel-9 | SP-43 | Dionisio |  |  |  |  |
| 265 | 108.4.1 | SON self-optimization management | 545d? | 2008-02-22 A | 2010-03-25 | 75% | 136.25d? | 2008-02-22 | 2010-03-25 | 545d? | 647d | finish no earlier than 2010-03-25 | S5 | 4360h | 3270h | LTE_SON-OAM | PCG-21 | Rel-9 | SP-39 | Dionisio | Huawei | SP-090741 |  |  |
| 266 | 108.4.2 | Automatic Radio Network Configuration Data Preparation | 211d? | 2009-06-04 A | 2010-03-25 | 50% | 105.5d? | 2009-06-04 | 2010-03-25 | 211d? | 647d | finish no earlier than 2010-03-25 | S5 | 1688h | 844h | OAM9 | PCG-23 | Rel-9 | SP-44 | Dionisio | Nokia Siemens Networks | SP-090752 |  |  |
| 267 | 108.5 | Subscription Management (SuM) evolution | 211d? | 2009-06-04 A | 2010-03-25 | 30% | 147.7d? | 2009-06-04 | 2010-03-25 | 211d? | 647d | finish no earlier than 2010-03-25 | S5 | 1688h | 506.4h | OAM9-SuM | PCG-23 | Rel-9 | SP-44 | Dionisio | Ericsson | SP-090746 |  |  |
| 268 | 109 | **Charging Management small Enhancements** | 211d? | 2009-06-04 A | 2010-03-25 | 25% | 158.25d? | 2009-06-04 | 2010-03-25 | 211d? | 647d |  | S5 | 3376h | 844h | CH9 | PCG-23 | Rel-9 | SP-44 | Dionisio |  |  |  |  |
| 269 | 109.1 | IWLAN mobility charging | 211d? | 2009-06-04 A | 2010-03-25 | 25% | 158.25d? | 2009-06-04 | 2010-03-25 | 211d? | 647d | finish no earlier than 2010-03-25 | S5 | 1688h | 422h | eIWLAN_Mob | PCG-23 | Rel-9 | SP-44 | Dionisio | Orange | SP-090755 |  |  |
| 270 | 110 | **CS-IBCF and CS-TrGW definition in 3GPP specifications** | 397d? | 2008-05-30 A | 2009-12-04 A | 100% |  | 2008-05-30 | 2010-03-19 | 472d? |  |  | C3,C4 | 9513.27h | 9513.27h | CS-IBCF | PCG-21 | Rel-9 | CP-40 | Gwiho | Telecom Italia |  |  |  |
| 271 | 110.1 | CT3 aspects of CS-IBCF | 397d? | 2008-05-30 A | 2009-12-04 A | 100% |  | 2008-05-30 | 2010-03-19 | 472d? |  | finish no earlier than 2009-12-04 | C3 | 3169.27h | 3169.27h | CS-IBCF | PCG-21 | Rel-9 | CP-40 | Gwiho | Telecom Italia |  |  |  |
| 272 | 110.2 | CT4 aspects of CS-IBCF | 396d? | 2008-05-30 A | 2009-12-04 A | 100% |  | 2008-05-30 | 2009-12-04 | 396d? |  | finish no earlier than 2009-12-04 | C4 | 3168h | 3168h | CS-IBCF | PCG-21 | Rel-9 | CP-40 | Kimmo | Telecom Italia |  |  |  |
| 273 | 111 | **IMS – Interconnection Border Control Function (IBCF) – Transition Gateway (TrGW); Ix Interface; Stage 3** | 322d? | 2008-09-12 A | 2009-12-04 A | 100% |  | 2008-09-12 | 2010-03-19 | 397d? |  |  | C4,C3 | 6858.4h | 6858.4h | IMS_IBCF | PCG-21 | Rel-9 | CP-41 | Kimmo | Alcatel-Lucent |  |  |  |
| 274 | 111.1 | CT4 part of IMS_IBCF | 321d? | 2008-09-12 A | 2009-12-04 A | 100% |  | 2008-09-12 | 2009-12-04 | 321d? |  | finish no earlier than 2009-12-04 | C4 | 2568h | 2568h | IMS_IBCF | PCG-21 | Rel-9 | CP-41 | Kimmo | Alcatel-Lucent |  |  |  |
| 275 | 111.2 | CT3 part of IMS_IBCF | 295.8d? | 2008-09-12 A | 2009-12-04 A | 100% |  | 2008-09-12 | 2010-03-19 | 370.8d? |  | finish no earlier than 2010-03-19 | C3 | 2366.4h | 2366.4h | IMS_IBCF | PCG-21 | Rel-9 | CP-41 | Gwiho | Alcatel-Lucent |  |  |  |
| 276 | 112 | IMS Application Level Gateway Control Function (ALGCF) – IMS Access Media Gateway (IMA-MGW); Iq Interface; Stage 2 and Stage 3 | 321d? | 2008-09-12 A | 2009-12-04 A | 100% |  | 2008-09-12 | 2009-12-04 | 321d? |  | finish no earlier than 2009-12-04 | C4 | 2568h | 2568h | IMS_AGCF | PCG-21 | Rel-9 | CP-41 | Kimmo | Alcatel-Lucent |  |  |  |
| 277 | 113 | **Enhancements of IMS Customized Alerting Tone (CAT) Service** | 337d? | 2008-12-05 A | 2010-03-19 | 95% | 16.85d? | 2008-12-05 | 2010-03-19 | 337d? | 651d |  | C1 | 4966.4h | 4718.08h | eCAT | PCG-22 | Rel-9 | CP-42 | Frederic | China Mobile |  |  |  |
| 278 | 113.1 | Stage 3 Enhancements of IMS CAT Supplementary Service | 336d? | 2008-12-05 A | 2010-03-19 | 95% | 16.8d? | 2008-12-05 | 2010-03-19 | 336d? | 651d | finish no earlier than 2010-03-19 | C1 | 2688h | 2553.6h | eCAT-SS | PCG-22 | Rel-9 | CP-42 | Frederic | China Mobile | CP-090870 |  |  |

Notes:
- 254: SP#42 umbrella Feature created to host OAM WIs
- 255: SP#42 umbrella BB created to host OAM WIs
- 256: SP#46 exception to 03/10 in SP-090742 / Text3: 32.531, 32.532, 32.533, 32.537 / Text5: Bidipta Das (bidipta@huawei.com), Clemens Suerbaum (clemens.suerbaum@nsn.com)
- 257: SP#46 exception to 03/10 in SP-090749. Triggered by UID_400029 Study on Service Oriented Architecture (SOA) for IRP (TR 32.824) / Text3: 32.101, 32.102, 32.150 / Text5: Edwin Tse (Ericsson), Joerg Schmidt (NSN)
- 258: SP#46 exception to 03/10 in SP-090750. Continuation of Rel-8 UID_400030 IRP SOAP Solution Sets / Text3: 32.127, 32.327, 32.337, 32.357, 32.387, 32.397, 32.447, 32.121, 32.122, 32.123, 32.321, 32.322, 32.323, 32.325, 32.331, 32.332, 32.333, 32.335, 32.351, 32.352, 32.353, 32.381, 32.382, 32.383, 32.385, 32.391, 32.392, 32.393, 32.395, 32.441, 32.442, 32.443 / Text5: John Power
- 259: SP#42 umbrella BB created to host OAM WIs
- 260: SP#46 exception to 03/10 in SP-090745 / Text3: 32.425 / Text5: Yizhi Yao (yzyao@motorola.com),Lan Zou (zlan@huawei.com)
- 261: SP#46 completed / Text3: 32.426 / Text5: Li Jian (lijian@chinamobile.com), Liang Shuangchun (liangshuangchun@cmdi.chinamobile.com)
- 262: SP#46 completed / Text3: 32.405 / Text5: Liang Shuangchun, Li Jian, Bao Haitao
- 263: SP#46 stopped (no work in Rel-9)
- 264: SP#43 umbrella BB created to host OAM WIs
- 265: SP#46 exception to 03/10 in SP-090741. WID updated SP-090054=>SP-090762 (removed Self-Healing handling which becomes a Rel-10 dedicated WI SP-090757) / Text3: 32.425, new 32.521, 32.522, 32.523 / Text5: Lan Zou (zlan@huawei.com)
- 266: SP#46 exception to 03/10 in SP-090752. WID updated SP-090317=>SP-090869. 10/09 moved on SA5 request WT from BB OAM9-NIM to BB OAM9-SON / Text3: 32.501, 32.502, 32.503 / Text5: clemens.suerbaum@nsn.com
- 267: SP#46 exception to 03/10 in SP-090746 / Text3: 32.140, 32.141, 32.152, 32.172, 32.175 / Text5: frode.nergard@ericsson.com
- 268: -
- 269: SP#46 exception to 03/10 in SP-090755. RAT differentiation for charging. Completes Rel-8 Feature IWLAN_Mob UID_370049 Mobility between 3GPP-WLAN Interworking and 3GPP Systems / Text3: 32.240, 32.252, 32.298, 32.299 / Text5: Jean-Luc Garcia
- 270: CP#46 completed. Rel-8 UID_380061 (Ipinterc) covers Stage 1 in SA1 22.101, 22.228 / Text5: mauro.ficaccio@telecomitalia.it
- 271: CP#46 completed / Text3: 29.235 / Text5: mauro.ficaccio@telecomitalia.it
- 272: CP#46 completed / Text3: 23.231, 29.232, 29.238 / Text5: mauro.ficaccio@telecomitalia.it
- 273: CP#46 completed / Text5: Bruno.Landais@alcatel-lucent.fr
- 274: CP#46 completed / Text3: new 29.238 / Text5: Bruno.Landais@alcatel-lucent.fr
- 275: CP#46 completed / Text3: 29.162, 29.235 / Text5: Bruno.Landais@alcatel-lucent.fr
- 276: CP#46 completed / Text3: new (23.334, 29.334) / Text5: bruno.landais@alcatel-lucent.fr
- 277: CP#46 completion 12/09=>03/10. CP#42 umbrella Feature created to host CT1 CAT WI (Stage 1 in 22.182) / Text5: Jiang Yi
- 278: CP#46 exception to 03/10 in CP-090870 / Text3: 24.182 / Text5: Jiang Yi

| ID | WBS | Task | Duration | Start | Finish | Complete | Remaining | Baseline start | Baseline finish | Baseline duration | Total slack | Constraint | Resources | Work | Actual work | Text1 | Text2 | Text4 | Text5 | Text6 | Text7 | Text8 | Text11 |
| --- | --- | --- | --- | --- | --- | --- | --- | --- | --- | --- | --- | --- | --- | --- | --- | --- | --- | --- | --- | --- | --- | --- | --- |
| 279 | 114 | **Completion of IMS Restoration Procedures** | 212d? | 2009-05-29 A | 2010-03-19 | 33% | 141.33d? | 2009-05-29 | 2010-03-19 | 212d? | 651d |  | C3, C4,C1 | 6784h | 1696h | eIMS_RP | PCG-23 | Ericsson | Emiliano Merino (emiliano.merino@ericsson.com) | Rel-9 | CP-44 | Kimmo |  |
| 280 | 114.1 | CT4 aspects of eIMS_RP | 212d? | 2009-05-29 A | 2010-03-19 | 60% | 84.8d? | 2009-05-29 | 2010-03-19 | 212d? | 651d | finish no earlier than 2010-03-19 | C4 | 1696h | 1017.6h | eIMS_RP | PCG-23 | Ericsson | Emiliano Merino (emiliano.merino@ericsson.com) | Rel-9 | CP-44 | Kimmo | CP-090806 |
| 281 | 114.2 | CT1 aspects of eIMS_RP | 212d? | 2009-05-29 | 2010-03-19 |  |  | 2009-05-29 | 2010-03-19 | 212d? | 651d | finish no earlier than 2010-03-19 | C1 | 1696h |  | eIMS_RP | PCG-23 | Ericsson | Emiliano Merino (emiliano.merino@ericsson.com) | Rel-9 | CP-44 | Kimmo | CP-090871 |
| 282 | 114.3 | CT3 aspects of eIMS_RP | 212d? | 2009-05-29 A | 2010-03-19 | 40% | 127.2d? | 2009-05-29 | 2010-03-19 | 212d? | 651d | finish no earlier than 2010-03-19 | C3 | 1696h | 678.4h | eIMS_RP | PCG-24 | Ericsson | Emiliano Merino (emiliano.merino@ericsson.com) | Rel-9 | CP-46 | Kimmo | CP-090863 |
| 283 | 115 | IMS Stage 3 - IETF Protocol Alignment | 212d? | 2009-05-29 A | 2010-03-19 | 95% | 10.6d? | 2009-05-29 | 2010-03-19 | 212d? | 651d | finish no earlier than 2010-03-19 | C1 | 1696h | 1611.2h | IMSProtoc3 | PCG-23 | Alcatel-Lucent | Keith Drage (drage@alcatel-lucent.com) | Rel-9 | CP-44 | Frederic |  |
| 284 | 116 | Operational description of the Inter-IMS Network to Network Interface (II-NNI) | 212d? | 2009-05-29 A | 2010-03-19 | 80% | 42.4d? | 2009-05-29 | 2010-03-19 | 212d? | 651d | finish no earlier than 2010-03-19 | C3 | 1696h | 1356.8h | II-NNI | PCG-23 | Orange | sebastien.daudet@orange-ftgroup.com | Rel-9 | CP-44 | Gwiho | CP-090862 |
| 285 | 117 | Definition of Ml interface for Control Plane LCS (Stage 3) | 131d? | 2009-09-18 A | 2010-03-19 | 75% | 32.75d? | 2009-09-18 | 2010-03-19 | 131d? | 651d | finish no earlier than 2010-03-19 | C1 | 1048h | 786h | EMC2 | PCG-23 | Alcatel-Lucent | Keith Drage (drage@alcatel-lucent.com) | Rel-9 | CP-45 | Frederic | CP-090872 |
| 286 | 118 | PCC enhancements | 56d? | 2009-09-18 A | 2009-12-04 A | 100% |  | 2009-09-18 | 2009-12-04 | 56d? |  | finish no earlier than 2009-12-04 | C3 | 448h | 448h | PCC-Enh | PCG-23 | Huawei | Wei Weihua (weiwh@huawei.com) | Rel-9 | CP-45 | Gwiho |  |
| 287 | 119 | 3GPP IMS Conferencing Management Object (MO) | 2d? | 2009-12-03 A | 2009-12-04 A | 100% |  | 2009-12-03 | 2009-12-04 | 2d? |  | start no earlier than 2009-12-03 | C1 | 16h | 16h | IMS_ConfMO | PCG-24 |  |  | Rel-9 | CP-46 |  |  |
| 288 | 120 | **Rel-9 Improvements of the Radio Interface** | 657d? | 2007-11-30 A | 2010-06-04 | 81% | 122.47d? | 2007-11-30 | 2010-06-04 | 657d? | 596d |  | RP,GP | 23059.6h | 19218.5h | RInImp9 | PCG-21 |  |  | Rel-9 | RP-41 | Issam |  |
| 289 | 120.1 | UMTS/LTE 3500 MHz | 645d? | 2007-11-30 A | 2010-06-04 | 55% | 290.25d? | 2007-11-30 | 2010-06-04 | 645d? | 596d | finish no earlier than 2010-06-04 | R4,R2,R3 | 5160h | 2838h | RInImp8-UMTSLTE3500 | PCG-21 | Ericsson | Jjohan.skold@ericsson.com | Rel-10 | RP-38 | Issam | RP-091032 |
| 290 | 120.2 | LCR TDD UE OTA Performance Requirements | 186d? | 2008-09-12 A | 2009-05-29 A | 100% |  | 2008-09-12 | 2009-05-29 | 186d? |  | finish no earlier than 2009-05-29 | R4 | 1488h | 1488h | RInImp9-RFLCROTA | PCG-21 | RITT | Wu Xiang (wuxiang@chinattl.com) | Rel-9 | RP-41 | Issam | RP-090389 |
| 291 | 120.3 | **RF requirements for Multicarrier and Multi-RAT BS** | 347d? | 2008-11-21 A | 2010-03-19 | 99% | 3.91d? | 2008-11-21 | 2010-03-19 | 347d? | 651d |  | R4,G1 | 7403.6h | 7320.15h | RInImp9-RFmulti | PCG-21 | Ericsson | Johan.skold@ericsson.com | Rel-9 | RP-41 | Issam |  |
| 292 | 120.3.1 | RAN4 part of RF requirements for Multicarrier and Multi RAT BS | 337d? | 2008-12-05 A | 2010-03-19 | 98% | 6.74d? | 2008-12-05 | 2010-03-19 | 337d? | 651d | finish no earlier than 2010-03-19 | R4 | 2696h | 2642.08h | RInImp9-RFmulti | PCG-22 | Ericsson | Johan.skold@ericsson.com | Rel-9 | RP-42 | Issam | RP-091033 |
| 293 | 120.3.2 | GERAN part of RF requirements for Multicarrier and Multi RAT BS | 261d? | 2008-11-21 A | 2009-11-20 A | 100% |  | 2008-11-21 | 2009-11-20 | 261d? |  | finish no earlier than 2009-11-20 | G1 | 2088h | 2088h | RInImp9-RFmulti-GERAN | PCG-22 | Ericsson | mats.y.samuelsson@ericsson.com | Rel-9 | GP-40 | Paolo |  |
| 294 | 120.4 | Extended UMTS/LTE 800 MHz | 207d? | 2008-12-05 A | 2009-09-18 A | 100% |  | 2008-12-05 | 2009-09-18 | 207d? |  |  | R4,R2,R3 | 1648h | 1648h | RInImp9-UMTSLTE800 | PCG-22 | NTT DoCoMo | Shingo Suwa (suwas@nttdocomo.co.jp) | Rel-9 | RP-42 | Issam | RP-090687 |
| 295 | 120.5 | UMTS/LTE 800 MHz for Europe | 272d? | 2009-03-06 A | 2010-03-19 | 65% | 95.2d? | 2009-03-06 | 2010-03-19 | 272d? | 651d | finish no earlier than 2010-03-19 | R4,R2,R3 | 2176h | 1414.4h | RInImp9-UMTSLTE800EU | PCG-22 | Ericsson | olav.queseth@ericsson.com | Rel-9 | RP-43 | Issam | RP-091034 |
| 296 | 120.6 | Performance requirement for LCR TDD with UE speeds up to 350 kph | 196d? | 2009-03-06 A | 2009-12-04 A | 100% |  | 2009-03-06 | 2009-12-04 | 196d? |  | finish no earlier than 2009-12-04 | R4 | 1568h | 1568h | RInImp9-LCRTDD350 | PCG-22 | CATT | Yuexia Song (songyuexia@datangmobile.cn) | Rel-9 | RP-43 | Issam | RP-091035 |
| 297 | 121 | Extended UMTS/LTE 1500 MHz | 211d? | 2009-05-30 A | 2010-03-19 | 95% | 10.55d? | 2009-05-30 | 2010-03-19 | 211d? | 651d | finish no earlier than 2010-03-19 | R4,R2,R3 | 1688h | 1603.6h | UMTSLTE1500 | PCG-23 | NTT DoCoMo | Shingo Suwa (suwas@nttdocomo.co.jp) | Rel-9 | RP-44 | Issam | RP-091365 |
| 298 | 122 | **Rel-9 Improvements of the Radio Interface - UE Conformance Testing** | 392d? | 2008-12-05 A | 2010-06-04 | 9% | 357.21d? | 2008-12-05 | 2010-06-04 | 392d? | 596d |  | R5 | 12824h | 1138.17h | RInImp-UEConTest | PCG-23 |  |  | Rel-9 | RP-44 | Ingbert |  |
| 299 | 122.1 | Conformance Test Aspects – LTE 3500 | 392d? | 2008-12-05 A | 2010-06-04 | 2% | 383.96d? | 2008-12-05 | 2010-06-04 | 392d? | 596d | finish no earlier than 2010-06-04 | R5 | 3136h | 64.32h | LTE-UEConTest_LTE3500 | PCG-22 | Ericsson | fredrik.sundstrom@ericsson.com | Rel-10 | RP-42 | Ingbert | RP-091063 |
| 300 | 122.2 | Conformance Test Aspects – UMTS 3500 | 392d? | 2008-12-05 A | 2010-06-04 | 2% | 384.16d? | 2008-12-05 | 2010-06-04 | 392d? | 596d | finish no earlier than 2010-06-04 | R5 | 3136h | 62.72h | RInImp-UEConTest_UMTS3500 | PCG-22 | Nokia | jukka.vikstedt@nokia.com | Rel-10 | RP-42 | Ingbert | RP-091064 |
| 301 | 122.3 | Conformance Test Aspects – UMTS/LTE in 800 MHz for Europe | 220d? | 2009-05-19 A | 2010-03-19 | 2% | 215.7d? | 2009-05-19 | 2010-03-19 | 220d? | 651d | finish no earlier than 2010-03-19 | R5 | 1760h | 34.4h | RInImp-UEConTest-UMTSLTE800EU | PCG-23 | Ericsson | fredrik.sundstrom@ericsson.com | Rel-9 | RP-44 | Ingbert | RP-091069 |
| 302 | 122.4 | Conformance Test Aspects – Extended UMTS/LTE 1500 MHz | 126d? | 2009-09-18 A | 2010-03-12 | 5% | 119.7d? | 2009-09-18 | 2010-03-12 | 126d? | 656d | finish no earlier than 2010-03-12 | R5 | 1008h | 50.4h | UMTSLTE1500_UEConTest | PCG-23 | NTT DoCoMo | Nguyen Dung Dao (dao@nttdocomo.co.jp) | Rel-9 | RP-45 | Ingbert | RP-091073 |
| 303 | 122.5 | TDD UE Over The Air (Antenna) conformance testing methodology | 81d? | 2009-05-30 A | 2009-09-18 A | 100% |  | 2009-05-30 | 2009-09-18 | 81d? |  | finish no earlier than 2009-09-18 | R5 | 648h | 648h | UEAnt_TDDTest | PCG-23 | CATR | Qu Yan (quyan@emcite.com) | Rel-9 | RP-44 | Ingbert | RP-090727 |
| 304 | 123 | Conformance Test Aspects – SMS over IMS in E-UTRAN | 196d? | 2009-09-18 A | 2010-06-18 | 5% | 186.2d? | 2009-09-18 | 2010-06-18 | 196d? | 586d | finish no earlier than 2010-06-18 | R5 | 1568h | 78.4h | SMSoverIMS_UEConTest | PCG-23 | Alcatel-Lucent | Nidal Khrais (khrais@alcatel-lucent.com) | Rel-9 | RP-45 | Ingbert | RP-091074 |

Notes:
- 279: CP#46 exception to 03/10. WID updated CP-090316=>CP-091050 (added CT3 part). Continuation of Rel-8 Feature UID_400012 IMS Restoration Procedures
- 280: CP#46 exception to 03/10 in CP-090806 / Text3: 23.380, 23.820
- 281: CP#46 exception to 03/10 in CP-090871 / Text3: 24.229
- 282: CP#46 exception to 03/10 in CP-090863 / Text3: 29.061, 29.212, 29.213, 29.214, 29.215
- 283: CP#46 completion 12/09=>03/10 / Text3: 23.218, 24.229, 24.940
- 284: CP#46 exception to 03/10 in CP-090862 / Text3: 29.165
- 285: CP#46 exception to 03/10 in CP-090872. Stage 3 for Rel-7 Emergency Calls (EMC1). Related to Rel-9 UID_400038 LCS Control Plane Solution for EPS. Stage 2 in Rel-9 UID_400038 (23.271), UID_410037 (23.167) / Text3: 24.229
- 286: CP#46 completed / Text3: 29.212, 29.213, 29.215
- 287: CP#46 TS 24.166 v10x approved in CP-091044. Linked to Rel-6 UID_11051 (IMS Management objects) under the Feature UID_32021 (IMS Phase 2). MO compatible with OMA DM v1.2 & upwards and defined using OMA DM Device Description Framework (OMA-ERELD _DM-V1_2) / Text3: new 24.166
- 288: RP#41 umbrella Feature created to host Rel-9 WIs
- 289: RP#46 completion 12/09(was 05/09)=>06/10. Moved to Rel-10. Testing in UID_420013 & UID_420014 / Text3: 25.101, 25.104, 25.113, 25.133, 25.141, 34.124, 36.101, 36.104, 36.141, 25.307, 25.331, 25.307, 36.331, 25.461, 25.463
- 290: RP#44 completed (Technical work completed, RAN4 internal TR abandoned. / Text3: Produced no TR 25.8xy (LCR TDD UE OTA performance requirements)
- 291: RF requirements specification applicable to Multi-Standard Radio (MSR) Base Station with multiple carriers and/or multiple 3GPP Radio Access Technologies (RAT)
- 292: RP#46 exception to 03/10 in RP-091382. WID updated RP-081098=>RP-091106 / Text3: 25.104, 25.105, 36.104, new 37.104, 37.113, 37.141, 37.900
- 293: GP#44 Core spec completed (ongoing BS conformance spec). GP#40 WID approved / Text3: 45.005, 51.021
- 294: RP#45 completed. TR 36.800-200 for Approval / Text3: 36.800 (Extended UMTS/LTE 800 Work Item Technical Report), 25.101, 25.104, 25.113, 25.133, 34.124, 36.101, 36.104, 36.113, 36.124, 36.133, 36.141, 25.306, 25.307, 25.331, 36.331, 25.461, 25.466
- 295: RP#46 exception to 03/10 in RP-091383. TR 36.810 v100 for Information / Text3: 25.101, 25.104, 25.113, 25.133, 25.141, 34.124, 36.101, 36.104, 36.113, 36.124, 36.133, 36.141, new 36.810, 25.306, 25.307, 25.331, 36.331, 25.461, 25.466
- 296: RP#46 completed / Text3: 25.102, 25.105, 25.142
- 297: RP#46 exception to 03/10 in RP-091367. For potential deployment in Japan / Text3: 25.101, 25.104, 25.113, 25.133, 25.141, 34.124, 36.101, 36.104, 36.113, 36.124, 36.133, 36.141, new 36.821, 25.306, 25.307, 25.331, 36.331, 25.461, 25.466
- 298: -
- 299: RP#45 completion 12/09=>06/10 (RAN5 waiting for RAN4 to complete LTE3500 work item before RAN5 can get any progress). Testing for UID_380073 / Text3: 36.508, 36.521-1, 36.521-2, 36.521-3
- 300: RP#45 completion 12/09=>06/10. Testing for UID_380073 / Text3: 34.108, 34.121-1, 34.121-2
- 301: Testing for UID_430009 UMTS/LTE 800 MHz for Europe / Text3: 34.108, 34.121-1, 34.121-2, 36.508, 36.521-1, 36.521-2, 36.521-3
- 302: - / Text3: 34.108, 34.121-1, 34.121-2, 34.123-1, 34.123-2, 34.123-3, 36.508, 36.521-1, 36.521-2, 36.521-3, 36.523-1, 36.523-2, 36.523-3
- 303: RP#45 completed. Finalize TDD UE test methodology based on R4 TR 25.914 (UE and MS antenna performance evaluation method) and TS 25.144 Over the Air (Antenna) minimum performance requirements for the speech mode (terminal close to head) / Text3: 34.114
- 304: - / Text3: 34.229-1, 34.229-2, 34.229-3

| ID | WBS | Task | Duration | Start | Finish | Complete | Remaining | Baseline start | Baseline finish | Baseline duration | Total slack | Constraint | Resources | Work | Actual work | Text1 | Text2 | Text6 | Text7 | Text8 | Text4 | Text5 | Text11 |
| --- | --- | --- | --- | --- | --- | --- | --- | --- | --- | --- | --- | --- | --- | --- | --- | --- | --- | --- | --- | --- | --- | --- | --- |
| 305 | 124 | **Rel-9 RAN improvements** | 272d? | 2009-03-06 A | 2010-03-19 | 99% | 3.7d? | 2009-03-06 | 2010-03-19 | 272d? | 651d |  | RP | 9536h | 9397.58h | RANimp | PCG-22 | Rel-9 | RP-43 | Issam |  |  |  |
| 306 | 124.1 | Dual-Cell HSUPA | 272d? | 2009-03-06 A | 2010-03-19 | 95% | 13.6d? | 2009-03-06 | 2010-03-19 | 272d? | 651d | finish no earlier than 2010-03-19 | R1,R2,R3,R4 | 1568h | 1459.2h | RANimp-DC_HSUPA | PCG-22 | Rel-9 | RP-43 | Patrick | Nokia Siemens Networks | Karri Ranta-aho (karri.ranta-aho@nsn.com) | RP-091037 |
| 307 | 124.2 | Support for different bands for Dual-Cell HSDPA | 197d? | 2009-03-06 A | 2009-12-04 A | 100% |  | 2009-03-06 | 2009-12-04 | 197d? |  |  | R4,R2,R3 | 1568h | 1568h | RANimp-MultiBand_DC_HSDPA | PCG-22 | Rel-9 | RP-43 | Issam | Nokia Siemens Networks | Tuomo Säynäjäkangas (tuomo.saynajakangas@nsn.com) | RP-091038 |
| 308 | 124.3 | Combination of DC-HSDPA with MIMO | 197d? | 2009-03-06 A | 2009-12-04 A | 100% |  | 2009-03-06 | 2009-12-04 | 197d? |  |  | R1,R2,R3,R4 | 1568h | 1568h | RANimp-DC_MIMO | PCG-22 | Rel-9 | RP-43 | Patrick | Ericsson | johan.bergman@ericsson.com | RP-091039 |
| 309 | 124.4 | Transmit Antenna Array (TxAA) extension for non-MIMO UEs | 197d? | 2009-03-06 A | 2009-12-04 A | 100% |  | 2009-03-06 | 2009-12-04 | 197d? |  |  | R1,R2,R3,R4 | 1568h | 1568h | RANimp-TxAA_nonMIMO | PCG-22 | Rel-9 | RP-43 | Patrick | Nokia | Arto Lehti (arto.lehti@nokia.com) | RP-091040 |
| 310 | 124.5 | Cell Portion for 1.28 Mcps TDD | 136d? | 2009-05-30 A | 2009-12-04 A | 100% |  | 2009-05-30 | 2009-12-04 | 136d? |  |  | R3,R1,R4 | 1088h | 1088h | CP_LCRTDD | PCG-23 | Rel-9 | RP-44 | Juha | CATT | Ying Zhang (zhangying2@datangmobile.cn) | RP-091041 |
| 311 | 125 | **LTE improvements** | 272d? | 2009-03-06 A | 2010-03-19 | 88% | 31.62d? | 2009-03-06 | 2010-03-19 | 272d? | 651d |  | RP | 5920h | 5231.86h | LTEimp | PCG-22 | Rel-9 | RP-42 | Issam |  |  |  |
| 312 | 125.1 | LTE Pico NodeB RF Requirements | 196d? | 2009-03-06 A | 2009-12-04 A | 100% |  | 2009-03-06 | 2009-12-04 | 196d? |  | finish no earlier than 2010-03-05 | R4 | 1568h | 1568h | LTEimp-Pico_eNB-RF | PCG-22 | Rel-9 | RP-43 | Issam | Huawei | Liyan Yin (yinliyan@huawei.com) | RP-091045 |
| 313 | 125.2 | Enhanced Dual-Layer transmission for LTE | 272d? | 2009-03-06 A | 2010-03-19 | 80% | 54.4d? | 2009-03-06 | 2010-03-19 | 272d? | 651d | finish no earlier than 2010-03-19 | R1,R2,R4 | 2176h | 1740.8h | LTEimp-eDL | PCG-22 | Rel-9 | RP-43 | Patrick | China Mobile | Xu Xiaodong (xuxiaodong@chinamobile.com) | RP-091046 |
| 314 | 126 | **System aspects of vocoder rate adaptation for LTE** | 140d? | 2009-05-30 A | 2009-12-10 A | 100% |  | 2009-05-30 | 2009-12-10 | 140d? |  |  | S2,S4,R2 | 3504h | 3504h | LTEimp-Vocoder | PCG-23 | Rel-9 | SP-45 | Maurice | Qualcomm Europe | AC Mahendran (ac@qualcomm.com) |  |
| 315 | 126.1 | SA2 system aspects of vocoder rate adaptation for LTE | 81d? | 2009-06-04 A | 2009-09-24 A | 100% |  | 2009-06-04 | 2009-09-24 | 81d? |  | start no earlier than 2009-06-04 | S2 | 648h | 648h | LTEimp-Vocoder | PCG-23 | Rel-9 | SP-45 | Maurice | Qualcomm Europe | AC Mahendran (ac@qualcomm.com) |  |
| 316 | 126.2 | SA4 system aspects of vocoder rate adaptation for LTE | 136d? | 2009-06-04 A | 2009-12-10 A | 100% |  | 2009-06-04 | 2009-12-10 | 136d? |  | finish no earlier than 2009-12-07 | S4 | 1088h | 1088h | LTEimp-Vocoder | PCG-23 | Rel-9 | SP-45 | Paolo | Qualcomm Europe | Nikolai Leung |  |
| 317 | 126.3 | Vocoder rate adaptation for LTE | 81d? | 2009-05-30 A | 2009-09-18 A | 100% |  | 2009-05-30 | 2009-09-18 | 81d? |  | finish no earlier than 2009-09-18 | R2 | 648h | 648h | LTEimp-Vocoder | PCG-23 | Rel-9 | RP-44 | Joern | Alcatel-Lucent | Sudeep Palat (spalat@alcatel-lucent.com) | RP-090704 |
| 318 | 127 | Self-Organizing Networks (SON) | 272d? | 2009-03-06 A | 2010-03-19 | 91% | 24.48d? | 2009-03-06 | 2010-03-19 | 272d? | 651d | finish no earlier than 2010-03-19 | R3,R2 | 2176h | 1980.16h | SON | PCG-22 | Rel-9 | SP-42 | Juha | Nokia Siemens Networks | Krzysztof Kordybach | RP-091051 |
| 319 | 128 | **A-GNSS Performances and Testing Procedures** | 527d? | 2008-05-16 A | 2010-05-21 | 50% | 261.21d? | 2008-05-16 | 2010-05-21 | 527d? | 606d |  | GP | 12208h | 4348.4h | AGNSSPTP |  | Rel-9 |  | Paolo | Thales | Michel.monnerat@thalesaleniaspace.com | GP-092344 |
| 320 | 128.1 | A-GNSS Minimum Performances | 472d? | 2008-05-16 A | 2010-03-05 | 90% | 47.2d? | 2008-05-16 | 2010-03-05 | 472d? | 661d | finish no earlier than 2010-03-05 | G1 | 3776h | 3398.4h | AGNSSPTP- Perfreq |  | Rel-9 |  | Paolo | Thales | Michel.monnerat@thalesaleniaspace.com | GP-092344 |
| 321 | 128.2 | A-GNSS Testing Procedures | 527d? | 2008-05-16 A | 2010-05-21 | 15% | 447.95d? | 2008-05-16 | 2010-05-21 | 527d? | 606d | finish no earlier than 2010-05-21 | G3new | 4216h | 632.4h | AGNSSPTP-MStest |  | Rel-9 |  | Ingbert | Thales | Michel.monnerat@thalesaleniaspace.com | GP-092344 |
| 322 | 129 | **Voice services over Adaptive Multi-user channels on One Slot** | 392d? | 2008-11-21 A | 2010-05-21 | 63% | 143.64d? | 2008-11-21 | 2010-05-21 | 392d? | 606d |  | GP | 12520.7h | 7929.92h | VAMOS | PCG-22 | Rel-9 | SP-42 | Paolo | Nokia Siemens Networks, China Mobile | juergen.hofmann@nsn.com, liuxiaoyu@chinamobile.com | GP-092470 |
| 323 | 129.1 | VAMOS Stage 2 | 392d? | 2008-11-21 A | 2010-05-21 | 90% | 39.2d? | 2008-11-21 | 2010-05-21 | 392d? | 606d | finish no earlier than 2010-05-21 | GP | 3128.68h | 2815.08h | VAMOS | PCG-22 | Rel-9 | GP-40 | Paolo | Nokia Siemens Networks, China Mobile | juergen.hofmann@nsn.com, liuxiaoyu@chinamobile.com | GP-092470 |
| 324 | 129.2 | VAMOS Stage 3 | 391d? | 2008-11-21 A | 2010-05-21 | 60% | 156.4d? | 2008-11-21 | 2010-05-21 | 391d? | 606d | finish no earlier than 2010-05-21 | GP | 3128h | 1876.8h | VAMOS | PCG-22 | Rel-9 | GP-40 | Paolo | Nokia Siemens Networks, China Mobile | juergen.hofmann@nsn.com, liuxiaoyu@chinamobile.com | GP-092470 |
| 325 | 129.3 | VAMOS Radio Performance Requirements | 391d? | 2008-11-24 A | 2010-05-21 | 40% | 234.6d? | 2008-11-24 | 2010-05-21 | 391d? | 606d | finish no earlier than 2010-05-21 | GP | 3128h | 1251.2h | VAMOS | PCG-22 | Rel-9 | GP-40 | Paolo | Nokia Siemens Networks, China Mobile | juergen.hofmann@nsn.com, liuxiaoyu@chinamobile.com | GP-092470 |
| 326 | 130 | **Local Call Local Switch** | 327d? | 2009-02-20 A | 2010-05-21 | 34% | 217.27d? | 2009-02-20 | 2010-05-21 | 327d? | 606d |  | GP,C4,C3,C1 | 12008h | 3460.2h | LCLS | PCG-22 | Rel-9 | GP-41 | Paolo | Huawei | Xing Zhu |  |
| 327 | 130.1 | Local Call Local Switch | 326d? | 2009-02-20 A | 2010-05-21 | 60% | 130.4d? | 2009-02-20 | 2010-05-21 | 326d? | 606d | finish no earlier than 2010-05-21 | GP | 2608h | 1564.8h | LCLS | PCG-22 | Rel-9 | GP-41 | Paolo | Huawei | Xing Zhu | GP-092473 |
| 328 | 130.2 | **CN aspects of Local Call Local Switch** | 212d? | 2009-05-29 A | 2010-03-19 | 20% | 169.6d? | 2009-05-29 | 2010-03-19 | 212d? | 651d |  | C4 | 6784h | 1017.6h | LCLS-CN | PCG-23 | Rel-9 | CP-44 | Kimmo | Vodafone | David Hutton |  |
| 329 | 130.2.1 | CT4 aspects of LCLS | 212d? | 2009-05-29 A | 2010-03-19 | 60% | 84.8d? | 2009-05-29 | 2010-03-19 | 212d? | 651d | finish no earlier than 2010-03-19 | C4 | 1696h | 1017.6h | LCLS-CN | PCG-23 | Rel-9 | CP-44 | Kimmo | Vodafone | David Hutton | CP-090807 |
| 330 | 130.2.2 | CT3 aspects of LCLS | 212d? | 2009-05-29 | 2010-03-19 |  |  | 2009-05-29 | 2010-03-19 | 212d? | 651d | finish no earlier than 2010-03-19 | C3 | 1696h |  | LCLS-CN | PCG-23 | Rel-9 | CP-44 | Gwiho | Vodafone | David Hutton |  |
| 331 | 130.2.3 | CT1 aspects of LCLS | 212d? | 2009-05-29 | 2010-03-19 |  |  | 2009-05-29 | 2010-03-19 | 212d? | 651d | finish no earlier than 2010-03-19 | C1 | 1696h |  | LCLS-CN | PCG-23 | Rel-9 | CP-44 | Frederic | Vodafone | David Hutton |  |

Notes:
- 305: -
- 306: RP#46 exception to 03/10 in RP-091388 / Text3: 25.101, 25.104, 25.133, 25.211, 25.212, 25.213, 25.214, 25.215, 25.319, 25.306, 25.321, 25.331, 25.423, 25.433
- 307: RP#46 completed / Text3: 25.101, 25.104, 25.133, 25.306, 25.308, 25.331, new 25.317 (Requirements on Ues supporting a release-independent frequency band combination), 25.423, 25.433
- 308: RP#46 completed (R1,R2,R3) / Text3: 25.101, 25.104, 25.133, 25.211, 25.212, 25.213, 25.214, 25.215, 25.308, 25.321, 25.331, 26.306, 25.423, 25.433
- 309: RP#46 completed / Text3: 25.101, 25.104, 25.211, 25.212, 25.213, 25.214, 25.215, 25.308, 25.306, 25.321, 25.331, 25.423, 25.433
- 310: RP#46 completed / Text3: 25.102, 25.105, 25.123, 25.225, 25.423, 25.433
- 311: -
- 312: RP#46 completed core RF requirements (Conformance testing target 03/10). WID updated RP-090096=>RP-091155 / Text3: 36.104, 36.141, new 36.931
- 313: RP#46 exception to 03/10 in RP-091147 / Text3: 36.101, 36.104, 36.106, 36.133, 36.211, 36.212, 36.213, 36.321, 36.331
- 314: SP#46 completed. Triggered by RAN2 UID_440013 Vocoder rate adaptation for LTE
- 315: SP#45 completed (CR adding support for Explicit Congestion Notification) / Text3: 23.401 CR#1103r3
- 316: SP#46 completed / Text3: 26.114
- 317: RP#45 completed (Stage 2 CR RP-090929). WID updated RP-090660=>RP-090978 / Text3: 36.300 CR#0114
- 318: RP#46 extension to 03/10 in RP-091395 / Text3: 25.413, 36.300, 36.413, 36.423, 36.902, 48.018
- 319: GP#44 moved to Rel-9. Rel-9 exception to 03/10 in GP-092344. Linked to Rel-10 RAN4 UID_450027 (A-GNSS Minimum Performance for UTRAN)
- 320: GP#44 moved to Rel-9. Rel-9 exception to 03/10 in GP-092344 / Text3: 45.005
- 321: GP#44 moved to Rel-9. Rel-9 exception to 03/10 in GP-092344 / Text3: 51.010-1
- 322: GP#44 exception to 05/10 in GP-092470. GP#40 WID approved. Triggered by UID_50590 (MUROS) Study on Multi-User Reusing-One-Slot
- 323: GP#44 exception to 05/10 in GP-092470 / Text3: 45.001 (Overview of VAMOS solution)
- 324: GP#44 exception to 05/10 in GP-092470 / Text3: 24.008, 44.018, 45.002, 45.003, 45.004, 45.008, 48.008, 48.058
- 325: GP#44 exception to 05/10 in GP-092470 / Text3: 45.005 (Test Scenarios for VAMOS Performance requirements)
- 326: GP#44 extension to 05/10 in GP-092473. GP#41 WID approved. CP#46 WID (CP-090519) revised to Study item (CP-090812).
- 327: GP#44 exception to 05/10 in GP-092473. GP#41 WID approved / Text3: 48.008 (MSC-BSS interface; Layer 3 specification)
- 328: CP#46 WID (CP-090519) revised to Study item (CP-090812). Normative work can be done in Rel-9 but then a complete set of CRs and WID must be provided for approval at CP#47 03/10.
- 329: CP#46 exception to 03/10 in CP-090807 to finish TR 23.889. Normative work target: 23.205, 23.153, 23.231, 29.232 / Text3: new 23.889
- 330: - / Text3: 29.007
- 331: - / Text3: 23.009

| ID | WBS | Task | Type | Duration | Start | Finish | Complete | Remaining | Baseline start | Baseline finish | Baseline duration | Total slack | Constraint | Resources | Work | Actual work | Text1 | Text2 | Text4 | Text5 | Text6 | Text7 | Text8 | Text11 | Text9 | Text12 |
| --- | --- | --- | --- | --- | --- | --- | --- | --- | --- | --- | --- | --- | --- | --- | --- | --- | --- | --- | --- | --- | --- | --- | --- | --- | --- | --- |
| 332 | 131 | **Cell Broadcast protocol Base Station Controller – Cell Broadcast Centre (BSC-CBC)** |  | 222d? | 2009-05-15 A | 2010-03-19 | 39% | 135.25d? | 2009-05-15 | 2010-03-19 | 222d? | 651d |  | GP,C1 | 5248h | 2050.83h | CEBRO | PCG-23 | Ericsson | Claes-Göran Persson | Rel-9 | GP-42 | Paolo |  |  |  |
| 333 | 131.1 | Cell Broadcast protocol Base Station Controller – Cell Broadcast Centre (BSC-CBC) |  | 212d? | 2009-05-15 A | 2010-03-05 | 80% | 42.4d? | 2009-05-15 | 2010-03-05 | 212d? | 661d | finish no earlier than 2010-03-05 | GP | 1696h | 1356.8h | CEBRO | PCG-23 | Ericsson | Claes-Göran Persson | Rel-9 | GP-42 | Paolo | GP-092475 |  |  |
| 334 | 131.2 | Cell Broadcast protocol Base Station Controller – Cell Broadcast Centre (BSC-CBC) |  | 222d? | 2009-05-15 | 2010-03-19 |  |  | 2009-05-15 | 2010-03-19 | 222d? | 651d | finish no earlier than 2010-03-19 | C1 | 1776h |  | CEBRO | PCG-23 | Ericsson | Claes-Göran Persson | Rel-9 | GP-42 | Frederic | CP-090867 |  |  |
| 335 | 132 | Hybrid Location |  | 136d? | 2009-05-18 A | 2009-11-20 A | 100% |  | 2009-05-18 | 2009-11-20 | 136d? |  | finish no earlier than 2009-11-20 | GP | 1088h | 1088h | HILT | PCG-23 | TruePosition | Matt Ward (mward@trueposition.com) | Rel-9 | GP-42 | Paolo |  |  |  |
| 336 | 133 | (Small) Technical Enhancements and Improvements for Rel-9 |  | 325d? | 2008-09-15 A | 2009-12-10 A | 100% |  | 2008-09-15 | 2009-12-10 | 325d? |  | finish no earlier than 2009-12-10 | All | 2600h | 2600h | TEI9 | PCG-22 |  |  | Rel-9 | SP-42 |  |  |  |  |
| 337 | 134 | Test - (Small) Technical Enhancements and Improvements for Rel-8 |  | 286d? | 2009-11-20 | 2010-12-24 |  |  | 2009-11-20 | 2010-12-24 | 286d? | 451d | finish no earlier than 2010-12-24 | R5,G3new | 2288h |  | TEI9_Test | PCG-24 |  |  | Rel-9 | GP-44 |  |  |  |  |
| 338 | 135 | **Deleted - SAES Enhancements (non RAN aspects)** |  | 381d? | 2007-06-25 A | 2008-12-08 A | 100% |  | 2007-06-25 | 2008-12-08 | 381d? |  |  | S2 | 11664h | 11664h | SAES_Ph2 | PCG-21 | Nokia Siemens Networks |  | Rel-9 | SP-39 | Maurice |  | PCG-21 | SP-39 |
| 339 | 135.1 | Deleted - Functions and procedures for SAE to support LTE MBMS |  | 381d? | 2007-06-25 A | 2008-12-08 A | 100% |  | 2007-06-25 | 2008-12-08 | 381d? |  | finish no earlier than 2008-12-08 | S2 | 3048h | 3048h | SAES_Ph2 |  |  |  | Rel-9 | SP-35 | Maurice |  | PCG-21 | SP-39 |
| 340 | 135.2 | Deleted - CS over EPS |  | 194d? | 2008-03-12 A | 2008-12-08 A | 100% |  | 2008-03-12 | 2008-12-08 | 194d? |  | finish no earlier than 2008-12-08 | S2 | 1552h | 1552h | SAES_Ph2 | PCG-21 |  |  | Rel-9 | SP-39 | Maurice |  | PCG-21 | SP-39 |
| 341 | 135.3 | **Deleted - SAE for generic support for non-3GPP accesses** |  | 251d? | 2007-06-25 A | 2008-06-09 A | 100% |  | 2007-06-25 | 2008-06-09 | 251d? |  |  | S2 | 4016h | 4016h | SAES_Ph2 | PCG-21 |  |  | Rel-9 | SP-39 | Maurice |  | PCG-21 | SP-39 |
| 342 | 135.3.1 | Deleted - Single Radio Aspects of SAE for Optimized Handover with WiMAX |  | 251d? | 2007-06-25 A | 2008-06-09 A | 100% |  | 2007-06-25 | 2008-06-09 | 251d? |  | finish no earlier than 2008-06-09 | S2 | 2008h | 2008h | SAES_Ph2 | PCG-21 |  |  | Rel-9 | SP-39 | Maurice |  | PCG-21 | SP-39 |
| 343 | 136 | Deleted - Harmonization of Gq'/Rx for Common IMS |  | 304d? | 2008-01-14 A | 2009-03-12 A | 100% |  | 2008-01-14 | 2009-03-12 | 304d? |  | finish no earlier than 2009-03-12 | S2 | 2432h | 2432h | IMS_Comm_GqRx_Harm | PCG-21 | Alcatel-Lucent | geoffrey.cristallo@alcatel-lucent.be | Rel-9 | SP-38 | Maurice |  | PCG-22 | SP-43 |
| 344 | 137 | Deleted - Support of WiMAX - LTE Mobility |  | 407d? | 2008-06-06 A | 2009-12-25 A | 100% |  | 2008-06-06 | 2009-12-25 | 407d? |  | start no earlier than 2008-06-06 | R2 | 3248h | 3248h | WiMAX_LTE_Mobility | PCG-21 | Samsung |  | Rel-9 | RP-38 | Joern |  | PCG-21 | SP-39 |
| 345 | 138 | Deleted - Support of WiMAX - UMTS Mobility |  | 407d? | 2008-06-06 A | 2009-12-25 A | 100% |  | 2008-06-06 | 2009-12-25 | 407d? |  | start no earlier than 2008-06-06 | R2 | 3248h | 3248h | WiMAX_UMTS_Mobility | PCG-21 | Intel |  | Rel-9 | RP-38 | Joern |  | PCG-21 | SP-39 |
| 346 | 139 | Release 9 Studies | milestone | 0d? | 2000-01-01 | 2000-01-01 |  |  | 2000-01-01 | 2000-01-01 | 0d? | 3318d |  | CP,RP,SP |  |  |  |  |  |  | Rel-9 |  |  |  |  |  |
| 347 | 140 | **Study on enhanced voice service requirements for the Evolved Packet System (EPS)** |  | 670d? | 2007-09-03 A | 2010-03-25 | 70% | 201.1d? | 2007-09-03 | 2010-03-25 | 670d? | 647d |  | S1,S4 | 13384h | 9366.8h | FS_EV_EPS |  | Orange | tim.haysom@orange-ftgroup.com | Rel-9 | SP-37 | Alain |  |  |  |
| 348 | 140.1 | Use cases definition and service and system requirements |  | 334d? | 2007-09-03 A | 2008-12-11 A | 100% |  | 2007-09-03 | 2008-12-11 | 334d? |  | finish no earlier than 2008-12-11 | S1 | 2672h | 2672h | FS_EV_EPS-S1 |  | Orange | tim.haysom@orange-ftgroup.com | Rel-9 | SP-37 | Alain |  |  |  |
| 349 | 140.2 | Codec specific part of FS_EV_EPS |  | 669d? | 2007-09-03 A | 2010-03-25 | 55% | 301.05d? | 2007-09-03 | 2010-03-25 | 669d? | 647d | finish no earlier than 2010-03-25 | S4 | 5352h | 2943.6h | FS_EV_EPS-S4 |  | Ericsson | stefan.bruhn@ericson.com | Rel-9 | SP-37 | Paolo |  |  |  |
| 350 | 141 | Study on Service Specific Access Control in EPS |  | 136d? | 2008-06-05 A | 2008-12-11 A | 100% |  | 2008-06-05 | 2008-12-11 | 136d? |  | start no earlier than 2008-06-05 | S1 | 1088h | 1088h | FS_SSAC | PCG-21 | NTT DoCoMo | Frederic Thepot (thepot@docomolab-euro.com) | Rel-9 | SP-40 | Alain |  |  |  |
| 351 | 142 | Study on CS Domain Services over EPS access |  | 492d? | 2007-04-25 A | 2009-03-12 A | 100% |  | 2007-04-25 | 2009-03-12 | 492d? |  | finish no earlier than 2009-03-12 | S2 | 3936h | 3936h | FS_CSoPS |  | T-Mobile | Karl-Heinz.Nenner@T-Mobile.net | Rel-9 | SP-35 | Maurice |  |  |  |
| 352 | 143 | Study on Extended Support of IMS Emergency Calls |  | 319d? | 2007-09-24 A | 2008-12-11 A | 100% |  | 2007-09-24 | 2008-12-11 | 319d? |  | finish no earlier than 2009-06-18 | S2 | 2552h | 2552h | FS_IMS-eCall |  | Qualcomm Europe | Stephen Edge | Rel-9 | SP-37 | Maurice |  |  |  |
| 353 | 144 | Study on Service Continuity for Emergency Voice Calls |  | 721d? | 2006-06-08 A | 2009-03-12 A | 100% |  | 2006-06-08 | 2009-03-12 | 721d? |  | finish no earlier than 2009-03-12 | S2 | 5768h | 5768h | FS_VCCEm |  | Nortel | Ricky Kaura (rkaura@nortel.com) | Rel-9 | SP-32 | Maurice |  |  |  |
| 354 | 145 | Study on Security Aspects of Remote Provisioning and Change of Subscription for M2M Equipment |  | 582d? | 2004-04-06 A | 2009-12-10 A | 100% |  | 2004-04-06 | 2009-12-10 | 582d? |  | finish no earlier than 2009-12-10 | S3,C6 | 4656h | 4656h | FS_UM2M |  | Ericsson | vesa.lehtovirta@ericsson.com | Rel-9 | SP-37 | Dionisio |  |  |  |
| 355 | 146 | Study on Surround Sound codec extension for PSS and MBMS |  | 271d? | 2009-03-12 A | 2010-03-25 | 50% | 135.5d? | 2009-03-12 | 2010-03-25 | 271d? | 647d | finish no earlier than 2010-03-25 | S4 | 2168h | 1084h | FS_SS_PSS_MBMS | PCG-22 | Fraunhofer Gesellschaft | jan.plogsties@iis.franhofer.de | Rel-9 | SP-43 | Paolo |  |  |  |
| 356 | 147 | Study on System Maintenance over Itf-N |  | 602d? | 2007-06-07 A | 2009-09-24 A | 100% |  | 2007-06-07 | 2009-09-24 | 602d? |  | finish no earlier than 2009-09-24 | S5 | 4808h | 4808h | FS_OAM-Maint-Itf-N |  | ZTE | HUANG, Shuqiang | Rel-9 | SP-36 | Dionisio |  |  |  |
| 357 | 148 | Study on Self-Organizing Networks (SON) related OAM interfaces for Home NodeB |  | 522d? | 2007-06-07 A | 2009-06-04 A | 100% |  | 2007-06-07 | 2009-06-04 | 522d? |  | finish no earlier than 2009-12-10 | S5 | 4168h | 4168h | FS_OAM-SON-HNB |  | Huawei | Zou Lan (zlan@huawei.com) | Rel-9 | SP-36 | Dionisio |  |  |  |
| 358 | 149 | Study on Self-healing of Self-Organizing Networks (SON) |  | 416d? | 2008-02-22 A | 2009-09-24 A | 100% |  | 2008-02-22 | 2009-09-24 | 416d? |  | finish no earlier than 2009-09-24 | S5 | 3320.15h | 3320.15h | FS_OAM-SON-SH | PCG-21 | ZTE | zhu.weihong@zte.com.cn | Rel-9 | SP-39 | Dionisio |  |  |  |
| 359 | 150 | Study on Service Oriented Architecture (SOA) for IRP |  | 262d? | 2008-06-05 A | 2009-06-04 A | 100% |  | 2008-06-05 | 2009-06-04 | 262d? |  | finish no earlier than 2009-05-20 | S5 | 2088h | 2088h | FS_OAM_SOA_IRP | PCG-21 | Ericsson | edwin.tse@ericsson.com | Rel-9 | SP-40 | Dionisio |  |  |  |
| 360 | 151 | Study on Interworking Proxy between GTP based and PMIP based interfaces |  | 131d? | 2009-09-18 A | 2010-03-19 | 60% | 52.4d? | 2009-09-18 | 2010-03-19 | 131d? | 651d | finish no earlier than 2010-03-19 | C4 | 1048h | 628.8h | FS_GTP-MIP-IW | PCG-23 | NTT DoCoMo | takaaki.matsuura.sp@s1.nttdocomo.com | Rel-9 | CP-45 | Kimmo | CP-090810 |  |  |
| 361 | 152 | Study on Evaluation of the inclusion of Path Loss Based Technology in the UTRAN |  | 516d? | 2007-12-17 A | 2009-12-04 A | 100% |  | 2007-12-17 | 2009-12-04 | 516d? |  | finish no earlier than 2009-09-18 | R4 | 4120h | 4120h | FS_RAN-Pathloss | PCG-21 | Polaris Wireless | Norman Shaw (nshaw@polariswireless.com) | Rel-9 | RP-38 | Issam | RP-091080 |  |  |
| 362 | 153 | Study on LTE-Advanced |  | 461d? | 2007-03-23 A | 2010-03-19 | 80% | 92.8d? | 2007-03-23 | 2010-03-19 | 461d? | 651d | finish no earlier than 2010-03-19 | R1,R2,R3,R4 | 3688h | 2945.6h | FS_RAN_LTEA | PCG-21 | NTT DoCoMo | Tetsushi Abe | Rel-9 | RP-39 | Patrick | RP-091082 |  |  |
| 363 | 154 | Study on 1.28 Mcps TDD Home NodeB |  | 387d? | 2008-02-20 A | 2009-12-04 A | 100% |  | 2008-02-20 | 2009-12-04 | 387d? |  | finish no earlier than 2009-12-04 | R4 | 3096h | 3096h | FS_RAN-HNBLCRTDD | PCG-21 | TD Tech | Li Rong (lirong@td-tech.com) | Rel-9 | RP-41 | Issam | RP-091081 |  |  |
| 364 | 155 | Study on E-UTRAN Mobility Evaluation and Enhancement |  | 126d? | 2008-12-05 A | 2009-05-29 A | 100% |  | 2008-12-05 | 2009-05-29 | 126d? |  | finish no earlier than 2009-05-29 | R1 | 1008h | 1008h | FS_EUTRAN_mob | PCG-22 | Qualcomm Europe | Rajat Prakash (rprakash@qualcomm.com) | Rel-9 | RP-42 | Patrick | RP-090426 |  |  |
| 365 | 156 | Study on Minimization of drive-tests in Next Generation Networks |  | 196d? | 2009-03-06 A | 2009-12-04 A | 100% |  | 2009-03-06 | 2009-12-04 | 196d? |  | finish no earlier than 2009-12-04 | R2 | 1568h | 1568h | FS_NGN_min_drive-tests | PCG-22 | Qualcomm Europe | Masato Kitazoe (mkitazoe@qualcomm.com) | Rel-9 | RP-43 | Joern | RP-091084 |  |  |
| 366 | 157 | Study on Enhanced Interference Management for HNBs |  | 61d? | 2009-03-06 A | 2009-05-29 A | 100% |  | 2009-03-06 | 2009-05-29 | 61d? |  | start no earlier than 2009-03-06 | R4 | 488h | 488h | FS_eInterfMgmt_HNB | PCG-22 | Qualcomm Europe | Farhad Meshkati (fmeshkat@qualcomm.com) | Rel-9 | RP-43 | Issam | RP-090429 |  |  |
| 367 | 158 | Study on Enhanced Interference Management Mechanisms for HNBs |  | 81d? | 2009-05-30 A | 2009-09-18 A | 100% |  | 2009-05-30 | 2009-09-18 | 81d? |  | finish no earlier than 2009-09-18 | R3 | 648h | 648h | FS_eInterfMgmtMchsm_HNB | PCG-23 | Qualcomm Europe | Farhad Meshkati (fmeshkat@qualcomm.com) | Rel-9 | RP-44 | Juha | RP-090733 |  |  |
| 368 | 159 | Deleted - Study on Protection against SMS and MMS spam |  | 862d? | 2006-06-08 A | 2009-09-24 A | 100% |  | 2006-06-08 | 2009-09-24 | 862d? |  | finish no earlier than 2009-09-24 | S3 | 6896h | 6896h | FS_CPSMal |  | Orange | eric.gauthier@orange.ch | Rel-9 | SP-32 | Dionisio |  | PCG-23 | SP-45 |
| 369 | 160 | Release 8 Features | milestone | 0d? | 2000-01-03 | 2000-01-03 |  |  | 2000-01-03 | 2000-01-03 | 0d? | 3317d | start no earlier than 2000-01-03 | CP,GP,RP,SP |  |  |  |  |  |  | Rel-8 |  |  |  |  |  |

Notes:
- 332: GP#42 WID approved
- 333: GP#44 exception to 03/10 in GP-092475. GP#42 WID approved / Text3: new 48.049
- 334: CP#46 extension to 03/10 in CP-090867 / Text3: 23.041
- 335: GP#44 completed. GP#42 WID approved (Hybrid Integrated Location Technology=HILT) / Text3: 43.059, 48.071
- 336: SP#46 completed
- 337: GP#44 created
- 338: SP#39 created to host Rel-9 Wis. BUT no agreed WID
- 339: SP#39 SAE functionality moved to Rel-9. WID returned to SA2 for re-consideration & remove MBMS for EPS from Rel 8
- 340: SP#39 SAE functionality moved to Rel-9. BUT no agreed WID
- 341: SP#39 SAE functionality moved to Rel-9. BUT no agreed WID
- 342: SP#39 SAE functionality moved to Rel-9. BUT no agreed WID
- 343: SP#43 stopped. LS_out to TISPAN informs about stopping this activity / Text3: 23.822, 23.203
- 344: RP#39: No agreed WID / Text3: 36.306, 36.331, 36.413, 36.300, 36.214, 36.133, 36.304
- 345: RP#39: No agreed WID / Text3: 25.306, 25.331, 25.413
- 346: -
- 347: SP#42 SA1 completed. SP#46 target completion 12/09=>03/10 / Text3: 22.813
- 348: SP#42 completed. SA1 responsibility for use cases definition and service & system requirements identification / Text3: 22.813
- 349: SP#46 target completion 12/09=>03/10. SA4 responsibility for codec (e.g. detailed codec requirements such as performance requirements and design constraints), including assessment of existing 3GPP codecs / Text3: 22.813
- 350: SP#42 completed. Spin-off Feature UID_420020 (SSAC) / Text3: 22.986
- 351: SP#43 completed / Text3: 23.879
- 352: SP#42 completed / Text3: 23.868
- 353: SP#43 completed / Text3: 23.826
- 354: SP#46 completed. Triggered by SA1 Study UID_7027 (FS_M2M) TR 22.868 / Text3: 33.812
- 355: SP#46 target completion 12/09=>03/10. Work to extend Rel-8 UID_34043 PSS_MBMS_OMTV (Extending PSS and MBMS User Services for optimized Mobile TV) / Text3: 26.950
- 356: SP#45 completed / Text3: 32.822
- 357: SP#44 completed / Text3: 32.821
- 358: SP#45 completed / Text3: 32.823
- 359: SP#44 completed. Spin-off implementation WI UID_440064 Service Oriented Architecture (SOA) for IRP / Text3: 32.824
- 360: CP#46 exception to 03/10 in CP-090810 / Text3: 29.875
- 361: RP#46 completed / Text3: 25.907
- 362: RP#46 updated WID RP-090735=>RP-091360 / Text3: 36.913 , new 36.814, 36.912, R2 36.806 (Relay architectures for E-UTRA), R4 36.815 (LTE-Advanced feasibility studies in RAN4)
- 363: RP#46 completed (25.866v100 for Approval) / Text3: 25.866
- 364: RP#44 completed (RP-090452 R1 LS to RAN on Conclusions for LTE Mobility Study Item - no further Rel-9 action/TR needed
- 365: RP#46 completed / Text3: 36.805
- 366: RP#44 completed. Spin-off RAN3 UID_440015 Study on Enhanced Interference Management Mechanisms for HNBs / Text3: 25.967
- 367: Triggered by RAN4 UID_430027 Study on Enhanced Interference Management for HNBs. RP#45 completed / Text3: 25.967
- 368: SP#45 work stopped/abandoned / Text3: 33.9xx
- 369: -

| ID | WBS | Task | Duration | Start | Finish | Complete | Remaining | Baseline start | Baseline finish | Baseline duration | Total slack | Constraint | Resources | Work | Actual work | Text1 | Text4 | Text5 | Text6 | Text8 | Text7 | Text2 |
| --- | --- | --- | --- | --- | --- | --- | --- | --- | --- | --- | --- | --- | --- | --- | --- | --- | --- | --- | --- | --- | --- | --- |
| 370 | 161 | **3GPP System Architecture Evolution Specification - Evolved Packet System (non RAN aspects)** | 1024d? | 2006-04-12 A | 2010-03-12 | 99% | 5.09d? | 2006-04-12 | 2010-03-12 | 1024d? | 656d |  | SP,CP | 259980h | 258340h | SAES | T-Mobile | michael.kurz@t-mobile.at | Rel-8 | Alain |  |  |
| 371 | 161.1 | Requirements for evolution of the 3GPP system architecture | 395d? | 2006-06-08 A | 2007-12-12 A | 100% |  | 2006-06-08 | 2007-12-12 | 395d? |  | finish no earlier than 2007-11-30 | S1 | 3160h | 3160h | AIPN-SAE | T-Mobile | michael.kurz@t-mobile.at | Rel-8 | Alain |  |  |
| 372 | 161.2 | **High level and common (for all accesses) functions** | 629d? | 2007-01-02 A | 2009-05-29 A | 100% |  | 2007-01-02 | 2009-05-29 | 629d? |  |  | SP,CP | 42536h | 42536h | EPS-ComF | Nokia Siemens Networks | balazs.bertenyi@nsn.com | Rel-8 | Maurice | SP-37 |  |
| 373 | 161.2.1 | Stage 2 for High level functions | 370d? | 2007-01-02 A | 2008-06-02 A | 100% |  | 2007-01-02 | 2008-06-02 | 370d? |  | finish no earlier than 2008-06-02 | S2 | 2960h | 2960h | SAES-SA-HLF | Motorola | Irfan.Ali@motorola.com | Rel-8 | Maurice |  |  |
| 374 | 161.2.2 | Stage 2 Security Architecture | 197d? | 2008-03-12 A | 2008-12-11 A | 100% |  | 2008-03-12 | 2008-12-11 | 197d? |  | finish no earlier than 2008-12-11 | S3 | 1576h | 1576h | SAES | Nokia Siemens Networks | marc.blommaert.ext@nsn.com | Rel-8 | Dionisio | SP-39 | PCG-21 |
| 375 | 161.2.3 | Stage 3 (CT1) for SAE impact on services, network functions and capabilities | 545d? | 2007-02-05 A | 2009-03-06 A | 100% |  | 2007-02-05 | 2009-03-06 | 545d? |  | finish no earlier than 2009-03-06 | C1 | 4360h | 4360h | SAES | Nokia Siemens Networks | robert.zaus@nsn.com | Rel-8 | Frederic |  |  |
| 376 | 161.2.4 | Stage 3 SAE impact on existing capabilities | 480d? | 2007-02-05 A | 2008-12-05 A | 100% |  | 2007-02-05 | 2008-12-05 | 480d? |  | finish no earlier than 2008-12-12 | C3 | 3840h | 3840h | SAES | Huawei | Wei Weihua (weiwh@huawei.com) | Rel-8 | Gwiho |  |  |
| 377 | 161.2.5 | Stage 3 (CT4) of SAE impact on existing capabilities | 545d? | 2007-02-05 A | 2009-03-06 A | 100% |  | 2007-02-05 | 2009-03-06 | 545d? |  | finish no earlier than 2009-03-06 | C4 | 4360h | 4360h | SAES | Huawei | shahab.lavasani@huawei.com | Rel-8 | Kimmo |  |  |
| 378 | 161.2.6 | Stage 2/3 for Network selection procedures | 480d? | 2007-02-05 A | 2008-12-05 A | 100% |  | 2007-02-05 | 2008-12-05 | 480d? |  | finish no earlier than 2009-03-06 | C1 | 3840h | 3840h | SAES | Nokia Siemens Networks | robert.zaus@nsn.com | Rel-8 | Frederic |  |  |
| 379 | 161.2.7 | Stage 3 EPC interworking with external PDNs (SGi) | 605d? | 2007-02-05 A | 2009-05-29 A | 100% |  | 2007-02-05 | 2009-05-29 | 605d? |  | finish no earlier than 2009-05-29 | C3 | 4840h | 4840h | SAES-St3-intwk | Huawei | Wei Weihua (weiwh@huawei.com) | Rel-8 | Gwiho |  |  |
| 380 | 161.2.8 | Stage 3 PCC within SAE | 605d? | 2007-02-05 A | 2009-05-29 A | 100% |  | 2007-02-05 | 2009-05-29 | 605d? |  | finish no earlier than 2009-05-29 | C3 | 4840h | 4840h | SAES-St3-PCC | Ericsson | j.javier.pastor@ericsson.com | Rel-8 | Gwiho |  |  |
| 381 | 161.2.9 | Stage 3 for SAE / LTE identities | 545d? | 2007-02-05 A | 2009-03-06 A | 100% |  | 2007-02-05 | 2009-03-06 | 545d? |  | finish no earlier than 2009-03-06 | C4 | 4360h | 4360h | SAES | Huawei | shahab.lavasani@huawei.com | Rel-8 | Kimmo |  |  |
| 382 | 161.2.10 | Unified guidelines for Diameter usage within 3GPP | 316d? | 2007-09-21 A | 2008-12-05 A | 100% |  | 2007-09-21 | 2008-12-05 | 316d? |  | finish no earlier than 2008-12-05 | C3 | 2528h | 2528h | SAES-DIAM | Huawei | Javier Gonzalez Gallego | Rel-8 | Gwiho | CP-37 |  |
| 383 | 161.3 | **SAE for LTE access** | 569d? | 2007-01-02 A | 2009-03-06 A | 100% |  | 2007-01-02 | 2009-03-06 | 569d? |  |  | S2,C1,C3,C4 | 57824h | 57824h | SAES-LTE | Motorola | Irfan.Ali@motorola.com | Rel-8 | Maurice |  |  |
| 384 | 161.3.1 | CT4 Stage 3 for protocol between EPCs | 545d? | 2007-02-05 A | 2009-03-06 A | 100% |  | 2007-02-05 | 2009-03-06 | 545d? |  | finish no earlier than 2009-03-06 | C4 | 4360h | 4360h | SAES | Huawei | shahab.lavasani@huawei.com | Rel-8 | Kimmo |  |  |
| 385 | 7.2.2.1 | **SAES-SA-FP_LTE with GTP variant** | 569d? | 2007-01-02 A | 2009-03-06 A | 100% |  | 2007-01-02 | 2009-03-06 | 569d? |  |  | S2,C4 | 11896h | 11896h | SAES-SA-FP_LTE-GTP | Nokia Siemens Networks | balazs.bertenyi@nsn.com | Rel-8 | Maurice |  |  |
| 386 | 161.3.2.1 | Stage 2 for SAES-SA-FP_LTE with GTP variant | 373d? | 2007-01-02 A | 2008-06-05 A | 100% |  | 2007-01-02 | 2008-06-05 | 373d? |  | finish no earlier than 2008-06-02 | S2 | 2984h | 2984h | SAES-SA-FP_LTE-GTP-St2 | Nokia Siemens Networks | balazs.bertenyi@nsn.com | Rel-8 | Maurice |  |  |
| 387 | 161.3.2.2 | CT4 Stage 3 for GTP v2 protocol | 545d? | 2007-02-05 A | 2009-03-06 A | 100% |  | 2007-02-05 | 2009-03-06 | 545d? |  | finish no earlier than 2009-03-06 | C4 | 4360h | 4360h | SAES | Huawei | shahab.lavasani@huawei.com | Rel-8 | Kimmo |  |  |
| 388 | 7.2.2.2 | **SAES-SA-FP_LTE with PMIP variant** | 569d? | 2007-01-02 A | 2009-03-06 A | 100% |  | 2007-01-02 | 2009-03-06 | 569d? |  |  | S2,C4 | 15736h | 15736h | SAES-SA-FP_LTE-IETF | Nokia Siemens Networks | balazs.bertenyi@nsn.com | Rel-8 | Maurice |  |  |
| 389 | 161.3.3.1 | Stage 2 for SAES-SA-FP_LTE with PMIP variant | 373d? | 2007-01-02 A | 2008-06-05 A | 100% |  | 2007-01-02 | 2008-06-05 | 373d? |  | finish no earlier than 2008-06-02 | S2 | 2984h | 2984h | SAES-SA-FP_LTE-IETF-St2 | Nokia Siemens Networks | balazs.bertenyi@nsn.com | Rel-8 | Maurice |  |  |
| 390 | 161.3.3.2 | CT4 Stage 3 for PMIP protocol within EPC | 545d? | 2007-02-05 A | 2009-03-06 A | 100% |  | 2007-02-05 | 2009-03-06 | 545d? |  | finish no earlier than 2009-03-06 | C4 | 4360h | 4360h | SAES | Huawei | shahab.lavasani@huawei.com | Rel-8 | Kimmo | CP-37 |  |
| 391 | 161.3.3.3 | Mobile IPv4 (MIPv4) based Mobility protocols | 480d? | 2007-02-05 A | 2008-12-05 A | 100% |  | 2007-02-05 | 2008-12-05 | 480d? |  | finish no earlier than 2008-12-05 | C4 | 3840h | 3840h | SAES | Motorola | Lewis Milton | Rel-8 | Kimmo | CP-41 |  |
| 392 | 161.3.4 | Stage 3 for UE NAS mobility procedures in idle and active mode | 545d? | 2007-02-05 A | 2009-03-06 A | 100% |  | 2007-02-05 | 2009-03-06 | 545d? |  | finish no earlier than 2009-03-06 | C1 | 4360h | 4360h | SAES | Nokia Siemens Networks | robert.zaus@nsn.com | Rel-8 | Frederic |  |  |
| 393 | 161.3.5 | Stage 3 for Session management, bearer control and QoS aspects | 545d? | 2007-02-05 A | 2009-03-06 A | 100% |  | 2007-02-05 | 2009-03-06 | 545d? |  | finish no earlier than 2009-03-06 | C1 | 4360h | 4360h | SAES | Nokia Siemens Networks | robert.zaus@nsn.com | Rel-8 | Frederic |  |  |
| 394 | 161.3.6 | Stage 3 for security aspects of LTE Access | 545d? | 2007-02-05 A | 2009-03-06 A | 100% |  | 2007-02-05 | 2009-03-06 | 545d? |  | finish no earlier than 2009-03-06 | C1 | 4360h | 4360h | SAES | Nokia Siemens Networks | robert.zaus@nsn.com | Rel-8 | Frederic |  |  |
| 395 | 161.3.7 | Stage 3 for QoS mechanisms | 480d? | 2007-02-05 A | 2008-12-05 A | 100% |  | 2007-02-05 | 2008-12-05 | 480d? |  | finish no earlier than 2008-12-12 | C3 | 3840h | 3840h | SAES | Ericsson | j.javier.pastor@ericsson.com | Rel-8 | Gwiho |  |  |
| 396 | 161.3.8 | Stage 3 for EPC - HSS interface | 545d? | 2007-02-05 A | 2009-03-06 A | 100% |  | 2007-02-05 | 2009-03-06 | 545d? |  | finish no earlier than 2009-03-06 | C4 | 4360h | 4360h | SAES | Huawei | shahab.lavasani@huawei.com | Rel-8 | Kimmo |  |  |

Notes:
- 370: SP#39 WID updated SP-070933=>SP-080132. Role model for SAE/LTE system wide project management by SA2 in SP-060166
- 371: SP#38 completed / Text3: 22.278, 22.011, 22.246
- 372: SP#39 WID updated SP-070933=>SP-080132
- 373: SP#40 completed / Text3: 23.402
- 374: SP#42 completed. SP#39 WID updated SP-070933=>SP-080132 / Text3: 33.401, 33.210, 33.310
- 375: CP#43 completed / Text3: 24.229, 24.305, 27.007
- 376: CP#42 completed. WID updated CP-080056=>CP-080772 / Text3: 29.061
- 377: CP#43 completed. WID updated CP-080724=>CP-090247. Network sharing, etc, MBMS removed / Text3: 29.274, 29.275
- 378: CP#42 completed. CP#41 WID updated CP-080075=>CP-080493. / Text3: 23.122, 24.302
- 379: CP#44 completed / Text3: 29.061
- 380: CP#44 completed / Text3: 29.212, 29.213, 29.214, 29.215
- 381: CP#43 completed. WID updated CP-080724=>CP-090247 / Text3: 23.003
- 382: CP#42 completed / Text3: 29.909
- 383: CP#43 completed. SP#39 WID updated SP-070933=>SP-080132
- 384: CP#43 completed. WID updated CP-080724=>CP-090247. PMIP and GTP based S8 interface (EPC-EPC) / Text3: 29.274, 29.275
- 385: CP#43 completed. SP#39 WID updated SP-070933=>SP-080132
- 386: SP#40 completed / Text3: 23.401, 23.060, 23.002, 23.246, 23.203, 23.107, 23.234, 23.271
- 387: CP#43 completed. WID updated CP-080724=>CP-090247 / Text3: 29.274
- 388: CP#43 completed. SP#39 WID updated SP-070933=>SP-080132
- 389: SP#40 completed. Multiple PDN related alignments, 23.060-derived changes.
- 390: CP#43 completed. WID updated CP-080724=>CP-090247. PMIP based S5 interface / Text3: 29.275, 29.282
- 391: CP#42 completed. CP#43 WID updated CP-080724=>CP-090247 / Text3: 29.279
- 392: CP#43 completed / Text3: 24.007, 24.301
- 393: CP#43 completed / Text3: 24.007, 24.301
- 394: CP#43 completed / Text3: 24.008, 24.301
- 395: CP#42 completed. CP#41 updated WID CP-080057=>CP-080576. / Text3: 29.213
- 396: CP#43 completed. WID updated CP-080724=>CP-090247. S6a, S6d, S13, S13' interface / Text3: 29.272

| ID | WBS | Task | Type | Duration | Start | Finish | Complete | Baseline start | Baseline finish | Baseline duration | Constraint | Resources | Work | Actual work | Text1 | Text4 | Text5 | Text6 | Text8 | Text3 | Text7 | Text2 | Text12 |
| --- | --- | --- | --- | --- | --- | --- | --- | --- | --- | --- | --- | --- | --- | --- | --- | --- | --- | --- | --- | --- | --- | --- | --- |
| 397 | 161.4 | **SAE for Interoperation between LTE and legacy cellular PS accesses** |  | 545d? | 2007-02-05 A | 2009-03-06 A | 100% | 2007-02-05 | 2009-03-06 | 545d? |  | S2,C1,C4 | 40152h | 40152h | SAES-SA-FP_3GPP | Motorola | Irfan.Ali@motorola.com | Rel-8 | Maurice |  |  |  |  |
| 398 | 161.4.1 | Stage 2 for Interoperation between LTE and 2G/3G |  | 424d? | 2007-02-05 A | 2008-09-18 A | 100% | 2007-02-05 | 2008-09-18 | 424d? | finish no earlier than 2008-09-11 | S2 | 3392h | 3392h | EPSto2_3G | Motorola | Irfan.Ali@motorola.com | Rel-8 | Maurice | 23.401, 23.402 | SP-37 |  |  |
| 399 | 161.4.2 | Stage 3 for Inter-system mobility between E-UTRAN and 2G/3G |  | 545d? | 2007-02-05 A | 2009-03-06 A | 100% | 2007-02-05 | 2009-03-06 | 545d? | finish no earlier than 2009-03-06 | C1 | 4360h | 4360h | SAES | Nokia Siemens Networks | robert.zaus@nsn.com | Rel-8 | Frederic | 24.008, 24.301 | CP-38 | PCG-21 |  |
| 400 | 161.4.3 | Stage 2 GPRS enhancements for LTE access |  | 272d? | 2007-09-04 A | 2008-09-18 A | 100% | 2007-09-04 | 2008-09-18 | 272d? | start no earlier than 2007-09-04 | S2 | 2176h | 2176h | SAES-GPRS_LTE | Vodafone | chris.pudney@vodafone.com | Rel-8 | Maurice | 23.401 |  |  |  |
| 401 | 161.4.4 | Stage 2 GPRS for EPC (23.060, etc.) |  | 179d? | 2008-01-14 A | 2008-09-18 A | 100% | 2008-01-14 | 2008-09-18 | 179d? | finish no earlier than 2008-09-18 | S2 | 1432h | 1432h | SAES | Nokia Siemens Networks | balazs.bertenyi@nsn.com | Rel-8 | Maurice | 23.060 | SP-39 | PCG-21 |  |
| 402 | 161.4.5 | Stage 3 for EPC - GPRS |  | 545d? | 2007-02-05 A | 2009-03-06 A | 100% | 2007-02-05 | 2009-03-06 | 545d? | finish no earlier than 2009-03-06 | C4 | 4360h | 4360h | SAES | Huawei | shahab.lavasani@huawei.com | Rel-8 | Kimmo | 29.274, 29.275, 29.281 |  |  |  |
| 403 | 161.4.6 | Stage 3 for EPC to UTRAN |  | 545d? | 2007-02-05 A | 2009-03-06 A | 100% | 2007-02-05 | 2009-03-06 | 545d? | finish no earlier than 2009-03-06 | C4 | 4360h | 4360h | SAES | Huawei | shahab.lavasani@huawei.com | Rel-8 | Kimmo | 29.274, 29.275, 29.281 | CP-38 | PCG-21 |  |
| 404 | 161.4.7 | Stage 3 for EPC to 3GPP2 |  | 545d? | 2007-02-05 A | 2009-03-06 A | 100% | 2007-02-05 | 2009-03-06 | 545d? | finish no earlier than 2009-03-06 | C4 | 4360h | 4360h | SAES | Huawei | shahab.lavasani@huawei.com | Rel-8 | Kimmo | 29.277, 29.276 | CP-38 | PCG-21 |  |
| 405 | 161.4.8 | Stage 2 for Interoperation between LTE and CDMA2000 |  | 329d? | 2007-06-18 A | 2008-09-18 A | 100% | 2007-06-18 | 2008-09-18 | 329d? | finish no earlier than 2008-04-25 | S2 | 2632h | 2632h | EPStoC2k | Motorola, Vodafone | Irfan.Ali@motorola.com, chris.pudney@vodafone.com | Rel-8 | Maurice | 23.401, 23.402 | CP-37 |  |  |
| 406 | 161.4.9 | Stage 3 for Inter-system mobility between E-UTRAN and CDMA2000 |  | 545d? | 2007-02-05 A | 2009-03-06 A | 100% | 2007-02-05 | 2009-03-06 | 545d? | finish no earlier than 2009-03-06 | C1 | 4360h | 4360h | SAES | Nokia Siemens Networks | robert.zaus@nsn.com | Rel-8 | Frederic | 24.301, 24.302 |  |  |  |
| 407 | 161.4.10 | Stage 3 for MME - SGSN "signalling free" protocol |  | 545d? | 2007-02-05 A | 2009-03-06 A | 100% | 2007-02-05 | 2009-03-06 | 545d? | finish no earlier than 2009-03-06 | C4 | 4360h | 4360h | SAES | Huawei | shahab.lavasani@huawei.com | Rel-8 | Kimmo | 29.272, 29.274 |  |  |  |
| 408 | 161.5 | **SAE for support for non-3GPP accesses** |  | 569d? | 2007-01-02 A | 2009-03-06 A | 100% | 2007-01-02 | 2009-03-06 | 569d? |  | S2,S3,C1,C4 | 53872h | 53872h | SAES-SA-FP_n3GPP | Motorola | Irfan.Ali@motorola.com | Rel-8 | Maurice |  |  |  |  |
| 409 | 7.2.4.1 | Stage 2 for Host-based Mobility aspects |  | 373d? | 2007-01-02 A | 2008-06-05 A | 100% | 2007-01-02 | 2008-06-05 | 373d? | finish no earlier than 2008-04-11 | S2 | 2984h | 2984h | SAES-SA-FP_n3GPP-HBMob | Motorola | Irfan.Ali@motorola.com | Rel-8 | Maurice | 23.402 |  |  |  |
| 410 | 7.2.4.2 | Stage 2 for Network-based Mobility aspects |  | 448d? | 2007-01-02 A | 2008-09-18 A | 100% | 2007-01-02 | 2008-09-18 | 448d? | finish no earlier than 2008-09-18 | S2 | 3584h | 3584h | SAES-SA-FP_n3GPP-NBMob | Motorola | Irfan.Ali@motorola.com | Rel-8 | Maurice | 23.402 |  |  |  |
| 411 | 161.5.3 | Stage 3 for Mobility management based on DSMIP v6 |  | 480d? | 2007-02-05 A | 2008-12-05 A | 100% | 2007-02-05 | 2008-12-05 | 480d? | finish no earlier than 2008-12-05 | C1 | 3840h | 3840h | SAES | Nokia Siemens Networks | robert.zaus@nsn.com | Rel-8 | Frederic | 24.303 |  |  |  |
| 412 | 161.5.4 | Stage 3 for Mobility management based on MIP v4 |  | 480d? | 2007-02-05 A | 2008-12-05 A | 100% | 2007-02-05 | 2008-12-05 | 480d? | start no earlier than 2007-02-05 | C1 | 3840h | 3840h | SAES | Nokia Siemens Networks | robert.zaus@nsn.com | Rel-8 | Frederic | 24.304 | CP-39 | PCG-21 |  |
| 413 | 161.5.5 | Stage 3 for Inter-system mobility between E-UTRAN and non 3GPP accesses |  | 545d? | 2007-02-05 A | 2009-03-06 A | 100% | 2007-02-05 | 2009-03-06 | 545d? | finish no earlier than 2009-03-06 | C1 | 4360h | 4360h | SAES | Nokia Siemens Networks | robert.zaus@nsn.com | Rel-8 | Frederic | 24.008, 24.301 | CP-38 | PCG-21 |  |
| 414 | 161.5.6 | Stage 2 for Optimized Dual-Radio Handover with WiMAX |  | 249d? | 2007-06-25 A | 2008-06-05 A | 100% | 2007-06-25 | 2008-06-05 | 249d? | finish no earlier than 2008-06-09 | S2 | 1992h | 1992h | SAES-SA-FP_n3GPP-OptWIMAX | Motorola | Irfan.Ali@motorola.com | Rel-8 | Maurice | 23.402 |  |  |  |
| 415 | 161.5.7 | Stage 2 Security aspects for non-3GPP Access |  | 197d? | 2008-03-12 A | 2008-12-11 A | 100% | 2008-03-12 | 2008-12-11 | 197d? | finish no earlier than 2008-12-11 | S3 | 1576h | 1576h | SAES | Nokia Siemens Networks | marc.blommaert.ext@nsn.com | Rel-8 | Dionisio | 33.402, 33.210, 33.310 | SP-39 | PCG-21 |  |
| 416 | 161.5.8 | Stage 3 security aspects for DSMIP v6 Access |  | 480d? | 2007-02-05 A | 2008-12-05 A | 100% | 2007-02-05 | 2008-12-05 | 480d? | finish no earlier than 2008-12-05 | C1 | 3840h | 3840h | SAES | Nokia Siemens Networks | robert.zaus@nsn.com | Rel-8 | Frederic | 24.303 | CP-37 |  |  |
| 417 | 161.5.9 | Stage 3 security aspects for MIPv4 Access |  | 480d? | 2007-02-05 A | 2008-12-05 A | 100% | 2007-02-05 | 2008-12-05 | 480d? | finish no earlier than 2008-12-05 | C1 | 3840h | 3840h | SAES | Nokia Siemens Networks | robert.zaus@nsn.com | Rel-8 | Frederic | 24.304 | CP-39 | PCG-21 |  |
| 418 | 161.5.10 | Stage 3 for Access to the EPC via non-3GPP access networks |  | 545d? | 2007-02-05 A | 2009-03-06 A | 100% | 2007-02-05 | 2009-03-06 | 545d? | finish no earlier than 2009-03-06 | C1 | 4360h | 4360h | SAES | Nokia Siemens Networks | robert.zaus@nsn.com | Rel-8 | Frederic | 24.302, 24.312 |  |  |  |
| 419 | 161.5.11 | Stage 3 for interfaces within EPC |  | 383d? | 2007-09-19 A | 2009-03-06 A | 100% | 2007-09-19 | 2009-03-06 | 383d? | finish no earlier than 2009-03-06 | C4 | 3064h | 3064h | SAES | Huawei | shahab.lavasani@huawei.com | Rel-8 | Kimmo | 29.274, 29.281 | CP-37 |  |  |
| 420 | 161.5.12 | Stage 3 for Interfaces EPC - non-3GPP IP access |  | 545d? | 2007-02-05 A | 2009-03-06 A | 100% | 2007-02-05 | 2009-03-06 | 545d? | finish no earlier than 2009-03-06 | C4 | 4360h | 4360h | SAES | Huawei | shahab.lavasani@huawei.com | Rel-8 | Kimmo | 29.273, 29.275 |  |  |  |
| 421 | 161.5.13 | Stage 3 for AAA/HSS related |  | 480d? | 2007-02-05 A | 2008-12-05 A | 100% | 2007-02-05 | 2008-12-05 | 480d? | finish no earlier than 2008-12-05 | C4 | 3840h | 3840h | SAES | Huawei | shahab.lavasani@huawei.com | Rel-8 | Kimmo | 29.273 |  |  |  |
| 422 | 161.5.14 | Stage 3 for EPC - AAA interface |  | 480d? | 2007-02-05 A | 2008-12-05 A | 100% | 2007-02-05 | 2008-12-05 | 480d? | finish no earlier than 2008-12-05 | C4 | 3840h | 3840h | SAES | Huawei | shahab.lavasani@huawei.com | Rel-8 | Kimmo | 29.273 |  |  |  |
| 423 | 161.5.15 | Deleted (already covered) SAES-SA-FP_n3GPP Optimized Handover with CDMA | milestone | 0d? | 2007-06-25 A | 2007-06-25 A | 100% | 2007-06-25 | 2007-06-25 | 0d? | finish no earlier than 2007-06-25 | S2 |  |  | SAES-SA-FP_n3GPP-OptCDMA | Nokia Siemens Networks |  | Rel-8 | Maurice |  |  |  | SP-37 |

Notes:
- 397: CP#43 completed. SP#39 WID updated SP-070933=>SP-080132
- 398: SP#41 completed
- 399: CP#43 completed
- 400: SP#41 completed. 25/03/08 claimed as SP#34 stopped. Resurrected. WID updated SP-060926 => SP-080132
- 401: SP#41 completed
- 402: CP#43 completed. WID updated CP-080724=>CP-090247
- 403: CP#43 completed. WID updated CP-080724=>CP-090247
- 404: CP#43 completed. WID updated CP-080724=>CP-090247. S101, S103 Interface MME - HRPD access S102, Interface to CDMA2000 1x RTT
- 405: SP#41 completed (except: Handover of multiple PDNs=>Rel-9)
- 406: CP#43 completed
- 407: CP#43 completed. WID updated CP-080724=>CP-090247
- 408: CP#43 completed. SP#39 retained in Rel-8 (in addition to the essential functionality defined in SP-070699). Replaces UID_340037
- 409: SP#40 completed
- 410: SP#41 completed
- 411: CP#41 WID updated CP-080075=>CP-080493. CP#42 completed
- 412: CP#41 WID updated CP-080075=>CP-080493. CP#42 completed
- 413: CP#43 completed
- 414: SP#40 completed
- 415: SP#42 completed. SP#39 WID updated SP-070933=>SP-080132
- 416: CP#42 completed. post-CP#39: split into DSMIP v6 and MIPv4 Access. CP#41 WID updated CP-080075=>CP-080493
- 417: CP#42 completed. post-CP#39: split into DSMIP v6 and MIPv4 Access. UID_390072->390172. CP#41 WID updated CP-080075=>CP-080493
- 418: CP#43 completed
- 419: CP#43 completed. WID updated CP-080724=>CP-090247. S10, S11. GTP based S5 Interface
- 420: CP#43 completed. WID updated CP-080724=>CP-090247. S2a, S2b, SWa, STa, SWn (Untrusted IP access - ePDG) interface
- 421: CP#42 completd. CP#43 WID updated CP-080724=>CP-090247
- 422: CP#42 completd. CP#43 WID updated CP-080724=>CP-090247
- 423: SP#37 stopped

| ID | WBS | Task | Type | Duration | Start | Finish | Complete | Remaining | Baseline start | Baseline finish | Baseline duration | Total slack | Constraint | Resources | Work | Actual work | Text1 | Text4 | Text5 | Text6 | Text8 | Text2 | Text7 | Text9 | Text12 | Text11 |
| --- | --- | --- | --- | --- | --- | --- | --- | --- | --- | --- | --- | --- | --- | --- | --- | --- | --- | --- | --- | --- | --- | --- | --- | --- | --- | --- |
| 424 | 161.6 | **Single Radio Voice Call Continuity for 3GPP (SRVCC)** |  | 569d? | 2007-01-02 A | 2009-03-06 A | 100% |  | 2007-01-02 | 2009-03-06 | 569d? |  |  | S2,C1,C4 | 10752h | 10752h | SAES-SRVCC | Nokia Siemens Networks | curt.c.wong@nokia.com | Rel-8 | Maurice |  |  |  |  |  |
| 425 | 161.6.1 | Stage 2 for 2G/3G SRVCC |  | 448d? | 2007-01-02 A | 2008-09-18 A | 100% |  | 2007-01-02 | 2008-09-18 | 448d? |  | finish no earlier than 2008-09-15 | S2 | 3584h | 3584h | SAES-SRVCC | Nokia Siemens Networks | curt.c.wong@nokia.com | Rel-8 | Maurice |  |  |  |  |  |
| 426 | 161.6.2 | Stage 3 for SRVCC in EPS |  | 201d? | 2008-05-30 A | 2009-03-06 A | 100% |  | 2008-05-30 | 2009-03-06 | 201d? |  | finish no earlier than 2009-03-06 | C1 | 1608h | 1608h | SAES-SRVCC | Nokia Siemens Networks | robert.zaus@nsn.com | Rel-8 | Frederic | PCG-21 | CP-41 |  |  |  |
| 427 | 161.6.3 | MME to MSC interface for SRVCC |  | 126d? | 2008-09-12 A | 2009-03-06 A | 100% |  | 2008-09-12 | 2009-03-06 | 126d? |  | finish no earlier than 2009-03-06 | C4 | 1008h | 1008h | SAES-SRVCC | Nokia Siemens Networks | Giorgi Gulbani | Rel-8 | Kimmo | PCG-21 | CP-41 |  |  |  |
| 428 | 161.7 | Voice Call Continuity for CDMA2000 1X |  | 249d? | 2007-06-25 A | 2008-06-05 A | 100% |  | 2007-06-25 | 2008-06-05 | 249d? |  | finish no earlier than 2008-06-13 | S2 | 1992h | 1992h | SAES-VCC_1X | Nokia Siemens Networks | balazs.bertenyi@nsn.com | Rel-8 | Maurice |  |  |  |  |  |
| 429 | 161.8 | SAE impacts on IMS |  | 373d? | 2007-01-02 A | 2008-06-05 A | 100% |  | 2007-01-02 | 2008-06-05 | 373d? |  | finish no earlier than 2008-06-13 | S2 | 2984h | 2984h | SAES-SA_IMS | Nokia Siemens Networks | balazs.bertenyi@nsn.com | Rel-8 | Maurice |  |  |  |  |  |
| 430 | 161.9 | **CS Fallback in EPS** |  | 258d? | 2008-03-12 A | 2009-03-06 A | 100% |  | 2008-03-12 | 2009-03-06 | 258d? |  |  | S2,C1,C4 | 4800h | 4800h | SAES-CSFB | T-Mobile, Vodafone | sabine.demel@t-mobile.at, chris.pudney@vodafone.com | Rel-8 | Maurice | PCG-21 | SP-39 |  |  |  |
| 431 | 161.9.1 | Stage 2 for CS Fallback in EPS |  | 62d? | 2008-03-12 A | 2008-06-05 A | 100% |  | 2008-03-12 | 2008-06-05 | 62d? |  | finish no earlier than 2008-12-05 | S2 | 496h | 496h | SAES-CSFB | T-Mobile, Vodafone | sabine.demel@t-mobile.at, chris.pudney@vodafone.com | Rel-8 | Maurice | PCG-21 | SP-40 |  |  |  |
| 432 | 161.9.2 | Stage 3 for CS Fallback in EPS |  | 201d? | 2008-05-30 A | 2009-03-06 A | 100% |  | 2008-05-30 | 2009-03-06 | 201d? |  | finish no earlier than 2009-03-06 | C1 | 1608h | 1608h | SAES-CSFB | NEC | yannick.lair@nectech.fr | Rel-8 | Frederic | PCG-21 | CP-40 |  |  |  |
| 433 | 161.9.3 | Stage 3 for CS Fallback in EPS |  | 136d? | 2008-05-30 A | 2008-12-05 A | 100% |  | 2008-05-30 | 2008-12-05 | 136d? |  | finish no earlier than 2008-12-05 | C4 | 1088h | 1088h | SAES-CSFB | NEC | yannick.lair@nectech.fr | Rel-8 | Kimmo | PCG-21 | CP-40 |  |  |  |
| 434 | 161.10 | System enhancements for the use of IMS services in local breakout |  | 62d? | 2008-03-12 A | 2008-06-05 A | 100% |  | 2008-03-12 | 2008-06-05 | 62d? |  | finish no earlier than 2008-06-05 | S2 | 496h | 496h | SAES-IMS_LBO | Telecom Italia | mario.madella@telecomitalia.it | Rel-8 | Maurice | PCG-21 | SP-39 |  |  |  |
| 435 | 161.11 | **EPC Data Definitions** |  | 309d? | 2008-01-07 A | 2009-03-12 A | 100% |  | 2008-01-07 | 2009-03-12 | 309d? |  |  | S5 | 7144h | 7144h | EPC-OAM |  |  | Rel-8 | Dionisio | PCG-21 | SP-39 |  |  |  |
| 436 | 161.11.1 | EPC Network Resource Model (NRM) Integration Reference Point (IRP) |  | 309d? | 2008-01-07 A | 2009-03-12 A | 100% |  | 2008-01-07 | 2009-03-12 | 309d? |  | finish no earlier than 2009-03-12 | S5 | 2472h | 2472h | EPC-OAM | Huawei | WANG, Xuelong | Rel-8 | Dionisio | PCG-21 | SP-38 |  |  |  |
| 437 | 161.11.2 | Performance measurements for EPC |  | 275d? | 2008-02-22 A | 2009-03-12 A | 100% |  | 2008-02-22 | 2009-03-12 | 275d? |  | finish no earlier than 2009-03-12 | S5 | 2200h | 2200h | EPC-OAM | China Mobile | Li Jian, Liang Shuangchun | Rel-8 | Dionisio | PCG-21 | SP-39 |  |  |  |
| 438 | 161.12 | EPC Charging |  | 309d? | 2008-01-07 A | 2009-03-12 A | 100% |  | 2008-01-07 | 2009-03-12 | 309d? |  | finish no earlier than 2009-03-12 | S5 | 2472h | 2472h | EPC-CH | Nokia Siemens Networks | GÖRMER, Gerald | Rel-8 | Dionisio | PCG-21 | SP-38 |  |  |  |
| 439 | 161.13 | Issues for CT1 TR 24.801 |  | 420d? | 2007-01-04 A | 2008-12-05 A | 100% |  | 2007-01-04 | 2008-12-05 | 420d? |  | finish no earlier than 2008-12-05 | C1 | 3360h | 3360h | SAES | Nokia Siemens Networks | robert.zaus@nsn.com | Rel-8 | Frederic | PCG-21 | CP-39 |  |  |  |
| 440 | 161.14 | Issues for CT3 TR 29.804 |  | 420d? | 2007-02-05 A | 2008-09-12 A | 100% |  | 2007-02-05 | 2008-09-12 | 420d? |  | finish no earlier than 2008-12-12 | C3 | 3360h | 3360h | SAES | Ericsson | j.javier.pastor@ericsson.com | Rel-8 | Gwiho | PCG-21 | CP-39 |  |  |  |
| 441 | 161.15 | Deleted - Issues for CT4 TR 29.803 |  | 420d? | 2007-01-04 A | 2008-09-12 A | 100% |  | 2007-01-04 | 2008-09-12 | 420d? |  | finish no earlier than 2008-12-11 | C4 | 3360h | 3360h | SAES | Huawei |  | Rel-8 | Kimmo | PCG-21 | CP-39 | PCG-21 | CP-41 |  |
| 442 | 161.16 | Domain Name System Procedures for Evolved Packet System (DEPS) |  | 179.75d? | 2008-05-30 A | 2009-03-06 A | 100% |  | 2008-05-30 | 2009-03-06 | 179.75d? |  | finish no earlier than 2009-03-06 | C4 | 1438h | 1438h | SAES-DEPS | TeliaSonera | jouni.korhonen@teliasonera.com | Rel-8 | Kimmo | PCG-21 | CP-40 |  |  |  |
| 443 | 161.17 | InterWorking Function (IWF) between MAP based and Diameter based interfaces |  | 126d? | 2008-09-12 A | 2009-03-06 A | 100% |  | 2008-09-12 | 2009-03-06 | 126d? |  | finish no earlier than 2009-03-06 | C4 | 1008h | 1008h | SAES-MAP2Diam | Huawei | liming49985@huawei.com | Rel-8 | Kimmo | PCG-21 | CP-41 |  |  |  |
| 444 | 161.18 | **CT6 aspects of SAE** |  | 527d? | 2008-03-07 A | 2010-03-12 | 80% | 107.02d? | 2008-03-07 | 2010-03-12 | 527d? | 656d |  | C6 | 7872h | 6273.45h | SAES | Nokia | Rune Lindholm | Rel-8 | Xavier | PCG-21 | SP-39 |  |  |  |
| 445 | 161.18.1 | CT6 aspects of SAE |  | 321d? | 2008-03-07 A | 2009-05-29 A | 100% |  | 2008-03-07 | 2009-05-29 | 321d? |  | finish no earlier than 2009-05-29 | C6 | 2568h | 2568h | SAES | Nokia | Rune Lindholm | Rel-8 | Xavier | PCG-21 | CP-39 |  |  |  |
| 446 | 161.18.2 | Test interworking of LTE Terminals with the USIM |  | 331d? | 2008-12-05 A | 2010-03-12 | 60% | 132.4d? | 2008-12-05 | 2010-03-12 | 331d? | 656d | finish no earlier than 2010-03-12 | C6 | 2648h | 1588.8h | SAES-USIM_LTE-Test | Comprion | Udo Willenbrink | Rel-8 | Xavier | PCG-22 | CP-42 |  |  |  |
| 447 | 161.19 | Deleted (covered by 380068): Functions and procedures for SAE to support LCS | milestone | 0d? | 2008-03-03 A | 2008-03-03 A | 100% |  | 2008-03-03 | 2008-03-03 | 0d? |  | finish no earlier than 2008-03-03 | S2 |  |  | SAES-SA-FP_LCS | Nokia Siemens Networks |  | Rel-8 | Maurice |  |  |  | SP-37 |  |
| 448 | 161.20 | Deleted (covered by 380064): SAE aspects of Emergency Calls | milestone | 0d? | 2008-03-03 A | 2008-03-03 A | 100% |  | 2008-03-03 | 2008-03-03 | 0d? |  | start no earlier than 2008-03-03 | S2 |  |  | SAES-SA-EmCall | Nokia Siemens Networks |  | Rel-8 | Maurice |  |  |  | SP-37 |  |
| 449 | 161.21 | Deleted - CT1 aspects of SAES |  | 16.7d? | 2007-09-04 A | 2007-09-27 A | 100% |  | 2007-09-04 | 2007-09-27 | 16.7d? |  | start no earlier than 2007-09-04 | CP,C1 | 133.62h | 133.62h | SAES-St3 |  |  | Rel-8 | Frederic |  |  |  | SP-37 |  |
| 450 | 161.22 | Deleted - CT1 aspects of SAES | milestone | 0d? | 2007-09-04 A | 2007-09-04 A | 100% |  | 2007-09-04 | 2007-09-04 | 0d? |  | start no earlier than 2007-09-04 | C1 |  |  | SAES-St3 |  |  | Rel-8 | Frederic |  |  |  | SP-37 |  |
| 451 | 161.23 | Deleted - Interoperability | milestone | 0d? | 2008-03-14 A | 2008-03-14 A | 100% |  | 2008-03-14 | 2008-03-14 | 0d? |  | start no earlier than 2008-03-14 | C1 |  |  | SAES-St3-interop |  |  | Rel-8 | Frederic |  |  |  | SP-37 |  |
| 452 | 161.24 | Deleted - CT3 aspects of SAES | milestone | 0d? | 2007-09-04 A | 2007-09-04 A | 100% |  | 2007-09-04 | 2007-09-04 | 0d? |  | start no earlier than 2007-09-04 | C3 |  |  | SAES-St3 |  |  | Rel-8 | Gwiho |  |  |  | SP-37 |  |
| 453 | 161.25 | Deleted - CT4 aspects of SAES | milestone | 0d? | 2007-09-04 A | 2007-09-04 A | 100% |  | 2007-09-04 | 2007-09-04 | 0d? |  | start no earlier than 2007-09-04 | C4 |  |  | SAES-St3 |  |  | Rel-8 | Kimmo |  |  |  | SP-37 |  |
| 454 | 161.26 | Deleted - UE to EPC NAS signalling (incl. MBMS and QoS aspects) | milestone | 0d? | 2008-03-14 A | 2008-03-14 A | 100% |  | 2008-03-14 | 2008-03-14 | 0d? |  | start no earlier than 2008-03-14 | C1 |  |  | SAES-St3-sig |  |  | Rel-8 | Frederic |  |  |  | SP-37 |  |
| 455 | 161.27 | Deleted - User and Control plane protocols | milestone | 0d? | 2007-09-21 A | 2007-09-21 A | 100% |  | 2007-09-21 | 2007-09-21 | 0d? |  | start no earlier than 2007-09-21 | C4 |  |  | SAES-St3-prot |  |  | Rel-8 | Kimmo |  |  |  | SP-37 |  |
| 456 | 161.28 | Deleted - Architecture enhancements for non-3GPP accesses | milestone | 0d? | 2007-09-04 A | 2007-09-04 A | 100% |  | 2007-09-04 | 2007-09-04 | 0d? |  | start no earlier than 2007-09-04 | S2 |  |  | SAES-non_3GPP | Motorola | Irfan.Ali@motorola.com | Rel-8 | Maurice |  |  |  | SP-34 |  |
| 457 | 161.29 | Deleted - Stage 2 of architecture for the 3GPP System Architecture Evolution | milestone | 0d? | 2007-10-02 A | 2007-10-02 A | 100% |  | 2007-10-02 | 2007-10-02 | 0d? |  | start no earlier than 2007-10-02 | S2 |  |  | SAES-St2 | Vodafone | chris.pudney@vodafone.com | Rel-8 | Maurice |  |  |  | SP-34 |  |
| 458 | 161.30 | Deleted - SA aspects of System Architecture Evolution |  | 384d? | 2006-04-12 A | 2007-10-01 A | 100% |  | 2006-04-12 | 2007-10-01 | 384d? |  | finish no earlier than 2007-10-02 | S2 | 3072h | 3072h | SAES-SA |  |  | Rel-8 | Maurice |  |  |  | SP-34 |  |
| 459 | 162 | Conformance Test Aspects – Mobility management based on DSMIPv6 (Dual-Stack Mobile IPv6) |  | 196d? | 2009-09-18 A | 2010-06-18 | 20% | 156.8d? | 2009-09-18 | 2010-06-18 | 196d? | 586d | finish no earlier than 2010-06-18 | R5 | 1568h | 313.6h | DSMIPv6_UEConTest | Qualcomm Europe | Lena Chaponniere (lchaponn@qualcomm.com) | Rel-8 | Ingbert | PCG-23 | RP-45 |  |  | RP-091075 |

Notes:
- 424: CP#43 completed. SP#41 Stage 2 completed. SP#38 WID approved (extract from SAE WID SP-070817).
- 425: SP#41 completed. SP#38 WID approved / Text3: 23.216
- 426: CP#43 completed / Text3: 23.009, 24.008, 24.301
- 427: CP#43 completed / Text3: 29.274, 29.277, 23.003, 23.008, 29.280
- 428: SP#40 completed
- 429: SP#40 completed
- 430: CP#43 completed. SP#40 Stage 2 completed.
- 431: SP#40 completed / Text3: 23.272, 23.401
- 432: CP#43 completed / Text3: 24.301, 24.801, 24.007, 24.008, 24.011, 29.018, 29.118 [Mobility Management Entity (MME) – Visitor Location Register (VLR) SGs interface specification]
- 433: CP#42 completed. WID updated CP-080321=>CP-080495=>CP-080791 / Text3: 23.007, 23.008, 29.274, 29.277
- 434: SP#40 completed / Text3: 23.228, 23.221, 23.203
- 435: SP#43 completed
- 436: SP#43 completed / Text3: 32.751, 32.752, 32.753, 32.755
- 437: SP#43 completed / Text3: 32.426
- 438: SP#43 completed / Text3: 32.240/296/251/252/298/299
- 439: CP#43 completed / Text3: 24.801
- 440: CP#41 completed / Text3: 29.804
- 441: CP#41 Work stopped and continued in Normative specifications / Text3: 29.803
- 442: CP#43 completed / Text3: 23.003, 29.303
- 443: CP#43 completed. Triggered by UID_380023 (FS_MAP2Diam) / Text3: 29.305
- 444: CP#44 completed core specification. Testing ongoing
- 445: CP#44 completed (Network Measurement Results collection via USAT are now specified) / Text3: 31.102, 31.111
- 446: CP#45 WID updated CP-080899=>CP-090711. Completion 09/09=>03/10. Testing for UID_390021 (BB: Rel-8 CT6 aspects of SAE) / Text3: 31.121, 31.124
- 447: SP#37 stopped
- 448: SP#37 stopped
- 449: SP#37 stopped
- 450: SP#37 stopped
- 451: SP#37 stopped
- 452: SP#37 stopped
- 453: SP#37 stopped / Text3: 29.803
- 454: SP#37 stopped
- 455: SP#37 stopped
- 456: SP#34 stopped. Replaced by UID_350027 and its children / Text3: 23.402
- 457: SP#34 stopped. Replaced by UIDs 340018 and 340037. (SP#34 report discussion of SP-060917.) / Text3: 23.002, 23.060, 23.107, 23.203, 23.228, 23.234, 23.246, 23.271, 23.279
- 458: SP#34 stopped
- 459: RP#45 testing for CT1's UID_360022 (24.303) under Rel-8 Feature SAES / Text3: 36.508, 36.523-1, 36.523-2, 36.523-3

| ID | WBS | Task | Duration | Start | Finish | Complete | Baseline start | Baseline finish | Baseline duration | Constraint | Resources | Work | Actual work | Text1 | Text4 | Text5 | Text6 | Text7 | Text8 | Text2 | Text9 | Text12 |
| --- | --- | --- | --- | --- | --- | --- | --- | --- | --- | --- | --- | --- | --- | --- | --- | --- | --- | --- | --- | --- | --- | --- |
| 460 | 163 | **IMS Centralized Service Control (ICSRA)** | 395d? | 2007-09-03 A | 2009-03-06 A | 100% | 2007-09-03 | 2009-03-06 | 395d? |  | S1,S2,C1,C3,C4 | 10680h | 10680h | ICSRA | AT&T | Randolph Wohlert (rwohlert@tri.sbc.com) | Rel-8 | SP-37 | Alain |  |  |  |
| 461 | 163.1 | Stage 1 for ICSRA | 138d? | 2007-09-03 A | 2008-03-12 A | 100% | 2007-09-03 | 2008-03-12 | 138d? | finish no earlier than 2007-12-14 | S1 | 1104h | 1104h | ICSRA | AT&T | Randolph Wohlert (rwohlert@tri.sbc.com) | Rel-8 | SP-38 | Alain | PCG-21 |  |  |
| 462 | 163.2 | Stage 2 for ICSRA | 125d? | 2007-12-14 A | 2008-06-05 A | 100% | 2007-12-14 | 2008-06-05 | 125d? | start no earlier than 2007-12-14 | S2 | 1000h | 1000h | ICSRA-St2 | Alcatel-Lucent |  | Rel-8 | SP-38 | Maurice | PCG-21 |  |  |
| 463 | 163.3 | **Stage 3 for ICSRA – Protocol, Addressing, Subscriber Data** | 201d? | 2008-05-30 A | 2009-03-06 A | 100% | 2008-05-30 | 2009-03-06 | 201d? |  | C1,C3,C4 | 6520h | 6520h | ICSRA | Ericsson | Sean Schneyer | Rel-8 |  |  |  |  |  |
| 464 | 163.3.1 | CT1 aspects - Stage 3 for ICSRA | 201d? | 2008-05-30 A | 2009-03-06 A | 100% | 2008-05-30 | 2009-03-06 | 201d? | finish no earlier than 2009-03-06 | C1 | 1608h | 1608h | ICSRA | Ericsson | Sean Schneyer | Rel-8 | CP-40 | Frederic | PCG-21 |  |  |
| 465 | 163.3.2 | CT3 aspects - Stage 3 for ICSRA | 201d? | 2008-05-30 A | 2009-03-06 A | 100% | 2008-05-30 | 2009-03-06 | 201d? | finish no earlier than 2009-03-06 | C3 | 1608h | 1608h | ICSRA | Mavenir | Brett Wallis | Rel-8 | CP-40 | Gwiho | PCG-21 |  |  |
| 466 | 163.3.3 | CT4 aspects - Stage 3 for ICSRA | 136d? | 2008-05-30 A | 2008-12-05 A | 100% | 2008-05-30 | 2008-12-05 | 136d? | start no earlier than 2008-05-30 | C4 | 1088h | 1088h | ICSRA | Ericsson | Sean Schneyer | Rel-8 | CP-40 | Kimmo | PCG-21 |  |  |
| 467 | 163.3.4 | Deleted - Stage 3 for ICSRA – I1 interface | 76d? | 2008-05-30 A | 2008-09-12 A | 100% | 2008-05-30 | 2008-09-12 | 76d? | finish no earlier than 2008-09-12 | C1 | 608h | 608h | ICSRA | Huawei | xupeili@huawei.com | Rel-8 | CP-40 | Frederic | PCG-21 | PCG-21 | CP-41 |
| 468 | 164 | **IMS Multimedia Telephony and Supplementary Services** | 487d? | 2007-05-02 A | 2009-03-12 A | 100% | 2007-05-02 | 2009-03-12 | 487d? |  | S1,S5,C1,C3,C4 | 46006.4h | 46006.4h | IMSTSS |  |  | Rel-8 | SP-37 | Alain |  |  |  |
| 469 | 164.1 | **General aspects of IMS Sup Services** | 395d? | 2007-09-03 A | 2009-03-06 A | 100% | 2007-09-03 | 2009-03-06 | 395d? |  | S1,C1,C3,C4 | 9752h | 9752h | IMSSS-Gal | Ericsson | Susana Sabater | Rel-8 | SP-37 | Alain |  |  |  |
| 470 | 164.1.1 | Service and Capability for Core IMS - inclusion of TISPAN requirements | 75d? | 2007-09-03 A | 2007-12-14 A | 100% | 2007-09-03 | 2007-12-14 | 75d? | finish no earlier than 2007-12-14 | S1 | 600h | 600h | TISCAPR8 | Ericsson | Susana Sabater | Rel-8 | SP-37 | Alain |  |  |  |
| 471 | 164.1.2 | Documentation of TISPAN R1 and R2 in CT1 | 208d? | 2007-11-28 A | 2008-09-12 A | 100% | 2007-11-28 | 2008-09-12 | 208d? | finish no earlier than 2008-09-12 | C1 | 1664h | 1664h | REDOC_TIS-C1 | Nokia Siemens Networks | peter.leis@nsn.com | Rel-8 | CP-38 | Frederic | PCG-21 |  |  |
| 472 | 164.1.3 | Documentation of TISPAN R1 and R2 in CT3 | 333d? | 2007-11-28 A | 2009-03-06 A | 100% | 2007-11-28 | 2009-03-06 | 333d? | finish no earlier than 2009-03-06 | C3 | 2664h | 2664h | REDOC_TIS-C3 | Nokia Siemens Networks | peter.leis@nsn.com | Rel-8 | CP-38 | Gwiho | PCG-21 |  |  |
| 473 | 164.1.4 | Documentation of TISPAN R1 and R2 in CT4 | 208d? | 2007-11-28 A | 2008-09-12 A | 100% | 2007-11-28 | 2008-09-12 | 208d? | finish no earlier than 2008-09-12 | C4 | 1664h | 1664h | REDOC_TIS-C4 | Nokia Siemens Networks | peter.leis@nsn.com | Rel-8 | CP-38 | Kimmo | PCG-21 |  |  |
| 474 | 164.2 | **IMS Multimedia Telephony Service** | 394d? | 2007-09-10 A | 2009-03-12 A | 100% | 2007-09-10 | 2009-03-12 | 394d? |  | S1,S5 | 5096h | 5096h | IMS-MMTel |  |  | Rel-8 | SP-37 | Alain |  |  |  |
| 475 | 164.2.1 | Merging TISPAN MMTel [requirements] for Common IMS | 65d? | 2007-09-10 A | 2007-12-07 A | 100% | 2007-09-10 | 2007-12-07 | 65d? | finish no earlier than 2007-12-07 | S1 | 520h | 520h | TMMTEL | Nokia Siemens Networks |  | Rel-8 | SP-37 | Alain |  |  |  |
| 476 | 164.2.2 | Multimedia Telephony Service and Supplementary Services (MMTel) offline Charging | 309d? | 2008-01-07 A | 2009-03-12 A | 100% | 2008-01-07 | 2009-03-12 | 309d? | finish no earlier than 2009-03-12 | S5 | 2472h | 2472h | MMTel-CH | Alcatel-Lucent | GARDELLA, Maryse | Rel-8 | SP-38 | Dionisio | PCG-21 |  |  |
| 477 | 164.3 | **Call Completion on Busy Subscriber (CCBS)/Call Completion on Non-Reachable (CCNR) on IMS** | 483d? | 2007-05-02 A | 2009-03-06 A | 100% | 2007-05-02 | 2009-03-06 | 483d? |  | C1,C3 | 11072h | 11072h | CCBS_CCNR | Deutsche Telekom | martin.huelsemann@telekom.de | Rel-8 | SP-38 | Frederic | PCG-21 |  |  |
| 478 | 164.3.1 | Stage 3 CCBS_CCNR | 483d? | 2007-05-02 A | 2009-03-06 A | 100% | 2007-05-02 | 2009-03-06 | 483d? | finish no earlier than 2009-03-06 | C1 | 3864h | 3864h | CCBS_CCNR | Deutsche Telekom | martin.huelsemann@telekom.de | Rel-8 | CP-38 | Frederic | PCG-21 |  |  |
| 479 | 164.3.2 | Stage 3 CCBS_CCNR | 418d? | 2007-05-02 A | 2008-12-05 A | 100% | 2007-05-02 | 2008-12-05 | 418d? | finish no earlier than 2008-12-05 | C3 | 3344h | 3344h | CCBS_CCNR | Deutsche Telekom | martin.huelsemann@telekom.de | Rel-8 | CP-38 | Gwiho | PCG-21 |  |  |
| 480 | 164.4 | **Flexible Alerting** | 288d? | 2008-01-30 A | 2009-03-06 A | 100% | 2008-01-30 | 2009-03-06 | 288d? |  | S1,C1 | 5278.4h | 5278.4h | FA | Nortel | milanpa@nortel.com | Rel-8 | SP-39 | Alain | PCG-21 |  |  |
| 481 | 164.4.1 | Stage 1 FA | 92d? | 2008-01-30 A | 2008-06-05 A | 100% | 2008-01-30 | 2008-06-05 | 92d? |  | S1 | 670.4h | 670.4h | FA | Telecom Italia |  | Rel-8 | SP-39 | Alain | PCG-21 |  |  |
| 482 | 164.4.2 | Stage 3 FA | 288d? | 2008-01-30 A | 2009-03-06 A | 100% | 2008-01-30 | 2009-03-06 | 288d? | finish no earlier than 2009-03-06 | C1 | 2304h | 2304h | FA | Nortel | milanpa@nortel.com | Rel-8 | CP-39 | Frederic | PCG-21 |  |  |
| 483 | 164.5 | **Communication Wait on IMS** | 331d? | 2007-11-30 A | 2009-03-06 A | 100% | 2007-11-30 | 2009-03-06 | 331d? |  | C1,C3 | 7416h | 7416h | CW_IMS | Deutsche Telekom | martin.huelsemann@telekom.de | Rel-8 | SP-38 | Frederic | PCG-21 |  |  |
| 484 | 164.5.1 | Stage 3 CW-IMS | 331d? | 2007-11-30 A | 2009-03-06 A | 100% | 2007-11-30 | 2009-03-06 | 331d? | finish no earlier than 2009-03-06 | C1 | 2648h | 2648h | CW_IMS | Deutsche Telekom | martin.huelsemann@telekom.de | Rel-8 | CP-38 | Frederic | PCG-21 |  |  |
| 485 | 164.5.2 | Stage 3 CW-IMS | 265d? | 2007-11-30 A | 2008-12-04 A | 100% | 2007-11-30 | 2008-12-04 | 265d? | finish no earlier than 2008-12-05 | C3 | 2120h | 2120h | CW_IMS | Deutsche Telekom | martin.huelsemann@telekom.de | Rel-8 | CP-38 | Gwiho | PCG-21 |  |  |
| 486 | 164.6 | Advice of Charge (AoC) support in IMS Charging | 309d? | 2008-01-07 A | 2009-03-12 A | 100% | 2008-01-07 | 2009-03-12 | 309d? | finish no earlier than 2009-03-12 | S5 | 2472h | 2472h | IMSTSS | Nokia Siemens Networks | GÖRMER, Gerald | Rel-8 | SP-38 | Dionisio | PCG-21 |  |  |
| 487 | 164.7 | Add Interconnection Border Control Function (IBCF) to IMS Charging | 128d? | 2007-09-17 A | 2008-03-12 A | 100% | 2007-09-17 | 2008-03-12 | 128d? | finish no earlier than 2008-03-12 | S5 | 1024h | 1024h | IMSTSS | Alcatel-Lucent | GARDELLA, Maryse | Rel-8 | SP-37 | Dionisio |  |  |  |

Notes:
- 460: CP#46 WID updated CP-080492=>CP-091046. Approved new TS 24.286. SP#40 SA1/2 completed
- 461: SP#38 WID approved. SP#39 completed / Text3: 22.101
- 462: SP#38 WID approved. SP#40 completed / Text3: 23.292, 23.206
- 463: CP#46 WID updated CP-080492=>CP-091046. Approved new TS 24.286
- 464: CP#46 WID updated CP-080492=>CP-091046. Approved new TS 24.286 / Text3: 24.229, new (24.292, 24.286)
- 465: CP#43 completed / Text3: new 29.292
- 466: CP#42 completed / Text3: 23.003, 29.232, 23.018, 29.002
- 467: 23/07/08 Line created at CT1 Zagreb request. CP#41 WID updated CP-080319=>CP-080492. CP#41 work stopped / Text3: 24.293
- 468: SP#43 completed
- 469: CP#43 completed
- 470: SP#39 completed / Text3: 22.228, 22.115, 22.101
- 471: CP#41 completed / Text3: 24.141, 24.147, 24.173, 24.229, 24.247, 24.341, 24.604, 24.605, 24.606, 24.607, 24.608, 24.610, 24.611, 24.616, 24.623, 24.628, 24.629, 24.647, 24.654
- 472: CP#43 completed. CP#46 withdrawn 29.612 from Rel-9 onwards / Text3: 29.162, 29.163, 29.658
- 473: CP#41 completed / Text3: 29.228, 29.229
- 474: SP#43 completed
- 475: SP#38 completed / Text3: 22.173
- 476: CP#43 completed / Text3: 32.275, 32.298/299
- 477: CP#43 completed
- 478: CP#43 completed / Text3: 24.642, 24.229, 24.173
- 479: CP#42 completed / Text3: 29.163
- 480: CP#43 completed
- 481: SP#40 completed / Text3: 22.173
- 482: CP#43 completed / Text3: 24.239, 24.173
- 483: CP#43 completed
- 484: CP#43 completed / Text3: 24.615, 24.229, 24.173
- 485: CP#42 completed / Text3: 29.163
- 486: SP#43 completed / Text3: 32.280, 32.240/260/296/298/299
- 487: SP#39 completed / Text3: 32.260, 32.298

| ID | WBS | Task | Duration | Start | Finish | Complete | Remaining | Baseline start | Baseline finish | Baseline duration | Total slack | Constraint | Resources | Work | Actual work | Text1 | Text2 | Text4 | Text5 | Text6 | Text7 | Text8 |
| --- | --- | --- | --- | --- | --- | --- | --- | --- | --- | --- | --- | --- | --- | --- | --- | --- | --- | --- | --- | --- | --- | --- |
| 488 | 165 | **3GPP2 Input to Common IMS** | 200d? | 2008-03-07 A | 2008-12-11 A | 100% |  | 2008-03-07 | 2008-12-11 | 200d? |  |  | S1,S2,S3,C1,C3,C4 | 8653.2h | 8653.2h | CIMS_3GPP2 | PCG-21 | Nortel | Amar Deol (deola@nortelnetworks.com) | Rel-8 | SP-39 | Alain |
| 489 | 165.1 | Stage 1 CIMS_3GPP2 (SA1) | 30.65d? | 2008-03-12 A | 2008-06-05 A | 100% |  | 2008-03-12 | 2008-06-05 | 30.65d? |  | finish no earlier than 2008-06-12 | S1 | 245.2h | 245.2h | CIMS_3GPP2 | PCG-21 | Nortel | Amar Deol (deola@nortelnetworks.com) | Rel-8 | SP-39 | Alain |
| 490 | 165.2 | Stage 2 CIMS_3GPP2 (SA2) | 62d? | 2008-03-12 A | 2008-06-05 A | 100% |  | 2008-03-12 | 2008-06-05 | 62d? |  | finish no earlier than 2008-09-11 | S2 | 496h | 496h | IMS_Common | PCG-21 | Nortel | Amar Deol (deola@nortelnetworks.com) | Rel-8 | SP-39 | Maurice |
| 491 | 165.3 | Security CIMS_3GPP2 (SA3) | 197d? | 2008-03-12 A | 2008-12-11 A | 100% |  | 2008-03-12 | 2008-12-11 | 197d? |  | finish no earlier than 2008-12-11 | S3 | 1576h | 1576h | IMS_Common | PCG-21 | Nortel | Amar Deol (deola@nortelnetworks.com) | Rel-8 | SP-39 | Dionisio |
| 492 | 165.4 | Stage 3 CIMS_3GPP2 (CT1) | 196d? | 2008-03-07 A | 2008-12-05 A | 100% |  | 2008-03-07 | 2008-12-05 | 196d? |  | finish no earlier than 2008-12-11 | C1 | 1568h | 1568h | REDOC_3GPP2 | PCG-21 | Alcatel-Lucent | orsic@alcatel-lucent.com | Rel-8 | CP-39 | Frederic |
| 493 | 165.5 | Stage 3 CIMS_3GPP2 (CT3) | 196d? | 2008-03-07 A | 2008-12-05 A | 100% |  | 2008-03-07 | 2008-12-05 | 196d? |  | finish no earlier than 2008-12-05 | C3 | 1568h | 1568h | REDOC_3GPP2 | PCG-21 | Alcatel-Lucent | orsic@alcatel-lucent.com | Rel-8 | CP-39 | Gwiho |
| 494 | 165.6 | Stage 3 CIMS_3GPP2 (CT4) | 200d? | 2008-03-07 A | 2008-12-11 A | 100% |  | 2008-03-07 | 2008-12-11 | 200d? |  | finish no earlier than 2008-12-11 | C4 | 1600h | 1600h | REDOC_3GPP2 | PCG-21 | Alcatel-Lucent | orsic@alcatel-lucent.com | Rel-8 | CP-39 | Kimmo |
| 495 | 166 | **IMS Enhancements for support of Packet Cable access** | 388d? | 2006-12-06 A | 2008-05-30 A | 100% |  | 2006-12-06 | 2008-05-30 | 388d? |  |  | S2,S3,C1,C3,C4 | 27448h | 27448h | PktCbl |  | Cablelabs | Bernie McKibben | Rel-8 |  | Maurice |
| 496 | 166.1 | **IMS Enhancements for Cable Client Types and Deployment Models** | 345d? | 2007-02-05 A | 2008-05-30 A | 100% |  | 2007-02-05 | 2008-05-30 | 345d? |  |  | S2,C1 | 6992h | 6992h | PktCbl-Deploy |  | Cablelabs | Bernie McKibben | Rel-8 |  | Maurice |
| 497 | 166.1.1 | Architecture aspects of PktCbl-Deploy | 219d? | 2007-02-05 A | 2007-12-06 A | 100% |  | 2007-02-05 | 2007-12-06 | 219d? |  | finish no earlier than 2007-12-03 | S2 | 1752h | 1752h | PktCbl-Deploy |  | Cablelabs | Bernie McKibben | Rel-8 |  | Maurice |
| 498 | 166.1.2 | CT1 aspects of PktCbl-Deploy | 310d? | 2007-03-26 A | 2008-05-30 A | 100% |  | 2007-03-26 | 2008-05-30 | 310d? |  | finish no earlier than 2008-06-15 | C1 | 2480h | 2480h | PktCbl-Deploy |  | Cablelabs | D.Hancock@ CableLabs.com | Rel-8 |  | Frederic |
| 499 | 166.2 | **IMS Inter-working aspects in Support of Cable Regulatory requirements** | 290d? | 2007-02-05 A | 2008-03-14 A | 100% |  | 2007-02-05 | 2008-03-14 | 290d? |  |  | S2,C1,C3 | 5640h | 5640h | PktCbl-Intw |  | Cablelabs | B.McKibben@CableLabs.com | Rel-8 |  | Maurice |
| 500 | 166.2.1 | Architecture PktCbl-Interwork | 160d? | 2007-02-05 A | 2007-09-14 A | 100% |  | 2007-02-05 | 2007-09-14 | 160d? |  | start no earlier than 2007-02-05 | S2 | 1280h | 1280h | PktCbl-Intw |  | Cablelabs | B.McKibben@CableLabs.com | Rel-8 |  | Maurice |
| 501 | 166.2.2 | CT1,CT3 PktCbl-Interwork | 255d? | 2007-03-26 A | 2008-03-14 A | 100% |  | 2007-03-26 | 2008-03-14 | 255d? |  | finish no earlier than 2008-03-15 | C1,C3 | 2040h | 2040h | PktCbl-Intw |  | Cablelabs | D.Hancock@ CableLabs.com | Rel-8 |  | Frederic |
| 502 | 166.3 | **IMS Enhancements for Security Requirements in Support of Cable Deployments** | 388d? | 2006-12-06 A | 2008-05-30 A | 100% |  | 2006-12-06 | 2008-05-30 | 388d? |  |  | S3,C1,C3,C4 | 11712h | 11712h | PktCbl-Sec |  | Cablelabs | s.dotson@cablelabs.com | Rel-8 |  | Dionisio |
| 503 | 166.3.1 | SA3 Aspects of PktCbl-Sec | 331d? | 2006-12-06 A | 2008-03-12 A | 100% |  | 2006-12-06 | 2008-03-12 | 331d? |  | finish no earlier than 2007-12-20 | S3 | 2648h | 2648h | PktCbl-Sec |  | Cablelabs | s.dotson@cablelabs.com | Rel-8 |  | Dionisio |
| 504 | 166.3.2 | CT1 Aspects of PktCbl-Sec | 310d? | 2007-03-26 A | 2008-05-30 A | 100% |  | 2007-03-26 | 2008-05-30 | 310d? |  | finish no earlier than 2008-06-06 | C1 | 2480h | 2480h | PktCbl-Sec |  | Cablelabs | D.Hancock@ CableLabs.com | Rel-8 |  | Frederic |
| 505 | 166.3.3 | CT3 Aspects of PktCbl-Sec | 180d? | 2007-03-26 A | 2007-11-30 A | 100% |  | 2007-03-26 | 2007-11-30 | 180d? |  | finish no earlier than 2008-03-15 | C3 | 1440h | 1440h | PktCbl-Intw | PCG-21 | Cablelabs | D.Hancock@ CableLabs.com | Rel-8 | CP-38 | Gwiho |
| 506 | 166.3.4 | CT4 Aspects of PktCbl-Sec | 255d? | 2007-03-26 A | 2008-03-14 A | 100% |  | 2007-03-26 | 2008-03-14 | 255d? |  | finish no earlier than 2008-03-14 | C4 | 2040h | 2040h | PktCbl-Sec |  | Cablelabs | D.Hancock@ CableLabs.com | Rel-8 |  | Kimmo |
| 507 | 167 | **IMS System enhancements for corporate network access** | 642d? | 2007-06-22 A | 2009-12-04 | 99% | 5.86d? | 2007-06-22 | 2009-12-04 | 642d? | 726d |  | S2,S1,C1,C4 | 13138.6h | 13018.8h | IMS_Corp |  | Orange | Delphin Barankanira | Rel-8 |  | Maurice |
| 508 | 167.1 | SA1 aspects of IMS_Corp | 23.6d? | 2008-03-12 A | 2008-06-05 A | 100% |  | 2008-03-12 | 2008-06-05 | 23.6d? |  | finish no earlier than 2008-06-05 | S1 | 188.8h | 188.8h | IMS_Corp | PCG-21 | Telecom Italia |  | Rel-8 | SP-39 | Alain |
| 509 | 167.2 | SA2 aspects of IMS_Corp | 325d? | 2007-06-22 A | 2008-09-18 A | 100% |  | 2007-06-22 | 2008-09-18 | 325d? |  | finish no earlier than 2008-12-25 | S2 | 2600h | 2600h | IMS_Corp |  | Orange | Delphin Barankanira | Rel-8 |  | Maurice |
| 510 | 167.3 | CT1 aspects of IMS_Corp | 457d? | 2008-03-07 A | 2009-12-04 | 98% | 9.14d? | 2008-03-07 | 2009-12-04 | 457d? | 726d | finish no earlier than 2009-12-04 | C1 | 3645.77h | 3572.86h | IMS_Corp | PCG-21 | Alcatel-Lucent | Keith Drage (drage@alcatel-lucent.com) | Rel-8 | CP-39 | Frederic |
| 511 | 167.4 | CT4 aspects of IMS_Corp | 196d? | 2008-02-26 A | 2008-12-05 A | 100% |  | 2008-02-26 | 2008-12-05 | 196d? |  | finish no earlier than 2008-12-11 | C4 | 1568h | 1568h | IMS_Corp | PCG-21 | Alcatel-Lucent | Keith Drage (drage@alcatel-lucent.com) | Rel-8 | CP-39 | Kimmo |

Notes:
- 488: TSG#42 completed
- 489: SP#40 completed / Text3: 22.228, 22.173, 22.101, 22.153
- 490: SP#40 completed / Text3: 23.002, 23.141, 23.203, 23.167, 23.228
- 491: SP#42 completed [issues addressed under UID_370078 (IMS-Sec)] / Text3: 33.141, 33.203, 33.210
- 492: CP#42 completed. WID updated CP-080218=>CP-080494=>CP-080795 / Text3: 23.218, 24.141, 24.147, 24.173, 24.229, 24.238, 24.247, 24.604, 24.605, 24.606, 24.607, 24.608, 24.610, 24.611, 24.629, 24.930
- 493: CP#42 completed. WID updated CP-080218=>CP-080494=>CP-080795 / Text3: 29.163, 29.212, 29.213, 29.214
- 494: CP#42 completed. WID updated CP-080218=>CP-080494=>CP-080795 / Text3: 29.228, 29.229, 29.328, 29.329
- 495: CP#40 completed
- 496: CP#40 completed
- 497: SP#38 completed / Text3: 23.228
- 498: CP#40 completed
- 499: CP#39 completed
- 500: SP#37 completed / Text3: 23.228
- 501: CP#39 completed / Text3: 24.229
- 502: CP#40 completed
- 503: SP#39 completed / Text3: 33.203, 33.210, 33.220
- 504: CP#40 completed / Text3: 24.229
- 505: CP#38 completed / Text3: 29.163
- 506: CP#39 completed / Text3: 29.228, 29.229, 23.008
- 507: CP#45 still some unresolved issue. SP#41 no Stage 2 impacts identified by Joint Workshop
- 508: SP#40 completed
- 509: SP#41 completed / Text3: 23.228
- 510: CP#45 still some unresolved issue / Text3: 24.229, 24.503
- 511: CP#42 completed / Text3: 29.228, 29.229, 23.003, 23.008, 29.433

| ID | WBS | Task | Duration | Start | Finish | Complete | Baseline start | Baseline finish | Baseline duration | Constraint | Resources | Work | Actual work | Text1 | Text2 | Text7 | Text8 | Text4 | Text5 | Text6 |
| --- | --- | --- | --- | --- | --- | --- | --- | --- | --- | --- | --- | --- | --- | --- | --- | --- | --- | --- | --- | --- |
| 512 | 168 | **Maintenance of TISPAN documentation** | 244d? | 2007-07-02 A | 2008-06-05 A | 100% | 2007-07-02 | 2008-06-05 | 244d? |  | S2,C1,C3,C4 | 5984h | 5984h | MAINTISP | PCG-21 | SP-38 | Maurice |  |  |  |
| 513 | 168.1 | Maintenance of TISPAN R1 | 86d? | 2007-11-09 A | 2008-03-07 A | 100% | 2007-11-09 | 2008-03-07 | 86d? | start no earlier than 2007-11-09 | C1,C3,C4 | 688h | 688h | MAINT_R1 | PCG-21 | CP-38 | Frederic | Alcatel-Lucent | Keith Drage (drage@alcatel-lucent.com) | Rel-7 |
| 514 | 168.2 | Maintenance of TISPAN R2 | 86d? | 2007-11-09 A | 2008-03-07 A | 100% | 2007-11-09 | 2008-03-07 | 86d? | start no earlier than 2007-11-09 | C1,C3,C4 | 688h | 688h | MAINT_R2 | PCG-21 | CP-38 | Frederic | Alcatel-Lucent | Keith Drage (drage@alcatel-lucent.com) | Rel-8 |
| 515 | 168.3 | Documentation of TISPAN NGN R1 and R2 in 3GPP SA2 | 104d? | 2008-01-14 A | 2008-06-05 A | 100% | 2008-01-14 | 2008-06-05 | 104d? | finish no earlier than 2008-06-20 | S2 | 832h | 832h | IMS_Comm_Doc | PCG-21 | SP-38 | Maurice | Nokia Siemens Networks | jozsef.varga@nsn.com | Rel-8 |
| 516 | 168.4 | Maintenance of TISPAN release 1 common IMS | 114d? | 2007-07-02 A | 2007-12-06 A | 100% | 2007-07-02 | 2007-12-06 | 114d? | finish no earlier than 2007-12-06 | S2,S1 | 912h | 912h | IMS_Comm_Mtce7 | PCG-21 | SP-38 | Maurice | BT, Ericsson | Dick Knight, Raymond Forbes | Rel-7 |
| 517 | 168.5 | Maintenance of TISPAN release 2 common IMS | 114d? | 2007-07-02 A | 2007-12-06 A | 100% | 2007-07-02 | 2007-12-06 | 114d? | finish no earlier than 2007-12-06 | S2 | 912h | 912h | IMS_Comm_Mtce8 | PCG-21 | SP-38 | Maurice | Telecom Italia | antonio.ascolese@telecomitalia.it | Rel-8 |
| 518 | 169 | **IMS Service Continuity** | 318d? | 2008-03-12 A | 2009-05-29 A | 100% | 2008-03-12 | 2009-05-29 | 318d? |  | S2,S1,C1 | 5624h | 5624h | IMS-Cont | PCG-21 | SP-39 | Maurice | LG Electronics | JaeSeung SONG (anthonys@lge.com) | Rel-8 |
| 519 | 169.1 | Stage 1 IMS Service Continuity | 62d? | 2008-03-12 A | 2008-06-05 A | 100% | 2008-03-12 | 2008-06-05 | 62d? | start no earlier than 2008-03-12 | S1 | 496h | 496h | IMS-Cont | PCG-21 | SP-39 | Alain | LG Electronics | JaeSeung SONG (anthonys@lge.com) | Rel-8 |
| 520 | 169.2 | Stage 2 IMS Service Continuity | 62d? | 2008-03-12 A | 2008-06-05 A | 100% | 2008-03-12 | 2008-06-05 | 62d? | finish no earlier than 2008-06-05 | S2 | 496h | 496h | IMS-Cont | PCG-21 | SP-39 | Maurice | LG Electronics | JaeSeung SONG (anthonys@lge.com) | Rel-8 |
| 521 | 169.3 | Stage 3 IMS Service Continuity | 261d? | 2008-05-30 A | 2009-05-29 A | 100% | 2008-05-30 | 2009-05-29 | 261d? | finish no earlier than 2009-05-29 | C1 | 2088h | 2088h | IMS-Cont | PCG-21 | CP-40 | Frederic | Huawei | Lili Yang (kadyyang@huawei.com) | Rel-8 |
| 522 | 170 | **Security Enhancements for IMS** | 643.3d? | 2006-09-19 A | 2009-03-06 A | 100% | 2006-09-19 | 2009-03-06 | 643.3d? |  | S3,C1,C4 | 18624h | 18624h | IMS-Sec |  | SP-37 | Dionisio | Ericsson | Bengt.Sahlin@ericsson.com | Rel-8 |
| 523 | 170.1 | Stage 2 for IMS-Sec | 466d? | 2007-03-01 A | 2008-12-11 A | 100% | 2007-03-01 | 2008-12-11 | 466d? | finish no earlier than 2008-12-11 | S3 | 3728h | 3728h | IMS-Sec |  |  | Dionisio | Ericsson | Bengt.Sahlin@ericsson.com | Rel-8 |
| 524 | 170.2 | CT1 part of Stage 3 for IMS-Sec | 392d? | 2006-09-19 A | 2008-12-05 A | 100% | 2006-09-19 | 2008-12-05 | 392d? | finish no earlier than 2008-12-05 | C1 | 3136h | 3136h | IMS-Sec | PCG-21 | CP-39 | Frederic | Ericsson |  | Rel-8 |
| 525 | 170.3 | CT4 part of Stage 3 for IMS-Sec | 457d? | 2007-06-07 A | 2009-03-06 A | 100% | 2007-06-07 | 2009-03-06 | 457d? | finish no earlier than 2009-03-06 | C4 | 3656h | 3656h | IMS-Sec | PCG-21 | CP-39 | Kimmo | Ericsson |  | Rel-8 |
| 526 | 170.4 | CT1 part of NASS Bundled Authentication | 343d? | 2007-11-14 A | 2009-03-06 A | 100% | 2007-11-14 | 2009-03-06 | 343d? | finish no earlier than 2009-03-06 | C1 | 2744h | 2744h | NBA | PCG-21 | CP-39 | Frederic | Alcatel-Lucent | Keith Drage (drage@alcatel-lucent.com) | Rel-8 |
| 527 | 170.5 | CT4 part of NASS Bundled Authentication | 143d? | 2007-11-14 A | 2008-05-30 A | 100% | 2007-11-14 | 2008-05-30 | 143d? | start no earlier than 2007-11-14 | C4 | 1144h | 1144h | NBA-CT4 | PCG-21 | CP-39 | Kimmo | Alcatel-Lucent |  | Rel-8 |
| 528 | 171 | IMS initiated and controlled PSS and MBMS User Service | 262d? | 2008-03-12 A | 2009-03-12 A | 100% | 2008-03-12 | 2009-03-12 | 262d? | finish no earlier than 2009-03-12 | S4,S3 | 1003.2h | 1003.2h | IMS_PSS_MBMS_US |  |  | Paolo | FT, Ericsson | olle.franceschi@ericsson.com | Rel-8 |
| 529 | 172 | **Multimedia interworking between IMS and CS networks** | 836d? | 2005-09-23 A | 2008-12-05 A | 100% | 2005-09-23 | 2008-12-05 | 836d? |  | C3,C4 | 16112h | 16112h | MIW-IMS |  |  | Gwiho | Vodafone | nico.gabriele@vodafone.com | Rel-8 |
| 530 | 172.1 | Note: Stages 1 and 2 defined in earlier Release | 49d? | 2005-09-23 A | 2005-11-30 A | 100% | 2005-09-23 | 2005-11-30 | 49d? | start no earlier than 2005-09-23 | S2 | 392h | 392h | MIW-IMS |  |  | Maurice | Vodafone | nico.gabriele@vodafone.com | Rel-8 |
| 531 | 172.2 | Stage 3 of MW-IMS | 571d? | 2005-09-23 A | 2007-11-30 A | 100% | 2005-09-23 | 2007-11-30 | 571d? | finish no earlier than 2007-09-14 | C3 | 4568h | 4568h | MIW-IMS-St3 |  |  | Gwiho | Vodafone | nico.gabriele@vodafone.com | Rel-8 |
| 532 | 172.3 | Stage 3 for MW-IMS, MONA extension | 285d? | 2007-11-05 A | 2008-12-05 A | 100% | 2007-11-05 | 2008-12-05 | 285d? | finish no earlier than 2008-12-05 | C3 | 2280h | 2280h | MIW-IMS | PCG-21 | CP-38 | Gwiho | Vodafone | Christer.Holmberg@ericsson.com | Rel-8 |
| 533 | 172.4 | Mn interface (MGCF – IM MGW) | 273d? | 2007-11-21 A | 2008-12-05 A | 100% | 2007-11-21 | 2008-12-05 | 273d? | finish no earlier than 2008-12-19 | C4 | 2184h | 2184h | MIW-IMS | PCG-21 | CP-38 | Kimmo | Vodafone | Christer.Holmberg@ericsson.com | Rel-8 |
| 534 | 173 | IMS Stage 3 IETF Protocol Alignment | 446d? | 2007-06-22 A | 2009-03-06 A | 100% | 2007-06-22 | 2009-03-06 | 446d? | finish no earlier than 2009-03-06 | C1 | 3568h | 3568h | IMSProtoc2 |  |  | Frederic | Alcatel-Lucent | Keith Drage (drage@alcatel-lucent.com) | Rel-8 |
| 535 | 174 | **Interworking between User-to-User Signalling (UUS) and SIP** | 335d? | 2007-11-30 A | 2009-03-12 A | 100% | 2007-11-30 | 2009-03-12 | 335d? |  | C1,C3 | 7488h | 7488h | UUSIW | PCG-21 | CP-38 | Kimmo | Huawei | Lili Yang (kadyyang@huawei.com) | Rel-8 |
| 536 | 174.1 | Stage 3 MGCF UUSIW | 266d? | 2007-11-30 A | 2008-12-05 A | 100% | 2007-11-30 | 2008-12-05 | 266d? | finish no earlier than 2008-12-05 | C1 | 2128h | 2128h | UUSIW | PCG-21 | CP-38 | Frederic | Huawei | Lili Yang (kadyyang@huawei.com) | Rel-8 |
| 537 | 174.2 | Stage 3 MGCF UUSIW | 335d? | 2007-11-30 A | 2009-03-12 A | 100% | 2007-11-30 | 2009-03-12 | 335d? | finish no earlier than 2009-03-12 | C3 | 2680h | 2680h | UUSIW | PCG-21 | CP-38 | Gwiho | Huawei | Lili Yang (kadyyang@huawei.com) | Rel-8 |

Notes:
- 512: SP#40 completed
- 513: CP#39 completed / Text3: 24.404, 24.405, 24.406, 24.407, 24.408, 24.410, 24.411, 24.416, 29.421, 24.423, 24.428, 24.429, 29.433, 24.441, 24.403, 29.427, 24.430, 29.412
- 514: CP#39 completed. CP#46 withdrawn 29.624 from Rel-9 onwards / Text3: 24.406, 24.407, 24.410, 24.411, 24.423, 24.430, 24.447, 24.451, 24.454, 24.503, 24.505, 24.508, 24.516, 24.528, 24.529, 29.412, 29.421, 29.433, 29.458, 29.527, 29.624
- 515: WID approved SP#38. per OPs & ETSI GA 39. This is a joint effort of SA WG2 and TISPAN WG2. SP#40 completed / Text3: 23.228, 23.204, 23.167
- 516: SP#38 WID and TSs approved. SP#40 WID updated SP-070915=>SP-080315. SP#41 WID updated SP-080315=>SP-080501 / Text3: 22.273, 22.401, 23.406, 23.417, 23.508, 23.509, 23.511, 22.401, 22.173
- 517: SP#38 approved WID and TSs / Text3: 23.506, 23.507,23.517, 23.521
- 518: CP#44 completed. SP#40 Stage 1/2 completed
- 519: SP#40 completed
- 520: SP#40 completed / Text3: 23.237, 23.292
- 521: CP#44 completed / Text3: 24.237, 24.229, 24.216
- 522: CP#43 completed. SP#36 WID approved
- 523: SP#42 completed. SP#39 SA3 to remove Stage 3 from 33.178-100 for CTx work. SP#40 withdrawn 33.178-100. / Text3: 33.203, 33.141, 33.978, 33.803
- 524: CP#42 completed. SP#39 SA3 to remove Stage 3 from 33.178-100 for CT1 work
- 525: CP#43 completed
- 526: CP#43 completed / Text3: 24.229
- 527: CP#40 completed / Text3: 29.229, 29.228, 23.008
- 528: SP#43 completed. SP#39 WID approved / Text3: 26.237, 26.234, 26.346, 33.246
- 529: CP#42 completed
- 530: SP#31 Moved from FS section Feb 2006
- 531: Moved from R7 WP because it is part of Feature UID_713024. This feature was extended to R8 by the inclusion (at Nov 2007 CT3 meeting) of Stage 3 covering MONA (WI 380021) / Text3: 29.863, 29.163
- 532: CP#42 completed / Text3: 29.863, 29.163
- 533: CP#42 completed / Text3: 29.332
- 534: CP#43 completed / Text3: 23.218, 24.229, 24.930
- 535: CP#43 completed
- 536: CP#42 completed / Text3: 24.279, 24.229
- 537: Depending on IETF draft. CP#43 completed / Text3: 29.163

| ID | WBS | Task | Type | Duration | Start | Finish | Complete | Baseline start | Baseline finish | Baseline duration | Total slack | Constraint | Resources | Work | Actual work | Text1 | Text2 | Text4 | Text5 | Text6 | Text7 | Text8 | Text3 |
| --- | --- | --- | --- | --- | --- | --- | --- | --- | --- | --- | --- | --- | --- | --- | --- | --- | --- | --- | --- | --- | --- | --- | --- |
| 538 | 175 | **Support of Overlap signalling** |  | 331d? | 2007-11-30 A | 2009-03-06 A | 100% | 2007-11-30 | 2009-03-06 | 331d? |  |  | C3,C1,C4 | 10008.2h | 10008.2h | Overlap | PCG-21 | Deutsche Telekom | r.jesske@telekom.de | Rel-8 | CP-38 | Gwiho |  |
| 539 | 175.1 | Stage 3 Overlap (CT1) |  | 331d? | 2007-11-30 A | 2009-03-06 A | 100% | 2007-11-30 | 2009-03-06 | 331d? |  | finish no earlier than 2009-03-06 | C1 | 2648h | 2648h | Overlap | PCG-21 | Deutsche Telekom | r.jesske@telekom.de | Rel-8 | CP-38 | Frederic | 24.229 |
| 540 | 175.2 | Stage 3 Overlap (CT3) |  | 331d? | 2007-11-30 A | 2009-03-06 A | 100% | 2007-11-30 | 2009-03-06 | 331d? |  | finish no earlier than 2009-03-06 | C3 | 2648h | 2648h | Overlap | PCG-21 | Deutsche Telekom | r.jesske@telekom.de | Rel-8 | CP-38 | Gwiho | 29.163 |
| 541 | 175.3 | Stage 3 Overlap (CT4) |  | 258.02d? | 2007-11-30 A | 2008-12-05 A | 100% | 2007-11-30 | 2008-12-05 | 258.02d? |  | start no earlier than 2007-11-30 | C4 | 2064.16h | 2064.16h | Overlap | PCG-21 | Deutsche Telekom | r.jesske@telekom.de | Rel-8 | CP-38 | Kimmo | 29.228, 29.229 |
| 542 | 176 | AS/MRFC Stage 2 and 3 |  | 278d? | 2007-11-14 A | 2008-12-05 A | 100% | 2007-11-14 | 2008-12-05 | 278d? |  | finish no earlier than 2008-12-05 | C1 | 2224h | 2224h | MRFC_TS | PCG-21 | HP | mark.syrett@hp.com | Rel-8 | CP-38 | Frederic | 23.218, 24.229, 24.147, 24.247 |
| 543 | 177 | **IMS Restoration Procedures** |  | 201d? | 2008-05-30 A | 2009-03-06 A | 100% | 2008-05-30 | 2009-03-06 | 201d? |  |  | C4,C1 | 4824h | 4824h | IMS_RP | PCG-21 | Ericsson | german.blanco@ericsson.com | Rel-8 | SP-40 | Kimmo |  |
| 544 | 177.1 | IMS Restoration Procedures |  | 201d? | 2008-05-30 A | 2009-03-06 A | 100% | 2008-05-30 | 2009-03-06 | 201d? |  | finish no earlier than 2009-03-06 | C4 | 1608h | 1608h | IMS_RP | PCG-21 | Ericsson | german.blanco@ericsson.com | Rel-8 | SP-40 | Kimmo | 23.380, 29.228, 29.229, 29.230, 23.008 |
| 545 | 177.2 | IMS Restoration Procedures |  | 201d? | 2008-05-30 A | 2009-03-06 A | 100% | 2008-05-30 | 2009-03-06 | 201d? |  | finish no earlier than 2009-03-06 | C1 | 1608h | 1608h | IMS_RP | PCG-21 | Ericsson | german.blanco@ericsson.com | Rel-8 | SP-40 | Frederic | 24.229 |
| 546 | 178 | IMS Application Server Service Data Descriptions for AS interoperability |  | 125d? | 2008-09-12 A | 2009-03-06 A | 100% | 2008-09-12 | 2009-03-06 | 125d? |  | finish no earlier than 2009-03-06 | C4 | 1000h | 1000h | IMS_ASIO | PCG-21 | Alcatel-Lucent | nhberry@alcatel-lucent.com | Rel-8 | CP-41 | Kimmo | 29.328, 29.329, 29.364 |
| 547 | 179 | **I-WLAN Network Selection Principle (NSP)** |  | 451d? | 2007-06-14 A | 2009-03-06 A | 100% | 2007-06-14 | 2009-03-06 | 451d? |  |  | S1,C1,C6 | 6643.2h | 6643.2h | IWLANNSP |  | Telefonica O2 | chris.friel@o2.com | Rel-8 |  | Alain |  |
| 548 | 179.1 | Stage 1 for I-WLAN NSP | milestone | 0d? | 2007-06-14 A | 2007-06-14 A | 100% | 2007-06-14 | 2007-06-14 | 0d? |  |  | S1 |  |  | IWLANNSP | PCG-21 | Telefonica O2 | chris.friel@o2.com | Rel-8 | SP-39 | Alain | 22.234 |
| 549 | 179.2 | Stage 3 for I-WLAN NSP |  | 261d? | 2008-03-07 A | 2009-03-06 A | 100% | 2008-03-07 | 2009-03-06 | 261d? |  | finish no earlier than 2008-12-05 | C1 | 2088h | 2088h | IWLANNSP | PCG-21 | RIM | Adrian Buckley (abuckley@rim.com) | Rel-8 | CP-39 | Frederic | 24.234 |
| 550 | 179.3 | Stage 3 for I-WLAN NSP |  | 118.4d? | 2008-03-07 A | 2008-12-11 A | 100% | 2008-03-07 | 2008-12-11 | 118.4d? |  | finish no earlier than 2008-12-11 | C6 | 947.2h | 947.2h | IWLANNSP | PCG-21 | RIM | Adrian Buckley (abuckley@rim.com) | Rel-8 | CP-39 | Xavier | 31.102, 31.111 |
| 551 | 180 | **Mobility between 3GPP-WLAN Interworking and 3GPP Systems** |  | 386d? | 2007-09-14 A | 2009-03-06 A | 100% | 2007-09-14 | 2009-03-06 | 386d? |  |  | S2,C1 | 6216h | 6216h | IWLAN_Mob |  | Orange | xiaobao.chen@orange-ftgroup.com | Rel-8 | SP-37 | Maurice |  |
| 552 | 180.1 | Stage 2: I-WLAN Mobility |  | 190d? | 2007-09-14 A | 2008-06-05 A | 100% | 2007-09-14 | 2008-06-05 | 190d? |  | finish no earlier than 2008-09-08 | S2 | 1520h | 1520h | IWLAN_Mob | PCG-21 | Orange | xiaobao.chen@orange-ftgroup.com | Rel-8 | SP-38 | Maurice | 23.327 |
| 553 | 180.2 | CT1 aspects of I-WLAN Mobility |  | 201d? | 2008-05-30 A | 2009-03-06 A | 100% | 2008-05-30 | 2009-03-06 | 201d? |  | finish no earlier than 2009-03-06 | C1 | 1608h | 1608h | IWLAN_Mob | PCG-21 | Orange | reina.nader@orange-ftgroup.com | Rel-8 | CP-40 | Frederic | 24.327, 24.303 |
| 554 | 181 | Conformance Test Aspects – Mobility between 3GPP WLAN Interworking and 3GPP Systems |  | 131d? | 2009-12-04 | 2010-06-04 |  | 2009-12-04 | 2010-06-04 | 131d? | 596d | finish no earlier than 2010-06-04 | R5 | 1048h |  | IWLAN_Mob_UEConfTest | PCG-24 | Qualcomm Europe | Patrick Stupar (pstupar@qualcomm.com) | Rel-8 | RP-46 |  | 34.108, 34.123-1, 34.123-2, 34.123-3 |
| 555 | 182 | **Enhancements for VGCS Applications (EVA)** |  | 919d? | 2006-03-15 A | 2009-09-18 A | 100% | 2006-03-15 | 2009-09-18 | 919d? |  |  | S1,C1,C4,G2 | 23503.5h | 23503.5h | EVA |  | Nortel | Amar Deol (deola@nortelnetworks.com) | Rel-8 |  | Alain |  |
| 556 | 182.1 | SA1 aspects of EVA |  | 191d? | 2006-03-15 A | 2006-12-06 A | 100% | 2006-03-15 | 2006-12-06 | 191d? |  | finish no earlier than 2006-12-06 | S1 | 1528h | 1528h | EVA |  | Nortel | Amar Deol (deola@nortelnetworks.com) | Rel-8 |  | Alain | 42.068 |
| 557 | 182.2 | VGCS/VBS and GPRS Interactions |  | 145d? | 2007-09-03 A | 2008-03-21 A | 100% | 2007-09-03 | 2008-03-21 | 145d? |  | finish no earlier than 2008-03-21 | S1 | 1160h | 1160h | EVA |  | Huawei | Ling Liu | Rel-8 | SP-37 | Alain | 42.068, 42.069 |
| 558 | 182.3 | CT1 aspects of EVA |  | 862d? | 2006-06-02 A | 2009-09-18 A | 100% | 2006-06-02 | 2009-09-18 | 862d? |  | finish no earlier than 2009-12-04 | C1 | 6887.53h | 6887.53h | EVA |  | Nortel | milanpa@nortel.com | Rel-8 |  | Frederic | 43.068, 44.068 |
| 559 | 182.4 | CT4 aspects of EVA |  | 391d? | 2006-06-02 A | 2007-11-30 A | 100% | 2006-06-02 | 2007-11-30 | 391d? |  | finish no earlier than 2007-06-01 | C4 | 3128h | 3128h | EVA |  | Nortel |  | Rel-8 |  | Kimmo | 29.002 |
| 560 | 182.5 | GERAN2 aspects of EVA |  | 431d? | 2006-06-30 A | 2008-02-22 A | 100% | 2006-06-30 | 2008-02-22 | 431d? |  | finish no earlier than 2008-02-22 | G2 | 3448h | 3448h | EVA |  | Nortel | frank.billenkamp@nortel.com | Rel-8 |  | Gert | 44.018, 48.008 |
| 561 | 183 | **Personal Network Management** |  | 955d? | 2005-07-11 A | 2009-03-06 A | 100% | 2005-07-11 | 2009-03-06 | 955d? |  |  | S1,C1,S3 | 27008h | 27008h | PNM |  | Vodafone | armin.toepfer@vodafone.com | Rel-8 |  | Alain |  |
| 562 | 183.1 | Stage 1 for PNM |  | 276d? | 2005-07-11 A | 2006-07-31 A | 100% | 2005-07-11 | 2006-07-31 | 276d? |  | start no earlier than 2005-07-11 | S1 | 2208h | 2208h | PNM |  | Vodafone | armin.toepfer@vodafone.com | Rel-8 |  | Alain | 22.259 |
| 563 | 183.2 | Stage 2 for PNM |  | 445d? | 2007-03-26 A | 2008-12-05 A | 100% | 2007-03-26 | 2008-12-05 | 445d? |  | finish no earlier than 2008-12-05 | C1 | 3560h | 3560h | PNM |  | Vodafone | yang.lu@vodafone.com | Rel-8 |  | Frederic | 23.259 |

Notes:
- 538: CP#43 completed
- 539: CP#43 completed
- 540: CP#43 completed
- 541: CP#42 completed
- 542: CP#42 completed. Triggered by Study UID_7048 (MRFC)
- 543: CP#43 completed. CP#41 WID updated CP-080281=>CP-080447. Triggered by Study TR 23.820 (FS_IMS_RP) UID_350018
- 544: CP#43 completed
- 545: CP#43 completed
- 546: CP#43 completed. Triggered by UID_360030 (FS_IMS_ASIO)
- 547: CP#43 completed. SP#36 Stage 1 completed
- 548: SP#36 completed
- 549: CP#43 completed
- 550: CP#42 completed
- 551: CP#43 completed. SP#40 Stage 2 completed
- 552: SP#40 completed
- 553: CP#43 completed
- 554: Testing for Rel-8 UID_400013 CT1 aspects of mobility between 3GPP WLAN Interworking and 3GPP Systems (24.327)
- 555: CP#45 completed (Voice Group Call Service)
- 556: SP#38 completed
- 557: SP#39 completed
- 558: CP#45 completed. CT1 will not do more but SA1 may remove the requirement not solved by CT1
- 559: CP#38 completed
- 560: GP#37 completed
- 561: CP#43 completed. Feb 06 moved FS=>Feature. SP#31 Stage 1 completed. SP#40 WID updated with reduced scope SP-060574=>SP-080327
- 562: SP#31 completed. SP#40 WID updated SP-060574=>SP-080327
- 563: CP#42 completed

| ID | WBS | Task | Type | Duration | Start | Finish | Complete | Remaining | Baseline start | Baseline finish | Baseline duration | Total slack | Constraint | Resources | Work | Actual work | Text1 | Text4 | Text5 | Text6 | Text8 | Text3 | Text12 | Text7 | Text2 | Text11 |
| --- | --- | --- | --- | --- | --- | --- | --- | --- | --- | --- | --- | --- | --- | --- | --- | --- | --- | --- | --- | --- | --- | --- | --- | --- | --- | --- |
| 564 | 183.3 | **Stage 3 for PNM** |  | 510d? | 2007-03-26 A | 2009-03-06 A | 100% |  | 2007-03-26 | 2009-03-06 | 510d? |  |  | C1,C4 | 11720h | 11720h | PNM | Vodafone | yang.lu@vodafone.com | Rel-8 | Frederic |  |  |  |  |  |
| 565 | 183.3.1 | CT1 aspects of Stage 3 PNM |  | 510d? | 2007-03-26 A | 2009-03-06 A | 100% |  | 2007-03-26 | 2009-03-06 | 510d? |  | finish no earlier than 2008-12-05 | C1 | 4080h | 4080h | PNM | Vodafone | yang.lu@vodafone.com | Rel-8 | Frederic | 24.259, 24.229 |  |  |  |  |
| 566 | 183.3.2 | CT4 aspects of Stage 3 PNM |  | 445d? | 2007-03-26 A | 2008-12-05 A | 100% |  | 2007-03-26 | 2008-12-05 | 445d? |  | finish no earlier than 2008-12-11 | C4 | 3560h | 3560h | PNM | Vodafone | yang.lu@vodafone.com | Rel-8 | Kimmo |  |  |  |  |  |
| 567 | 183.4 | Key establishment between a UICC hosting device and a remote device |  | 235d? | 2006-12-06 A | 2007-10-30 A | 100% |  | 2006-12-06 | 2007-10-30 | 235d? |  | finish no earlier than 2007-10-30 | S3 | 1880h | 1880h | PNM | Ericsson | Vesa.Lehtovirta@ericsson.com | Rel-8 | Dionisio | 33.259 |  |  |  |  |
| 568 | 183.5 | Deleted - Actual Requirements of PNM | milestone | 0d? | 2007-03-26 A | 2007-03-26 A | 100% |  | 2007-03-26 | 2007-03-26 | 0d? |  | finish no earlier than 2007-03-26 | C1 |  |  | PNM | Ericsson |  | Rel-8 | Frederic |  | SP-37 |  |  |  |
| 569 | 184 | **eCall Data Transfer** |  | 637d? | 2006-09-28 A | 2009-03-06 A | 100% |  | 2006-09-28 | 2009-03-06 | 637d? |  |  | S1,C1 | 9744h | 9744h | EData | Airbiquity | rrobinson@airbiquity.com | Rel-8 | Alain |  |  |  |  |  |
| 570 | 184.1 | eData Requirements |  | 380d? | 2006-09-28 A | 2008-03-12 A | 100% |  | 2006-09-28 | 2008-03-12 | 380d? |  | finish no earlier than 2006-12-07 | S1 | 3040h | 3040h | EData | Airbiquity | rrobinson@airbiquity.com | Rel-8 | Alain | 22.101, 22.105 |  | SP-37 |  |  |
| 571 | 184.2 | Transfer of data during an emergency call |  | 201d? | 2008-05-30 A | 2009-03-06 A | 100% |  | 2008-05-30 | 2009-03-06 | 201d? |  | finish no earlier than 2009-03-06 | C1 | 1608h | 1608h | EData | T-Mobile | Dieter Jacobsohn | Rel-8 | Frederic | 24.008 |  | SP-40 | PCG-21 |  |
| 572 | 185 | eCall data transfer Phase 2: Comparison of alternative in-band modem solutions and standardization of one in-band modem solution |  | 472d? | 2007-12-06 A | 2009-09-24 A | 100% |  | 2007-12-06 | 2009-09-24 | 472d? |  | finish no earlier than 2009-09-24 | S4 | 3768.09h | 3768.09h | eCall_Phase2 | Airbiquity | lhong@airbiquity.com & rrobinson@airbiquity.com | Rel-8 | Paolo | 26.267, 26.268, 26.269, 26.967, 26.969 |  |  |  |  |
| 573 | 186 | eCall Conformance Testing |  | 181d? | 2009-09-04 A | 2010-05-14 | 45% | 99.55d? | 2009-09-04 | 2010-05-14 | 181d? | 611d | finish no earlier than 2010-05-14 | G3new | 1448h | 651.6h | eCall_MSTest | Ericsson, Qualcomm Europe | Vikrant Jain (vikrantj@qualcomm.com) | Rel-8 | Ingbert | 51.010-1, 51.010-2 |  | GP-45 | PCG-23 |  |
| 574 | 187 | Conformance Test Aspects – non-modem procedures of eCall sessions in UTRA |  | 126d? | 2009-09-18 A | 2010-03-12 | 15% | 107.1d? | 2009-09-18 | 2010-03-12 | 126d? | 656d | finish no earlier than 2010-03-12 | R5 | 1008h | 151.2h | UMTS_eCall_UEConTest | Ericsson, Qualcomm Europe | Shubhang Vora (svora@qualcomm.com) | Rel-8 | Ingbert | 34.108, 34.123-1, 34.123-2, 34.123-3 |  | RP-45 | PCG-23 | RP-091076 |
| 575 | 188 | **IP Interconnection of Services** |  | 668d? | 2006-08-16 A | 2009-03-06 A | 100% |  | 2006-08-16 | 2009-03-06 | 668d? |  |  | S1,S2,S5,C3 | 17520h | 17520h | IPinterc | Telefonica O2 | chris.friel@O2.com | Rel-8 | Alain |  |  | SP-38 | PCG-21 |  |
| 576 | 188.1 | Stage 1 for IPinterc |  | 70d? | 2007-12-06 A | 2008-03-12 A | 100% |  | 2007-12-06 | 2008-03-12 | 70d? |  | start no earlier than 2007-12-06 | S1 | 560h | 560h | IPinterc | Telefonica O2 | chris.friel@O2.com | Rel-8 | Alain | 22.101, 22.228 |  | SP-38 | PCG-21 |  |
| 577 | 188.2 | **System enhancements for interconnection interfaces between two IMSs** |  | 668d? | 2006-08-16 A | 2009-03-06 A | 100% |  | 2006-08-16 | 2009-03-06 | 668d? |  |  | S2,S5,C3 | 11616h | 11616h | IMS_NNI | Telecom Italia | Mario Madella (mario.madella@telecomitalia.it) | Rel-8 | Maurice |  |  |  |  |  |
| 578 | 188.2.1 | Stage 2 for IMS_NNI |  | 120d? | 2007-06-22 A | 2007-12-06 A | 100% |  | 2007-06-22 | 2007-12-06 | 120d? |  | finish no earlier than 2007-12-21 | S2 | 960h | 960h | IMS_NNI | Telecom Italia | Mario Madella (mario.madella@telecomitalia.it) | Rel-8 | Maurice | 23.002, 23.228 |  |  |  |  |
| 579 | 188.2.2 | IMS inter-operator service interconnection interface |  | 461d? | 2007-06-01 A | 2009-03-06 A | 100% |  | 2007-06-01 | 2009-03-06 | 461d? |  | finish no earlier than 2009-03-06 | C3 | 3688h | 3688h | FBI2-IOPSI | Telecom Italia | antonio.ascolese@telecomitalia.it | Rel-8 | Gwiho | 29.865, 29.165 |  |  |  |  |
| 580 | 188.2.3 | Charging harmonization for NGN between 3GPP and ATIS-TMOC |  | 51d? | 2006-09-28 A | 2006-12-07 A | 100% |  | 2006-09-28 | 2006-12-07 | 51d? |  | finish no earlier than 2006-12-07 | S5 | 408h | 408h | FBI2-TISP2-CH | Amdocs | Brown, Yishai | Rel-8 | Dionisio | 32.297 |  |  |  |  |
| 581 | 188.2.4 | Deleted - Protocol impact of FBI for TISPAN R2 |  | 152d? | 2006-08-16 A | 2007-03-15 A | 100% |  | 2006-08-16 | 2007-03-15 | 152d? |  | finish no earlier than 2007-03-15 | C1 | 1216h | 1216h | FBI2-TISP2-c1 | Ericsson |  | Rel-8 | Frederic |  | SP-38 |  |  |  |
| 582 | 188.2.5 | Deleted (never approved) - Stage 2 of FBI for TISPAN R2 - Rel 8 | milestone | 0d? | 2007-11-30 A | 2007-11-30 A | 100% |  | 2007-11-30 | 2007-11-30 | 0d? |  | finish no earlier than 2007-11-30 | S2 |  |  | FBI2-TISP2-s2 | Nokia Siemens Networks |  | Rel-8 | Maurice |  | SP-36 |  |  |  |
| 583 | 189 | **Support of (G)MSC-S – (G)MSC-S Nc Interface based on the SIP-I protocol** |  | 386d? | 2007-09-14 A | 2009-03-06 A | 100% |  | 2007-09-14 | 2009-03-06 | 386d? |  |  | C4,C3 | 11872h | 11872h | SIP_Nc | Vodafone | David.Hutton@vodafone.com | Rel-8 | Kimmo |  |  |  |  |  |
| 584 | 189.1 | Stage 1 for SIP_Nc (covered by Feature IPinterc) |  | 70d? | 2007-12-06 A | 2008-03-12 A | 100% |  | 2007-12-06 | 2008-03-12 | 70d? |  | start no earlier than 2007-12-06 | S1 | 560h | 560h | IPinterc | Telefonica O2 | chris.friel@O2.com | Rel-8 | Alain | 22.101, 22.228 |  | CP-41 | PCG-21 |  |
| 585 | 189.2 | SIP-I based circuit-switched core network; Stage 2 |  | 321d? | 2007-09-14 A | 2008-12-05 A | 100% |  | 2007-09-14 | 2008-12-05 | 321d? |  | finish no earlier than 2008-12-11 | C4 | 2568h | 2568h | SIP_Nc-St2 | Vodafone | David.Hutton@vodafone.com | Rel-8 | Kimmo | 23.231, 23.153, 23.205 |  |  |  |  |
| 586 | 189.3 | Application of SIP-I Protocols to Circuit Switched (CS) core network architecture; Stage 3 |  | 321d? | 2007-09-14 A | 2008-12-05 A | 100% |  | 2007-09-14 | 2008-12-05 | 321d? |  | finish no earlier than 2008-12-11 | C4 | 2568h | 2568h | SIP_Nc-St3 | Vodafone | David.Hutton@vodafone.com | Rel-8 | Kimmo | 29.231, 29.232, 29.332 |  |  |  |  |
| 587 | 189.4 | Interworking between the 3GPP CS domain with SIP-I as signalling protocol and other networks |  | 386d? | 2007-09-14 A | 2009-03-06 A | 100% |  | 2007-09-14 | 2009-03-06 | 386d? |  | finish no earlier than 2009-03-06 | C3 | 3088h | 3088h | SIP_Nc | Nokia Siemens Networks | Thomas.Belling@nsn.com | Rel-8 | Gwiho | 29.235, 23.172, 23.202, 29.007, 29.163, 29.414 |  |  |  |  |

Notes:
- 564: CP#43 completed. Moved from FS section Feb 06: SP-33: Create new section to capture the PNM stage 2 aspects and identify any impacts to existing stage 2 specifications.
- 565: CP#43 completed
- 566: CP#42 No impact to CT4 specifications
- 567: 07/08: Moved from Rel-7 to Rel-8 WP; Feature=>BB as per SA3/SA WID in SP-060839, keeping the same UID
- 568: SP#37 stopped
- 569: SP#39 completed. Linked to SA4 Feature UID_34042 (eCall_Phase2). CP#40 approved Stage 3 WID.
- 570: SA4 to select a suitable in-band modem. SP#39 completed
- 571: CP#43 completed
- 572: SP#45 completed. TR 26.969 for Approval. Triggered by Study UID_360015 (eCALLIBMS). Linked to SA1 Feature UID_330005 (EData)
- 573: GP#43 WID approved. Testing for Rel-8 eCall_Phase2 (UID_34042) and EData (UID_330005)
- 574: RP#45 testing for Rel-8 eCall_Phase2 (UID_34042) and Edata (UID_330005)
- 575: SP#43 completed. Covers Stage 1 for IMS_NNI (UID_360024),SIP_Nc (UID_360026),CS-IBCF (UID_400008). SP#41 WID updated SP-070871=>SP-080565 [Moved under it as BBs 2 existing Features: CS-IBCF, IMS_NNI]
- 576: SP#39 completed.
- 577: CP#43 completed. SP#36 Name changed from "System enhancements for TISPAN Rel2". Stage 1 in Feature UID_380060 (IPinterc). CP#41 updated WID CP-080054=>CP-080578 (Feature IMS_NNI=>BB under Ipinterc)
- 578: SP#38 completed. SP#41 WID updated SP-070490=>SP-080554
- 579: CP#43 completed
- 580: SP#34 completed
- 581: SP#38 stopped
- 582: SP#36 stopped
- 583: CP#43 completed. Stage 1 in Feature UID_380060 (IPinterc). CP#40 updated WID CP-070517=>CP-080282
- 584: 22/07/08 Created. Stage 1 for SIP_Nc (covered by SA1 Feature UID_380060 Ipinterc)
- 585: CP#42 completed
- 586: CP#42 completed
- 587: CP#43 completed. CP#42 target 12/08=>03/09

| ID | WBS | Task | Type | Duration | Start | Finish | Complete | Remaining | Baseline start | Baseline finish | Baseline duration | Total slack | Constraint | Resources | Work | Actual work | Text1 | Text4 | Text5 | Text6 | Text7 | Text8 | Text3 | Text2 | Text11 | Text9 | Text12 |
| --- | --- | --- | --- | --- | --- | --- | --- | --- | --- | --- | --- | --- | --- | --- | --- | --- | --- | --- | --- | --- | --- | --- | --- | --- | --- | --- | --- |
| 588 | 190 | **Earthquake and Tsunami Warning System** |  | 440d? | 2007-09-10 A | 2009-05-15 A | 100% |  | 2007-09-10 | 2009-05-15 | 440d? |  |  | S1,S2,CP,G2 | 6136h | 6136h | ETWS | NTT DoCoMo | kitaharar@nttdocomo.co.jp | Rel-8 | SP-37 | Alain |  |  |  |  |  |
| 589 | 190.1 | Stage 1 for ETWS |  | 133d? | 2007-09-10 A | 2008-03-12 A | 100% |  | 2007-09-10 | 2008-03-12 | 133d? |  | finish no earlier than 2008-03-12 | S1 | 1064h | 1064h | ETWS | NTT DoCoMo | kitaharar@nttdocomo.co.jp | Rel-8 | SP-37 | Alain | 22.168 |  |  |  |  |
| 590 | 190.2 | SA2 aspects of ETWS |  | 179d? | 2008-01-14 A | 2008-09-18 A | 100% |  | 2008-01-14 | 2008-09-18 | 179d? |  | finish no earlier than 2008-09-08 | S2 | 1432h | 1432h | ETWS | NTT DoCoMo | tanakai@nttdocomo.co.jp | Rel-8 | SP-38 | Maurice | 23.828, 23.401 | PCG-21 |  |  |  |
| 591 | 190.3 | CT1 aspects of ETWS |  | 50.5d? | 2008-05-30 A | 2008-12-05 A | 100% |  | 2008-05-30 | 2008-12-05 | 50.5d? |  | finish no earlier than 2008-12-05 | C1 | 404h | 404h | ETWS | NTT DoCoMo | yamashitahi@s1.nttdocomo.co.jp | Rel-8 | CP-40 | Frederic | 23.041 | PCG-21 |  |  |  |
| 592 | 190.4 | CT4 aspects of ETWS |  | 50.5d? | 2008-09-26 A | 2008-12-05 A | 100% |  | 2008-09-26 | 2008-12-05 | 50.5d? |  | finish no earlier than 2008-12-05 | C4 | 404h | 404h | ETWS | NTT DoCoMo | yamashitahi@s1.nttdocomo.co.jp | Rel-8 | CP-40 | Kimmo | 29.168 | PCG-21 |  |  |  |
| 593 | 190.5 | ETWS primary notification message definition in GERAN |  | 47d? | 2009-03-12 A | 2009-05-15 A | 100% |  | 2009-03-12 | 2009-05-15 | 47d? |  | finish no earlier than 2009-05-15 | G2 | 376h | 376h | ETWS | Ericsson | claes-goran.persson@ericsson.com | Rel-8 | SP-43 | Gert | 44.018, 44.060 | PCG-22 |  |  |  |
| 594 | 191 | Conformance Test Aspects – UMTS Earthquake and Tsunami Warning System (ETWS) FDD |  | 207d? | 2009-05-29 A | 2010-03-12 | 8% | 190.44d? | 2009-05-29 | 2010-03-12 | 207d? | 656d | finish no earlier than 2010-03-12 | R5 | 1656h | 132.48h | ETWS_UMTS_UEConTestFDD | NTT DoCoMo | Makoto Ito (itohm@nttdocomo.co.jp) | Rel-8 | RP-44 | Ingo | 34.108, 34.123-1, 34.123-2, 34.123-3 | PCG-23 | RP-091070 |  |  |
| 595 | 192 | **In Case of Emergency numbers storage and easy access on UICC** |  | 519d? | 2007-03-13 A | 2009-03-06 A | 100% |  | 2007-03-13 | 2009-03-06 | 519d? |  |  | S1,C6 | 8864h | 8864h | ICE | Vodafone | armin.toepfer@vodafone.com | Rel-8 | SP-38 | Alain |  | PCG-21 |  |  |  |
| 596 | 192.1 | Stage 1 for ICE |  | 262d? | 2007-03-13 A | 2008-03-12 A | 100% |  | 2007-03-13 | 2008-03-12 | 262d? |  | finish no earlier than 2008-03-12 | S1 | 2096h | 2096h | ICE | Vodafone | armin.toepfer@vodafone.com | Rel-8 | SP-38 | Alain | 22.030, 22.101 | PCG-21 |  |  |  |
| 597 | 192.2 | CT6 aspects of ICE |  | 519d? | 2007-03-13 A | 2009-03-06 A | 100% |  | 2007-03-13 | 2009-03-06 | 519d? |  | finish no earlier than 2009-03-06 | C6 | 4152h | 4152h | ICE | Vodafone | armin.toepfer@vodafone.com | Rel-8 | SP-38 | Xavier | 31.102 | PCG-21 |  |  |  |
| 598 | 193 | Local Charging Zone Requirements |  | 380d? | 2006-09-28 A | 2008-03-12 A | 100% |  | 2006-09-28 | 2008-03-12 | 380d? |  | finish no earlier than 2006-12-07 | S1 | 3040h | 3040h | LCZR | China Mobile | liuhongyfw@chinamobile.com | Rel-8 |  | Alain | 22.115 |  |  |  |  |
| 599 | 194 | **Customized Alerting Tone (CAT) Service** |  | 729d? | 2006-12-06 A | 2009-09-18 A | 100% |  | 2006-12-06 | 2009-09-18 | 729d? |  |  | S1,C1,C3,C4 | 12302h | 12302h | CAT | China Mobile | fenglingjuan@chinamobile.com | Rel-8 |  | Alain |  |  |  |  |  |
| 600 | 194.1 | Stage 1 for CAT |  | 207d? | 2006-12-06 A | 2007-09-20 A | 100% |  | 2006-12-06 | 2007-09-20 | 207d? |  | start no earlier than 2006-12-06 | S1 | 1656h | 1656h | CAT | China Mobile | fenglingjuan@chinamobile.com | Rel-8 | SP-37 | Alain | 22.182 |  |  |  |  |
| 601 | 194.2 | TISPAN requirements for customized multimedia information services |  | 71d? | 2007-09-03 A | 2007-12-10 A | 100% |  | 2007-09-03 | 2007-12-10 | 71d? |  | finish no earlier than 2007-12-10 | S1 | 568h | 568h | TISCMI | China Mobile | fenglingjuan@chinamobile.com | Rel-8 | SP-37 | Alain | 22.182 |  |  |  |  |
| 602 | 194.3 | IMS CAT Supplementary Service |  | 164d? | 2008-04-21 A | 2008-12-04 A | 100% |  | 2008-04-21 | 2008-12-04 | 164d? |  | finish no earlier than 2008-12-05 | C1 | 1312h | 1312h | CAT-SS | Nortel | milanpa@nortel.com | Rel-8 | CP-39 | Frederic | 24.182 | PCG-21 |  |  |  |
| 603 | 194.4 | CAT solution for voice and video call in CS domain |  | 389.8d? | 2008-03-12 A | 2009-09-18 A | 100% |  | 2008-03-12 | 2009-09-18 | 389.8d? |  | finish no earlier than 2009-09-11 | C3 | 3118.4h | 3118.4h | CAT-SS | Nortel | milanpa@nortel.com | Rel-8 | CP-39 | Gwiho | 29.163 | PCG-21 |  |  |  |
| 604 | 194.5 | CAT Service in 3GPP CS domain |  | 126d? | 2008-09-12 A | 2009-03-06 A | 100% |  | 2008-09-12 | 2009-03-06 | 126d? |  | finish no earlier than 2009-03-06 | C4 | 1008h | 1008h | CAT-3G_CS | China Mobile | zhaoyuyi@chinamobile.com | Rel-8 | CP-41 | Kimmo | 23.205, 23.231, 29.002 | PCG-21 |  |  |  |
| 605 | 194.6 | CAT Service in 3GPP CS domain |  | 57.95d? | 2008-09-12 A | 2008-12-05 A | 100% |  | 2008-09-12 | 2008-12-05 | 57.95d? |  | start no earlier than 2008-09-12 | C1 | 463.6h | 463.6h | CAT-3G_CS | China Mobile | zhaoyuyi@chinamobile.com | Rel-8 | CP-41 | Frederic | 24.008, 23.014 | PCG-21 |  |  |  |
| 606 | 195 | **Service-Level Interworking for Messaging Services** |  | 509d? | 2007-03-26 A | 2009-03-06 A | 100% |  | 2007-03-26 | 2009-03-06 | 509d? |  |  | S1,S2,C3,C1 | 8584h | 8584h | MESSIW | Huawei | ling.liu@huawei.com; duanxiaoqin@huawei.com | Rel-8 |  | Alain |  |  |  |  |  |
| 607 | 195.1 | Stage 1 for MESSIW | milestone | 0d? | 2007-03-26 A | 2007-03-26 A | 100% |  | 2007-03-26 | 2007-03-26 | 0d? |  | finish no earlier than 2007-12-01 | S1 |  |  | MESSIW | Huawei | ling.liu@huawei.com | Rel-8 |  | Alain | 22.105, 22.340 |  |  |  |  |
| 608 | 195.2 | Stage 2 for MESSIW |  | 227d? | 2007-04-26 A | 2008-03-07 A | 100% |  | 2007-04-26 | 2008-03-07 | 227d? |  | finish no earlier than 2008-03-07 | S2 | 1816h | 1816h | MESSIW | Huawei | patrice.hede@huawei.com | Rel-8 |  | Maurice | 23.811, 23.204 |  |  |  |  |
| 609 | 195.3 | Stage 3 for MESSIW |  | 201d? | 2008-05-30 A | 2009-03-06 A | 100% |  | 2008-05-30 | 2009-03-06 | 201d? |  | finish no earlier than 2008-12-05 | C3 | 1608h | 1608h | MESSIW | Huawei | xupeili@huawei.com | Rel-8 | CP-40 | Gwiho | 29.311 | PCG-21 |  |  |  |
| 610 | 195.4 | Stage 3 for MESSIW |  | 136d? | 2008-05-30 A | 2008-12-05 A | 100% |  | 2008-05-30 | 2008-12-05 | 136d? |  | finish no earlier than 2008-12-12 | C1 | 1088h | 1088h | MESSIW | Huawei | xupeili@huawei.com | Rel-8 | CP-40 | Frederic | 24.229 | PCG-21 |  |  |  |
| 611 | 196 | **Multimedia Priority Service** |  | 858d? | 2006-06-08 A | 2009-09-18 A | 100% |  | 2006-06-08 | 2009-09-18 | 858d? |  |  | S1,C1,C3,C4 | 22424h | 22424h | PRIOR | Telcordia | jgarraha@telcordia.com | Rel-8 | SP-34 | Alain |  |  |  |  |  |
| 612 | 196.1 | Service Requirements for PRIOR |  | 391d? | 2006-06-08 A | 2007-12-06 A | 100% |  | 2006-06-08 | 2007-12-06 | 391d? |  | finish no earlier than 2007-11-30 | S1 | 3128h | 3128h | PRIOR-EMR | Telcordia | jgarraha@telcordia.com | Rel-8 | SP-32 | Alain | 22.153 |  |  |  |  |
| 613 | 196.2 | Stage 3 for PRIOR |  | 732d? | 2006-12-01 A | 2009-09-18 A | 100% |  | 2006-12-01 | 2009-09-18 | 732d? |  | finish no earlier than 2009-09-18 | C1 | 5856h | 5856h | PRIOR | Alcatel-Lucent | Keith Drage (drage@alcatel-lucent.com) | Rel-8 | CP-34 | Frederic | 24.229 |  |  |  |  |
| 614 | 196.3 | Deleted - Stage 3 for PRIOR |  | 441d? | 2007-09-21 A | 2009-05-29 A | 100% |  | 2007-09-21 | 2009-05-29 | 441d? |  | finish no earlier than 2009-05-29 | C3 | 3528h | 3528h | PRIOR | Alcatel-Lucent | Keith Drage (drage@alcatel-lucent.com) | Rel-8 | CP-37 | Gwiho | 29.212, 29.213, 29.214, 29.163 |  |  | PCG-23 | CP-44 |
| 615 | 196.4 | Stage 3 for PRIOR |  | 381d? | 2007-09-21 A | 2009-03-06 A | 100% |  | 2007-09-21 | 2009-03-06 | 381d? |  | finish no earlier than 2009-03-06 | C4 | 3048h | 3048h | PRIOR | Alcatel-Lucent | Keith Drage (drage@alcatel-lucent.com) | Rel-8 | CP-37 | Kimmo | 23.008, 29.228, 29.229 |  |  |  |  |

Notes:
- 588: SP#43 GERAN task included. Larger scope Feature UID_380057 (PWS) moved to Rel-9
- 589: SP#39 completed
- 590: SP#41 completed
- 591: CP#42 completed. WID updated CP-080318=>CP-080659=>CP-080951
- 592: CP#42 completed. WID updated CP-080318=>CP-080659=>CP-080951
- 593: SP#44 completed with CT1 help (GERAN2 LS_in SP-090154)
- 594: Testing for Rel-8 ETWS UID_370051
- 595: CP#43 completed (ICE Graphics not included in Rel-8)
- 596: SP#39 Stage 1 completed
- 597: CP#43 completed (ICE Graphics not in Rel-8 / not explicitly in SA1 WID either)
- 598: SP#39 Stage 1 completed
- 599: CP#45 completed
- 600: -
- 601: SP#38 completed
- 602: CP#42 completed. CP#41 WID updated CP-080074=>CP-080496.
- 603: CP#45 completed. CP#44 sent LS to ITU-T (CP-090501) request to specify explicit parameter for CAT signalling and APM container for 3GPP to define the contents. Triggered by Study UID_360031 (FS_CAT_VVC_CS) TR 29.882
- 604: CP#43 completed. Triggered by Study UID_360031 (FS_CAT_VVC_CS) TR 29.882.
- 605: Triggered by Study UID_360031 (FS_CAT_VVC_CS) TR 29.882. CP#42 completed
- 606: CP#43 completed. SP#39 Stage 2 completed
- 607: SP#35 completed
- 608: SP#39 completed
- 609: CP#43 completed
- 610: CP#42 completed. WID updated CP-080391=>CP-080575=>CP-080773
- 611: CP#45 completed. SP#38 Stage 1 completed. No Stage 2 identified
- 612: SP#38 completed
- 613: CP#45 completed
- 614: CP#44 closed (Reason: No Rel-8 solution expected (LS sent to SA2, but not prioritized in SA2)
- 615: CP#43 completed

| ID | WBS | Task | Duration | Start | Finish | Complete | Baseline start | Baseline finish | Baseline duration | Constraint | Resources | Work | Actual work | Text1 | Text4 | Text5 | Text6 | Text8 | Text3 | Text7 | Text2 | Text9 | Text12 |
| --- | --- | --- | --- | --- | --- | --- | --- | --- | --- | --- | --- | --- | --- | --- | --- | --- | --- | --- | --- | --- | --- | --- | --- |
| 616 | 197 | **OSA Rel-8** | 202d? | 2007-08-23 A | 2008-05-30 A | 100% | 2007-08-23 | 2008-05-30 | 202d? |  | S1,C5 | 23552h | 23552h | OSA8 | Orange | Song Dong | Rel-8 | Alain |  |  |  |  |  |
| 617 | 197.1 | OSA Stage 1 - Service Requirements | 145d? | 2007-08-23 A | 2008-03-12 A | 100% | 2007-08-23 | 2008-03-12 | 145d? | finish no earlier than 2007-12-04 | S1 | 1160h | 1160h | OSA8 | Orange, AePONA | Song Dong | Rel-8 | Alain | 22.127 |  |  |  |  |
| 618 | 197.2 | OSA Stage 1 - NGN Service Requirement | 140d? | 2007-09-03 A | 2008-03-14 A | 100% | 2007-09-03 | 2008-03-14 | 140d? | finish no earlier than 2008-03-14 | S1 | 1120h | 1120h | OSA8-IMS | Orange | Song Dong | Rel-8 | Alain | 22.127 | SP-37 |  |  |  |
| 619 | 197.3 | **OSA Stage 2/3 enhancements** | 157d? | 2007-10-25 A | 2008-05-30 A | 100% | 2007-10-25 | 2008-05-30 | 157d? |  | C5 | 20016h | 20016h | OSA8 | Alcatel-Lucent | unmehopa@alcatel-lucent.com | Rel-8 | Kimmo | 23.198, 29.198, 29.199 |  |  |  |  |
| 620 | 197.3.1 | Delete - Ensure Parlay-X composable with identity management frameworks, in particular Liberty Alliance | 157d? | 2007-10-25 A | 2008-05-30 A | 100% | 2007-10-25 | 2008-05-30 | 157d? | finish no earlier than 2008-12-25 | C5 | 1256h | 1256h | OSA8 | Ericsson, FT/Orange, Sprint, Telecom Italia | catherine.mulligan@ericsson.com | Rel-8 | Kimmo | existing 29.199-xy | CP-37 | PCG-21 | PCG-21 | CP-40 |
| 621 | 197.3.2 | Parlay-X Content Management web service (store/manage meta-data) | 157d? | 2007-10-25 A | 2008-05-30 A | 100% | 2007-10-25 | 2008-05-30 | 157d? | finish no earlier than 2008-12-04 | C5 | 1256h | 1256h | OSA8 | Alcatel-Lucent | unmehopa@alcatel-lucent.com | Rel-8 | Kimmo | 29.199-21 | CP-37 |  |  |  |
| 622 | 197.3.3 | Parlay-X Policy web service | 157d? | 2007-10-25 A | 2008-05-30 A | 100% | 2007-10-25 | 2008-05-30 | 157d? | finish no earlier than 2008-12-04 | C5 | 1256h | 1256h | OSA8 | Alcatel-Lucent | unmehopa@alcatel-lucent.com | Rel-8 | Kimmo | 29.199-22 | CP-37 |  |  |  |
| 623 | 197.3.4 | Parlay-X Terminal status web service | 157d? | 2007-10-25 A | 2008-05-30 A | 100% | 2007-10-25 | 2008-05-30 | 157d? | finish no earlier than 2008-05-30 | C5 | 1256h | 1256h | OSA8 | Alcatel-Lucent | unmehopa@alcatel-lucent.com | Rel-8 | Kimmo | 29.199-08 | CP-37 |  |  |  |
| 624 | 197.3.5 | Delete - Identify communication format used by a particular application | 157d? | 2007-10-25 A | 2008-05-30 A | 100% | 2007-10-25 | 2008-05-30 | 157d? | finish no earlier than 2008-05-30 | C5 | 1256h | 1256h | OSA8 | Ericsson | catherine.mulligan@ericsson.com | Rel-8 | Kimmo | existing 29.199-xy | CP-37 | PCG-21 | PCG-21 | CP-40 |
| 625 | 197.3.6 | Delete - Security on User Profile Management - reuse GUP API (22.127 CR 0084 S1-071794) | 128d? | 2007-12-05 A | 2008-05-30 A | 100% | 2007-12-05 | 2008-05-30 | 128d? | finish no earlier than 2008-12-25 | C5 | 1024h | 1024h | OSA8 | Telecom Italia | vincenzo.amorino@telecomitalia.it | Rel-8 | Kimmo | PXWS Framework | CP-38 | PCG-21 | PCG-21 | CP-40 |
| 626 | 197.3.7 | Delete - Privacy on Subscriber Identity (Liberty Alliance, OASIS) (22.127 CR 0085 S1-071835) | 128d? | 2007-12-05 A | 2008-05-30 A | 100% | 2007-12-05 | 2008-05-30 | 128d? | finish no earlier than 2008-12-25 | C5 | 1024h | 1024h | OSA8 | Telecom Italia | vincenzo.amorino@telecomitalia.it | Rel-8 | Kimmo | PXWS Framework | CP-38 | PCG-21 | PCG-21 | CP-40 |
| 627 | 197.3.8 | Delete - Topology Hiding (22.127 CR 0086 S1-071838) | 128d? | 2007-12-05 A | 2008-05-30 A | 100% | 2007-12-05 | 2008-05-30 | 128d? | finish no earlier than 2008-12-25 | C5 | 1024h | 1024h | OSA8 | Telecom Italia | vincenzo.amorino@telecomitalia.it | Rel-8 | Kimmo | PXWS Framework | CP-38 | PCG-21 | PCG-21 | CP-40 |
| 628 | 197.3.9 | Delete - Subscriber event notification (22.127 CR 0087 S1-071836) | 128d? | 2007-12-05 A | 2008-05-30 A | 100% | 2007-12-05 | 2008-05-30 | 128d? | finish no earlier than 2008-12-25 | C5 | 1024h | 1024h | OSA8 | Telecom Italia | vincenzo.amorino@telecomitalia.it | Rel-8 | Kimmo | PXWS Framework | CP-38 | PCG-21 | PCG-21 | CP-40 |
| 629 | 197.3.10 | Delete - Event notification (22.127 CR 0088 S1-071762) | 128d? | 2007-12-05 A | 2008-05-30 A | 100% | 2007-12-05 | 2008-05-30 | 128d? | finish no earlier than 2008-12-25 | C5 | 1024h | 1024h | OSA8 | Telecom Italia | vincenzo.amorino@telecomitalia.it | Rel-8 | Kimmo | PXWS Framework | CP-38 | PCG-21 | PCG-21 | CP-40 |
| 630 | 197.3.11 | Delete - Access policy (22.127 CR 0089 S1-071763) | 128d? | 2007-12-05 A | 2008-05-30 A | 100% | 2007-12-05 | 2008-05-30 | 128d? | finish no earlier than 2008-12-25 | C5 | 1024h | 1024h | OSA8 | Telecom Italia | vincenzo.amorino@telecomitalia.it | Rel-8 | Kimmo | PXWS Framework | CP-38 | PCG-21 | PCG-21 | CP-40 |
| 631 | 197.3.12 | Delete - API usage accounting (22.127 CR 0090 S1-071792) | 128d? | 2007-12-05 A | 2008-05-30 A | 100% | 2007-12-05 | 2008-05-30 | 128d? | finish no earlier than 2008-12-25 | C5 | 1024h | 1024h | OSA8 | Telecom Italia | vincenzo.amorino@telecomitalia.it | Rel-8 | Kimmo | PXWS Framework | CP-38 | PCG-21 | PCG-21 | CP-40 |
| 632 | 197.3.13 | Presence alignment with OMA and IETF (22.127 CR 0092 S1-071764) | 128d? | 2007-12-05 A | 2008-05-30 A | 100% | 2007-12-05 | 2008-05-30 | 128d? | finish no earlier than 2008-05-30 | C5 | 1024h | 1024h | OSA8 | Alcatel-Lucent | unmehopa@alcatel-lucent.com | Rel-8 | Kimmo | 29.199-14/13 | CP-38 | PCG-21 |  |  |
| 633 | 197.3.14 | Delete - Service identification (22.127 CR 0095 S1-071837) | 128d? | 2007-12-05 A | 2008-05-30 A | 100% | 2007-12-05 | 2008-05-30 | 128d? | finish no earlier than 2008-05-30 | C5 | 1024h | 1024h | OSA8 | Ericsson | catherine.mulligan@ericsson.com | Rel-8 | Kimmo | existing 29.199-xy | CP-38 | PCG-21 | PCG-21 | CP-40 |
| 634 | 197.3.15 | Framework Enterprise Operator (Service Subscription function) | 102d? | 2008-01-10 A | 2008-05-30 A | 100% | 2008-01-10 | 2008-05-30 | 102d? | finish no earlier than 2008-05-30 | C5 | 816h | 816h | OSA8 | Alcatel-Lucent | unmehopa@alcatel-lucent.com | Rel-8 | Kimmo | 29.198-03 | CP-39 | PCG-21 |  |  |
| 635 | 197.3.16 | Mobility Emergency Location | 102d? | 2008-01-10 A | 2008-05-30 A | 100% | 2008-01-10 | 2008-05-30 | 102d? | finish no earlier than 2008-05-30 | C5 | 816h | 816h | OSA8 | Alcatel-Lucent | unmehopa@alcatel-lucent.com | Rel-8 | Kimmo | 29.198-06 | CP-39 | PCG-21 |  |  |
| 636 | 197.3.17 | Connectivity Manager SCF | 102d? | 2008-01-10 A | 2008-05-30 A | 100% | 2008-01-10 | 2008-05-30 | 102d? |  | C5 | 816h | 816h | OSA8 | Alcatel-Lucent | unmehopa@alcatel-lucent.com | Rel-8 | Kimmo | 29.198-10 | CP-39 | PCG-21 |  |  |
| 637 | 197.3.18 | PAM Presence Agent | 102d? | 2008-01-10 A | 2008-05-30 A | 100% | 2008-01-10 | 2008-05-30 | 102d? | finish no earlier than 2008-05-30 | C5 | 816h | 816h | OSA8 | Alcatel-Lucent | unmehopa@alcatel-lucent.com | Rel-8 | Kimmo | 29.198-14 | CP-39 | PCG-21 |  |  |
| 638 | 198 | **Paging Permission with Access Control (PPACR)** | 389d? | 2007-06-12 A | 2008-12-05 A | 100% | 2007-06-12 | 2008-12-05 | 389d? |  | S1,C1 | 5888h | 5888h | PPACR | NTT DoCoMo | Morita Takashi | Rel-8 | Alain |  |  |  |  |  |
| 639 | 198.1 | Stage 1 for PPACR | 69d? | 2007-06-12 A | 2007-09-14 A | 100% | 2007-06-12 | 2007-09-14 | 69d? | finish no earlier than 2007-09-14 | S1 | 552h | 552h | PPACR-S1 | NTT DoCoMo | Morita Takashi | Rel-8 | Alain | 22.011 | SP-37 |  |  |  |
| 640 | 198.2 | Stage 3 for PPACR (CT1) | 278d? | 2007-11-14 A | 2008-12-05 A | 100% | 2007-11-14 | 2008-12-05 | 278d? | finish no earlier than 2008-12-05 | C1 | 2224h | 2224h | PPACR-CT1 | NTT DoCoMo |  | Rel-8 | Frederic | 24.008, 23.122, 24.301 | CP-38 | PCG-21 |  |  |

Notes:
- 616: TSG#40 completed. New OSA work in OMA. SA1 need to remove unfulfilled Requirements to align with CT5 Stage 2/3 reality.
- 617: TSG#40 New OSA work in OMA. SA1 to remove non-fulfilled Requirements.
- 618: TSG#40 New OSA work in OMA. SA1 to remove non-fulfilled Requirements.
- 619: CP#40 WID updated CP-070349=>CP-080252. Started work completed. Unfulfilled Rel-8 Stage 1 and New OSA work to be done in OMA. SA1 needs to remove non-fulfilled requirements in 22.127
- 620: CP#40: Work moved to OMA
- 621: CP#40 completed
- 622: CP#40 completed
- 623: CP#40 completed
- 624: CP#40: Work moved to OMA
- 625: SP#38 SP-070853 R8 CRs 22.127 OSA Stage 1. CP#40: Work moved to OMA
- 626: SP#38 SP-070853 R8 CRs 22.127 OSA Stage 1. CP#40: Work moved to OMA
- 627: SP#38 SP-070853 R8 CRs 22.127 OSA Stage 1. CP#40: Work moved to OMA
- 628: SP#38 SP-070853 R8 CRs 22.127 OSA Stage 1. CP#40: Work moved to OMA
- 629: SP#38 SP-070853 R8 CRs 22.127 OSA Stage 1. CP#40: Work moved to OMA
- 630: SP#38 SP-070853 R8 CRs 22.127 OSA Stage 1. CP#40: Work moved to OMA
- 631: SP#38 SP-070853 R8 CRs 22.127 OSA Stage 1. CP#40: Work moved to OMA
- 632: CP#40 completed
- 633: SP#38 SP-070853 R8 CRs 22.127 OSA Stage 1. CP#40: Work moved to OMA
- 634: CP#40 completed
- 635: CP#40 completed
- 636: CP#40 completed
- 637: CP#40 completed
- 638: CP#42 completed. Triggered by Study UID_330016 (PPAC).
- 639: SP#37 completed
- 640: CP#42 completed

| ID | WBS | Task | Duration | Start | Finish | Complete | Remaining | Baseline start | Baseline finish | Baseline duration | Total slack | Constraint | Resources | Work | Actual work | Text1 | Text2 | Text4 | Text6 | Text7 | Text8 | Text11 |
| --- | --- | --- | --- | --- | --- | --- | --- | --- | --- | --- | --- | --- | --- | --- | --- | --- | --- | --- | --- | --- | --- | --- |
| 641 | 199 | **Charging for multi-phases services** | 70d? | 2007-12-06 A | 2008-03-12 A | 100% |  | 2007-12-06 | 2008-03-12 | 70d? |  |  | S1 | 560h | 560h | CHRGMPH | PCG-21 | Telecom Italia | Rel-8 | SP-38 | Alain |  |
| 642 | 199.1 | Stage 1 for CHRGMPH | 70d? | 2007-12-06 A | 2008-03-12 A | 100% |  | 2007-12-06 | 2008-03-12 | 70d? |  | start no earlier than 2007-12-06 | S1 | 560h | 560h | CHRGMPH-s1 | PCG-21 | Telecom Italia | Rel-8 | SP-38 | Alain |  |
| 643 | 200 | **Home NodeB / eNodeB** | 327d? | 2007-12-06 A | 2009-03-06 A | 100% |  | 2007-12-06 | 2009-03-06 | 327d? |  |  | S1,C1,C4 | 5720h | 5720h | HomeNB | PCG-21 | Vodafone | Rel-8 | SP-38 | Alain |  |
| 644 | 200.1 | Stage 1 for HNB_eHNB | 70d? | 2007-12-06 A | 2008-03-12 A | 100% |  | 2007-12-06 | 2008-03-12 | 70d? |  | start no earlier than 2007-12-06 | S1 | 560h | 560h | HomeNB-S1 | PCG-21 | Vodafone | Rel-8 | SP-38 | Alain |  |
| 645 | 200.2 | CSG and Idle Mode Mobility for LTE Home eNodeB | 126d? | 2008-09-12 A | 2009-03-06 A | 100% |  | 2008-09-12 | 2009-03-06 | 126d? |  | finish no earlier than 2009-03-06 | C1 | 1008h | 1008h | HomeNB-LTE | PCG-21 | Huawei | Rel-8 | CP-41 | Frederic |  |
| 646 | 200.3 | CSG and Idle Mode Mobility for 3G Home NodeB | 126d? | 2008-09-12 A | 2009-03-06 A | 100% |  | 2008-09-12 | 2009-03-06 | 126d? |  | finish no earlier than 2009-03-06 | C1 | 1008h | 1008h | HomeNB-3G | PCG-21 | Qualcomm Europe | Rel-8 | CP-41 | Frederic |  |
| 647 | 200.4 | Support of Closed Subscriber Group (CSG) | 66d? | 2008-12-05 A | 2009-03-06 A | 100% |  | 2008-12-05 | 2009-03-06 | 66d? |  | finish no earlier than 2009-03-06 | C4 | 528h | 528h | HomeNB | PCG-22 | CT#42 | Rel-8 | CP-42 | Kimmo | CT#42 report |
| 648 | 201 | **UTRA HNB** | 326d? | 2008-03-07 A | 2009-06-04 A | 100% |  | 2008-03-07 | 2009-06-04 | 326d? |  |  | RP,S5 | 6832h | 6832h | HNB | PCG-21 |  | Rel-8 | SP-39 | Issam |  |
| 649 | 201.1 | Support of UTRA HNB | 201d? | 2008-05-30 A | 2009-03-06 A | 100% |  | 2008-05-30 | 2009-03-06 | 201d? |  | finish no earlier than 2009-03-06 | R2 | 1608h | 1608h | HNB-supp | PCG-21 | Huawei | Rel-8 | SP-40 | Joern | RP-090040 |
| 650 | 201.2 | FDD Home NodeB RF requirements | 261d? | 2008-03-07 A | 2009-03-06 A | 100% |  | 2008-03-07 | 2009-03-06 | 261d? |  | finish no earlier than 2009-03-06 | R4 | 2088h | 2088h | HNB-RF | PCG-21 | Motorola | Rel-8 | SP-39 | Issam | RP-090041 |
| 651 | 201.3 | UTRAN Architecture for 3G HNB | 136d? | 2008-05-30 A | 2008-12-05 A | 100% |  | 2008-05-30 | 2008-12-05 | 136d? |  | finish no earlier than 2008-12-05 | R3 | 1088h | 1088h | HNB-arch | PCG-21 | Alcatel-Lucent | Rel-8 | SP-40 | Juha | RP-090042 |
| 652 | 201.4 | 3G Home NodeB OAM&P Type 1 Management Interface | 127d? | 2008-12-11 A | 2009-06-04 A | 100% |  | 2008-12-11 | 2009-06-04 | 127d? |  | finish no earlier than 2009-06-04 | S5 | 1008h | 1008h | HNB-3G_OAM | PCG-22 | Huawei | Rel-8 | SP-42 | Dionisio |  |
| 653 | 202 | **UTRA HNB – UE Conformance Testing** | 327d? | 2009-03-06 A | 2010-06-04 | 60% | 130.8d? | 2009-03-06 | 2010-06-04 | 327d? | 596d |  | R5 | 5224h | 3134.4h | HNB-UEConTest | PCG-22 |  | Rel-8 | RP-43 | Ingbert |  |
| 654 | 202.1 | Conformance Test Aspects – UTRA HNB (FDD) | 326d? | 2009-03-06 A | 2010-06-04 | 60% | 130.4d? | 2009-03-06 | 2010-06-04 | 326d? | 596d | finish no earlier than 2010-06-04 | R5 | 2608h | 1564.8h | HNB-UEConTestFDD | PCG-22 | Huawei | Rel-8 | RP-43 | Ingbert | RP-091065 |
| 655 | 203 | Lawful Interception in the 3GPP Rel-8 | 524d? | 2007-03-12 A | 2009-03-12 A | 100% |  | 2007-03-12 | 2009-03-12 | 524d? |  | finish no earlier than 2009-03-12 | S3 | 4192h | 4192h | LI8 |  | BMWI, Verizon | Rel-8 |  | Dionisio |  |
| 656 | 204 | **Generic Bootstrapping Architecture Push Function** | 258d? | 2008-03-12 A | 2009-03-06 A | 100% |  | 2008-03-12 | 2009-03-06 | 258d? |  |  | S3,C1,C4 | 6468.8h | 6468.8h | GBAPush | PCG-21 | Ericsson | Rel-8 | SP-39 | Dionisio |  |
| 657 | 204.1 | SA3 part of GBAPush (33.223) | 193d? | 2008-03-12 A | 2008-12-05 A | 100% |  | 2008-03-12 | 2008-12-05 | 193d? |  | finish no earlier than 2008-12-05 | S3 | 1544h | 1544h | GBAPush | PCG-21 | Ericsson | Rel-8 | SP-39 | Dionisio |  |
| 658 | 204.2 | CT1 part of GBAPush | 178.8d? | 2008-03-12 A | 2009-03-06 A | 100% |  | 2008-03-12 | 2009-03-06 | 178.8d? |  | finish no earlier than 2009-03-06 | C1 | 1430.4h | 1430.4h | GBAPush | PCG-21 | Ericsson | Rel-8 | SP-39 | Frederic |  |
| 659 | 204.3 | CT4 part of GBAPush | 178.8d? | 2008-03-12 A | 2009-03-06 A | 100% |  | 2008-03-12 | 2009-03-06 | 178.8d? |  | finish no earlier than 2009-03-06 | C4 | 1430.4h | 1430.4h | GBAPush | PCG-21 | Ericsson | Rel-8 | SP-39 | Kimmo |  |
| 660 | 205 | Requirements and Test methods for Wideband Terminals | 197d? | 2008-03-12 A | 2008-12-11 A | 100% |  | 2008-03-12 | 2008-12-11 | 197d? |  | start no earlier than 2008-03-12 | S4 | 1576h | 1576h | RETEM_WB_T |  | FT, Ericsson | Rel-8 |  | Paolo |  |
| 661 | 206 | Extending PSS and MBMS User Services for optimized Mobile TV | 266d? | 2007-12-06 A | 2008-12-11 A | 100% |  | 2007-12-06 | 2008-12-11 | 266d? |  | finish no earlier than 2008-12-11 | S4 | 2128h | 2128h | PSS_MBMS_OMTV |  | Ericsson | Rel-8 |  | Paolo |  |
| 662 | 207 | **Encoding formats, transport formats and media description signalling for interworking, QoE, and other enhancements to MTSI-MHI** | 331d? | 2007-12-06 A | 2009-03-12 A | 100% |  | 2007-12-06 | 2009-03-12 | 331d? |  |  | S4,C3,C1,C4 | 9640h | 9640h | MTSI_eMHI | PCG-21 | Ericsson, Qualcomm Europe | Rel-8 | SP-40 | Paolo |  |
| 663 | 207.1 | MTSI Video - Dynamic Rate Adaptation/Signalling of Image Size | 331d? | 2007-12-06 A | 2009-03-12 A | 100% |  | 2007-12-06 | 2009-03-12 | 331d? |  | finish no earlier than 2009-03-12 | S4 | 2648h | 2648h | MTSI_eMHI-DRASIS |  | Qualcomm Europe, Samsung | Rel-8 |  | Paolo |  |
| 664 | 207.2 | CT3 part of Enhancement of interworking between MTSI and CS networks | 201d? | 2008-05-30 A | 2009-03-06 A | 100% |  | 2008-05-30 | 2009-03-06 | 201d? |  | finish no earlier than 2009-03-06 | C3 | 1608h | 1608h | MTSI_eMHI | PCG-21 | Huawei | Rel-8 | CP-40 | Gwiho |  |
| 665 | 207.3 | CT1 part of Enhancement of interworking between MTSI and CS networks | 141d? | 2008-05-30 A | 2008-12-12 A | 100% |  | 2008-05-30 | 2008-12-12 | 141d? |  | start no earlier than 2008-05-30 | C1 | 1128h | 1128h | MTSI_eMHI | PCG-21 | Huawei | Rel-8 | CP-40 | Frederic |  |
| 666 | 207.4 | CT4 part of Enhancement of interworking between MTSI and CS networks | 201d? | 2008-05-30 A | 2009-03-06 A | 100% |  | 2008-05-30 | 2009-03-06 | 201d? |  | finish no earlier than 2009-03-06 | C4 | 1608h | 1608h | MTSI_eMHI | PCG-21 | Huawei | Rel-8 | CP-40 | Kimmo |  |

Notes:
- 641: SP#39 Stage 1 completed / Text3: 22.115 / Text5: Marco.DeLuca1@telecomitalia.it
- 642: SP#39 completed / Text3: 22.115 / Text5: Marco.DeLuca1@telecomitalia.it
- 643: CP#43 completed. SP#39 Stage 1 completed / Text5: John Watson
- 644: SP#39 completed / Text3: 22.011, 22.115 / Text5: John Watson
- 645: CP#43 completed / Text3: 23.122, 24.301, 24.801, 24.285 / Text5: zhang.peng@huawei.com
- 646: CP#43 completed / Text3: 23.122, 24.008, 24.285 / Text5: Osok Song
- 647: CP#43 completed. SP#42 SP-080874 22.011CR0141 confirmed Requirement to support roaming subscribers with CSG home network subscription but did NOT confirmed requirement for home network independent support of roamers in CSG / Text3: 29.002, 29.272, 23.008, 23.003 / Text5: Hannu Hietalahti
- 648: RP#43 completed. SP#44 completed
- 649: RP#43 completed. RP#41 WID updated RP-080483=>RP-080752. / Text3: 25.304, 25.306, 25.331, 25.367 / Text5: Yang Xudong (yangxudong@huawei.com)
- 650: RP#43 completed / Text3: 25.104, 25.141, 25.967 / Text5: Ying Cai (yingcai@motorola.com)
- 651: RP#42 completed / Text3: 25.401, 25.410, 25.412, 25.413, 25.414, 25.415, 25.467, 25.468, 25.469 / Text5: Martin Warner (mw15@alcatel-lucent.com)
- 652: SP#44 completed. Complements work in BroadBand Forum / Text3: 32.581, 32.582, 32.583, 32.584 / Text5: Zou Lan (zlan@huawei.com)
- 653: Testing for Feature UID_390033 UTRA HNB
- 654: RP#46 completion 12/09=>06/10 / Text3: 34.108, 34.123-1, 34.123-2, 34.123-3 / Text5: Trica Li (trica_li@huawei.com)
- 655: SP#43 completed / Text3: 33.106, 33.107, 33.108 / Text5: berthold.wilhelm@bnetza.de, ron_ryan@verizon.net
- 656: CP#43 completed / Text5: Rolf Blom
- 657: SP#42 completed 33.223 as Rel-8. TS 33.224 moved to Rel-9 under new UID_420039 / Text3: 33.223 / Text5: Rolf Blom
- 658: CP#43 completed / Text3: 24.109 / Text5: Rolf Blom
- 659: CP#43 completed / Text3: 29.109 / Text5: Rolf Blom
- 660: SP#42 completed. SP#39 WID approved. / Text3: 26.131, 26.132 / Text5: stephane.ragot@orange-ftgroup.com, wanqing.shi@sonyericsson.com
- 661: SP#42 completed. SP#38 WID approved. / Text3: 26.234, 26.346, 26.946 / Text5: thorsten.lohmar@ericsson.com
- 662: TSG#43 completed / Text5: olle.franceschi@ericsson.com, nleung@qualcomm.com
- 663: SP#43 completed. SP#40 WID updated SP-070755=>SP-080246. [Feature=>BB under new Feature UID_400028 (MTSI)] / Text3: 26.114 / Text5: nleung@qualcomm.com & kyunghun.jung@samsung.com
- 664: CP#43 completed / Text3: 29.163 / Text5: Tingfang Tang (tagna_online@huawei.com)
- 665: CP#42 completed (No CT1-impact). WID updated CP-080422=>CP-080774 / Text5: Tingfang Tang (tagna_online@huawei.com)
- 666: CP#43 completed / Text3: 29.332 / Text5: Tingfang Tang (tagna_online@huawei.com)

| ID | WBS | Task | Duration | Start | Finish | Complete | Baseline start | Baseline finish | Baseline duration | Constraint | Resources | Work | Actual work | Text1 | Text6 | Text8 | Text4 | Text5 | Text2 | Text7 | Text9 | Text12 |
| --- | --- | --- | --- | --- | --- | --- | --- | --- | --- | --- | --- | --- | --- | --- | --- | --- | --- | --- | --- | --- | --- | --- |
| 667 | 208 | **OAM&P 8** | 653d? | 2007-06-07 A | 2009-12-04 A | 100% | 2007-06-07 | 2009-12-04 | 653d? |  | S5,C1 | 43227.2h | 43227.2h | OAM8 | Rel-8 | Dionisio |  |  |  |  |  |  |
| 668 | 208.1 | **Network Infrastructure Management** | 653d? | 2007-06-07 A | 2009-12-04 A | 100% | 2007-06-07 | 2009-12-04 | 653d? |  | S5 | 19464h | 19464h | OAM8-NIM | Rel-8 | Dionisio |  |  |  |  |  |  |
| 669 | 208.1.1 | Telecom Management Methodology | 461d? | 2007-06-07 A | 2009-03-12 A | 100% | 2007-06-07 | 2009-03-12 | 461d? | finish no earlier than 2009-03-12 | S5 | 3688h | 3688h | OAM8 | Rel-8 | Dionisio | Ericsson | thomas.tovinger@ericsson.com |  |  |  |  |
| 670 | 208.1.2 | Advanced Alarming on Itf-N | 266d? | 2007-06-07 A | 2008-06-12 A | 100% | 2007-06-07 | 2008-06-12 | 266d? | finish no earlier than 2008-12-11 | S5 | 2128h | 2128h | OAM8 | Rel-8 | Dionisio | Nokia Siemens Networks | SUERBAUM, Clemens |  |  |  |  |
| 671 | 208.1.3 | CN CS Bearer Transport Network (BTN) relative NRM | 266d? | 2007-06-07 A | 2008-06-12 A | 100% | 2007-06-07 | 2008-06-12 | 266d? | finish no earlier than 2008-12-11 | S5 | 2128h | 2128h | OAM8 | Rel-8 | Dionisio | China Mobile | LI, Jian |  |  |  |  |
| 672 | 208.1.4 | Alignment with eTOM and M.3060 architectural concepts | 210d? | 2008-02-22 A | 2008-12-11 A | 100% | 2008-02-22 | 2008-12-11 | 210d? | start no earlier than 2008-02-22 | S5 | 1680h | 1680h | OAM8 | Rel-8 | Dionisio | TeliaSonera | Berggren, Tommy | PCG-21 | SP-39 |  |  |
| 673 | 208.1.5 | IRP SOAP Solution Sets | 201d? | 2008-06-05 A | 2009-03-12 A | 100% | 2008-06-05 | 2009-03-12 | 201d? | finish no earlier than 2009-03-12 | S5 | 1608h | 1608h | OAM8 | Rel-8 | Dionisio | Ericsson | edwin.tse@ericsson.com | PCG-21 | SP-40 |  |  |
| 674 | 208.1.6 | Create missing specifications for IRP XML definitions | 52d? | 2009-09-24 A | 2009-12-04 A | 100% | 2009-09-24 | 2009-12-04 | 52d? | finish no earlier than 2010-03-12 | S5 | 416h | 416h | OAM8 | Rel-8 | Dionisio | ZTE | Shuqiang Huang (huangsq@zte.com.cn) | PCG-23 | SP-45 |  |  |
| 675 | 208.1.7 | Deleted - End point modelling for reference point | 324d? | 2007-09-17 A | 2008-12-11 A | 100% | 2007-09-17 | 2008-12-11 | 324d? | finish no earlier than 2008-12-11 | S5 | 2592h | 2592h | OAM8 | Rel-8 | Dionisio | Motorola | YAO, Yizhi |  | SP-37 | PCG-21 | SP-41 |
| 676 | 208.2 | **Performance Management** | 461d? | 2007-06-07 A | 2009-03-12 A | 100% | 2007-06-07 | 2009-03-12 | 461d? |  | S5 | 13712h | 13712h | OAM8-PM | Rel-8 | Dionisio |  |  |  |  |  |  |
| 677 | 208.2.1 | IP bearer network Performance measurement definitions | 396d? | 2007-06-07 A | 2008-12-11 A | 100% | 2007-06-07 | 2008-12-11 | 396d? | finish no earlier than 2008-12-11 | S5 | 3168h | 3168h | OAM8 | Rel-8 | Dionisio | China Mobile | lilianyuan@chinamobile.com |  |  |  |  |
| 678 | 208.2.2 | HSUPA performance measurements | 396d? | 2007-06-07 A | 2008-12-11 A | 100% | 2007-06-07 | 2008-12-11 | 396d? | finish no earlier than 2008-12-11 | S5 | 3168h | 3168h | OAM8 | Rel-8 | Dionisio | China Mobile | LI, Jian |  |  |  |  |
| 679 | 208.2.3 | Key Performance Indicators (KPIs) for UMTS and GSM | 461d? | 2007-06-07 A | 2009-03-12 A | 100% | 2007-06-07 | 2009-03-12 | 461d? | finish no earlier than 2009-03-12 | S5 | 3688h | 3688h | OAM8 | Rel-8 | Dionisio | China Mobile | Liang Shuangchun |  |  |  |  |
| 680 | 208.3 | **Trace Management** | 196d? | 2008-03-07 A | 2008-12-05 A | 100% | 2008-03-07 | 2008-12-05 | 196d? |  | S5,C1,C3,C4 | 5777.6h | 5777.6h | OAM8-Trace | Rel-8 | Dionisio |  |  |  |  |  |  |
| 681 | 208.3.1 | Service Level Tracing in IMS | 196d? | 2008-03-07 A | 2008-12-05 A | 100% | 2008-03-07 | 2008-12-05 | 196d? | finish no earlier than 2008-12-05 | C1 | 1568h | 1568h | OAM8-Trace | Rel-8 | Frederic | Vodafone | peter.dawes@vodafone.com |  |  |  |  |
| 682 | 208.3.2 | Service Level Tracing in IMS | 175.4d? | 2008-03-07 A | 2008-12-05 A | 100% | 2008-03-07 | 2008-12-05 | 175.4d? | finish no earlier than 2008-12-05 | C3 | 1403.2h | 1403.2h | OAM8-Trace | Rel-8 | Gwiho | Vodafone | peter.dawes@vodafone.com | PCG-21 | CP-40 |  |  |
| 683 | 208.3.3 | Service Level Tracing in IMS | 175.4d? | 2008-03-07 A | 2008-12-05 A | 100% | 2008-03-07 | 2008-12-05 | 175.4d? | finish no earlier than 2008-12-05 | C4 | 1403.2h | 1403.2h | OAM8-Trace | Rel-8 | Frederic | Vodafone | peter.dawes@vodafone.com | PCG-21 | CP-40 |  |  |
| 684 | 209 | **Charging Management small Enhancements** | 716d? | 2006-03-16 A | 2008-12-11 A | 100% | 2006-03-16 | 2008-12-11 | 716d? |  | S5 | 12544h | 12544h | CH8 | Rel-8 | Dionisio |  |  |  |  |  |  |
| 685 | 209.1 | Online charging correlation | 457d? | 2006-03-16 A | 2007-12-14 A | 100% | 2006-03-16 | 2007-12-14 | 457d? | start no earlier than 2006-03-16 | S5 | 3656h | 3656h | CH8 | Rel-8 | Dionisio | Orange | Chahine, Rony |  |  |  |  |
| 686 | 209.2 | SMS online charging | 137d? | 2007-06-07 A | 2007-12-14 A | 100% | 2007-06-07 | 2007-12-14 | 137d? | finish no earlier than 2007-12-14 | S5 | 1096h | 1096h | CH8 | Rel-8 | Dionisio | Vodafone | WONG, Gavin |  |  |  |  |
| 687 | 209.3 | Introduce Online Charging from SMS-SC into the SMS Charging Specifications | 61d? | 2008-09-18 A | 2008-12-11 A | 100% | 2008-09-18 | 2008-12-11 | 61d? | finish no earlier than 2008-12-11 | S5 | 488h | 488h | CH8 | Rel-8 | Dionisio | Acision | Gebler, Erik - Acision [erik.gebler (at) acision.com] | PCG-21 | SP-41 |  |  |
| 688 | 209.4 | Deleted - WLAN Offline Charging | 244d? | 2008-01-07 A | 2008-12-11 A | 100% | 2008-01-07 | 2008-12-11 | 244d? | finish no earlier than 2008-12-11 | S5 | 1952h | 1952h | CH8 | Rel-8 | Dionisio | Alcatel-Lucent | GARDELLA, Maryse | PCG-21 | SP-38 | PCG-22 | SP-42 |
| 689 | 210 | **Conferencing enhancements for Mp interface** | 266d? | 2007-11-30 A | 2008-12-05 A | 100% | 2007-11-30 | 2008-12-05 | 266d? |  | C4 | 6384h | 6384h | eMp | Rel-8 | Kimmo | Huawei | Chencheng@huawei.com | PCG-21 |  |  |  |
| 690 | 210.1 | Stage 2 for eMp | 266d? | 2007-11-30 A | 2008-12-05 A | 100% | 2007-11-30 | 2008-12-05 | 266d? | finish no earlier than 2008-12-11 | C4 | 2128h | 2128h | eMp | Rel-8 | Kimmo | Huawei | Chencheng@huawei.com | PCG-21 | CP-38 |  |  |
| 691 | 210.2 | Stage 3 for eMp | 266d? | 2007-11-30 A | 2008-12-05 A | 100% | 2007-11-30 | 2008-12-05 | 266d? | finish no earlier than 2008-12-05 | C4 | 2128h | 2128h | eMp | Rel-8 | Kimmo | Huawei | Chencheng@huawei.com | PCG-21 | CP-38 |  |  |

Notes:
- 667: -
- 668: -
- 669: SP#43 completed / Text3: 32.155, 32.153
- 670: SP#40 completed / Text3: 32.121, 32.122, 32.123
- 671: SP#40 completed / Text3: 32.632/3/5
- 672: SP#42 completed / Text3: 32.101/2, 32-series
- 673: SP#43 completed. WID updated SP-080276=>SP-090148 (removed the planned but not delivered new TSs 32.127, 32.327, 32.337, 32.357, 32.387, 32.397, 32.447) / Text3: 32.111-7, 32.617, 32.417, 32.367, 32.347, 32.111-1, 32.111-2, 32.111-3, 32.111-5, 32.307, 32.317, 32.341, 32.342, 32.343, 32.345, 32.361, 32.362, 32.363, 32.365, 32.411, 32.412, 32.413, 32.415, 32.611, 32.612, 32.613, 32.615, 32.625
- 674: SP#46 completed. Create missing XML definitions specs for IRPs (Advanced Alarm Management, Communication Surveillance, Self-Configuration of Network Elements, Software Management) needed for implementation of Rel-8 Notification Log IRP (TS 32.33x) / Text3: new TS (32.125, 32.355, 32.505, 32.535), 32.150, 32.153, 32.335
- 675: SP#41 Work stopped. Contributions related to E-UTRAN/EPC to be submitted to UID_380036 E-UTRAN NRM IRP/ UID_380037 EPC NRM IRP / Text3: 32.152, 32.62/3/4x, 32.73x
- 676: -
- 677: SP#42 completed. SP#36 WID updated SP-050319=>SP-070301 / Text3: 32.321/2/3/5
- 678: SP#42 completed / Text3: 32.405
- 679: SP#43 completed / Text3: 32.410
- 680: -
- 681: CP#42 completed. CP#40 WID updated CP-060521=>CP-080315. / Text3: 24.323, 24.229
- 682: CP#42 completed (No CT3-impact). CP#40 WID updated CP-060521=>CP-080315
- 683: CP#42 completed. CP#40 WID updated CP-060521=>CP-080315. / Text3: 29.228, 29.229
- 684: SP#42 completed.
- 685: SP#38 completed / Text3: 32.296
- 686: SP#38 completed / Text3: 32.274, 32.240/299
- 687: SP#42 completed. Linked to SA2 UID 32081 (Support of SMS over IP networks) and CT4 UID 340016 (Routeing of MT-SMS via the HPLMN). / Text3: 32.274, 32.299
- 688: SP#42 stopped / Text3: 32.252, 32.298, 32.299
- 689: CP#42 completed. WID updated CP-070868=>CP-080725
- 690: CP#42 completed. WID updated CP-070868=>CP-080725 / Text3: 23.333
- 691: CP#42 completed. WID updated CP-070868=>CP-080725 / Text3: 29.333

| ID | WBS | Task | Type | Duration | Start | Finish | Complete | Baseline start | Baseline finish | Baseline duration | Total slack | Constraint | Resources | Work | Actual work | Text1 | Text4 | Text5 | Text6 | Text8 | Text7 | Text12 | Text2 | Text11 |
| --- | --- | --- | --- | --- | --- | --- | --- | --- | --- | --- | --- | --- | --- | --- | --- | --- | --- | --- | --- | --- | --- | --- | --- | --- |
| 692 | 211 | **Contact Manager for 3GPP UICC applications** |  | 642d? | 2006-06-22 A | 2008-12-05 A | 100% | 2006-06-22 | 2008-12-05 | 642d? |  |  | C6 | 13352h | 13352h | eUPHBOOK | Gemalto | Jacques.seif@gemalto.com | Rel-8 | Xavier |  |  |  |  |
| 693 | 211.1 | Requirements for Contact Manager |  | 392d? | 2006-06-22 A | 2007-12-21 A | 100% | 2006-06-22 | 2007-12-21 | 392d? |  | finish no earlier than 2007-12-21 | C6 | 3136h | 3136h | eUPHBOOK-St1 | Gemalto | Jacques.seif@gemalto.com | Rel-8 | Xavier |  |  |  |  |
| 694 | 211.2 | External interface for eUPHBOOK |  | 220d? | 2007-05-07 A | 2008-03-07 A | 100% | 2007-05-07 | 2008-03-07 | 220d? |  | finish no earlier than 2008-03-07 | C6 | 1760h | 1760h | eUPHBOOK-Ext_Spec | Gemalto | Jacques.seif@gemalto.com | Rel-8 | Xavier |  |  |  |  |
| 695 | 211.3 | Internal interface for eUPHBOOK |  | 415d? | 2007-05-07 A | 2008-12-05 A | 100% | 2007-05-07 | 2008-12-05 | 415d? |  | finish no earlier than 2008-12-05 | C6 | 3320h | 3320h | eUPHBOOK-Int_Spec | Gemalto | Jacques.seif@gemalto.com | Rel-8 | Xavier | CP-37 |  |  |  |
| 696 | 211.4 | Deleted - Implementation of eUPHBOOK | milestone | 0d? | 2007-06-21 A | 2007-06-21 A | 100% | 2007-06-21 | 2007-06-21 | 0d? |  | start no earlier than 2007-06-21 | C6 |  |  | eUPHBOOK-St23 | Giesecke & Devrient | Claus Dietze | Rel-8 | Xavier |  | SP-33 |  |  |
| 697 | 212 | **Contact Manager Conformance Test specifications** |  | 396d? | 2008-06-02 | 2009-12-04 |  | 2008-06-02 | 2009-12-04 | 396d? | 726d |  | C6 | 9504h |  | eUPHBOOK-Test | Comprion, Gemalto | Udo Willenbrink, Jacques Seif | Rel-8 | Xavier | CP-40 |  | PCG-21 |  |
| 698 | 212.1 | Contact Manager for 3GPP UICC applications test specifications |  | 396d? | 2008-06-02 | 2009-12-04 |  | 2008-06-02 | 2009-12-04 | 396d? | 726d | finish no earlier than 2009-12-04 | C6 | 3168h |  | eUPHBOOK-Test | Comprion | Udo Willenbrink | Rel-8 | Xavier | CP-40 |  | PCG-21 |  |
| 699 | 212.2 | Contact Manager API for Java™ Card test specification |  | 396d? | 2008-06-02 | 2009-12-04 |  | 2008-06-02 | 2009-12-04 | 396d? | 726d | finish no earlier than 2009-12-04 | C6 | 3168h |  | eUPHBOOK-Test | Gemalto | jacques.seif@gemalto.com | Rel-8 | Xavier | CP-40 |  | PCG-21 |  |
| 700 | 213 | **Rel-8 LTE – 3G Long Term Evolution - Evolved Packet System RAN part** |  | 644d? | 2006-09-25 A | 2009-03-12 A | 100% | 2006-09-25 | 2009-03-12 | 644d? |  |  | RP,S5 | 44896h | 44896h | LTE | NTT DoCoMo | Takehiro Nakamura (nakamurata@nttdocomo.co.jp) | Rel-8 |  |  |  |  | RP-080741 |
| 701 | 213.1 | LTE – Physical Layer |  | 380d? | 2006-09-25 A | 2008-03-07 A | 100% | 2006-09-25 | 2008-03-07 | 380d? |  | finish no earlier than 2007-09-14 | R1 | 3040h | 3040h | LTE-Phys | NTT DoCoMo | Sadayuki Abeta | Rel-8 | Patrick |  |  |  | RP-080741 |
| 702 | 213.2 | LTE – Radio Interface Layer 2 and 3 Protocol Aspect |  | 575d? | 2006-09-25 A | 2008-12-05 A | 100% | 2006-09-25 | 2008-12-05 | 575d? |  | finish no earlier than 2008-12-11 | R2 | 4600h | 4600h | LTE-L23 | Nokia Siemens Networks | benoist.sebire@nokia.com | Rel-8 | Joern |  |  |  | RP-080741 |
| 703 | 213.3 | LTE – eUTRAN Interfaces |  | 575d? | 2006-09-25 A | 2008-12-05 A | 100% | 2006-09-25 | 2008-12-05 | 575d? |  | finish no earlier than 2008-12-11 | R3 | 4600h | 4600h | LTE-interfaces | Ericsson | Martin Israelsson | Rel-8 | Juha |  |  |  | RP-080741 |
| 704 | 213.4 | LTE – Evolved UTRA and UTRAN RF Radio Transmission/Reception, System Performance Requirements and Conformance Testing |  | 575d? | 2006-09-25 A | 2008-12-05 A | 100% | 2006-09-25 | 2008-12-05 | 575d? |  | finish no earlier than 2008-12-11 | R4 | 4600h | 4600h | LTE-RF | Nokia Siemens Networks | Tuomo Saynajakangas | Rel-8 | Issam |  |  |  | RP-080741 |
| 705 | 213.5 | LTE – FDD repeaters |  | 386d? | 2007-09-14 A | 2009-03-06 A | 100% | 2007-09-14 | 2009-03-06 | 386d? |  | finish no earlier than 2009-03-06 | R4 | 3088h | 3088h | LTE-Repeaters | Powerwave Technologies, Andrew Wireless | ralf.michanikl@andrew.com, Alf.Ahlstrom@pwav.com | Rel-8 | Issam | RP-37 |  |  | RP-090037 |
| 706 | 213.6 | **E-UTRAN Data Definitions** |  | 389d? | 2007-09-17 A | 2009-03-12 A | 100% | 2007-09-17 | 2009-03-12 | 389d? |  |  | S5 | 13096h | 13096h | E-UTRAN-OAM |  |  | Rel-8 | Dionisio | SP-39 |  | PCG-21 |  |
| 707 | 213.6.1 | Subscriber and Equipment Trace for E-UTRAN and EPC |  | 389d? | 2007-09-17 A | 2009-03-12 A | 100% | 2007-09-17 | 2009-03-12 | 389d? |  | finish no earlier than 2009-03-12 | S5 | 3112h | 3112h | E-UTRAN-OAM | Ericsson | PETERSEN, Robert | Rel-8 | Dionisio | SP-37 |  |  |  |
| 708 | 213.6.2 | E-UTRAN Network Resource Model (NRM) Integration Reference Point (IRP) |  | 309d? | 2008-01-07 A | 2009-03-12 A | 100% | 2008-01-07 | 2009-03-12 | 309d? |  | finish no earlier than 2009-03-12 | S5 | 2472h | 2472h | E-UTRAN-OAM | Ericsson | ELMDAHL, Per | Rel-8 | Dionisio | SP-38 |  | PCG-21 |  |
| 709 | 213.6.3 | Performance measurements for E-UTRAN |  | 275d? | 2008-02-22 A | 2009-03-12 A | 100% | 2008-02-22 | 2009-03-12 | 275d? |  | finish no earlier than 2009-03-12 | S5 | 2200h | 2200h | E-UTRAN-OAM | Motorola, Huawei | YAO, Yizhi | Rel-8 | Dionisio | SP-39 |  | PCG-21 |  |
| 710 | 213.6.4 | Key Performance Indicators (KPIs) for E-UTRAN |  | 275d? | 2008-02-22 A | 2009-03-12 A | 100% | 2008-02-22 | 2009-03-12 | 275d? |  | finish no earlier than 2009-03-12 | S5 | 2200h | 2200h | E-UTRAN-OAM | Ericsson | HÜBINETTE, Ulf | Rel-8 | Dionisio | SP-39 |  | PCG-21 |  |
| 711 | 213.7 | **Self-Organizing Networks (SON)** |  | 210d? | 2008-02-22 A | 2008-12-11 A | 100% | 2008-02-22 | 2008-12-11 | 210d? |  |  | S5 | 6720h | 6720h | LTE_SON-OAM | Vodafone | GOMPAKIS, Panagiotis | Rel-8 | Dionisio | SP-39 |  | PCG-21 |  |
| 712 | 213.7.1 | SON Concepts and requirements |  | 210d? | 2008-02-22 A | 2008-12-11 A | 100% | 2008-02-22 | 2008-12-11 | 210d? |  |  | S5 | 1680h | 1680h | LTE_SON-OAM | Vodafone | GOMPAKIS, Panagiotis | Rel-8 | Dionisio | SP-39 |  | PCG-21 |  |
| 713 | 213.7.2 | Self-Establishment of eNBs, including automated Software Management |  | 210d? | 2008-02-22 A | 2008-12-11 A | 100% | 2008-02-22 | 2008-12-11 | 210d? |  | start no earlier than 2008-02-22 | S5 | 1680h | 1680h | LTE_SON-OAM | Nokia Siemens Networks | SUERBAUM, Clemens | Rel-8 | Dionisio | SP-39 |  | PCG-21 |  |
| 714 | 213.7.3 | SON Automatic Neighbour Relations (ANR) List Management |  | 210d? | 2008-02-22 A | 2008-12-11 A | 100% | 2008-02-22 | 2008-12-11 | 210d? |  | finish no earlier than 2008-12-11 | S5 | 1680h | 1680h | LTE_SON-OAM | Ericsson | edwin.tse@ericsson.com | Rel-8 | Dionisio | SP-39 |  | PCG-21 |  |
| 715 | 214 | **Rel-8 LTE – Terminal Conformance Test Specification** |  | 657d? | 2007-06-01 A | 2009-12-04 A | 100% | 2007-06-01 | 2009-12-04 | 657d? |  |  | R5 | 14336h | 14336h | LTE-UEConTest |  |  | Rel-8 | Ingbert |  |  |  |  |
| 716 | 214.1 | 3G LTE – Terminal Protocol Conformance Test Specifications |  | 657d? | 2007-06-01 A | 2009-12-04 A | 100% | 2007-06-01 | 2009-12-04 | 657d? |  | finish no earlier than 2009-12-04 | R5 | 5256h | 5256h | LTE-UEConTest_SIG | NEC, Motorola | david.lecompte@nectech.fr, Jacob.John@motorola.com | Rel-8 | Ingbert |  |  |  | RP-091060 |
| 717 | 214.2 | LTE – Terminal Radio Transmission and Reception Conformance Test Specifications |  | 657d? | 2007-06-01 A | 2009-12-04 A | 100% | 2007-06-01 | 2009-12-04 | 657d? |  |  | R5 | 5256h | 5256h | LTE-UEConTest_RF | Agilent | andrea_leonardi@agilent.com | Rel-8 | Ingbert |  |  |  | RP-091059 |

Notes:
- 692: CP#42 completed. CP#40: WID updated CP-070622=>CP-080382. aka Enhanced USIM phonebook
- 693: CP#38 completed / Text3: 21.111
- 694: CP#39 completed / Text3: 31.220
- 695: CP#42 completed / Text3: 31.221
- 696: SP#33 stopped / Text3: 31.102
- 697: CP#45 work not started
- 698: CP#45 work not started / Text3: 31.320 (external interface for communication with the ME)
- 699: CP#45 work not started / Text3: 31.321 (internal interface (API))
- 700: RP#43 completed. Role model for SAE/LTE system wide project management by SA2 in SP-060166 / Text3: 36.300, 36.938
- 701: RP#39 completed. / Text3: 36.201, 36.211, 36.212, 36.213, 36.214, 25.215, 25.225
- 702: RP#42 completed. ASN.1 freezing target 03/09 / Text3: 36.302, 36.304, 36.306, 36.314, 36.321, 36.322, 36.323, 36.331, 25.302, 25.304, 25.331
- 703: RP#42 completed / Text3: 36.401, 36.410, 36.411, 36.412, 36.413, 36.414, 36.420, 36.421, 36.422, 36.423, 36.424, 25.413
- 704: RP#42 completed (closed at 95%) / Text3: 36.101, 36.104, 36.113, 36.124, 36.133, 36.141, 36.942, 25.123, 25.133
- 705: RP#43 completed / Text3: 36.106, 36.143, 25.113
- 706: SP#43 completed
- 707: SP#43 completed / Text3: 32.42x, 32.44x
- 708: SP#43 completed / Text3: 32.761, 32.762, 32.763, 32.765
- 709: SP#43 completed / Text3: 32.425
- 710: SP#43 completed / Text3: 32.450, 32.451
- 711: SP#42 completed (WT UID_390007 moved to Rel-9). SP#40 updated WID SP-080064=>SP-080275.
- 712: SP#42 completed. SP#40 updated WID SP-080064=>SP-080275. SP#41 UID_390004 split to monitor 32.500 progress. / Text3: 32.500
- 713: SP#42 completed. WID updated SP-080065=>SP-080849 / Text3: 32.501, 32.502, 32.531, 32.532, 32.533
- 714: SP#42 completed / Text3: 32.511, 32.761, 32.762, 32.763, 32.765
- 715: Testing for Feature UID_20068 (LTE)
- 716: RP#46 completed / Text3: 36.521-1, 36.521-2, 36.508, 36.509, 36.523-1, 36.523-2, 36.523-3
- 717: RP#46 completed / Text3: 36.521-1, 36.521-2, 36.521-3

| ID | WBS | Task | Duration | Start | Finish | Complete | Baseline start | Baseline finish | Baseline duration | Constraint | Resources | Work | Actual work | Text1 | Text6 | Text8 | Text4 | Text5 | Text11 | Text2 | Text7 | Text9 | Text12 |
| --- | --- | --- | --- | --- | --- | --- | --- | --- | --- | --- | --- | --- | --- | --- | --- | --- | --- | --- | --- | --- | --- | --- | --- |
| 718 | 215 | **Rel-8 Improvements of the Radio Interface** | 525d? | 2007-03-05 A | 2009-03-06 A | 100% | 2007-03-05 | 2009-03-06 | 525d? |  | RP | 18152h | 18152h | RInImp8 | Rel-8 | Issam |  |  |  |  |  |  |  |
| 719 | 215.1 | UMTS 1500 MHz | 140d? | 2007-03-05 A | 2007-09-14 A | 100% | 2007-03-05 | 2007-09-14 | 140d? | finish no earlier than 2007-09-14 | R4 | 1120h | 1120h | RInImp8-UMTS1500 | Rel-8 | Issam | NTT DoCoMo | Takehiro Nakamura (nakamurata@nttdocomo.co.jp) | RP-070526 |  |  |  |  |
| 720 | 215.2 | UMTS 700 MHz FDD | 325d? | 2007-03-05 A | 2008-05-30 A | 100% | 2007-03-05 | 2008-05-30 | 325d? | finish no earlier than 2008-06-12 | R4 | 2600h | 2600h | RInImp8-UMTS700 | Rel-8 | Issam | Nokia | Tuomo Saynajakangas | RP-080260 |  |  |  |  |
| 721 | 215.3 | UMTS 2300 MHz TDD LCR | 195d? | 2007-12-17 A | 2008-09-12 A | 100% | 2007-12-17 | 2008-09-12 | 195d? | finish no earlier than 2008-09-12 | R4 | 1560h | 1560h | RInImp8-UMTS2300TDD | Rel-8 | Issam | CATT | songyuexia@datangmobile.cn | RP-080517 | PCG-21 | RP-38 |  |  |
| 722 | 215.4 | Further Improved Minimum Performance Requirements for HSDPA UE (FDD) - Two-Branch Interference Cancellation | 265d? | 2007-03-05 A | 2008-03-07 A | 100% | 2007-03-05 | 2008-03-07 | 265d? | finish no earlier than 2008-03-12 | R4 | 2120h | 2120h | RInImp8-2BIC | Rel-8 | Issam | AT&T | Marc Grant | RP-080041 |  |  |  |  |
| 723 | 215.5 | CS Voice Service over HSPA | 167d? | 2007-07-19 A | 2008-03-07 A | 100% | 2007-07-19 | 2008-03-07 | 167d? |  | R2 | 1336h | 1336h | RInImp8-CsHspa | Rel-8 | Joern | Nokia Siemens Networks | woonhee.hwang@nsn.com | RP-080042 |  | RP-37 |  |  |
| 724 | 215.6 | Performance requirements for 15 code reception with 16QAM/QPSK (FDD) | 126d? | 2007-06-11 A | 2008-03-07 A | 100% | 2007-06-11 | 2008-03-07 | 126d? | finish no earlier than 2008-06-12 | R4 | 1008h | 1008h | RInImp8-Hsdpa15codes | Rel-8 | Issam | Vodafone | tim.frost@vodafone.com | RP-080043 |  | RP-37 |  |  |
| 725 | 215.7 | UMTS 1880 MHz TDD | 126d? | 2008-09-12 A | 2009-03-06 A | 100% | 2008-09-12 | 2009-03-06 | 126d? | finish no earlier than 2009-03-09 | R4 | 1008h | 1008h | RInImp9-UMTS1880TDD | Rel-8 | Issam | CATT | Yuexia Song (songyuexia@datangmobile.cn) | RP-090044 | PCG-21 | RP-41 |  |  |
| 726 | 215.8 | Deleted - UMTS 2300 MHz FDD/TDD | 400d? | 2007-03-05 A | 2008-09-12 A | 100% | 2007-03-05 | 2008-09-12 | 400d? | finish no earlier than 2008-12-11 | R4 | 3200h | 3200h | RInImp8-UMTS2300 | Rel-8 | Issam | AT&T | Marc Grant | RP-080515 |  |  | PCG-21 | RP-41 |
| 727 | 216 | **Rel-8 Improvements of the Radio Interface - UE Conformance Testing** | 396d? | 2007-06-01 A | 2008-12-05 A | 100% | 2007-06-01 | 2008-12-05 | 396d? |  | R5 | 6256h | 6256h | RInImp-UEConTest | Rel-8 | Ingbert |  |  |  |  |  |  |  |
| 728 | 216.1 | Conformance Test Aspects – CS Voice Service over HSPA | 336d? | 2007-06-01 A | 2008-09-12 A | 100% | 2007-06-01 | 2008-09-12 | 336d? | finish no earlier than 2008-09-12 | R5 | 2688h | 2688h | RInImp8-CsHspa_UEConTest | Rel-8 | Ingbert | Huawei | baoyi@huawei.com | RP-080542 |  |  |  |  |
| 729 | 216.2 | Conformance Test Aspects – Performance requirements for 15 code reception with 16QAM/QPSK (FDD) | 195d? | 2008-03-07 A | 2008-12-05 A | 100% | 2008-03-07 | 2008-12-05 | 195d? | finish no earlier than 2008-12-05 | R5 | 1560h | 1560h | RInImp8-UEConTest_ Hsdpa15codes | Rel-8 | Ingbert | Ericsson | Mikael.Ziren@Ericsson.com | RP-080818 | PCG-21 | RP-40 |  |  |
| 730 | 217 | **Rel-8 RAN improvements** | 520d? | 2007-06-04 A | 2009-05-29 A | 100% | 2007-06-04 | 2009-05-29 | 520d? |  | RP | 29776h | 29776h | RANimp | Rel-8 |  |  |  |  |  |  |  |  |
| 731 | 217.1 | Combination of 64QAM and MIMO for HSDPA (FDD) | 205d? | 2007-06-04 A | 2008-09-12 A | 100% | 2007-06-04 | 2008-09-12 | 205d? | finish no earlier than 2008-09-12 | R1 | 1640h | 1640h | RANimp-64QamMimoHsdpa | Rel-8 | Patrick | Ericsson | Johan.Bergman@ericsson.com | RP-080518 |  |  |  |  |
| 732 | 217.2 | Improved L2 for uplink | 186d? | 2007-09-14 A | 2008-05-30 A | 100% | 2007-09-14 | 2008-05-30 | 186d? | finish no earlier than 2008-05-30 | R2 | 1488h | 1488h | RANimp-UplinkL2dataRates | Rel-8 | Joern | Ericsson | Janne.Peisa@ericsson.com | RP-080265 |  | RP-37 |  |  |
| 733 | 217.3 | Enhanced Uplink for CELL_FACH State in FDD | 321d? | 2007-09-14 A | 2008-12-05 A | 100% | 2007-09-14 | 2008-12-05 | 321d? | finish no earlier than 2008-12-12 | R2 | 2568h | 2568h | RANimp-UplinkEnhState | Rel-8 | Joern | Nokia Siemens Networks | markus.wimmer@nsn.com | RP-080804 |  | RP-37 |  |  |
| 734 | 217.4 | Enhanced UE DRX for FDD | 261d? | 2007-09-14 A | 2008-09-12 A | 100% | 2007-09-14 | 2008-09-12 | 261d? | finish no earlier than 2008-09-12 | R2 | 2088h | 2088h | RANimp-DRX | Rel-8 | Joern | Nokia | luis.barreto@nokia.com | RP-080520 |  | RP-37 |  |  |
| 735 | 217.5 | Enhancements for SRNS Relocation Procedure | 261d? | 2007-09-14 A | 2008-09-12 A | 100% | 2007-09-14 | 2008-09-12 | 261d? | finish no earlier than 2008-09-12 | R3 | 2088h | 2088h | RANimp-SrnsReloc | Rel-8 | Juha | Nokia Siemens Networks | masatoshi.nakamata@nsn.com | RP-080521 |  | RP-37 |  |  |
| 736 | 217.6 | Enhancements for FDD HSPA Evolution | 321d? | 2007-09-14 A | 2008-12-05 A | 100% | 2007-09-14 | 2008-12-05 | 321d? | finish no earlier than 2008-12-05 | R3,R2 | 2568h | 2568h | RANimp-HSPAEvo | Rel-8 | Juha | Nokia Siemens Networks | masatoshi.nakamata@nsn.com | RP-080805 |  | RP-37 |  |  |
| 737 | 217.7 | 64QAM for 1.28 Mcps TDD HSDPA | 264d? | 2007-12-04 A | 2008-12-05 A | 100% | 2007-12-04 | 2008-12-05 | 264d? | finish no earlier than 2008-12-05 | R1 | 2112h | 2112h | RANimp-64Qam1.28TDD | Rel-8 | Patrick | ZTE | zfmail@zte.com.cn | RP-080806 | PCG-21 | RP-38 |  |  |
| 738 | 217.8 | Enhanced CELL_FACH state in 1.28 Mcps TDD | 264d? | 2007-12-04 A | 2008-12-05 A | 100% | 2007-12-04 | 2008-12-05 | 264d? | finish no earlier than 2008-12-12 | R2 | 2112h | 2112h | RANimp-EnhState1.28TDD | Rel-8 | Joern | ZTE | zhang.yincheng@zte.com.cn | RP-080807 | PCG-21 | RP-38 |  |  |
| 739 | 217.9 | Continuous Connectivity for packet data users for 1.28 Mcps TDD | 321d? | 2008-03-07 A | 2009-05-29 A | 100% | 2008-03-07 | 2009-05-29 | 321d? | finish no earlier than 2009-05-29 | R1 | 2568h | 2568h | RANimp-LCRCPC | Rel-8 | Patrick | TD Tech | chenying@td-tech.com | RP-090394 | PCG-21 | RP-39 |  |  |
| 740 | 217.10 | HSPA VoIP to WCDMA/GSM CS continuity | 261d? | 2008-03-07 A | 2009-03-06 A | 100% | 2008-03-07 | 2009-03-06 | 261d? | finish no earlier than 2009-03-06 | R2 | 2088h | 2088h | RANimp-HSPAVoIP | Rel-8 | Joern | Nokia | Simone.Provvedi@nokia.com | RP-090050 | PCG-21 | RP-39 |  |  |
| 741 | 217.11 | HS-DSCH Serving Cell Change Enhancements | 196d? | 2008-03-07 A | 2008-12-05 A | 100% | 2008-03-07 | 2008-12-05 | 196d? | finish no earlier than 2008-12-12 | R2 | 1568h | 1568h | RANimp-HSDSCH | Rel-8 | Joern | Ericsson | henrik.enbuske@ericsson.com | RP-080811 | PCG-21 | RP-39 |  |  |
| 742 | 217.12 | MIMO for 1.28 Mcps TDD | 201d? | 2007-11-01 A | 2009-03-06 A | 100% | 2007-11-01 | 2009-03-06 | 201d? | finish no earlier than 2009-05-29 | R1,R4 | 1608h | 1608h | RANimp-MIMOLCR | Rel-8 | Patrick | CATT | wangke@datangmobile.cn | RP-090313 | PCG-21 | RP-40 |  |  |
| 743 | 217.13 | Dual-Cell HSDPA operation on adjacent carriers | 140d? | 2008-05-30 A | 2008-12-11 A | 100% | 2008-05-30 | 2008-12-11 | 140d? | finish no earlier than 2009-05-29 | R1,R4 | 1120h | 1120h | RANimp-DCHSDPA | Rel-8 | Patrick | Ericsson | johan.bergman@ericsson.com | RP-080814 | PCG-21 | RP-40 |  |  |

Notes:
- 718: -
- 719: SR in RP-070526. Introduction of Band XI / Text3: 25.101, 25.104, 25.133, 25.141, 25.331, 25.942, 25.306, 25.307, 34.121
- 720: SR in RP-080260. Introduction of UMTS 700 MHz (Bands XII XIV) in 25.307 / Text3: 25.101, 25.104, 25.133, 25.141, 25.331, 25.942, 25.306, 25.307, 34.121
- 721: SR in RP-080517. RP#41 completed / Text3: 25.102, 25.105, 25.113, 25.123, 25.142, 34.124, 25.306, 25.331, 34.122
- 722: SR in RP-080041.
- 723: SR in RP-080042. / Text3: 25.323, 25.331, 25.322
- 724: SR in RP-080043. / Text3: 25.101
- 725: RP#43 completed as Rel-8 / Text3: 25.102, 25.105, 25.113, 25.123, 25.142, 34.124, 25.307
- 726: SR in RP-080515. RP#41 stopped / Text3: 25.101, 25.104, 25.133, 25.141, 25.331, 25.942, 25.306, 25.307, 34.121
- 727: 05/08: Linked to Feature UID_20028 (RInImp)
- 728: SR in RP-080542. RP#41 completed. / Text3: 34.108, 34.123-1, 34.123-2, 34.123-3
- 729: RP#42 completed. SR in RP-080818. Linked to UID_370033. / Text3: 34.121-1, 34.121-2
- 730: -
- 731: SR in RP-080518. RP#41 completed / Text3: 25.308, 25.211, 25.212, 25.213, 25.306, 25.331, 25.433, 25.435, 25.423, 25.425, 25.101, 25.104, 25.141
- 732: SR in RP-080265. RP#40 completed / Text3: 25.319, 25.301, 25.306, 25.321, 25.331, 25.433, 25.435, 25.423, 25.425, 25.427
- 733: SR in RP-080804. RP#42 completed / Text3: 25.309, 25.211, 25.214, 25.321, 25.331, 25.423, 25.433
- 734: SR in RP-080520. RP#41 completed / Text3: 25.306, 25.308, 25.321, 25.331, 25.423
- 735: SR in RP-080521. RP#41 completed / Text3: 25.306, 25.308, 25.321, 25.331, 25.423, 25.433, 25.214, 25.133
- 736: SR in RP-080805. RP#42 completed. WID updated RP-070760=>RP-080830 / Text3: 25.401, 25.413, 25.420, 25.423, 25.427, 25.433, 25.446, 25.301, 25.346
- 737: SR in RP-080806. RP#42 completed / Text3: 25.102, 25.105, 25.123, 25.142, 25.201, 25.221, 25.222, 25.223, 25.224, 25.306, 25.308, 25.321, 25.331, 25.423, 25.433
- 738: SR in RP-080807. RP#42 completed / Text3: 25.123, 25.221, 25.222, 25.224, 25.301, 25.302, 25.304, 25.306, 25.308, 25.319, 25.321, 25.331, 25.401, 25.423, 25.425, 25.433, 25.435
- 739: RP#44 completed / Text3: 25.929, 25.308, 25.319
- 740: RP#43 completed / Text3: 25.331, 25.413
- 741: SR in RP-080811. RP#42 completed / Text3: 25.101, 25.104, 25.133, 25.212, 25.214, 25.308, 25.321, 25.331, 25.423, 25.433
- 742: RP#43 completed (part missing R4 performance part) / Text3: 25.201, 25.221, 25.222, 25.223, 25.224, 25.306, 25.308, 25.321, 25.331, 25.423, 25.433, 25.102, 25.105, 25.142
- 743: RP#42 completed except R4 performance part 05/09. Triggered by FS_RAN-DCHS UID_390032 / Text3: 25.101, 25.104, 25.133, 25.141, 25.211, 25.212, 25.213, 25.214, 25.215, 25.306, 25.308, 25.321, 25.331, 25.423, 25.433

| ID | WBS | Task | Duration | Start | Finish | Complete | Remaining | Baseline start | Baseline finish | Baseline duration | Total slack | Constraint | Resources | Work | Actual work | Text1 | Text6 | Text8 | Text2 | Text4 | Text7 | Text11 |
| --- | --- | --- | --- | --- | --- | --- | --- | --- | --- | --- | --- | --- | --- | --- | --- | --- | --- | --- | --- | --- | --- | --- |
| 744 | 218 | **Rel-8 RAN improvements - UE Conformance Testing** | 602d? | 2008-05-30 A | 2010-09-17 | 57% | 255.96d? | 2008-05-30 | 2010-09-17 | 602d? | 521d |  | R5 | 28391.2h | 13671.6h | RANimp-UEConTest | Rel-8 | Ingbert |  |  |  |  |
| 745 | 218.1 | Conformance Test Aspects – Combination of 64QAM and MIMO for HSDPA (FDD) | 322d? | 2008-09-12 A | 2009-12-04 A | 100% |  | 2008-09-12 | 2009-12-04 | 322d? |  | finish no earlier than 2009-12-04 | R5 | 2576h | 2576h | RANimp-UEConTest_64QamMimoHsdpa | Rel-8 | Ingbert | PCG-21 | Ericsson | RP-41 | RP-091058 |
| 746 | 218.2 | Conformance Test Aspects – Improved L2 for uplink | 341d? | 2008-05-30 A | 2009-09-18 A | 100% |  | 2008-05-30 | 2009-09-18 | 341d? |  | finish no earlier than 2009-09-18 | R5 | 2728h | 2728h | RANimp-UEConTest_UplinkL2dataRates | Rel-8 | Ingbert | PCG-21 | Ericsson | RP-40 | RP-090712 |
| 747 | 218.3 | Conformance Test Aspects – 64QAM for 1.28 Mcps TDD HSDPA | 261d? | 2008-05-30 A | 2009-05-29 A | 100% |  | 2008-05-30 | 2009-05-29 | 261d? |  | finish no earlier than 2009-05-29 | R5 | 2088h | 2088h | RANimp-UEConTest_64Qam1.28TDD | Rel-8 | Ingbert | PCG-21 | ZTE | RP-40 | RP-090415 |
| 748 | 218.4 | Conformance Test Aspects – Dual-Cell HSDPA operation on adjacent carriers | 336d? | 2008-12-05 A | 2010-03-19 | 80% | 67.2d? | 2008-12-05 | 2010-03-19 | 336d? | 651d | finish no earlier than 2010-03-19 | R5 | 2688h | 2150.4h | RANimp-UEConTest_DCHSDPA | Rel-8 | Ingbert | PCG-22 | Qualcomm Europe | RP-42 | RP-091062 |
| 749 | 218.5 | Conformance Test Aspects – Enhanced Uplink for CELL_FACH State in FDD | 266d? | 2009-03-06 A | 2010-03-12 | 40% | 159.6d? | 2009-03-06 | 2010-03-12 | 266d? | 656d | finish no earlier than 2010-03-12 | R5 | 2128h | 851.2h | RANimp-UEConTest_EnhancedRACHCellFACHState | Rel-8 | Ingbert | PCG-22 | Nokia | RP-43 | RP-091067 |
| 750 | 218.6 | Conformance Test Aspects – Receiver Type3i | 196d? | 2009-03-06 A | 2009-12-04 A | 100% |  | 2009-03-06 | 2009-12-04 | 196d? |  | finish no earlier than 2009-12-04 | R5 | 1568h | 1568h | RANimp-UEConTest_ReceiverType3i | Rel-8 | Ingbert | PCG-22 | Qualcomm Europe | RP-43 | RP-091066 |
| 751 | 218.7 | Conformance Test Aspects – Enhanced CELL_FACH State in LCR TDD | 341d? | 2009-05-30 A | 2010-09-17 | 25% | 257d? | 2009-05-30 | 2010-09-17 | 341d? | 521d | finish no earlier than 2010-09-17 | R5 | 2728h | 672h | RANimp-UEConTest_EnhancedCellFACHStateLCRTDD | Rel-8 | Ingbert | PCG-23 | CATT | RP-44 | RP-091068 |
| 752 | 218.8 | Conformance Test Aspects – 1.28 Mcps TDD Improved L2 support for high data rates | 337d? | 2009-05-29 A | 2010-09-10 | 30% | 235.9d? | 2009-05-29 | 2010-09-10 | 337d? | 526d | finish no earlier than 2010-09-10 | R5 | 2696h | 808.8h | RANimp-UEConTest_ImprovedL2LCRTDD | Rel-8 | Ingbert | PCG-23 | CATT | RP-44 | RP-091071 |
| 753 | 218.9 | Conformance Test Aspects – Continuous Connectivity for packet data users for 1.28 Mcps TDD | 261d? | 2009-09-18 A | 2010-09-17 | 5% | 247.95d? | 2009-09-18 | 2010-09-17 | 261d? | 521d | finish no earlier than 2010-09-17 | R5 | 2088h | 104.4h | RANimp-UEConTest_CPCLCRTDD | Rel-8 | Ingbert | PCG-23 | ZTE | RP-45 | RP-091077 |
| 754 | 218.10 | Conformance Test Aspects – MIMO for 1.28 Mcps TDD | 186d? | 2009-09-18 A | 2010-06-04 | 5% | 176.7d? | 2009-09-18 | 2010-06-04 | 186d? | 596d | finish no earlier than 2010-06-04 | R5 | 1488h | 74.4h | RANimp-UEConTest_MIMOLCRTDD | Rel-8 | Ingbert | PCG-23 | ZTE | RP-45 | RP-091078 |
| 755 | 218.11 | Conformance Test Aspects – HS-DSCH Serving Cell Change Enhancements | 126d? | 2009-09-18 A | 2010-03-12 | 5% | 119.7d? | 2009-09-18 | 2010-03-12 | 126d? | 656d | finish no earlier than 2010-03-12 | R5 | 1008h | 50.4h | HSDSCH_UEConTest | Rel-8 | Ingbert | PCG-23 | Qualcomm Europe | RP-45 | RP-091079 |
| 756 | 219 | 3.84 Mcps TDD MBSFN Integrated Mobile Broadcast | 395d? | 2007-06-04 A | 2008-12-05 A | 100% |  | 2007-06-04 | 2008-12-05 | 395d? |  |  | R1 | 3160h | 3160h | MBSFN-DOB | Rel-8 | Patrick |  | Ericsson |  | RP-080218 |
| 757 | 220 | Conformance Test Aspects – 3.84 Mcps TDD MBSFN Integrated Mobile Broadcast | 211d? | 2009-05-30 A | 2010-03-19 | 95% | 10.55d? | 2009-05-30 | 2010-03-19 | 211d? | 651d | finish no earlier than 2010-03-19 | R5 | 1688h | 1603.6h | MBSFN_IMB_UEConTest | Rel-8 | Ingbert | PCG-23 | IPwireless | RP-44 | RP-091072 |
| 758 | 221 | GERAN support for GERAN - 3G Long Term Evolution interworking | 641d? | 2006-09-08 A | 2009-02-20 A | 100% |  | 2006-09-08 | 2009-02-20 | 641d? |  | finish no earlier than 2009-02-20 | GP | 5128h | 5128h | GELTE | Rel-8 | Paolo |  | Nokia, Nokia Siemens Networks |  |  |
| 759 | 222 | U-TDOA Enhancement | 131d? | 2007-05-18 A | 2007-11-16 A | 100% |  | 2007-05-18 | 2007-11-16 | 131d? |  | finish no earlier than 2007-05-18 | GP | 1048h | 1048h | GUTEN | Rel-8 | Paolo |  | TruePosition |  |  |
| 760 | 223 | **GAN Enhancements** | 604.2d? | 2007-05-15 A | 2009-09-04 A | 100% |  | 2007-05-15 | 2009-09-04 | 604.2d? |  |  | GP | 9432h | 9432h | GANENH | Rel-8 | Paolo |  | T-Mobile |  |  |
| 761 | 223.1 | Update to GAN specifications | 126d? | 2007-08-31 A | 2008-02-22 A | 100% |  | 2007-08-31 | 2008-02-22 | 126d? |  | finish no earlier than 2008-02-22 | GP | 1008h | 1008h | GANENH-SPEC | Rel-8 | Paolo |  | T-Mobile |  |  |
| 762 | 223.2 | Update TS 51.010 Mobile Station (MS) Conformance Specification for GAN Enhancements | 526d? | 2007-05-15 A | 2009-09-04 A | 100% |  | 2007-05-15 | 2009-09-04 | 526d? |  | finish no earlier than 2009-09-04 | G3new | 4208h | 4208h | GANENH-MStest | Rel-8 | Ingbert |  | T-Mobile |  |  |
| 763 | 224 | **AoIP (A-interface over IP)** | 2335d? | 2000-01-03 A | 2008-12-11 A | 100% |  | 2000-01-03 | 2008-12-11 | 2335d? |  |  | GP,S4,C4,C1,C3 | 41412.1h | 41412.1h | AoIP | Rel-8 | Paolo | PCG-21 | China Mobile, Ericsson |  |  |
| 764 | 224.1 | GERAN aspects of AoIP | 2321d? | 2000-01-03 A | 2008-11-21 A | 100% |  | 2000-01-03 | 2008-11-21 | 2321d? |  | finish no earlier than 2008-11-21 | GP | 18560h | 18560h | AoIP | Rel-8 | Paolo | PCG-21 | China Mobile, Ericsson | SP-40 |  |
| 765 | 224.2 | Media Requirements for CS over IP based User Plane | 267d? | 2007-12-05 A | 2008-12-11 A | 100% |  | 2007-12-05 | 2008-12-11 | 267d? |  | finish no earlier than 2008-12-11 | S4 | 1996.09h | 1996.09h | AoIP-CSoIP | Rel-8 | Paolo | PCG-21 | China Mobile, Ericsson | SP-40 |  |
| 766 | 224.3 | Core Network Impacts for A-Interface User Plane over IP | 136d? | 2008-05-30 A | 2008-12-05 A | 100% |  | 2008-05-30 | 2008-12-05 | 136d? |  | start no earlier than 2008-05-30 | C4 | 1088h | 1088h | AoIP-CN | Rel-8 | Kimmo | PCG-21 | Ericsson | CP-40 |  |
| 767 | 224.4 | Core Network Impacts for A-Interface User Plane over IP | 68d? | 2008-05-30 A | 2008-12-05 A | 100% |  | 2008-05-30 | 2008-12-05 | 68d? |  | finish no earlier than 2008-12-05 | C1 | 544h | 544h | AoIP-CN | Rel-8 | Frederic | PCG-21 | Ericsson | CP-40 |  |
| 768 | 224.5 | Core Network Impacts for A-Interface User Plane over IP | 68d? | 2008-05-30 A | 2008-12-05 A | 100% |  | 2008-05-30 | 2008-12-05 | 68d? |  | finish no earlier than 2008-12-05 | C3 | 544h | 544h | AoIP-CN | Rel-8 | Gwiho | PCG-21 | Ericsson | CP-40 |  |
| 769 | 225 | New multicarrier BTS class | 261d? | 2007-08-31 A | 2008-08-29 A | 100% |  | 2007-08-31 | 2008-08-29 | 261d? |  | finish no earlier than 2008-08-29 | G1 | 2088h | 2088h | MCBTS | Rel-8 | Paolo |  | Alcatel-Lucent |  |  |

Notes:
- 744: Linked to Feature UID_20029 (RANimp)
- 745: RP#46 completed / Text3: 34.108, 34.121-1, 34.121-2, 34.123-1, 34.123-2 / Text5: leif.mattisson@ericsson.com
- 746: RP#45 completed. Linked to UID_370036 / Text3: 34.108, 34.123-1, 34.123-2, 34.123-3 / Text5: leif.mattisson@ericsson.com
- 747: RP#44 completed. Linked UID_380075 RANimp-64Qam1.28TDD / Text3: 34.108, 34.122, 34.123-1, 34.123-2, 34.123-3 / Text5: ma.zijiang@zte.com.cn
- 748: RP#46 completion 12/09 (was 09/09)=>03/10. Testing for UID_400052 / Text3: 34.108, 34.121-1, 34.121-2, 34.123-1, 34.123-2, 34.123-3 / Text5: Shubhang Vora (svora@qualcomm.com)
- 749: Testing for UID_370037 / Text3: 34.108, 34.121-1, 34.121-2, 34.123-1, 34.123-2, 34.123-3 / Text5: jarkko.hellsten@nokia.com
- 750: RP#46 completed. Testing for Receiver Type3i in 25.101 UE radio Tx and Rx FDD / Text3: 34.108, 34.121-1, 34.121-2 / Text5: Ashok Kumar Narayanaswamy (anarayan@qualcomm.com)
- 751: Linked to UID_380076 Enhanced CELL_FACH state in 1.28 Mcps TDD / Text3: 34.108, 34.123-1, 34.123-2, 34.123-3 / Text5: Xiaozhong Chen (chenxiaozhong@datangmobile.cn)
- 752: Linked to Rel-7 UID_340039 Improved L2 support for high data rates and Rel-8 UID_370036 Improved L2 for uplink / Text3: 34.108, 34.123-1, 34.123-2, 34.123-3 / Text5: Xiaozhong Chen (chenxiaozhong@datangmobile.cn)
- 753: RP#45 testing for UID_390028 / Text3: 34.108, 34.123-1, 34.123-2, 34.123-3 / Text5: He Huang (huang.he4@zte.com.cn)
- 754: RP#45 testing for UID_400050 / Text3: 34.108, 34.123-1, 34.123-2, 34.123-3 / Text5: He Huang (huang.he4@zte.com.cn)
- 755: RP#45 testing for UID_390030 / Text3: 34.108, 34.121-1, 34.121-2, 34.123-1, 34.123-2, 34.123-3 / Text5: Shubhang Vora (svora@qualcomm.com)
- 756: RP#42 completed. WID updated RP-070493=>RP-081124 (changed WI title "MBSFN Downlink Optimized Broadcast (DOB) 3.84 Mcps TDD" => "3.84Mcps TDD MBSFN Integrated Mobile Broadcast"). RP#39 SR in RP-080218. / Text3: 25.102, 25.105, 25.123, 25.201, 25.221, 25.222, 25.223, 25.224, 25.304, 25.306, 25.331, 25.346, 25.402, 25.433 / Text5: Lars.Lindbom@ericsson.com
- 757: RP#46 completion 12/09=>03/10. Testing for Rel-8 MBSFN-DOB UID_360008 / Text3: 34.108, 34.122, 34.123-1, 34.123-2, 34.123-3 / Text5: Phil Young (pyoung@ipwireless.com)
- 758: GP#41 completed (MS conformance testing open) / Text3: 24.008, 43.055, 43.129, 43.246, 44.018, 44.060, 45.002, 45.008, 45.010, 48.008, 48.018, 51.010 / Text5: sergio.parolari@nsn.com, vlora.rexhepi@nokia.com
- 759: GP#36 completed U-TDOA (Uplink Time Difference of Arrival) / Text3: 43.059, 45.008, 48.071 / Text5: Terry Brooks (terri.brooks@trueposition.com)
- 760: GP#37 completed. GP#43 completed Testing / Text5: mohammed.versi@t-mobile.com
- 761: GP#37 completed / Text3: 43.318, 44.318 / Text5: mohammed.versi@t-mobile.com
- 762: GP#43 completed / Text3: 51.010 / Text5: mohammed.versi@t-mobile.com
- 763: GP#40/TSG#42 completed . Triggered by TR 43.903 Study on A-interface over IP (AINTIP) UID_50589. / Text5: wangshuaiyu@chinamobile.com, paul.schliwa-bertling@ericsson.com
- 764: GP#40 completed. GP#39 updated WID GP-080901=>GP-081362. / Text3: 48.001, 48.002, 48.008, 48.020, 49.008, 48.103 / Text5: wangshuaiyu@chinamobile.com, paul.schliwa-bertling@ericsson.com
- 765: SP#42 completed / Text3: 26.102, 26.103, 26.202 / Text5: Karl.Hellwig@Ericsson.com
- 766: CP#42 completed. Updated WID CP-080278=>CP-080722 / Text3: 23.205, 23.153, 23.231, 29.232 / Text5: philip.hodges@ericsson.com
- 767: CP#42 completed. Updated WID CP-080278=>CP-080722 / Text3: 23.009 / Text5: philip.hodges@ericsson.com
- 768: CP#42 completed. Updated WID CP-080278=>CP-080722 / Text3: 29.007 / Text5: philip.hodges@ericsson.com
- 769: GP#39 completed / Text3: 45.005, 45.050, 51.021 / Text5: thomas.bitzer@alcatel-lucent.de

| ID | WBS | Task | Type | Duration | Start | Finish | Complete | Remaining | Baseline start | Baseline finish | Baseline duration | Total slack | Constraint | Resources | Work | Actual work | Text1 | Text4 | Text6 | Text8 | Text11 | Text2 | Text3 | Text7 | Text12 | Text9 |
| --- | --- | --- | --- | --- | --- | --- | --- | --- | --- | --- | --- | --- | --- | --- | --- | --- | --- | --- | --- | --- | --- | --- | --- | --- | --- | --- |
| 770 | 226 | **Support for Additional Navigation Satellite Systems (ANSS) for LCS** |  | 150d? | 2008-05-16 A | 2008-12-11 A | 100% |  | 2008-05-16 | 2008-12-11 | 150d? |  |  | S1,G2 | 3384h | 3384h | ANSS | Qualcomm Europe | Rel-8 | Paolo | RP-080813 |  |  |  |  |  |
| 771 | 226.1 | Stage 1 for ANSS for LCS |  | 1d? | 2008-12-11 A | 2008-12-11 A | 100% |  | 2008-12-11 | 2008-12-11 | 1d? |  | start no earlier than 2008-12-11 | S1 | 8h | 8h | ANSS |  | Rel-8 | Alain |  | PCG-22 | 22.071 | SP-42 |  |  |
| 772 | 226.2 | Support for Additional Navigation Satellite Systems (ANSS) for LCS |  | 136d? | 2008-05-16 A | 2008-11-21 A | 100% |  | 2008-05-16 | 2008-11-21 | 136d? |  | start no earlier than 2008-05-16 | G2 | 1088h | 1088h | ANSS | Qualcomm Europe | Rel-8 | Paolo |  |  | 43.059, 44.031, 49.031, 44.071, 48.031, 51.010 |  |  |  |
| 773 | 226.3 | Support for Additional Navigation Satellite Systems (ANSS) for LCS |  | 136d? | 2008-05-30 A | 2008-12-05 A | 100% |  | 2008-05-30 | 2008-12-05 | 136d? |  | finish no earlier than 2008-12-08 | R2 | 1088h | 1088h | RANimp-ANSS | Qualcomm Europe | Rel-8 | Joern | RP-080813 | PCG-21 | 25.305, 25.306, 25.331, 25.413, 25.423, 25.433, 25.453 | RP-40 |  |  |
| 774 | 227 | **Conformance testing for the Latency Reductions feature** |  | 532d? | 2008-02-22 A | 2010-03-05 | 97% | 17.84d? | 2008-02-22 | 2010-03-05 | 532d? | 661d |  | G1, G3new | 10592h | 10236.4h | CTLATRED | Ericsson | Rel-8 | Paolo |  | PCG-21 |  |  |  |  |
| 775 | 227.1 | MS conformance testing for the Latency Reductions feature |  | 532d? | 2008-02-22 A | 2010-03-05 | 95% | 26.6d? | 2008-02-22 | 2010-03-05 | 532d? | 661d | finish no earlier than 2010-03-05 | G3new | 4248h | 4035.2h | CTLATRED-MStest | Ericsson | Rel-8 | Ingbert |  | PCG-21 | 51.010 |  |  |  |
| 776 | 227.2 | BTS conformance testing for the Latency Reductions feature |  | 261d? | 2008-02-22 A | 2009-02-20 A | 100% |  | 2008-02-22 | 2009-02-20 | 261d? |  | finish no earlier than 2009-02-20 | G1 | 2088h | 2088h | CTLATRED-BTStest | Ericsson | Rel-8 | Paolo |  | PCG-21 | 51.021 |  |  |  |
| 777 | 228 | MS conformance testing of changes introduced by WI “Support of Packet-switched Handover for GERAN A/Gb mode” |  | 196d? | 2008-02-22 A | 2008-11-21 A | 100% |  | 2008-02-22 | 2008-11-21 | 196d? |  | finish no earlier than 2008-11-21 | G3new | 1568h | 1568h | PSHCT-MStest | Rohde & Schwarz | Rel-8 | Ingbert |  | PCG-21 | 51.010 |  |  |  |
| 778 | 229 | (Small) Technical Enhancements and Improvements for Rel-8 |  | 509d? | 2007-01-01 A | 2008-12-11 A | 100% |  | 2007-01-01 | 2008-12-11 | 509d? |  | finish no earlier than 2008-12-11 | All | 4072h | 4072h | TEI8 | ALL | Rel-8 |  |  |  |  |  |  |  |
| 779 | 230 | Test - (Small) Technical Enhancements and Improvements for Rel-8 |  | 672d? | 2007-03-07 A | 2010-12-24 | 60% | 268.8d? | 2007-03-07 | 2010-12-24 | 672d? | 451d | finish no earlier than 2010-12-24 | R5,G3new | 5376h | 3225.6h | TEI8_Test | ALL | Rel-8 | Ingbert |  | PCG-21 |  | RP-40 |  |  |
| 780 | 231 | **Deleted - All-IP Network** |  | 448d? | 2004-06-28 A | 2006-03-15 A | 100% |  | 2004-06-28 | 2006-03-15 | 448d? |  |  | S1 | 7168h | 7168h | AIPN | NTT DoCoMo | Rel-8 | Alain |  |  |  |  | SP-38 |  |
| 781 | 231.1 | Deleted - Stage 1 |  | 448d? | 2004-06-28 A | 2006-03-15 A | 100% |  | 2004-06-28 | 2006-03-15 | 448d? |  | finish no earlier than 2006-03-15 | S1 | 3584h | 3584h | AIPN | NTT DoCoMo | Rel-8 | Alain |  |  | 22.258 |  | SP-38 |  |
| 782 | 232 | Deleted - was Rel7 - LCS for 3GPP Interworking WLAN | milestone | 0d? | 2007-09-28 A | 2007-09-28 A | 100% |  | 2007-09-28 | 2007-09-28 | 0d? |  | start no earlier than 2007-09-28 | S2 |  |  | LCS4_IWLAN | LG Electronics | Rel-8 | Maurice |  |  | 23.234, 23.271, 23.167 |  | SP-35 |  |
| 783 | 233 | Deleted - never approved- FBI Phase 2 | milestone | 0d | 2007-09-28 A | 2007-09-28 A | 100% |  | 2007-09-28 | 2007-09-28 | 0d |  | start no earlier than 2007-09-28 | S2 |  |  | FBI2 | Nokia Siemens Networks | Rel-8 | Maurice |  |  |  |  | SP-38 |  |
| 784 | 234 | Deleted -Enhancements to BS30 Bearer service for Videotelephony | milestone | 0d? | 2007-03-15 A | 2007-03-15 A | 100% |  | 2007-03-15 | 2007-03-15 | 0d? |  | finish no earlier than 2007-03-15 | S1 |  |  | BS30 |  | Rel-8 | Alain |  |  | 22.002, 22.004, 22.101, 22.105, 24.008 |  | SP-38 |  |
| 785 | 235 | Deleted - IMS Enhancements Rel-8 |  | 75d? | 2007-09-03 A | 2007-12-14 A | 100% |  | 2007-09-03 | 2007-12-14 | 75d? |  |  | S1 | 600h | 600h | IMS8 | Telecom Italia | Rel-8 | Alain |  |  |  | SP-37 | SP-38 |  |
| 786 | 236 | Deleted - MS conformance testing of Support of Conversational Services in A/Gb mode via the PS domain |  | 401d? | 2008-02-25 A | 2009-09-04 A | 100% |  | 2008-02-25 | 2009-09-04 | 401d? |  | finish no earlier than 2009-09-04 | G3new | 3208h | 3208h | SCSAGBCT-MStest | Nokia | Rel-8 | Ingbert |  | PCG-21 | 51.010 |  | GP-43 | PCG-23 |
| 787 | 237 | Release 8 Studies | milestone | 0d? | 2008-03-20 | 2008-03-20 |  |  | 2008-03-20 | 2008-03-20 | 0d? | 1173d | finish no earlier than 2008-03-20 | CP,GP,RP,SP |  |  |  |  | Rel-8 |  |  |  |  |  |  |  |
| 788 | 238 | Study on Customised Alerting Tone (CAT) Requirements |  | 245d? | 2005-10-07 A | 2006-09-14 A | 100% |  | 2005-10-07 | 2006-09-14 | 245d? |  | start no earlier than 2005-10-07 | S1 | 1960h | 1960h | FS_CAT | China Mobile | Rel-8 | Alain |  |  | 22.982 |  |  |  |
| 789 | 239 | Study on Facilitating Machine to Machine Communication in GSM and UMTS (M2M) |  | 350d? | 2005-11-04 A | 2007-03-08 A | 100% |  | 2005-11-04 | 2007-03-08 | 350d? |  | finish no earlier than 2006-06-16 | S1 | 2800h | 2800h | FS_M2M | Siemens | Rel-8 | Alain |  |  | 22.868 |  |  |  |
| 790 | 240 | Study on Network Composition |  | 526d? | 2005-12-07 A | 2007-12-12 A | 100% |  | 2005-12-07 | 2007-12-12 | 526d? |  | finish no earlier than 2006-09-27 | S1 | 4208h | 4208h | FS_NetComp | Nokia Siemens Networks | Rel-8 | Alain |  |  | 22.980 |  |  |  |
| 791 | 241 | Study on Requirements of IMS Multimedia Conferencing |  | 330d? | 2006-06-08 A | 2007-09-12 A | 100% |  | 2006-06-08 | 2007-09-12 | 330d? |  | finish no earlier than 2007-03-21 | S1 | 2640h | 2640h | FS_IMSconf | China Mobile | Rel-8 | Alain |  |  | 22.948 |  |  |  |
| 792 | 242 | Study on support of a Public Warning System |  | 140d? | 2007-09-03 A | 2008-03-14 A | 100% |  | 2007-09-03 | 2008-03-14 | 140d? |  |  | S1 | 1120h | 1120h | FS_PWS | T-Mobile | Rel-8 | Alain |  |  | 22.968 |  |  |  |
| 793 | 243 | Study on Paging Permission with Access Control |  | 256d? | 2006-09-28 A | 2007-09-20 A | 100% |  | 2006-09-28 | 2007-09-20 | 256d? |  | finish no earlier than 2007-09-20 | S1 | 2048h | 2048h | FS_PPAC | NTT DoCoMo | Rel-8 | Alain |  |  | 22.908 |  |  |  |
| 794 | 244 | Study on Non 3GPP access NSP |  | 392d? | 2006-12-06 A | 2008-06-05 A | 100% |  | 2006-12-06 | 2008-06-05 | 392d? |  | finish no earlier than 2007-11-19 | S1 | 3136h | 3136h | FS_N3GtoNSP | Telefonica O2 | Rel-8 | Alain |  |  | 22.912 |  |  |  |
| 795 | 245 | Study on Value Added Services for Short Message Service |  | 263d? | 2006-12-06 A | 2007-12-07 A | 100% |  | 2006-12-06 | 2007-12-07 | 263d? |  | finish no earlier than 2007-12-07 | S1 | 2104h | 2104h | FS_VAS4SMS | China Mobile | Rel-8 | Alain |  |  | 22.942 |  |  |  |
| 796 | 246 | Study on Service continuity between mobile and WLAN networks |  | 262d? | 2006-12-06 A | 2007-12-06 A | 100% |  | 2006-12-06 | 2007-12-06 | 262d? |  | finish no earlier than 2008-12-25 | S1 | 2096h | 2096h | FS_SMLSWLAN | BT | Rel-8 | Alain |  |  | 22.937 |  |  |  |
| 797 | 247 | Study on Services Alignment and Migration |  | 331d? | 2006-12-06 A | 2008-03-12 A | 100% |  | 2006-12-06 | 2008-03-12 | 331d? |  | finish no earlier than 2007-09-20 | S1 | 2648h | 2648h | FS_ServAl | China Mobile | Rel-8 | Alain |  |  | 22.983 | SP-37 |  |  |

Notes:
- 770: GP#40 completed. Align with RANimp-ANSS ongoing work item. GP#40 WID updated GP-080776=>GP-081784 (Conformance testing moved to A-GNSS WID) / Text5: Mungal Dhanda
- 771: SP#42 completed by 22.071 CR0077
- 772: GP#40 completed. Align with RANimp-ANSS ongoing work item. GP#40 WID updated GP-080776=>GP-081784 (Conformance testing moved to A-GNSS WID) / Text5: Mungal Dhanda
- 773: SR in RP-080813. RP#42 WI closed at 95%. GERAN leading the work / considers performance requirements for Rel-9 / Text5: Etienne Chaponniere (echaponn@qualcomm.com)
- 774: GP#41 completion 09/09=>11/09 / Text5: mats.y.samuelsson@ericsson.com, hakan.e.grunditz@ericsson.com
- 775: GP#44 completion 11/09=>03/10 / Text5: hakan.e.grunditz@ericsson.com
- 776: GP#41 completed / Text5: mats.y.samuelsson@ericsson.com
- 777: GP#40 completed / Text5: Franz.Segerer@ROHDE-SCHWARZ.COM
- 778: SP#42 completed
- 779: -
- 780: SP#38 stopped. 25/07/08 Moved UID_31059 Study on All-IP Network (FS_AIPN/was AIPFS ) to Rel-7 out of the stopped Rel-8 Feature UID_31067 Deleted - All-IP Network (AIPN) / Text5: c.masyu@nttdocomo.co.jp
- 781: 22.258 withdrawn, superseded by 22.278 (UID 320022). SP#38 stopped / Text5: c.masyu@nttdocomo.co.jp
- 782: SP-35 stopped / Text5: dhshim@lge.com
- 783: SP#38 stopped
- 784: SP#38 stopped (no support) / Text5: andre.jarvis@three.co.uk
- 785: SP#38 stopped
- 786: GP#43 work stopped/abandoned (completion 0%) / Text5: arsi.heino@nokia.com
- 787: -
- 788: Spin-off WID UID_370028 under Feature CAT UID_340029 / Text5: fenglingjuan@chinamobile.com
- 789: SP#35 completed. Spin-off SA3 SID UID_370053. SP#40 Spin-off new Feature UID_410030 (NIMTC) / Text5: Juergen Merkel
- 790: SP#38 completed / Text5: Joerg Swetina (joerg.swetina@nw.neclab.eu)
- 791: SP#37 completed. Spin-off New Feature UID_370026 (VAS4SM) / Text5: zhengjianping@chinamobile.com
- 792: SP#39 completed. Spin-off Rel-9 Feature UID_380057 (PWS) / Text5: mark.younge@t-mobile.com
- 793: SP#37 completed. Spin-off new Feature UID_370084 (PPACR) / Text5: noguchi@nttdocomo.co.jp
- 794: SP#38 completed. Spin-off New Feature UID_380062 (N3GTONSP). SP#40 WID updated SP-060930=>SP-080318. TR re-approved with new # 22.812=>22.912 / Text5: chris.friel@o2.com
- 795: SP#38 completed. Spin-off New Feature UID_370026 (VAS4SM) / Text5: wubin@chinamobile.com
- 796: SP#38 completed / Text5: mike.meyerstein@bt.com
- 797: SP#39 completed. Spin-off Feature UID_330017 (ServAl) / Text5: fenglingjuan@chinamobile.com

| ID | WBS | Task | Duration | Start | Finish | Complete | Remaining | Baseline start | Baseline finish | Baseline duration | Total slack | Constraint | Resources | Work | Actual work | Text1 | Text4 | Text5 | Text6 | Text8 | Text3 | Text2 | Text7 | Text11 | Text9 | Text12 |
| --- | --- | --- | --- | --- | --- | --- | --- | --- | --- | --- | --- | --- | --- | --- | --- | --- | --- | --- | --- | --- | --- | --- | --- | --- | --- | --- |
| 798 | 248 | **Study on 3GPP System Architecture Evolution** | 1115d? | 2004-12-03 A | 2009-03-12 A | 100% |  | 2004-12-03 | 2009-03-12 | 1115d? |  |  | S2,S3 | 23456h | 23456h | FS_SAE | Vodafone | Chris Pudney | Rel-8 | Maurice |  |  |  |  |  |  |
| 799 | 248.1 | Stage 2 Interim conclusion for RAN Work to start | 990d? | 2004-12-03 A | 2008-09-18 A | 100% |  | 2004-12-03 | 2008-09-18 | 990d? |  | finish no earlier than 2005-09-23 | S2 | 7920h | 7920h | FS_SAE | Vodafone | Chris Pudney | Rel-8 | Maurice | 23.882 |  |  |  |  |  |
| 800 | 248.2 | Stage 2 study on 3GPP architectural development | 704d? | 2006-01-09 A | 2008-09-18 A | 100% |  | 2006-01-09 | 2008-09-18 | 704d? |  | finish no earlier than 2007-09-28 | S2 | 5632h | 5632h | FS_SAE | Vodafone | Chris Pudney | Rel-8 | Maurice | 23.882 |  |  |  |  |  |
| 801 | 248.3 | Security study for Inter-access mobility between non-3GPP and 3GPP system | 334d? | 2007-09-03 A | 2009-03-12 A | 100% |  | 2007-09-03 | 2009-03-12 | 334d? |  | finish no earlier than 2009-03-12 | S3 | 2672h | 2672h | FS_SAE | Nokia | dajiang.zhang@nokia.com | Rel-8 | Dionisio | 33.821, 33.822 |  |  |  |  |  |
| 802 | 249 | Study on Stage 2 aspects of IMS Service Brokering | 589d? | 2006-06-19 A | 2008-09-18 A | 100% |  | 2006-06-19 | 2008-09-18 | 589d? |  | finish no earlier than 2008-09-18 | S2 | 4712h | 4712h | FS_ISB_ST2 | Telcordia | raquel@research.telcordia.com | Rel-8 | Maurice | 23.810 |  |  |  |  |  |
| 803 | 250 | Study on IMS utilizing multicast bearer services | 447d? | 2006-03-22 A | 2007-12-06 A | 100% |  | 2006-03-22 | 2007-12-06 | 447d? |  | finish no earlier than 2007-12-03 | S2 | 3576h | 3576h | FS_MLTICAST-IMS | Nokia Siemens Networks |  | Rel-8 | Maurice | 23.847 |  |  |  |  |  |
| 804 | 251 | Study on Mobility between 3GPP-WLAN Interworking and 3GPP Systems | 393d? | 2007-03-20 A | 2008-09-18 A | 100% |  | 2007-03-20 | 2008-09-18 | 393d? |  | finish no earlier than 2008-09-18 | S2 | 3144h | 3144h | FS_SM3GWLAN | Orange |  | Rel-8 | Maurice | 23.827 withdrawn |  |  |  |  |  |
| 805 | 252 | Study on Multimedia Session Continuity | 291d? | 2007-04-26 A | 2008-06-05 A | 100% |  | 2007-04-26 | 2008-06-05 | 291d? |  | finish no earlier than 2008-06-05 | S2 | 2328h | 2328h | FS_MMSC | LG Electronics |  | Rel-8 | Maurice | 23.893 |  |  |  |  |  |
| 806 | 253 | **Study on centralized IMS service control** | 363d? | 2006-10-23 A | 2008-03-12 A | 100% |  | 2006-10-23 | 2008-03-12 | 363d? |  |  | S2,S1 | 7952h | 7952h | FS_ICS | Ericsson | peter.bleckert@ericsson.com | Rel-8 | Alain |  | PCG-21 | SP-38 |  |  |  |
| 807 | 253.1 | Study on centralized IMS services requirements | 268d? | 2007-03-05 A | 2008-03-12 A | 100% |  | 2007-03-05 | 2008-03-12 | 268d? |  | start no earlier than 2007-03-05 | S1 | 2144h | 2144h | FS_ICS-S1 | Ericsson | peter.bleckert@ericsson.com | Rel-8 | Alain | 22.892 |  | SP-37 |  |  |  |
| 808 | 253.2 | Study on centralized IMS services control | 363d? | 2006-10-23 A | 2008-03-12 A | 100% |  | 2006-10-23 | 2008-03-12 | 363d? |  | finish no earlier than 2008-02-21 | S2 | 2904h | 2904h | FS_IMS_CSC | Alcatel-Lucent | Andy Bennett (andybennett@alcatel-lucent.com) | Rel-8 | Maurice | 23.892 |  |  |  |  |  |
| 809 | 254 | Study on Architecture of IMS based Customized Alerting Tone (CAT) | 208d? | 2007-12-04 A | 2008-09-18 A | 100% |  | 2007-12-04 | 2008-09-18 | 208d? |  | finish no earlier than 2008-09-08 | S2 | 1664h | 1664h | FS_CAT-St2 | China Mobile | WANG, Jing (wangjing@chinamobilecom) | Rel-8 | Maurice | 23.872 | PCG-21 | SP-38 |  |  |  |
| 810 | 255 | Study on Home (e)NodeB Security | 321d? | 2007-12-20 A | 2009-03-12 A | 100% |  | 2007-12-20 | 2009-03-12 | 321d? |  | finish no earlier than 2009-03-10 | S3 | 2568h | 2568h | FS_HNB_Sec | Huawei | yangyanmei@huawei.com | Rel-8 | Dionisio | 33.820 | PCG-21 | SP-38 |  |  |  |
| 811 | 256 | Study on Transferring of emergency call data – in-band modem solution | 265d? | 2006-12-07 A | 2007-12-12 A | 100% |  | 2006-12-07 | 2007-12-12 | 265d? |  | finish no earlier than 2008-09-18 | S4 | 2120h | 2120h | eCALLIBMS | Airbiquity | lhong@airbiquity.com | Rel-8 | Paolo | 26.967 |  |  |  |  |  |
| 812 | 257 | Study on Element Operations Systems Function (EOSF) definition | 266d? | 2007-06-07 A | 2008-06-12 A | 100% |  | 2007-06-07 | 2008-06-12 | 266d? |  | finish no earlier than 2008-12-11 | S5 | 2128h | 2128h | OAM7-NIM- EOSF | China Mobile | LI, Jian | Rel-8 | Dionisio | 32.819 |  |  |  |  |  |
| 813 | 258 | Study on SA5 MTOSI XML Harmonization | 351d? | 2006-05-10 A | 2007-09-12 A | 100% |  | 2006-05-10 | 2007-09-12 | 351d? |  | finish no earlier than 2007-12-14 | S5 | 2808h | 2808h | OAM8-NIM-XML | Nortel | jduguay@nortel.com | Rel-8 | Dionisio | 32.818 |  |  |  |  |  |
| 814 | 259 | Study on Common Profile Storage (CPS) Framework of User Data for network services and management | 244d? | 2006-07-03 A | 2007-06-07 A | 100% |  | 2006-07-03 | 2007-06-07 | 244d? |  | finish no earlier than 2007-06-07 | S5 | 1952h | 1952h | OAM7-CPS | T-Mobile | istvan.aba@t-mobile.at | Rel-8 | Dionisio | 32.808 |  |  |  |  |  |
| 815 | 260 | Study on Management for LTE and SAE | 526d? | 2006-12-07 A | 2008-12-11 A | 100% |  | 2006-12-07 | 2008-12-11 | 526d? |  | finish no earlier than 2008-12-11 | S5 | 4208h | 4208h | FS_OAM_LTE_SAE | Ericsson | PETERSEN, Robert | Rel-8 | Dionisio | 32.816 |  |  |  |  |  |
| 816 | 261 | Study on Charging Aspects of 3GPP System Evolution | 179d? | 2007-04-02 A | 2007-12-06 A | 100% |  | 2007-04-02 | 2007-12-06 | 179d? |  | finish no earlier than 2007-12-06 | S5 | 1432h | 1432h | FS_SAEcharg | Nokia Siemens Networks | GÖRMER, Gerald | Rel-8 | Dionisio | 32.820 |  |  |  |  |  |
| 817 | 262 | Study on AS-MRFC media server control protocol | 583d? | 2006-03-22 A | 2008-06-13 A | 100% |  | 2006-03-22 | 2008-06-13 | 583d? |  | finish no earlier than 2008-06-13 | C1 | 4664h | 4664h | MRFC | HP | mark.syrett@hp.com | Rel-8 | Frederic | 24.880 |  |  |  |  |  |
| 818 | 263 | Study on IMS Restoration Procedures | 310d? | 2007-03-26 A | 2008-05-30 A | 100% |  | 2007-03-26 | 2008-05-30 | 310d? |  | finish no earlier than 2008-05-30 | C4 | 2480h | 2480h | FS_IMS_RP | Ericsson | german.blanco@ericsson.com | Rel-8 | Kimmo | 23.820 |  |  |  |  |  |
| 819 | 264 | Study on IMS Application Server Service Data Descriptions for AS interoperability | 261d? | 2007-09-14 A | 2008-09-12 A | 100% |  | 2007-09-14 | 2008-09-12 | 261d? |  | finish no earlier than 2008-09-12 | C4 | 2088h | 2088h | FS_IMS_ASIO | Alcatel-Lucent | Jean-Jacques Trottin | Rel-8 | Kimmo | 29.864 |  |  |  |  |  |
| 820 | 265 | Study on Customized Alerting Tone (CAT) solution for voice and video call in CS domain | 261d? | 2007-09-14 A | 2008-09-12 A | 100% |  | 2007-09-14 | 2008-09-12 | 261d? |  |  | C4 | 626.4h | 626.4h | FS_CAT_VVC_CS | China Mobile | zhanghao@chinamobile.com | Rel-8 | Kimmo | 29.882 |  |  |  |  |  |
| 821 | 266 | Study on InterWorking Function between MAP based and Diameter based interfaces | 266d? | 2007-11-30 A | 2008-12-05 A | 100% |  | 2007-11-30 | 2008-12-05 | 266d? |  | finish no earlier than 2008-12-05 | C4 | 2128h | 2128h | FS_MAP2Diam | Huawei | liming49985@huawei.com | Rel-8 | Kimmo | 29.805 | PCG-21 | CP-38 |  |  |  |
| 822 | 267 | Study on Scope of future HSPA Evolution for 1.28 Mcps TDD | 186d? | 2007-09-14 A | 2008-05-30 A | 100% |  | 2007-09-14 | 2008-05-30 | 186d? |  | finish no earlier than 2008-05-30 | R1 | 1488h | 1488h | FS_RAN-LCRTDDHSPAEvo | RITT | Xu Fei | Rel-8 | Patrick | 25.824 |  | RP-37 | RP-080290 |  |  |
| 823 | 268 | Study on Synchronized E-DCH for UTRA FDD | 126d? | 2007-09-14 A | 2008-03-07 A | 100% |  | 2007-09-14 | 2008-03-07 | 126d? |  | finish no earlier than 2008-03-14 | R1 | 1008h | 1008h | FS_RAN-UplinkSync | Nokia Siemens Networks | Karri.Ranta-aho@nsn.com | Rel-8 | Patrick | 25.823 |  | RP-37 | RP-080068 |  |  |
| 824 | 269 | Study on Improved network controlled mobility between LTE and 3GPP2/mobile WiMAX radio technologies | 131d? | 2007-06-04 A | 2007-12-03 A | 100% |  | 2007-06-04 | 2007-12-03 | 131d? |  | finish no earlier than 2007-12-03 | R4 | 1048h | 1048h | FS_RAN-LTEmob | Motorola | hao.bi@Motorola.com | Rel-8 | Issam | 36.938 |  |  | RP-070827 |  |  |
| 825 | 270 | Study on 3G Home NodeB/eNodeB | 325d? | 2007-03-05 A | 2008-05-30 A | 100% |  | 2007-03-05 | 2008-05-30 | 325d? |  | finish no earlier than 2008-05-30 | R4 | 2600h | 2600h | FS_RAN-HNBeNB | Motorola | howard.thomas@motorola.com | Rel-8 | Issam | 25.820 |  |  | RP-080289 |  |  |
| 826 | 271 | Study on HS-PDSCH serving cell change enhancements | 60d? | 2007-12-17 A | 2008-03-07 A | 100% |  | 2007-12-17 | 2008-03-07 | 60d? |  | finish no earlier than 2008-06-12 | R4 | 480h | 480h | FS_RAN-HSPDSCH | Qualcomm Europe |  | Rel-8 | Issam | none | PCG-21 | RP-38 | RP-080070 |  |  |
| 827 | 272 | Study on Dual-Cell HSDPA operation | 261d? | 2007-08-15 A | 2009-03-06 A | 100% |  | 2007-08-15 | 2009-03-06 | 261d? |  | finish no earlier than 2009-03-06 | R1 | 2088h | 2088h | FS_RAN-DCHS | Qualcomm Europe | Josef Blanz | Rel-8 | Patrick | withdrawn 25.825 v100 | PCG-21 | RP-39 | RP-090066 |  |  |
| 828 | 273 | Study on A-interface over IP | 126d? | 2007-08-31 A | 2008-02-22 A | 100% |  | 2007-08-31 | 2008-02-22 | 126d? |  | finish no earlier than 2008-02-22 | GP | 1008h | 1008h | AINTIP | China Mobile, Ericsson | paul.schliwa-bertling@ericsson.com | Rel-8 | Paolo | 43.903 |  |  |  |  |  |
| 829 | 274 | Study on Multi-User Reusing-One-Slot | 602d? | 2007-11-16 A | 2010-03-05 | 98% | 12.04d? | 2007-11-16 | 2010-03-05 | 602d? | 661d | finish no earlier than 2010-03-05 | GP | 4808h | 4711.68h | MUROS | Nokia Siemens Networks | juergen.hofmann@nsn.com | Rel-8 | Paolo | 45.914 |  |  | GP-092021 |  |  |
| 830 | 275 | Study on Optimized Transmit Pulse Shape for Downlink EGPRS2-B | 602d? | 2007-11-16 A | 2010-03-05 | 95% | 30.1d? | 2007-11-16 | 2009-11-20 | 527d? | 661d | finish no earlier than 2010-03-05 | G1 | 4808h | 4567.2h | WIDER | RIM, Nokia Siemens Networks | jdwyer@RIM.COM and eddie.riddington@nsn.com | Rel-8 | Paolo | 45.913 |  |  | GP-092126 |  |  |
| 831 | 276 | Deleted - equals 340035 -FS on Service continuity between mobile and WLAN networks | 75d? | 2007-09-03 A | 2007-12-14 A | 100% |  | 2007-09-03 | 2007-12-14 | 75d? |  | finish no earlier than 2007-12-14 | S1 | 600h | 600h | FSSCMobToW | BT | mike.meyerstein@bt.com | Rel-8 | Alain | 22.937 |  | SP-37 |  | PCG-21 | SP-39 |
| 832 | 277 | Deleted - Study on Evaluation of LCS Control Plane Solution for EPS | 100d? | 2008-01-14 A | 2008-05-30 A | 100% |  | 2008-01-14 | 2008-05-30 | 100d? |  | finish no earlier than 2009-03-20 | S2 | 800h | 800h | FS_LCS_EPS | SiRF |  | Rel-8 | Maurice | 23.891 |  | SP-38 |  | PCG-21 | SP-40 |
| 833 | 278 | Release 7 Features | 1d? | 2000-01-03 | 2000-01-03 |  |  | 2000-01-03 | 2000-01-03 | 1d? | 3317d | start no earlier than 2000-01-01 | CP,GP,RP,SP | 8h |  |  |  |  | Rel-7 |  |  |  |  |  |  |  |

Notes:
- 798: SP#43 completed
- 799: SP#41 completed
- 800: SP#41 completed
- 801: SP#43 completed
- 802: SP#41 completed. No spin-off activity proposed. [Note: IMS Service Brokering enhancements UID_31088 moved back from R8 to R7 to give a home to 22228CR0036_(Rel-7)_S1-051232. Hence, Rel-7 ISB has Stage 1 only (and is misaligned with Rel-7 Stages 2/3.]
- 803: SP#38 completed
- 804: 08/08/08 TR 23.827 v 0.4.0 no progress for 1 year. MCC recommended FS be completed and 23.827 brought under CR. SP#41 completed (draft TR 23.827 not SA approved/published; TR content implemented in TSs)
- 805: SP#40 completed
- 806: SP#39 completed
- 807: SP#39 completed
- 808: SP#39 completed
- 809: SP#41 completed as Rel-8
- 810: SP#43 completed as Rel-8
- 811: SP#38 completed. Spin-off WID UID_34042 (eCall_Phase2)
- 812: SP#40 completed. SID updated SP-050608=>SP-070307
- 813: SP#37 completed. SID updated SP-050295=>SP-070305
- 814: SP#36 completed. Spin-off New Feature UID_400034 (UDC)
- 815: SP#42 completed
- 816: SP#38 completed
- 817: CP#40 completed. Spin-off New Feature UID_380035 (MRFC_TS)
- 818: CP#40 completed. Spin-off WID UID_400012 (IMS_RP)
- 819: CP#41 completed. Linked to SA5 Study on Common Profile Storage framework UID_320006. Spin-off WID UID_410003 (IMS_ASIO)
- 820: CP#41 completed. Spin-off WID under Feature CAT UID_340029
- 821: CP#41 Spin-off WID UID_410007 (MAP2Diam). CP#42 completed
- 822: RP#40 completed. SR in RP-080290
- 823: SID in RP-070678. RP#39 completed. SR in RP-080068
- 824: RP#38 completed. SR in RP-070827
- 825: RP#40 completed. SR in RP-080289
- 826: SID in RP-071044. SR in RP-080070. The study produced no TR. RP#39 completed. Spin-off New implementation WID in RP-080227
- 827: RP#43 closed. TR 25.825 v100 withdrawn. Conclusions in RP-090318 RAN1 findings of the UTRA Multi-Carrier Evolution study). RP#42 New WID RP-080490 (RANimp-DCHSDPA) UID_400052 approved
- 828: GP#37 completed. Spin-off implementation Feature AoIP (A-interface over IP) UID_50591
- 829: GP#44 completion 11/09=>03/10 (was 11/08=>02/09=>05/09=>11/09). Spin-off implementation WI UID_420002 VAMOS (Voice services over Adaptive Multi-user channels on One Slot)
- 830: GP#44 completion 11/09=>03/10 (was 11/08=>02/09=>05/09=>11/09). Needs some more work to define possible Rel-9 or Rel-10 implementation work
- 831: SP#39 stopped
- 832: SP#40 spin-off Feature UID_400038 (LCS_CPS_EPS). SP#40 FS stopped
- 833: -

| ID | WBS | Task | Type | Duration | Start | Finish | Complete | Baseline start | Baseline finish | Baseline duration | Constraint | Resources | Work | Actual work | Text1 | Text4 | Text5 | Text6 | Text8 | Text12 | Text11 | Text7 | Text2 |
| --- | --- | --- | --- | --- | --- | --- | --- | --- | --- | --- | --- | --- | --- | --- | --- | --- | --- | --- | --- | --- | --- | --- | --- |
| 834 | 279 | **Identification of Communication Services in IMS** |  | 620d? | 2005-05-02 A | 2007-09-14 A | 100% | 2005-05-02 | 2007-09-14 | 620d? |  | S2,S1,C1,S5 | 13016h | 13016h | ServID | Ericsson | stephen.terrill@ericsson.com | Rel-7 | Maurice |  |  |  |  |
| 835 | 279.1 | TR on ServID |  | 232d? | 2005-05-02 A | 2006-03-21 A | 100% | 2005-05-02 | 2006-03-21 | 232d? | finish no earlier than 2006-03-20 | S2 | 1856h | 1856h | ServID | Ericsson | stephen.terrill@ericsson.com | Rel-7 | Maurice |  |  |  |  |
| 836 | 279.2 | Stage 1,2 of ServID |  | 144d? | 2005-11-11 A | 2006-05-31 A | 100% | 2005-11-11 | 2006-05-31 | 144d? | start no earlier than 2005-11-11 | S1,S2 | 1152h | 1152h | ServID | Ericsson | stephen.terrill@ericsson.com | Rel-7 | Maurice |  |  |  |  |
| 837 | 279.3 | Stage 3 of ServID |  | 250d? | 2006-03-31 A | 2007-03-15 A | 100% | 2006-03-31 | 2007-03-15 | 250d? | finish no earlier than 2007-03-15 | C1 | 2000h | 2000h | ServID | Ericsson | christer.holmberg@ericsson.com | Rel-7 | Frederic |  |  |  |  |
| 838 | 279.4 | Charging of ServID |  | 381d? | 2006-03-31 A | 2007-09-14 A | 100% | 2006-03-31 | 2007-09-14 | 381d? | finish no earlier than 2007-09-14 | S5 | 3048h | 3048h | ServID | Orange | alain.bibas@orange-ft.com | Rel-7 | Dionisio |  |  |  |  |
| 839 | 280 | **Supporting Globally Routable User Agent URIs in IMS** |  | 415d? | 2005-11-14 A | 2007-06-15 A | 100% | 2005-11-14 | 2007-06-15 | 415d? |  | S2,S1,C1 | 7760h | 7760h | GRUU | RIM | Adrian Buckley (abuckley@rim.com) | Rel-7 | Maurice |  |  |  |  |
| 840 | 280.1 | Deleted - TR on GRUU |  | 219d? | 2005-11-14 A | 2006-09-14 A | 100% | 2005-11-14 | 2006-09-14 | 219d? | finish no earlier than 2006-09-14 | S2 | 1752h | 1752h | GRUU | RIM | Adrian Buckley (abuckley@rim.com) | Rel-7 | Maurice | SP-32 |  |  |  |
| 841 | 280.2 | Stage 1,2 of GRUU |  | 65d? | 2006-07-03 A | 2006-09-29 A | 100% | 2006-07-03 | 2006-09-29 | 65d? | start no earlier than 2006-07-03 | S1,S2 | 520h | 520h | GRUU | RIM | Adrian Buckley (abuckley@rim.com) | Rel-7 | Maurice |  |  |  |  |
| 842 | 280.3 | Stage 3 of GRUU |  | 271d? | 2006-06-02 A | 2007-06-15 A | 100% | 2006-06-02 | 2007-06-15 | 271d? | finish no earlier than 2007-06-15 | C1 | 2168h | 2168h | GRUU | CableLabs | Bernie McKibben | Rel-7 | Frederic |  |  |  |  |
| 843 | 281 | **Multimedia Telephony Service for IMS** |  | 357d? | 2006-02-01 A | 2007-06-15 A | 100% | 2006-02-01 | 2007-06-15 | 357d? |  | S1,C1,S4 | 8976h | 8976h | MTSI | Ericsson | peter.bleckert@ericsson.com | Rel-7 | Alain |  |  |  |  |
| 844 | 281.1 | Stage 1 of MTSI |  | 173d? | 2006-02-01 A | 2006-09-29 A | 100% | 2006-02-01 | 2006-09-29 | 173d? | start no earlier than 2006-02-01 | S1 | 1384h | 1384h | MTSI-REQ | Ericsson | peter.bleckert@ericsson.com | Rel-7 | Alain |  |  |  |  |
| 845 | 281.2 | Stage 3 of MTSI |  | 330d? | 2006-03-10 A | 2007-06-14 A | 100% | 2006-03-10 | 2007-06-14 | 330d? | finish no earlier than 2007-06-15 | C1 | 2640h | 2640h | MTSI | Ericsson | christer.holmberg@ericsson.com | Rel-7 | Frederic |  |  |  |  |
| 846 | 281.3 | Media handling and interaction in MTSI |  | 262d? | 2006-03-15 A | 2007-03-15 A | 100% | 2006-03-15 | 2007-03-15 | 262d? | finish no earlier than 2007-03-15 | S4 | 2096h | 2096h | MTSI-MHI | Ericsson | olle.franceschi@ericsson.com | Rel-7 | Paolo |  |  |  |  |
| 847 | 281.4 | Deleted - duplicates UID7039 - IMS Multimedia Telephony Service | milestone | 0d? | 2007-06-15 A | 2007-06-15 A | 100% | 2007-06-15 | 2007-06-15 | 0d? | start no earlier than 2007-06-15 | S1 |  |  | MMTEL | Ericsson | peter.bleckert@ericsson.com | Rel-7 | Alain | SP-32 |  |  |  |
| 848 | 282 | Multimedia Telephony Service for IMS (MTSI) - UE Conformance Testing |  | 387d | 2007-09-19 A | 2009-03-12 A | 100% | 2007-09-19 | 2009-03-12 | 387d | finish no earlier than 2009-03-13 | R5 | 1664h | 1664h | MTSI-UEConfTest | Ericsson, Motorola | Leif.Mattisson@ericsson.com, Jacob.John@motorola.com | Rel-7 | Ingbert |  | RP-090056 |  |  |
| 849 | 283 | TISPAN requirements for Multimedia Telephony with PSTN/ISDN simulation services |  | 58d? | 2007-09-18 A | 2007-12-06 A | 100% | 2007-09-18 | 2007-12-06 | 58d? | start no earlier than 2007-09-18 | S1 | 464h | 464h | TMMTEL7 |  |  | Rel-7 | Alain |  |  | SP-37 |  |
| 850 | 284 | **Maintenance of TISPAN release 1 common IMS** |  | 58d? | 2007-09-18 A | 2007-12-06 A | 100% | 2007-09-18 | 2007-12-06 | 58d? |  | S2 | 1392h | 1392h | MCIMSTR1 | Ericsson | Raymond Forbes | Rel-7 | Maurice |  |  | SP-38 | PCG-21 |
| 851 | 284.1 | SA1 aspects of MCIMSTR1 |  | 58d? | 2007-09-18 A | 2007-12-06 A | 100% | 2007-09-18 | 2007-12-06 | 58d? | finish no earlier than 2007-12-06 | S1 | 464h | 464h | MCIMSTR1-S1 | Telecom Italia | Marco.DeLuca1@telecomitalia.it | Rel-7 | Alain |  |  | SP-38 | PCG-21 |
| 852 | 284.2 | SA2 aspects of MCIMSTR1 |  | 58d? | 2007-09-18 A | 2007-12-06 A | 100% | 2007-09-18 | 2007-12-06 | 58d? | finish no earlier than 2007-12-06 | S2 | 464h | 464h | MCIMSTR1-S2 | Ericsson | Raymond Forbes | Rel-7 | Maurice |  |  | SP-38 | PCG-21 |
| 853 | 285 | **PS domain and IMS impacts for supporting IMS Emergency calls** |  | 1760d? | 2000-09-18 A | 2007-06-15 A | 100% | 2000-09-18 | 2007-06-15 | 1760d? |  | S2,S1 | 44157h | 44157h | EMC1 | Siemens | Rainer Liebhart | Rel-7 | Maurice |  |  |  |  |
| 854 | 10.1.1 | Service Requirements for IP-based emergency calls |  | 985d | 2000-09-18 A | 2004-06-25 A | 100% | 2000-09-18 | 2004-06-25 | 985d | finish no earlier than 2004-06-25 | S1 | 7880h | 7880h | EMC1 | Siemens | Rainer Liebhart | Rel-7 | Alain |  |  |  |  |
| 855 | 285.2 | Study on Stage 2 for IMS-level solution |  | 668d? | 2003-02-26 A | 2005-09-16 A | 100% | 2003-02-26 | 2005-09-16 | 668d? | finish no earlier than 2005-09-16 | S2 | 5344h | 5344h | EMC1 | Siemens | Rainer Liebhart | Rel-7 | Maurice |  |  |  |  |
| 856 | 285.3 | Study on Stage 2 for GPRS-level solution |  | 301d? | 2004-10-14 A | 2005-12-08 A | 100% | 2004-10-14 | 2005-12-08 | 301d? | finish no earlier than 2005-12-08 | S2 | 2408h | 2408h | EMC1 | Siemens | Rainer Liebhart | Rel-7 | Maurice |  |  |  |  |
| 857 | 285.4 | Stage 2 Specification Phase - IMS-level |  | 200d? | 2005-09-05 A | 2006-06-09 A | 100% | 2005-09-05 | 2006-06-09 | 200d? | finish no earlier than 2006-06-09 | S2 | 1600h | 1600h | EMC1 | Siemens | Rainer Liebhart | Rel-7 | Maurice |  |  |  |  |
| 858 | 285.5 | Deleted - Stage 2 Specification Phase - GPRS-level | milestone | 0d? | 2007-03-02 A | 2007-03-02 A | 100% | 2007-03-02 | 2007-03-02 | 0d? | start no earlier than 2007-03-02 | S2 |  |  | EMC1 | Siemens | Rainer Liebhart | Rel-7 | Maurice | SP-32 |  |  |  |

Notes:
- 834: WID approved SP#28. WID updated SP#32
- 835: - / Text3: 23.816
- 836: - / Text3: 22.228, 23.228, 23.203
- 837: CP#32 approved WID / Text3: 23.218, 24.229
- 838: - / Text3: 32.260, 32.298, 32.299
- 839: SP#29 approved WID
- 840: Abandoned
- 841: SP#29 approved WID / Text3: 22.228, 23.228, 23.218, 24.229
- 842: CP#32 approved WID / Text3: 24.229
- 843: -
- 844: - / Text3: 22.173
- 845: - / Text3: 24.173
- 846: - / Text3: 26.114
- 847: - / Text3: 22.173
- 848: RP#43 completed. Linked UID_7038 (MTSI) / Text3: 34.123-1, 34.123-2, 34.123-3, 34.229-1, 34.229-2
- 849: - / Text3: 22.273 (EI 181 002 maintenance)
- 850: - / Text3: http://www.3gpp.org/specs/TISPAN-IMS-ansfer.htm
- 851: - / Text3: 22.173, 22.273
- 852: - / Text3: 23.406, 23.417, 23.508,23.509, 23.511
- 853: -
- 854: - / Text3: 22.976 (DB shows 04/2003 withdrawn Study on PS domain services and capabilities (az: belongs this really here ?!)
- 855: - / Text3: 23.867
- 856: - / Text3: 23.867
- 857: - / Text3: 23.167, 23.228, 23.060, 23.002, 23.271
- 858: -

| ID | WBS | Task | Type | Duration | Start | Finish | Complete | Baseline start | Baseline finish | Baseline duration | Constraint | Resources | Work | Actual work | Text1 | Text4 | Text5 | Text6 | Text8 | Text3 | Text12 | Text10 | Text11 |
| --- | --- | --- | --- | --- | --- | --- | --- | --- | --- | --- | --- | --- | --- | --- | --- | --- | --- | --- | --- | --- | --- | --- | --- |
| 859 | 10.1 | **Emergency Call Enhancements for IP& PS Based Calls – stage 3** |  | 375d | 2006-01-09 A | 2007-06-15 A | 100% | 2006-01-09 | 2007-06-15 | 375d |  | C1 | 12845h | 12845h | EMC1 | Ericsson | alf.heidermark@ericsson.com | Rel-7 | Frederic |  |  |  |  |
| 860 | 10.1.2 | CT1 IMS aspects to support IMS Emergency sessions |  | 350.82d | 2006-01-09 A | 2007-06-15 A | 100% | 2006-01-09 | 2007-06-15 | 350.82d | finish no earlier than 2007-06-15 | C1 | 2806.57h | 2806.57h | EMC1 | Ericsson | alf.heidermark@ericsson.com | Rel-7 | Frederic | 24.229 |  |  |  |
| 861 | 10.1.2 | Deleted - CT3 IMS aspects to support IMS Emergency sessions |  | 95d | 2006-05-08 A | 2006-09-15 A | 100% | 2006-05-08 | 2006-09-15 | 95d | finish no earlier than 2006-09-15 | C3 | 760h | 760h | EMC1 | Ericsson | alf.heidermark@ericsson.com | Rel-7 | Gwiho | 29.163 | CP-33 |  |  |
| 862 | 10.1.5 | Deleted - CT3 PS domain aspects to support IMS Emergency sessions |  | 95d | 2006-05-08 A | 2006-09-15 A | 100% | 2006-05-08 | 2006-09-15 | 95d | start no earlier than 2006-05-08 | C3 | 760h | 760h | EMC1 | Ericsson | alf.heidermark@ericsson.com | Rel-7 | Gwiho | 29.061 | CP-33 |  |  |
| 863 | 10.1.5 | CT1 PS domain aspects to support IMS Emergency sessions |  | 349.9d | 2006-01-09 A | 2007-06-15 A | 100% | 2006-01-09 | 2007-06-15 | 349.9d | finish no earlier than 2007-06-15 | C1 | 2799.2h | 2799.2h | EMC1 | Ericsson | alf.heidermark@ericsson.com | Rel-7 | Frederic | 24.008, 24.234 |  |  |  |
| 864 | 10.1.5 | CT4 PS domain aspects to support IMS Emergency sessions |  | 365d | 2006-01-09 A | 2007-06-01 A | 100% | 2006-01-09 | 2007-06-01 | 365d | finish no earlier than 2007-06-01 | C4 | 2920h | 2920h | EMC1-GPRSc4 | Ericsson | alf.heidermark@ericsson.com | Rel-7 | Kimmo | 29.060 |  |  |  |
| 865 | 286 | IMS Support of Conferencing |  | 355d? | 2005-11-04 A | 2007-03-15 A | 100% | 2005-11-04 | 2007-03-15 | 355d? | finish no earlier than 2007-03-15 | C1 | 2840h | 2840h | IMSconf | Alcatel-Lucent | Keith Drage (drage@alcatel-lucent.com) | Rel-7 | Frederic | 24.147, 24.229 |  |  |  |
| 866 | 287 | Performance Characterization of VoIMS over HSDPA\EUL channels |  | 713d? | 2005-03-15 A | 2007-12-06 A | 100% | 2005-03-15 | 2007-12-06 | 713d? | finish no earlier than 2007-12-06 | S4 | 5704h | 5704h | VoIMS-PCVoIMS | Alcatel-Lucent | mcgowan@alcatel-lucent.com | Rel-7 | Paolo | 26.935 |  |  |  |
| 867 | 288 | **WLAN-UMTS Interworking Phase 2** |  | 371d? | 2004-01-05 A | 2005-06-07 A | 100% | 2004-01-05 | 2005-06-07 | 371d? |  | S1 | 3888h | 3888h | WLAN2 | Telenor | frederic.paint@telenor.com | Rel-7 | Alain | 33.234 (SP-36 SA3 CRs approved) |  |  |  |
| 868 | 288.1 | Stage 1 on Session Continuity |  | 115d? | 2004-01-05 A | 2004-06-11 A | 100% | 2004-01-05 | 2004-06-11 | 115d? | start no earlier than 2004-01-05 | S1 | 920h | 920h | WLAN-SC |  |  | Rel-7 | Alain | 22.234 |  | SP-24 |  |
| 869 | 288.2 | Stage 2 on Session Continuity: covered by SAE | milestone | 0d? | 2005-06-07 A | 2005-06-07 A | 100% | 2005-06-07 | 2005-06-07 | 0d? | finish no earlier than 2005-06-07 | S2 |  |  | WLAN-SC |  |  | Rel-7 | Maurice |  |  |  |  |
| 870 | 289 | **WLAN Interworking – Private Network access from WLAN 3GPP IP Access** |  | 252d? | 2005-10-10 A | 2006-09-26 A | 100% | 2005-10-10 | 2006-09-26 | 252d? |  | S2,C1,C3,C4 | 8936h | 8936h | WLANPNA | NEC | Toshiyuki Tamura (tamurato@aj.jp.nec.com) | Rel-7 | Maurice |  |  |  |  |
| 871 | 289.1 | WLAN-PNA - Stage 2 |  | 185d? | 2005-10-10 A | 2006-06-23 A | 100% | 2005-10-10 | 2006-06-23 | 185d? | start no earlier than 2005-10-10 | S2 | 1480h | 1480h | WLANPNA-st2 | NEC | Toshiyuki Tamura (tamurato@aj.jp.nec.com) | Rel-7 | Maurice | 23.234, 33.234 |  |  |  |
| 872 | 289.2 | **WLAN-PNA - Stage 3** |  | 170d? | 2006-02-01 A | 2006-09-26 A | 100% | 2006-02-01 | 2006-09-26 | 170d? |  | C1,C3,C4 | 5440h | 5440h | WLANPNA-st3 | NEC |  | Rel-7 | Frederic |  |  |  |  |
| 873 | 289.2.1 | CT1 aspets for WLAN-PNA |  | 170d? | 2006-02-01 A | 2006-09-26 A | 100% | 2006-02-01 | 2006-09-26 | 170d? | start no earlier than 2006-02-01 | C1 | 1360h | 1360h | WLANPNA-st3 | NEC |  | Rel-7 | Frederic | 24.234 |  |  |  |
| 874 | 289.2.2 | CT3 aspets for WLAN-PNA |  | 170d? | 2006-02-01 A | 2006-09-26 A | 100% | 2006-02-01 | 2006-09-26 | 170d? | start no earlier than 2006-02-01 | C3 | 1360h | 1360h | WLANPNA-st3 | NEC |  | Rel-7 | Gwiho | 29.161 |  |  |  |
| 875 | 289.2.3 | Deleted - CT4 aspets for WLAN-PNA |  | 170d? | 2006-02-01 A | 2006-09-26 A | 100% | 2006-02-01 | 2006-09-26 | 170d? | start no earlier than 2006-02-01 | C4 | 1360h | 1360h | WLANPNA-st3 | NEC |  | Rel-7 | Kimmo | 29.234 | CP-32 |  |  |
| 876 | 290 | **Enhancements to support QoS provisioning over 3GPP/WLAN Interworking** |  | 520d? | 2005-03-14 A | 2007-03-09 A | 100% | 2005-03-14 | 2007-03-09 | 520d? |  | S2,C4,C1 | 8360h | 8360h | WLANQOS | Samsung |  | Rel-7 | Maurice |  |  |  |  |
| 877 | 290.1 | Deleted - TR on support of QoS on WLAN |  | 232d? | 2005-03-14 A | 2006-01-31 A | 100% | 2005-03-14 | 2006-01-31 | 232d? | start no earlier than 2005-03-14 | S2 | 1856h | 1856h | WLANQOS | Samsung |  | Rel-7 | Maurice | 23.836 | SP-32 |  |  |
| 878 | 290.2 | Stage 2 on support of QoS over 3GPP/WLAN interworking |  | 108d? | 2006-02-01 A | 2006-06-30 A | 100% | 2006-02-01 | 2006-06-30 | 108d? | start no earlier than 2006-02-01 | S2 | 864h | 864h | WLANQOS | Samsung |  | Rel-7 | Maurice | 23.234 |  |  |  |
| 879 | 290.3 | Stage 3 CT4 on support of QoS over 3GPP/WLAN Interworking |  | 121d? | 2006-09-22 A | 2007-03-09 A | 100% | 2006-09-22 | 2007-03-09 | 121d? | finish no earlier than 2007-03-09 | C4 | 968h | 968h | WLANQOS | Huawei | zhang.peng@huawei.com | Rel-7 | Kimmo | 29.234, 23.008 |  |  |  |
| 880 | 290.4 | Stage 3 CT1 on support of QoS over 3GPP/WLAN Interworking |  | 64d? | 2006-09-04 A | 2006-11-30 A | 100% | 2006-09-04 | 2006-11-30 | 64d? | finish no earlier than 2006-11-30 | C1 | 512h | 512h | WLANQOS | Huawei | zhang.peng@huawei.com | Rel-7 | Frederic | 24.234 |  |  |  |
| 881 | 291 | **Location Services enhancements** |  | 906d? | 2004-06-28 A | 2007-12-17 A | 100% | 2004-06-28 | 2007-12-17 | 906d? |  | S1,S2,GP,C4,R2 | 46933.6h | 46933.6h | LCS3 |  |  | Rel-7 | Alain |  |  |  |  |
| 882 | 291.1 | Stage 2 for LCS3 (including IMS emergency location aspects) |  | 446d? | 2004-12-31 A | 2006-09-15 A | 100% | 2004-12-31 | 2006-09-15 | 446d? | finish no earlier than 2006-09-15 | S2 | 3568h | 3568h | LCS3 | SiRF | brodilitz@sirf.com | Rel-7 | Maurice | 23.271 |  |  |  |
| 883 | 291.2 | LCS Enhancements related to Location-Based Services |  | 695d? | 2005-01-03 A | 2007-08-31 A | 100% | 2005-01-03 | 2007-08-31 | 695d? | finish no earlier than 2007-08-31 | GP | 5560h | 5560h | LCS3-LBS | SiRF | kjudge@sirf.com | Rel-7 | Paolo | 43.059, 44.031, 48.008, 49.031 |  |  |  |
| 884 | 291.3 | CT4 aspects for LCS UEPos-LBS |  | 240d? | 2006-01-02 A | 2006-12-01 A | 100% | 2006-01-02 | 2006-12-01 | 240d? | finish no earlier than 2006-12-01 | C4 | 1920h | 1920h | LCS3-UEPos-LBS | SiRF | brodilitz@sirf.com | Rel-7 | Kimmo | 24.030, 24.080, 29.002 |  |  |  |
| 885 | 291.4 | UE positioning - Velocity |  | 394d? | 2005-03-15 A | 2006-09-15 A | 100% | 2005-03-15 | 2006-09-15 | 394d? | finish no earlier than 2006-09-15 | R2 | 3152h | 3152h | LCS3-UEPos-Velocity | SiRF | BRodilitz@SiRF.com | Rel-7 | Joern | 25.305, 25.331, 25.410, 25.413, 25.453 |  |  | RP-060459 |
| 886 | 291.5 | Inclusion of Uplink TDOA UE positioning method in the UTRAN specifications |  | 849d? | 2004-09-15 A | 2007-12-17 A | 100% | 2004-09-15 | 2007-12-17 | 849d? | finish no earlier than 2007-12-17 | R2 | 6792h | 6792h | LCS3-UEPos-UTDOA | TruePosition | Robert Gross | Rel-7 | Joern | 25.305, 25.453 |  |  | RP-070797 |

Notes:
- 859: -
- 860: -
- 861: Cancelled for Rel-7 and there is now corresponding Rel-8 WI
- 862: Cancelled for Rel-7 and there is now corresponding Rel-8 WI
- 863: -
- 864: -
- 865: CP#35 revised WID
- 866: -
- 867: Created at TSG#27 because of WLAN items belonging to Rel-7
- 868: -
- 869: -
- 870: -
- 871: Approved at SP#29
- 872: Approved at CP#29
- 873: Approved at CP#29
- 874: Approved at CP#29
- 875: CT4#31; no impacts identified, therefore completed. CP-32 stopped
- 876: Moved from FS section Feb 06. SP-30 updated WID
- 877: SP-32 stopped
- 878: SP-30 updated WID
- 879: CP-32 approved WID
- 880: CP-32 approved WID
- 881: -
- 882: SP#27 approved WID.
- 883: -
- 884: -
- 885: Completed Sept 2006; SR in RP-060459
- 886: Completed Nov 2007; SR in RP-070797

| ID | WBS | Task | Type | Duration | Start | Finish | Complete | Baseline start | Baseline finish | Baseline duration | Constraint | Resources | Work | Actual work | Text1 | Text4 | Text5 | Text6 | Text8 | Text12 | Text11 | Text2 | Text7 |
| --- | --- | --- | --- | --- | --- | --- | --- | --- | --- | --- | --- | --- | --- | --- | --- | --- | --- | --- | --- | --- | --- | --- | --- |
| 887 | 291.6 | **LCS for 3GPP Interworking WLAN** |  | 700d? | 2004-06-28 A | 2007-03-02 A | 100% | 2004-06-28 | 2007-03-02 | 700d? |  | S1 | 11901.6h | 11901.6h | LCS3-IWLAN | Telcordia | Mike Loushine | Rel-7 | Alain |  |  |  |  |
| 888 | 291.6.1 | FS on 3GPP system to WLAN Interworking with LCS |  | 512.7d? | 2004-06-28 A | 2006-06-30 A | 100% | 2004-06-28 | 2006-06-30 | 512.7d? | finish no earlier than 2005-09-29 | S1 | 4101.6h | 4101.6h | LCS3-IWLAN-FSs1 | Telcordia | Mike Loushine, Vijay Varma | Rel-7 | Alain |  |  |  |  |
| 889 | 291.6.2 | Delete - Study of work on an LCS architecture for I-WLAN. |  | 180d? | 2006-06-26 A | 2007-03-02 A | 100% | 2006-06-26 | 2007-03-02 | 180d? | finish no earlier than 2007-03-02 | S2 | 1440h | 1440h | LCS3-IWLAN-FSs2 | LG Electronics | dhshim@lge.com ; phede@lge.com | Rel-7 | Maurice | SP-35 |  |  |  |
| 890 | 291.6.3 | Stage 2 for LCS architecture for I-WLAN |  | 95d? | 2006-10-23 A | 2007-03-02 A | 100% | 2006-10-23 | 2007-03-02 | 95d? | finish no earlier than 2007-03-02 | S2 | 760h | 760h | LCS3-IWLAN | LG Electronics | dhshim@lge.com ; phede@lge.com | Rel-7 | Maurice |  |  |  |  |
| 891 | 291.7 | Deleted - UE positioning Rel-7 |  | 849d? | 2004-09-15 A | 2007-12-17 A | 100% | 2004-09-15 | 2007-12-17 | 849d? |  | RP | 6792h | 6792h | LCS3-UEpos |  |  | Rel-7 |  | RP-38 |  |  |  |
| 892 | 291.8 | Deleted - RAN2 aspects for LBS | milestone | 0d? | 2005-06-15 A | 2005-06-15 A | 100% | 2005-06-15 | 2005-06-15 | 0d? | start no earlier than 2005-06-15 | R2 |  |  | LCS3-UEPos-LBS | SiRF | BRodilitz@SiRF.com | Rel-7 | Joern | RP-31 |  |  |  |
| 893 | 292 | **MBMS Enhancements** |  | 625d? | 2005-07-11 A | 2007-11-30 A | 100% | 2005-07-11 | 2007-11-30 | 625d? |  | S1 | 10844.6h | 10844.6h | MBMSE | China Mobile | liuhongyfw@chinamobile.com | Rel-7 | Alain |  |  |  |  |
| 894 | 292.1 | Stage 1 of MBMSE |  | 109d? | 2005-07-11 A | 2005-12-08 A | 100% | 2005-07-11 | 2005-12-08 | 109d? | finish no earlier than 2005-12-08 | S1,R1,C3 | 872h | 872h | MBMSE | China Mobile | liuhongyfw@chinamobile.com | Rel-7 | Alain |  |  |  |  |
| 895 | 292.2 | MBMS FDD Physical layer Enhancements |  | 117.29d? | 2006-12-15 A | 2007-06-04 A | 100% | 2006-12-15 | 2007-06-04 | 117.29d? | finish no earlier than 2007-06-04 | R1 | 938.32h | 938.32h | MBMSE-RANPhysFDD | Ericsson | Lars.Lindbom@ericsson.com | Rel-7 | Patrick |  | RP-070290 |  |  |
| 896 | 292.3 | MBMS TDD Physical layer Enhancements |  | 117.29d? | 2006-12-15 A | 2007-06-04 A | 100% | 2006-12-15 | 2007-06-04 | 117.29d? | finish no earlier than 2007-06-04 | R1 | 938.32h | 938.32h | MBMSE-RANPhysTDD | IPWireless | Nicholas Anderson | Rel-7 | Patrick |  | RP-070291 |  |  |
| 897 | 292.4 | MBMS Low Chip Rate TDD Physical Layer Enhancement |  | 127d? | 2007-03-16 A | 2007-09-10 A | 100% | 2007-03-16 | 2007-09-10 | 127d? | finish no earlier than 2007-09-10 | R1 | 1016h | 1016h | MBMSE-RANPhysLCRTDD | RITT | Lin Hui | Rel-7 | Patrick |  | RP-070292 |  |  |
| 898 | 292.5 | MBMS Mz interface |  | 260d? | 2006-12-04 A | 2007-11-30 A | 100% | 2006-12-04 | 2007-11-30 | 260d? | finish no earlier than 2007-05-11 | C3 | 2080h | 2080h | MBMSMz | Huawei | Deng Tingting (ttdeng@huawei.com) | Rel-7 | Gwiho |  |  |  |  |
| 899 | 293 | **MBMS - UE Conformance Testing** |  | 657d? | 2007-06-01 A | 2009-12-04 A | 100% | 2007-06-01 | 2009-12-04 | 657d? |  | R5 | 13848h | 13848h | MBMSE_UEConTest |  |  | Rel-7 | Ingbert |  |  | PCG-21 | SP-40 |
| 900 | 293.1 | Conformance Test Aspects – MBMS TDD Physical layer Enhancements – MBSFN for HCR and VHCR TDD |  | 336d? | 2007-06-01 A | 2008-09-12 A | 100% | 2007-06-01 | 2008-09-12 | 336d? | start no earlier than 2007-06-01 | R5 | 2688h | 2688h | MBMSE-RANPhysTDD_UEConTest | IPWireless | tspeight@ipwireless.com | Rel-7 | Ingbert |  | RP-080541 |  |  |
| 901 | 293.2 | Conformance Test Aspects – MBMS LCR TDD Physical Layer Enhancement |  | 342d? | 2008-05-30 A | 2009-09-18 A | 100% | 2008-05-30 | 2009-09-18 | 342d? | finish no earlier than 2009-09-18 | R5 | 2728h | 2728h | MBMSE-RANPhysLCRTDD_UEConTest | CATT | chenxiaozhong@datangmobile.cn | Rel-7 | Ingbert |  | RP-090715 | PCG-21 | RP-40 |
| 902 | 293.3 | Conformance Test Aspects – MBSFN for FDD |  | 397d? | 2008-05-30 A | 2009-12-04 A | 100% | 2008-05-30 | 2009-12-04 | 397d? | finish no earlier than 2009-12-04 | R5 | 3176h | 3176h | MBMSE-UEConTest_RANPhysFDD | Huawei | Xiang Li (trica_li@huawei.com) | Rel-7 | Ingbert |  | RP-091214 | PCG-21 | RP-40 |
| 903 | 294 | MBMS User Service Extensions |  | 392d? | 2005-12-07 A | 2007-06-07 A | 100% | 2005-12-07 | 2007-06-07 | 392d? | finish no earlier than 2007-06-07 | S4 | 3136h | 3136h | MBMSUSE | Ericsson | Thorsten.Lohmar@ericsson.com | Rel-7 | Paolo |  |  |  |  |
| 904 | 295 | **Advanced Global Navigation Satellite System (A-GNSS) concept** |  | 830d? | 2004-06-28 A | 2007-08-31 A | 100% | 2004-06-28 | 2007-08-31 | 830d? |  | S1,GP,R2 | 9553.6h | 9553.6h | LCS3-AGNSS | Alcatel | Michel.monnerat@thalesaleniaspace.com | Rel-7 | Alain |  |  |  |  |
| 905 | 295.1 | Towards A-GNSS Concept |  | 811.2d? | 2004-06-28 A | 2007-08-31 A | 100% | 2004-06-28 | 2007-08-31 | 811.2d? | finish no earlier than 2007-08-31 | GP | 6489.6h | 6489.6h | AGNSS-GP | Alcatel | richard.couty@space.alcatel.fr | Rel-7 | Paolo |  |  |  |  |
| 906 | 295.2 | Global Navigation Satellite System (GNSS) in UTRAN |  | 383d? | 2005-12-15 A | 2007-06-04 A | 100% | 2005-12-15 | 2007-06-04 | 383d? | finish no earlier than 2007-06-04 | R2 | 3064h | 3064h | LCS3-GNSS-UTRAN | France Telecom | alain.abinakhoul@francetelecom.com | Rel-7 | Joern |  | RP-070482 |  |  |
| 907 | 295.3 | Deleted - Towards A-GNSS Concept | milestone | 0d? | 2007-02-16 A | 2007-02-16 A | 100% | 2007-02-16 | 2007-02-16 | 0d? | start no earlier than 2007-02-16 | S1 |  |  | GNSS | Alcatel | richard.couty@space.alcatel.fr | Rel-7 | Alain | SP-34 |  |  |  |
| 908 | 296 | A-GPS Minimum Performance |  | 351d? | 2006-04-28 A | 2007-08-31 A | 100% | 2006-04-28 | 2007-08-31 | 351d? | finish no earlier than 2007-08-31 | GP | 2808h | 2808h | GAGR | Spirent | richard.catmur@spirentcom.com | Rel-7 | Paolo |  |  |  |  |
| 909 | 297 | **USSD message delivery and transfer to USIM** |  | 376d? | 2004-03-05 A | 2005-08-12 A | 100% | 2004-03-05 | 2005-08-12 | 376d? |  | S1,C6 | 2762.4h | 2762.4h | USSD-USIM | Axalto | Christophe Dubois (cdubois@axalto.com) | Rel-7 | Alain |  |  |  |  |
| 910 | 297.1 | Stage 1 |  | 152d? | 2004-03-18 A | 2004-10-15 A | 100% | 2004-03-18 | 2004-10-15 | 152d? | start no earlier than 2004-03-18 | S1 | 1216h | 1216h | USSD-USIM | Axalto | Christophe Dubois (cdubois@axalto.com) | Rel-7 | Alain |  |  |  |  |
| 911 | 297.2 | Alignment with requirements regarding USSD usage |  | 193.3d? | 2004-03-05 A | 2005-08-12 A | 100% | 2004-03-05 | 2005-08-12 | 193.3d? | finish no earlier than 2005-08-12 | C6 | 1546.4h | 1546.4h | USSD-USIM | Axalto | Christophe Dubois (cdubois@axalto.com) | Rel-7 | Xavier |  |  |  |  |

Notes:
- 887: - / Text3: 22.935
- 888: - / Text3: 22.935
- 889: Updated WID at SP#32 to change "stage 2" to "study" , duplicated UID 320017 deleted. SP#33 TR for Information. Last mention SP-35 Mar 2007 (abandoned ?) / Text3: 23.837
- 890: WID at SP#55 / Text3: 23.234, 23.271, 23.167
- 891: -
- 892: - / Text3: 25.305, 25.331, 25.410, 25.413, 25.453
- 893: -
- 894: Structure created by MCC to include RAN aspects under SA1 Feature / Text3: 22.146, 22.246, 22.228
- 895: Completed May 2007; SR in RP-070290 / Text3: 25.211, 25.212, 25.213, 25.101, 25.104, 25.331, 25.433, 25.346, 25.306
- 896: Completed May 2007; SR in RP-070291 / Text3: 25.346, 25.221, 25.222, 25.223, 25.224, 25.306, 25.331, 25.402, 25.433, 25.102, 25.105, 25.123
- 897: Completed May 2007; SR in RP-070292 / Text3: 25.346, 25.221, 25.222, 25.223, 25.224, 25.306, 25.331, 25.402, 25.433, 25.102, 25.105, 25.123
- 898: - / Text3: 29.061
- 899: Linked to Feature UID_31084 (MBMSE). 1 Apr 2009 Flagged as Rel-7 i/o Rel-8 to match the Core specs release
- 900: SR in RP-080541. RP#41 completed / Text3: 34.108, 34.122, 34.123-1/2/3
- 901: RP#45 completed / Text3: 34.108, 34.123-1
- 902: RP#46 completed / Text3: 34.108, 34.109, 34.121-1, 34.121-2, 34.123-1, 34.123-2, 34.123-3
- 903: - / Text3: 26.346, 26.946
- 904: -
- 905: GP#36 completed
- 906: Completed Sept 2006; SR in RP-070482 / Text3: 25.305, 25.331, 25.306, 25.413, 25.423, 25.433, 25.453, 25.302, 25.215, 25.401, 25.402, 25.450, 25.452
- 907: -
- 908: - / Text3: 45.005, 51.010
- 909: -
- 910: - / Text3: 22.090
- 911: -

| ID | WBS | Task | Type | Duration | Start | Finish | Complete | Baseline start | Baseline finish | Baseline duration | Constraint | Resources | Work | Actual work | Text1 | Text4 | Text5 | Text6 | Text8 | Text3 | Text12 |
| --- | --- | --- | --- | --- | --- | --- | --- | --- | --- | --- | --- | --- | --- | --- | --- | --- | --- | --- | --- | --- | --- |
| 912 | 298 | **Combinational Services** |  | 296d? | 2005-01-17 A | 2006-03-06 A | 100% | 2005-01-17 | 2006-03-06 | 296d? |  | S1,S2,C1,S4 | 5176h | 5176h | CSICS | TeliaSonera | Robert.Frank@teliasonera.com | Rel-7 | Alain |  |  |
| 913 | 298.1 | Stage 1 for CSICS |  | 104d? | 2005-01-17 A | 2005-06-09 A | 100% | 2005-01-17 | 2005-06-09 | 104d? | start no earlier than 2005-01-17 | S1 | 832h | 832h | CSICS | TeliaSonera | Robert.Frank@teliasonera.com | Rel-7 | Alain | 22.279 |  |
| 914 | 298.2 | Stage 2 for CSICS |  | 130d? | 2005-01-17 A | 2005-07-15 A | 100% | 2005-01-17 | 2005-07-15 | 130d? | start no earlier than 2005-01-17 | S2 | 1040h | 1040h | CSICS | TeliaSonera | Robert.Frank@teliasonera.com | Rel-7 | Maurice | 23.279 |  |
| 915 | 298.3 | Stage 3 for CSICS CN aspects |  | 221d? | 2005-05-02 A | 2006-03-06 A | 100% | 2005-05-02 | 2006-03-06 | 221d? | finish no earlier than 2006-03-06 | C1 | 1768h | 1768h | CSICS | Vodafone | Peter Dawes | Rel-7 | Frederic | 24.879, 24.279, 24.229, 24.008 |  |
| 916 | 298.4 | Stage 3 for codec aspects |  | 192d? | 2005-03-15 A | 2005-12-07 A | 100% | 2005-03-15 | 2005-12-07 | 192d? | finish no earlier than 2005-12-07 | S4 | 1536h | 1536h | CSICS-Codec | Ericsson | Per.Frojdh@ericsson.com | Rel-7 | Paolo | 26.141, 26.235 |  |
| 917 | 299 | **CAMEL Trunk Triggers** |  | 251d? | 2004-12-17 A | 2005-12-05 A | 100% | 2004-12-17 | 2005-12-05 | 251d? |  | S1,C4 | 6024h | 6024h | TTCAMEL | Nortel | Amar Deol (deola@nortelnetworks.com) | Rel-7 | Alain |  |  |
| 918 | 299.1 | Stage 1 for CAMEL Trunk Triggers |  | 251d? | 2004-12-17 A | 2005-12-05 A | 100% | 2004-12-17 | 2005-12-05 | 251d? |  | S1 | 2008h | 2008h | TTCAMEL | Nortel | Amar Deol (deola@nortelnetworks.com) | Rel-7 | Alain | 22.078 |  |
| 919 | 299.2 | CAMEL Trunk Originated Trigger Detection Points |  | 251d? | 2004-12-17 A | 2005-12-05 A | 100% | 2004-12-17 | 2005-12-05 | 251d? | start no earlier than 2004-12-17 | C4 | 2008h | 2008h | CamelR7 | Nortel | David Hutton (dhutton@nortel.com) | Rel-7 | Kimmo |  |  |
| 920 | 300 | **IMS Service Brokering enhancements** |  | 69d? | 2005-12-07 A | 2006-03-13 A | 100% | 2005-12-07 | 2006-03-13 | 69d? |  | S1 | 1104h | 1104h | ISB | Telcordia | jbakker@telcordia.com | Rel-7 | Alain | 22.228 |  |
| 921 | 300.1 | Stage 1 for ISB |  | 69d? | 2005-12-07 A | 2006-03-13 A | 100% | 2005-12-07 | 2006-03-13 | 69d? | finish no earlier than 2006-03-13 | S1 | 552h | 552h | ISB-s1 | Telcordia | jbakker@telcordia.com | Rel-7 | Alain | 22.228 |  |
| 922 | 301 | **Enhancements of VGCS for public authority officials** |  | 731d? | 2004-08-27 A | 2007-06-15 A | 100% | 2004-08-27 | 2007-06-15 | 731d? |  | S1,C1,C4,G2 | 25920h | 25920h | EVGCS |  |  | Rel-7 | Alain | 43.068, 44.068, 24.008, 29.002 |  |
| 923 | 301.1 | Stage 1 | milestone | 0d? | 2004-08-27 A | 2004-08-27 A | 100% | 2004-08-27 | 2004-08-27 | 0d? | finish no earlier than 2004-08-27 | S1 |  |  | EVGCS | Siemens | Joerg Swetina (joerg.swetina@nw.neclab.eu) | Rel-7 | Alain | 42.068, 43.068 |  |
| 924 | 301.2 | **Architecture and protocol aspects** |  | 731d? | 2004-08-27 A | 2007-06-15 A | 100% | 2004-08-27 | 2007-06-15 | 731d? |  | C1,C4 | 14904h | 14904h | EVGCS | Siemens | robert.zaus@nsn.com | Rel-7 | Frederic | 43.068, 44.068 |  |
| 925 | 301.2.1 | CT1 aspects of EVGCS |  | 731d? | 2004-08-27 A | 2007-06-15 A | 100% | 2004-08-27 | 2007-06-15 | 731d? | finish no earlier than 2006-09-15 | C1 | 5848h | 5848h | EVGCS | Siemens | robert.zaus@nsn.com | Rel-7 | Frederic | 43.068, 44.068, 24.008 |  |
| 926 | 301.2.2 | CT4 aspects of EVGCS |  | 401d? | 2004-08-27 A | 2006-03-10 A | 100% | 2004-08-27 | 2006-03-10 | 401d? | finish no earlier than 2006-03-10 | C4 | 3208h | 3208h | EVGCS | Siemens | robert.zaus@nsn.com | Rel-7 | Kimmo | 29.002 |  |
| 927 | 301.3 | GERAN2 aspects |  | 646d? | 2004-08-27 A | 2007-02-16 A | 100% | 2004-08-27 | 2007-02-16 | 646d? | finish no earlier than 2007-02-16 | G2 | 5168h | 5168h | EVGCS | Siemens | kenneth.isaacs@roke.co.uk | Rel-7 | Gert |  |  |
| 928 | 302 | **Improvements of VGCS for parallel use of services** |  | 523d? | 2005-03-15 A | 2007-03-15 A | 100% | 2005-03-15 | 2007-03-15 | 523d? |  | S1 | 12230.2h | 12230.2h | IVGCS |  |  | Rel-7 | Alain |  |  |
| 929 | 302.1 | Service Requirements for VGCS improvements |  | 62d? | 2005-03-15 A | 2005-06-08 A | 100% | 2005-03-15 | 2005-06-08 | 62d? | finish no earlier than 2005-06-08 | S1 | 496h | 496h | IVGCS | T-Mobile | kurt.bischinger@t-mobile.at | Rel-7 | Alain | 42.068 |  |
| 930 | 302.2 | Stage 2 modifications for VGCS improvements |  | 335d? | 2005-12-01 A | 2007-03-14 A | 100% | 2005-12-01 | 2007-03-14 | 335d? | start no earlier than 2005-12-01 | C1 | 2680h | 2680h | IVGCS | T-Mobile | kurt.bischinger@t-mobile.at | Rel-7 | Frederic | 43.068 |  |
| 931 | 302.3 | **Protocol aspects** |  | 336d? | 2005-12-01 A | 2007-03-15 A | 100% | 2005-12-01 | 2007-03-15 | 336d? |  | C1 | 5376h | 5376h | IVGCS | T-Mobile | Dieter Jacobsohn | Rel-7 | Frederic | 44.068 |  |
| 932 | 302.3.1 | CT1 aspects of IVGCS |  | 336d? | 2005-12-01 A | 2007-03-15 A | 100% | 2005-12-01 | 2007-03-15 | 336d? | finish no earlier than 2007-03-15 | C1 | 2688h | 2688h | IVGCS | T-Mobile |  | Rel-7 | Frederic | 43.068, 44.068 |  |
| 933 | 302.3.2 | Deleted - CT4 aspects of IVGCS | milestone | 0d? | 2007-03-09 A | 2007-03-09 A | 100% | 2007-03-09 | 2007-03-09 | 0d? | finish no earlier than 2007-03-09 | C4 |  |  | IVGCS-St3-c4 | T-mobile |  | Rel-7 | Kimmo | 29.002 | CP-35 |
| 934 | 303 | **OSA Rel-7** |  | 584d? | 2005-03-15 A | 2007-06-08 A | 100% | 2005-03-15 | 2007-06-08 | 584d? |  | S1,C5 | 17920h | 17920h | OSA7 | AePONA | eamonn.murray@aepona.com | Rel-7 | Alain |  |  |
| 935 | 303.1 | Service Requirements for OSA Service Broker |  | 62d? | 2005-03-15 A | 2005-06-08 A | 100% | 2005-03-15 | 2005-06-08 | 62d? | finish no earlier than 2005-06-08 | S1 | 496h | 496h | OSA7-SB | AePONA | eamonn.murray@aepona.com | Rel-7 | Alain | 22.127 |  |
| 936 | 303.2 | Stage 2 OSA API Service Brokering |  | 156d? | 2006-04-28 A | 2006-12-01 A | 100% | 2006-04-28 | 2006-12-01 | 156d? |  | C5 | 1248h | 1248h | OSA7-SB | AePONA | damian.oneill@aepona.com | Rel-7 | Kimmo | 23.198 |  |
| 937 | 303.3 | Stage 3 OSA API Service Brokering |  | 156d? | 2006-04-28 A | 2006-12-01 A | 100% | 2006-04-28 | 2006-12-01 | 156d? | finish no earlier than 2006-12-01 | C5 | 1248h | 1248h | OSA7-SB | AePONA | damian.oneill@aepona.com | Rel-7 | Kimmo | 29.198-16 |  |

Notes:
- 912: -
- 913: -
- 914: -
- 915: -
- 916: -
- 917: -
- 918: -
- 919: -
- 920: No CR submitted in rel-8 (according to CR database).
- 921: No Rel-8 changes
- 922: Moved from Rel-6 UID_50563 Enhancements of VGCS in public networks for communication of public authority officials
- 923: Voice Group Call Service
- 924: -
- 925: -
- 926: -
- 927: -
- 928: Voice Group Call Service
- 929: -
- 930: -
- 931: Previous name (before CT32) was Architecture and protocol aspects
- 932: -
- 933: CT4#33 stage 2 solution is still open. ...
- 934: -
- 935: az: WID URL corrected
- 936: -
- 937: -

| ID | WBS | Task | Type | Duration | Start | Finish | Complete | Baseline start | Baseline finish | Baseline duration | Constraint | Resources | Work | Actual work | Text1 | Text3 | Text4 | Text5 | Text6 | Text8 | Text12 | Text11 |
| --- | --- | --- | --- | --- | --- | --- | --- | --- | --- | --- | --- | --- | --- | --- | --- | --- | --- | --- | --- | --- | --- | --- |
| 938 | 303.4 | **OSA Stage 2/3 enhancements** |  | 291d? | 2006-04-28 A | 2007-06-08 A | 100% | 2006-04-28 | 2007-06-08 | 291d? |  | C5 | 10256h | 10256h | OSA7 | 29.198/9, 23.198 | AePONA | damian.oneill@aepona.com | Rel-7 | Kimmo |  |  |
| 939 | 303.4.1 | Parlay X Message Broadcast Web Service |  | 156d? | 2006-04-28 A | 2006-12-01 A | 100% | 2006-04-28 | 2006-12-01 | 156d? | finish no earlier than 2006-12-01 | C5 | 1248h | 1248h | OSA7 | 29.199-15, 23.198 | ETRI |  | Rel-7 | Kimmo |  |  |
| 940 | 303.4.2 | Parlay X Geocoding Web Service |  | 156d? | 2006-04-28 A | 2006-12-01 A | 100% | 2006-04-28 | 2006-12-01 | 156d? | finish no earlier than 2006-12-01 | C5 | 1248h | 1248h | OSA7 | 29.199-16, 23.198 | ETRI |  | Rel-7 | Kimmo |  |  |
| 941 | 303.4.3 | Parlay X Application driven QoS Web Service |  | 226d? | 2006-04-28 A | 2007-03-09 A | 100% | 2006-04-28 | 2007-03-09 | 226d? | finish no earlier than 2007-03-09 | C5 | 1808h | 1808h | OSA7 | 29.199-17, 23.198 | BT |  | Rel-7 | Kimmo |  |  |
| 942 | 303.4.4 | Parlay-X Device Capabilities and Configuration |  | 162d? | 2006-10-26 A | 2007-06-08 A | 100% | 2006-10-26 | 2007-06-08 | 162d? | finish no earlier than 2007-06-09 | C5 | 1296h | 1296h | OSA7 | 29.199-18, 23.198 | Telenor |  | Rel-7 | Kimmo |  |  |
| 943 | 303.4.5 | Parlay-X Multimedia Streaming Session Management Web Service |  | 97d? | 2006-10-26 A | 2007-03-09 A | 100% | 2006-10-26 | 2007-03-09 | 97d? | start no earlier than 2006-10-26 | C5 | 776h | 776h | OSA7 | 29.199-19, 23.198 | Telenor |  | Rel-7 | Kimmo |  |  |
| 944 | 303.4.6 | Parlay-X Multimedia Multicast Control Web Service |  | 97d? | 2006-10-26 A | 2007-03-09 A | 100% | 2006-10-26 | 2007-03-09 | 97d? | start no earlier than 2006-10-26 | C5 | 776h | 776h | OSA7 | 29.199-20, 23.198 | ETRI |  | Rel-7 | Kimmo |  |  |
| 945 | 303.4.7 | OSA API Conference Call Control SCF |  | 97d? | 2006-10-26 A | 2007-03-09 A | 100% | 2006-10-26 | 2007-03-09 | 97d? | start no earlier than 2006-10-26 | C5 | 776h | 776h | OSA7 | 29.198-04-5, 23.198 | Ericsson |  | Rel-7 | Kimmo |  |  |
| 946 | 304 | **Selective Disabling of UE Capabilities** |  | 624.36d? | 2005-01-24 A | 2007-06-15 A | 100% | 2005-01-24 | 2007-06-15 | 624.36d? |  | S1,S2,C1 | 12351.7h | 12351.7h | SDoUE |  | Motorola |  | Rel-7 | Alain |  |  |
| 947 | 304.1 | Stage 1 of SDoUE |  | 393.6d? | 2005-01-24 A | 2006-12-08 A | 100% | 2005-01-24 | 2006-12-08 | 393.6d? | finish no earlier than 2006-12-08 | S1 | 3148.8h | 3148.8h | SDoUE-CR | 22.011 | Motorola |  | Rel-7 | Alain |  |  |
| 948 | 304.2 | Deleted - TR on different possible architectures |  | 195d? | 2005-03-21 A | 2005-12-16 A | 100% | 2005-03-21 | 2005-12-16 | 195d? | finish no earlier than 2005-12-16 | S2 | 1560h | 1560h | SDoUE-FS | 23.805 abandonned at SP-30; descendant C1 24.305 | Vodafone | Gavin.Wong@vodafone.com | Rel-7 | Maurice | SP-30 |  |
| 949 | 304.3 | Stage 3 of SDoUE |  | 331d? | 2006-03-10 A | 2007-06-15 A | 100% | 2006-03-10 | 2007-06-15 | 331d? | finish no earlier than 2007-06-15 | C1 | 2648h | 2648h | SDoUE | 24.305 | Ericsson | christian.herrero@ericsson.com | Rel-7 | Frederic |  |  |
| 950 | 305 | **Network selection enhancements (NSP)** |  | 328d? | 2006-03-15 A | 2007-06-15 A | 100% | 2006-03-15 | 2007-06-15 | 328d? |  | S1 | 6320h | 6320h | NSP-CR | 22.101, 22.011, 23.122, 24.008, 25.304, 31.102, 45.008 | O2 | chris.friel@o2.com | Rel-7 | Alain |  |  |
| 951 | 305.1 | Stage 1 of NSP |  | 191d? | 2006-03-15 A | 2006-12-06 A | 100% | 2006-03-15 | 2006-12-06 | 191d? | start no earlier than 2006-03-15 | S1 | 1528h | 1528h | NSP-TS | 22.101, 22.011, 23.122, 24.008, 25.304, 31.102, 45.008 | O2 | chris.friel@o2.com | Rel-7 | Alain |  |  |
| 952 | 305.2 | Procedural aspects of NSP |  | 271d? | 2006-06-02 A | 2007-06-15 A | 100% | 2006-06-02 | 2007-06-15 | 271d? | finish no earlier than 2007-06-15 | C1 | 2168h | 2168h | NSP-CR | 23.122, 24.008, 31.102 | Motorola | Andrew Howell | Rel-7 | Frederic |  |  |
| 953 | 306 | Network Selection enhancements (NSP) - UE Conformance Testing |  | 396d? | 2007-06-01 A | 2008-12-05 A | 100% | 2007-06-01 | 2008-12-05 | 396d? | finish no earlier than 2008-12-05 | R5 | 3168h | 3168h | NSP-CR_UEConTest | 34.108, 34.123-1, 34.123-2, 34.123-3 | Nokia | jarkko.hellsten@nokia.com | Rel-7 | Ingbert |  | RP-080819 |
| 954 | 307 | **Access Class Barring and Overload Protection** |  | 650d? | 2004-03-15 A | 2006-09-08 A | 100% | 2004-03-15 | 2006-09-08 | 650d? |  | S2,C1 | 3568h | 3568h | ACBOP | 23.898 | Vodafone | Chris Pudney | Rel-7 | Maurice |  |  |
| 955 | 307.1 | TR on Stage 2 |  | 274d? | 2004-03-15 A | 2005-03-31 A | 100% | 2004-03-15 | 2005-03-31 | 274d? | finish no earlier than 2005-03-31 | S2 | 2192h | 2192h | ACBOP | 23.898 | NTT DoCoMo | Jean-Jacques Davidian (davidian@docomo.fr) | Rel-7 | Maurice |  |  |
| 956 | 307.2 | Stage 3 CN aspects of ACBOP |  | 172d? | 2005-06-06 A | 2006-01-31 A | 100% | 2005-06-06 | 2006-01-31 | 172d? | start no earlier than 2005-06-06 | C1 | 1376h | 1376h | ACBOP | 24.008 |  |  | Rel-7 | Frederic |  |  |
| 957 | 307.3 | Deleted - Potential impact on Iu interface Overload functionality | milestone | 0d? | 2004-03-15 A | 2004-03-15 A | 100% | 2004-03-15 | 2004-03-15 | 0d? | finish no earlier than 2004-03-15 | RP |  |  | ACBOP | 25.413 |  |  | Rel-7 | Issam | RP-25 |  |
| 958 | 307.4 | Deleted - Extra ACBOP information in RAN | milestone | 0d? | 2004-03-15 A | 2004-03-15 A | 100% | 2004-03-15 | 2004-03-15 | 0d? | finish no earlier than 2004-03-15 | RP |  |  | ACBOP | 25.331 |  |  | Rel-7 | Issam | RP-25 |  |
| 959 | 307.5 | Deleted - Extra ACBOP information in GERAN | milestone | 0d? | 2006-09-08 A | 2006-09-08 A | 100% | 2006-09-08 | 2006-09-08 | 0d? | start no earlier than 2006-09-08 | GP |  |  | ACBOP | 44.018 |  |  | Rel-7 | Paolo | RP-33 |  |
| 960 | 308 | **System enhancements for fixed broadband access to IMS** |  | 876d? | 2003-11-05 A | 2007-03-14 A | 100% | 2003-11-05 | 2007-03-14 | 876d? |  | S2,S3,S5,C1,C3,C4 | 36656h | 36656h | FBI |  |  |  | Rel-7 | Maurice |  |  |
| 961 | 308.1 | **TISPAN Rel 1 related aspects** |  | 873d? | 2003-11-05 A | 2007-03-09 A | 100% | 2003-11-05 | 2007-03-09 | 873d? |  | S2 | 31568h | 31568h | FBI-TIS1 |  |  |  | Rel-7 | Maurice |  |  |
| 962 | 308.1.1 | Stage 2 of FBI for TISPAN R1 |  | 365d? | 2004-10-14 A | 2006-03-08 A | 100% | 2004-10-14 | 2006-03-08 | 365d? | start no earlier than 2004-10-14 | S2 | 2920h | 2920h | FBI-TIS1 |  |  |  | Rel-7 | Maurice |  |  |

Notes:
- 938: CP#34: WID updated. Completion 12/06 =>03/07
- 939: -
- 940: -
- 941: -
- 942: -
- 943: -
- 944: -
- 945: -
- 946: Moved from FS section Feb 06
- 947: Moved from FS section Feb 06
- 948: Moved from FS section Feb 06. Abandoned at SP-30
- 949: -
- 950: -
- 951: -
- 952: -
- 953: RP#42 completed. SR in RP-080819. Linked to UID_7041 (NSP-CR).
- 954: -
- 955: -
- 956: NEW - inserted on 2/9/2004
- 957: -
- 958: -
- 959: -
- 960: -
- 961: -
- 962: -

| ID | WBS | Task | Duration | Start | Finish | Complete | Baseline start | Baseline finish | Baseline duration | Constraint | Resources | Work | Actual work | Text1 | Text4 | Text5 | Text6 | Text8 | Text3 | Text12 |
| --- | --- | --- | --- | --- | --- | --- | --- | --- | --- | --- | --- | --- | --- | --- | --- | --- | --- | --- | --- | --- |
| 963 | 308.1.2 | **Protocol impact of FBI for TISPAN R1** | 873d? | 2003-11-05 A | 2007-03-09 A | 100% | 2003-11-05 | 2007-03-09 | 873d? |  | C1 | 20720h | 20720h | FBI-TIS1 | Siemens | peter.leis@nsn.com | Rel-7 | Frederic |  |  |
| 964 | 308.1.2.1 | CT1 aspects of FBI for TISPAN R1 | 802d? | 2003-11-05 A | 2006-11-30 A | 100% | 2003-11-05 | 2006-11-30 | 802d? | finish no earlier than 2006-11-30 | C1 | 6416h | 6416h | FBI-TIS1 | Siemens | peter.leis@nsn.com | Rel-7 | Frederic | 24.819, 24.229 |  |
| 965 | 308.1.2.2 | CT3 aspects of FBI for TISPAN R1 | 808d? | 2003-11-05 A | 2006-12-08 A | 100% | 2003-11-05 | 2006-12-08 | 808d? | finish no earlier than 2006-12-08 | C3 | 6464h | 6464h | FBI-TIS1 | Siemens | peter.leis@nsn.com | Rel-7 | Gwiho | 29.163, 29.209 |  |
| 966 | 308.1.2.3 | CT4 aspects of FBI for TISPAN R1 | 301d? | 2006-01-13 A | 2007-03-09 A | 100% | 2006-01-13 | 2007-03-09 | 301d? | finish no earlier than 2007-03-09 | C4 | 2408h | 2408h | FBI-TIS1-st3-c4 | Siemens | peter.leis@nsn.com | Rel-7 | Kimmo | 29.229 |  |
| 967 | 308.1.3 | Security Enhancements for FBI | 118d? | 2005-06-28 A | 2005-12-08 A | 100% | 2005-06-28 | 2005-12-08 | 118d? | start no earlier than 2005-06-28 | S3 | 944h | 944h | FBI-ISE | Ericsson | Bengt.Sahlin@ericsson.com | Rel-7 | Dionisio | 33.203 |  |
| 968 | 308.2 | **PacketCable Related aspects** | 291d? | 2006-02-01 A | 2007-03-14 A | 100% | 2006-02-01 | 2007-03-14 | 291d? |  | S2,S5,C1 | 5088h | 5088h | FBI-PCBL | CableLabs | Bernie McKibben | Rel-7 | Maurice |  |  |
| 969 | 308.2.1 | Stage 1,2 of FBI for PacketCable | 228d? | 2006-02-01 A | 2006-12-15 A | 100% | 2006-02-01 | 2006-12-15 | 228d? | finish no earlier than 2006-12-15 | S2 | 1824h | 1824h | FBI-PCBL | CableLabs | Bernie McKibben | Rel-7 | Maurice | 22.228, 23.228 |  |
| 970 | 308.2.2 | Protocol impact of FBI for PacketCable | 228d? | 2006-05-01 A | 2007-03-14 A | 100% | 2006-05-01 | 2007-03-14 | 228d? | finish no earlier than 2007-03-15 | C1 | 1824h | 1824h | FBI-PCBL |  |  | Rel-7 | Frederic |  |  |
| 971 | 308.2.3 | SA5 Charging aspects of FBI for PacketCable | 180d? | 2006-03-31 A | 2006-12-07 A | 100% | 2006-03-31 | 2006-12-07 | 180d? | finish no earlier than 2006-12-07 | S5 | 1440h | 1440h | FBI-PCBL-CH | CableLabs | Bernie McKibben | Rel-7 | Dionisio | 32.240, 32.260, 32.298, 32.299 |  |
| 972 | 309 | **Support of SMS over generic 3GPP IP access** | 696d? | 2004-10-14 A | 2007-06-14 A | 100% | 2004-10-14 | 2007-06-14 | 696d? |  | S2,C4,C1 | 12408h | 12408h | SMSIP | Huawei | zhangwenlin@huawei.com | Rel-7 | Maurice |  |  |
| 973 | 309.1 | FS on SMSIP | 173d? | 2004-10-14 A | 2005-06-13 A | 100% | 2004-10-14 | 2005-06-13 | 173d? | start no earlier than 2004-10-14 | S2 | 1384h | 1384h | SMSIP | Huawei | zhangwenlin@huawei.com | Rel-7 | Maurice | 23.804 |  |
| 974 | 309.2 | Stage 2 for SMSIP | 333d? | 2005-06-08 A | 2006-09-15 A | 100% | 2005-06-08 | 2006-09-15 | 333d? | finish no earlier than 2006-09-15 | S2 | 2664h | 2664h | SMSIP | Huawei | zhangwenlin@huawei.com | Rel-7 | Maurice | 23.204 |  |
| 975 | 309.3 | **Stage 3 for SMSIP** | 527d? | 2005-06-08 A | 2007-06-14 A | 100% | 2005-06-08 | 2007-06-14 | 527d? |  | C4,C1 | 8360h | 8360h | SMSIP-St3 | Nokia | jari.jansson@nokia.com | Rel-7 | Kimmo |  |  |
| 976 | 309.3.1 | CT1 aspects for SMSIP | 527d? | 2005-06-08 A | 2007-06-14 A | 100% | 2005-06-08 | 2007-06-14 | 527d? | finish no earlier than 2007-06-15 | C1 | 4216h | 4216h | SMSIP | Nokia | jari.jansson@nokia.com | Rel-7 | Frederic | 23.040, 24.229 |  |
| 977 | 309.3.2 | CT4 aspects for SMSIP | 518d? | 2005-06-08 A | 2007-06-01 A | 100% | 2005-06-08 | 2007-06-01 | 518d? | finish no earlier than 2007-06-01 | C4 | 4144h | 4144h | SMSIP-St3-c4 | Nokia | jari.jansson@nokia.com | Rel-7 | Kimmo | 23.008, 29.002 |  |
| 978 | 310 | **Evolution of Policy Control and Charging** | 817d? | 2004-10-14 A | 2007-11-30 A | 100% | 2004-10-14 | 2007-11-30 | 817d? |  | S2,S5,C3,C1 | 30336h | 30336h | PCC | Nokia | balazs.bertenyi@nsn.com | Rel-7 | Maurice |  |  |
| 979 | 310.1 | Deleted - TR for PCC | 315d? | 2004-10-14 A | 2005-12-29 A | 100% | 2004-10-14 | 2005-12-29 | 315d? | finish no earlier than 2005-12-28 | S2 | 2520h | 2520h | PCC | Nokia | balazs.bertenyi@nsn.com | Rel-7 | Maurice | 23.803 | SP-33 |
| 980 | 310.2 | Stage 2 for PCC | 315d? | 2005-07-04 A | 2006-09-15 A | 100% | 2005-07-04 | 2006-09-15 | 315d? | finish no earlier than 2006-09-15 | S2 | 2520h | 2520h | PCC | Nokia | balazs.bertenyi@nsn.com | Rel-7 | Maurice | 23.203 |  |
| 981 | 310.3 | Evolution of policy control and flow based bearer level charging | 109d? | 2006-08-01 A | 2006-12-29 A | 100% | 2006-08-01 | 2006-12-29 | 109d? | start no earlier than 2006-08-01 | S2 | 872h | 872h | PCC | Nokia | balazs.bertenyi@nsn.com | Rel-7 | Maurice | 23.207, 23.002, 23.228 |  |
| 982 | 310.4 | SA5 Charging aspects of PCC | 316d? | 2006-03-31 A | 2007-06-15 A | 100% | 2006-03-31 | 2007-06-15 | 316d? | finish no earlier than 2007-06-15 | S5 | 2528h | 2528h | PCC-CH | Orange | alain.bibas@orange-ft.com | Rel-7 | Dionisio | 32.250, 32.251, 32.298, 32.299 |  |
| 983 | 310.5 | Gx reference point for Policy and Charging Control | 521d? | 2005-12-02 A | 2007-11-30 A | 100% | 2005-12-02 | 2007-11-30 | 521d? | finish no earlier than 2007-09-14 | C3 | 4168h | 4168h | PCC-Gx | Siemens | Thomas.Belling@nsn.com | Rel-7 | Gwiho | 29.212 (not progressed to Rel-7: 29.210, 29.207, 29.208) |  |
| 984 | 310.6 | **Rx reference point for PCC CT3 aspects** | 521d? | 2005-12-02 A | 2007-11-30 A | 100% | 2005-12-02 | 2007-11-30 | 521d? |  | C3,C1 | 11192h | 11192h | PCC-Rx | Ericsson | j.javier.pastor@ericsson.com | Rel-7 | Gwiho |  |  |
| 985 | 310.6.1 | PCC-Rx CT3 aspects | 521d? | 2005-12-02 A | 2007-11-30 A | 100% | 2005-12-02 | 2007-11-30 | 521d? | finish no earlier than 2007-09-14 | C3 | 4168h | 4168h | PCC-Rx-c3 | Ericsson | j.javier.pastor@ericsson.com | Rel-7 | Gwiho | 29.213, 29.214 (not progressed to Rel-7: 29.209, 29.211) |  |
| 986 | 310.6.2 | PCC-Rx CT1 aspects | 357d? | 2005-12-02 A | 2007-06-15 A | 100% | 2005-12-02 | 2007-06-15 | 357d? | finish no earlier than 2007-06-15 | C1 | 2856h | 2856h | PCC-Rx-Gx-c1 | Ericsson | j.javier.pastor@ericsson.com | Rel-7 | Frederic | 24.229 |  |

Notes:
- 963: -
- 964: end date updated by CT1-chairman after CP#33
- 965: -
- 966: CT4#32: a set of CRs on FBI for cable labs
- 967: Duplicated entry ("ACCSEC2", "Access Security Enhancements", SP-040865) deleted by A.Sultan
- 968: -
- 969: -
- 970: -
- 971: 03/2006 SP#31 WID approved
- 972: SP#33 updated WID (removed MMS)
- 973: SP#33 updated WID
- 974: SP#33 updated WID
- 975: CP#34 updated WID
- 976: CP#34 updated WID
- 977: CP#34 updated WID
- 978: SP-29 approved WID. SP-31 updated WID adding SA5 charging. 23.125 will be discontinued from Rel-7.
- 979: SP-30: S2 has no intention for TR completion
- 980: SP-29 approved WID. SP-31 updated WID. 23.125 will be discontinued from Rel-7.
- 981: SP-29 approved WID. SP-31 updated WID. 23.125 will be discontinued from Rel-7.
- 982: SP-31 updated WID with SA5 charging.
- 983: -
- 984: WID approved at CP#30, Revised at CP#31, Revised at CP#33
- 985: -
- 986: -

| ID | WBS | Task | Type | Duration | Start | Finish | Complete | Baseline start | Baseline finish | Baseline duration | Constraint | Resources | Work | Actual work | Text1 | Text4 | Text5 | Text6 | Text8 | Text3 | Text12 |
| --- | --- | --- | --- | --- | --- | --- | --- | --- | --- | --- | --- | --- | --- | --- | --- | --- | --- | --- | --- | --- | --- |
| 987 | 311 | **Voice call continuity between CS and IMS (incl. I-WLAN)** |  | 641d? | 2004-12-31 A | 2007-06-15 A | 100% | 2004-12-31 | 2007-06-15 | 641d? |  | S2,S1,S5,C1,C4 | 12224h | 12224h | VCC | Alcatel-Lucent | Keith Drage (drage@alcatel-lucent.com) | Rel-7 | Maurice |  |  |
| 988 | 311.1 | TR for VCC |  | 245d? | 2004-12-31 A | 2005-12-08 A | 100% | 2004-12-31 | 2005-12-08 | 245d? | finish no earlier than 2005-12-08 | S2 | 1960h | 1960h | VCC | Alcatel-Lucent | Andy Bennett (andybennett@alcatel-lucent.com) | Rel-7 | Maurice | 23.806 |  |
| 989 | 311.2 | Stage 1 for VCC |  | 140d? | 2005-03-17 A | 2005-09-28 A | 100% | 2005-03-17 | 2005-09-28 | 140d? | finish no earlier than 2005-09-28 | S1 | 1120h | 1120h | VCC | Alcatel-Lucent | Andy Bennett (andybennett@alcatel-lucent.com) | Rel-7 | Alain | 22.101 |  |
| 990 | 311.3 | Stage 2 for VCC |  | 264d? | 2005-09-06 A | 2006-09-08 A | 100% | 2005-09-06 | 2006-09-08 | 264d? | finish no earlier than 2006-09-08 | S2 | 2112h | 2112h | VCC | Alcatel-Lucent | Andy Bennett (andybennett@alcatel-lucent.com) | Rel-7 | Maurice | 23.206 |  |
| 991 | 311.4 | SA5 Charging aspects of VCC |  | 325d? | 2006-03-17 A | 2007-06-14 A | 100% | 2006-03-17 | 2007-06-14 | 325d? | finish no earlier than 2007-06-14 | S5 | 2600h | 2600h | VCC-CH | Orange | alain.bibas@orange-ft.com | Rel-7 | Dionisio | 32.250, 32.260 |  |
| 992 | 311.5 | **Stage 3 for VCC** |  | 358d? | 2006-02-01 A | 2007-06-15 A | 100% | 2006-02-01 | 2007-06-15 | 358d? |  | C1,C4 | 4432h | 4432h | VCC | Alcatel-Lucent | Keith Drage (drage@alcatel-lucent.com) | Rel-7 | Frederic |  |  |
| 993 | 311.5.1 | CT1 aspects of VCC |  | 358d? | 2006-02-01 A | 2007-06-15 A | 100% | 2006-02-01 | 2007-06-15 | 358d? | finish no earlier than 2007-06-15 | C1 | 2864h | 2864h | VCC | Alcatel-Lucent | Keith Drage (drage@alcatel-lucent.com) | Rel-7 | Frederic | 24.206, 24.216 |  |
| 994 | 311.5.2 | CT4 aspects of VCC |  | 196d? | 2006-06-09 A | 2007-03-09 A | 100% | 2006-06-09 | 2007-03-09 | 196d? | start no earlier than 2006-06-09 | C4 | 1568h | 1568h | VCC-St3-c4 | Alcatel-Lucent | Keith Drage (drage@alcatel-lucent.com) | Rel-7 | Kimmo | 23.003 |  |
| 995 | 311.5.3 | Deleted - CT3 aspects of VCC | milestone | 0d? | 2006-11-02 A | 2006-11-02 A | 100% | 2006-11-02 | 2006-11-02 | 0d? | finish no earlier than 2006-11-02 | C3 |  |  | VCC | Alcatel-Lucent | Keith Drage (drage@alcatel-lucent.com) | Rel-7 | Gwiho | 29.163 | CP-33 |
| 996 | 312 | **One Tunnel solution for optimization of Packet Data Traffic** |  | 418d? | 2006-03-27 A | 2007-10-31 A | 100% | 2006-03-27 | 2007-10-31 | 418d? |  | S2 | 7048h | 7048h | OPTUNEL | Nokia | antti.j.pasanen@nokia.com | Rel-7 | Maurice |  |  |
| 997 | 312.1 | Deleted - Study on Stage 2 for One Tunnel solution |  | 125d? | 2006-03-27 A | 2006-09-15 A | 100% | 2006-03-27 | 2006-09-15 | 125d? | finish no earlier than 2005-09-12 | S2 | 1000h | 1000h | OPTUNEL-Study | Nokia | antti.j.pasanen@nokia.com | Rel-7 | Maurice | 23.809 | SP-34 |
| 998 | 312.2 | One Tunnel Deployment Guideline |  | 268d? | 2006-10-23 A | 2007-10-31 A | 100% | 2006-10-23 | 2007-10-31 | 268d? | finish no earlier than 2007-10-31 | S2 | 2144h | 2144h | OPTUNEL-Guide | Huawei | lan.liu@huawei.com | Rel-7 | Maurice | 23.919 |  |
| 999 | 312.3 | Stage 2 specification for One Tunnel solution |  | 70d? | 2006-09-11 A | 2006-12-15 A | 100% | 2006-09-11 | 2006-12-15 | 70d? | finish no earlier than 2006-12-15 | S2 | 560h | 560h | OPTUNEL-Stage2 | Nokia | antti.j.pasanen@nokia.com | Rel-7 | Maurice | 23.060 |  |
| 1000 | 313 | **CSI Terminating Session handling** |  | 267d? | 2006-06-08 A | 2007-06-15 A | 100% | 2006-06-08 | 2007-06-15 | 267d? |  | S2,C1 | 4728h | 4728h | CSItermS | Samsung | Osok Song | Rel-7 | Maurice |  |  |
| 1001 | 313.1 | Stage 2 of CStermS |  | 192d? | 2006-06-08 A | 2007-03-02 A | 100% | 2006-06-08 | 2007-03-02 | 192d? | start no earlier than 2006-06-08 | S2 | 1536h | 1536h | CSItermS | Samsung | Osok Song | Rel-7 | Maurice | 23.279 |  |
| 1002 | 313.2 | Stage 3 of CStermS |  | 132d? | 2006-12-14 A | 2007-06-15 A | 100% | 2006-12-14 | 2007-06-15 | 132d? | finish no earlier than 2007-06-15 | C1 | 1056h | 1056h | CSItermS | Samsung | chenho.chin@samsung.com | Rel-7 | Frederic | 24.229, 24.279 |  |
| 1003 | 313.3 | Deleted - duplicated with UID 340015 -Stage 3 CSI Terminating Session handling | milestone | 0d? | 2007-03-09 A | 2007-03-09 A | 100% | 2007-03-09 | 2007-03-09 | 0d? | start no earlier than 2007-03-09 | C1 |  |  | CSItermS | Samsung | chenho.chin@samsung.com | Rel-7 | Frederic | 24.229, 24.179, 24.279 | CP-34 |
| 1004 | 314 | Liberty Alliance and 3GPP Security Interworking |  | 451d? | 2005-03-10 A | 2006-11-30 A | 100% | 2005-03-10 | 2006-11-30 | 451d? | finish no earlier than 2006-11-30 | S3 | 3608h | 3608h | LibSec | Nokia | Silke.Holtmanns@NOKIA.COM | Rel-7 | Dionisio | 33.980 |  |
| 1005 | 315 | Trust Requirements for Open Platforms in 3GPP |  | 499d? | 2005-01-03 A | 2006-11-30 A | 100% | 2005-01-03 | 2006-11-30 | 499d? | finish no earlier than 2006-11-30 | S3 | 3992h | 3992h | TrustOP | Nokia | Silke.Holtmanns@NOKIA.COM | Rel-7 | Dionisio | 33.905 |  |
| 1006 | 316 | Development of UEA2 and UIA2 |  | 268d? | 2004-12-01 A | 2005-12-09 A | 100% | 2004-12-01 | 2005-12-09 | 268d? | finish no earlier than 2005-12-09 | S3 | 2144h | 2144h | AlgUEA2 | TeliaSonera | per.christoffersson@teliasonera.com | Rel-7 | Dionisio | 35.919, 35.215, 35.216, 35.217, 35.218 |  |
| 1007 | 317 | Lawful Interception in the 3GPP Rel-7 architecture |  | 118d? | 2005-06-28 A | 2005-12-08 A | 100% | 2005-06-28 | 2005-12-08 | 118d? | start no earlier than 2005-06-28 | S3 | 944h | 944h | LI-7A | BMWI | berthold.wilhelm@regtp.de | Rel-7 | Dionisio | 33.106, 33.107, 33.108 |  |
| 1008 | 318 | Key establishment between a UICC and a terminal |  | 201.45d? | 2005-12-07 A | 2006-09-28 A | 100% | 2005-12-07 | 2006-09-28 | 201.45d? | finish no earlier than 2006-09-28 | S3 | 1611.6h | 1611.6h | KeyEstUTerm | Gemalto | mireille.pauliac@gemplus.com | Rel-7 | Dionisio | 33.110 |  |
| 1009 | 319 | NDS Authentication Framework Extension for Transport Layer Security |  | 50d? | 2006-09-28 A | 2006-12-06 A | 100% | 2006-09-28 | 2006-12-06 | 50d? | finish no earlier than 2006-09-28 | S3 | 400h | 400h | NDSAFTLS | Nokia | tiina.s.koskinen@nokia.com | Rel-7 | Dionisio | 33.310 |  |
| 1010 | 320 | **Security enhancements** |  | 319d? | 2005-09-12 A | 2006-11-30 A | 100% | 2005-09-12 | 2006-11-30 | 319d? |  | S3,C1,C4 | 4856h | 4856h | SEC7 |  |  | Rel-7 | Dionisio |  |  |
| 1011 | 320.1 | HTTPS connection between a UICC and a NAF |  | 1d? | 2005-09-12 A | 2005-09-12 A | 100% | 2005-09-12 | 2005-09-12 | 1d? | start no earlier than 2005-09-12 | S3,C1 | 8h | 8h | SEC7-HSUN | Gemalto | JSeif@axalto.com, mireille.pauliac@gemplus.com | Rel-7 | Dionisio | 33.918, 33.222, 24.109 |  |
| 1012 | 320.2 | 2G GBA: 2G SIM usage in 3GPP GAA framework |  | 61d? | 2005-09-12 A | 2005-12-05 A | 100% | 2005-09-12 | 2005-12-05 | 61d? | finish no earlier than 2005-12-05 | S3 | 488h | 488h | SEC7-2GGBA | Nokia | Silke.Holtmanns@nokia.com | Rel-7 | Dionisio | 33.920, 33.220 |  |
| 1013 | 320.3 | Generic Authentication Architecture usage extensions and optimizations |  | 319d? | 2005-09-12 A | 2006-11-30 A | 100% | 2005-09-12 | 2006-11-30 | 319d? | finish no earlier than 2006-11-30 | S3 | 2552h | 2552h | SEC7-GAA2 | Nokia | Silke.Holtmanns@nokia.com | Rel-7 | Dionisio | 33.220, 29.109, 24.109, (33.223 goes to R8) |  |

Notes:
- 987: WID approved SP#27; updated SP#28; updated SP#32
- 988: -
- 989: -
- 990: -
- 991: 03/2006 SP#31 WID approved
- 992: -
- 993: -
- 994: -
- 995: -
- 996: -
- 997: S2#52 CREATED. TR for Info SP-33. SP-34: S2 Report intention to discontinue TR
- 999: S2#52 CREATED
- 1000: Triggered by the abandoned Study UID_32117
- 1001: -
- 1002: CP-34 approved WID. CP-35 updated WID
- 1003: CP-34 approved WID
- 1004: WID approved SP#27.
- 1005: WID approved SP#26.
- 1006: WID approved SP#26, Dependant on Funding Availability.
- 1007: -
- 1008: -
- 1009: TLS profile is moved to Rel-8
- 1010: -
- 1011: -
- 1012: -
- 1013: 33.223 goes to R8

| ID | WBS | Task | Duration | Start | Finish | Complete | Baseline start | Baseline finish | Baseline duration | Total slack | Constraint | Resources | Work | Actual work | Text1 | Text4 | Text5 | Text6 | Text8 | Text3 | Text12 | Text2 | Text7 |
| --- | --- | --- | --- | --- | --- | --- | --- | --- | --- | --- | --- | --- | --- | --- | --- | --- | --- | --- | --- | --- | --- | --- | --- |
| 1014 | 320.4 | **SS7 TCAP security Gateway** | 241d? | 2005-09-12 A | 2006-08-14 A | 100% | 2005-09-12 | 2006-08-14 | 241d? |  |  | S3,C4 | 1808h | 1808h | SEC7-NDS-TCAPsec | Siemens | marc.blommaert.ext@nsn.com | Rel-7 | Dionisio |  |  |  |  |
| 1015 | 320.4.1 | SA3 aspects of SEC7-NDS-TCAPsec | 130d? | 2005-09-12 A | 2006-03-10 A | 100% | 2005-09-12 | 2006-03-10 | 130d? |  | finish no earlier than 2006-03-10 | S3 | 1040h | 1040h | SEC7-NDS-TCAPsec-SA3 | Siemens | marc.blommaert.ext@nsn.com | Rel-7 | Dionisio | 33.204 |  |  |  |
| 1016 | 320.4.2 | TCAPsec Gateway | 96d? | 2006-04-03 A | 2006-08-14 A | 100% | 2006-04-03 | 2006-08-14 | 96d? |  | start no earlier than 2006-04-01 | C4 | 768h | 768h | SEC7-TCAP | Siemens | Ulrich.wiehe@gksag.de | Rel-7 | Kimmo | 29.204, 29.002 |  |  |  |
| 1017 | 321 | IMS Stage 3 IETF Protocol alignment | 589d? | 2004-12-10 A | 2007-03-14 A | 100% | 2004-12-10 | 2007-03-14 | 589d? |  | finish no earlier than 2007-03-15 | C1 | 4712h | 4712h | IMSProtoc |  |  | Rel-7 | Frederic | 24.930 |  |  |  |
| 1018 | 322 | **Interoperability between VGCS/VBS and A/Gb flexibility** | 253d? | 2006-03-22 A | 2007-03-09 A | 100% | 2006-03-22 | 2007-03-09 | 253d? |  |  | C1,C4 | 3296h | 3296h | VGCSFlex | Siemens | robert.zaus@nsn.com | Rel-7 | Frederic |  |  |  |  |
| 1019 | 322.1 | CT1 aspects of VGCSFlex | 159d? | 2006-03-22 A | 2006-10-30 A | 100% | 2006-03-22 | 2006-10-30 | 159d? |  | finish no earlier than 2006-10-30 | C1 | 1272h | 1272h | VGCSFlex | Siemens | robert.zaus@nsn.com | Rel-7 | Frederic | 43.068, 43.069 |  |  |  |
| 1020 | 322.2 | CT4 aspects of VGCSFlex | 253d? | 2006-03-22 A | 2007-03-09 A | 100% | 2006-03-22 | 2007-03-09 | 253d? |  | finish no earlier than 2007-03-09 | C4 | 2024h | 2024h | VGCSFlex-c4 | Siemens | robert.zaus@nsn.com | Rel-7 | Kimmo | 29.002 |  |  |  |
| 1021 | 323 | DIAMETER on the GGSN Gi interface | 586d? | 2004-09-10 A | 2006-12-08 A | 100% | 2004-09-10 | 2006-12-08 | 586d? |  | finish no earlier than 2006-12-08 | C3 | 4688h | 4688h | DIAMGi | Vodafone | Nico.Gabriele@vodafone.com | Rel-7 | Gwiho | 29.061 |  |  |  |
| 1022 | 324 | DIAMETER on the PDG Wi interface | 586d? | 2004-09-10 A | 2006-12-08 A | 100% | 2004-09-10 | 2006-12-08 | 586d? |  | finish no earlier than 2006-12-08 | C3 | 4688h | 4688h | DIAMWi | Vodafone | Nico.Gabriele@vodafone.com | Rel-7 | Gwiho | 29.161 |  |  |  |
| 1023 | 325 | Interworking between the 3GPP CS domain with BICC or ISUP as signalling protocol and external SIP-I networks | 478d? | 2006-09-22 A | 2008-07-22 A | 100% | 2006-09-22 | 2008-07-22 | 478d? |  | finish no earlier than 2007-09-14 | C3 | 3824h | 3824h | ExtSIPI | Siemens | Thomas.Belling@nsn.com | Rel-7 | Gwiho | 29.164 |  |  |  |
| 1024 | 326 | PDU multiplexing at Nb Interface with IP transport | 427d? | 2006-12-04 A | 2008-07-22 A | 100% | 2006-12-04 | 2008-07-22 | 427d? |  | start no earlier than 2006-12-04 | C3 | 3416h | 3416h | NbIPMux | Alcatel-Lucent | Jean.Rzeznik@alcatel-lucent.fr | Rel-7 | Gwiho | 29.414 |  |  |  |
| 1025 | 327 | **Mp (MRFC - MRFP) interface** | 345d? | 2006-02-13 A | 2007-06-08 A | 100% | 2006-02-13 | 2007-06-08 | 345d? |  |  | C4,C1 | 4384h | 4384h | Mp | Ericsson | philip.hodges@ericsson.com | Rel-7 | Kimmo |  |  |  |  |
| 1026 | 327.1 | CT1 aspects of Mp | 1d | 2006-02-13 A | 2006-02-13 A | 100% | 2006-02-13 | 2006-02-13 | 1d |  | finish no earlier than 2006-02-13 | C1 | 8h | 8h | Mp | Ericsson | philip.hodges@ericsson.com | Rel-7 | Frederic | 24.229 |  |  |  |
| 1027 | 327.2 | Deleted - CT3 aspects of Mp | 1d | 2006-09-22 A | 2006-09-22 A | 100% | 2006-09-22 | 2006-09-22 | 1d |  | start no earlier than 2006-09-22 | C3 | 8h | 8h | Mp | Ericsson | philip.hodges@ericsson.com | Rel-7 | Gwiho | 29.162 | CP-33 |  |  |
| 1028 | 327.3 | Procedures description | 201d? | 2006-06-02 A | 2007-03-09 A | 100% | 2006-06-02 | 2007-03-09 | 201d? |  | finish no earlier than 2007-03-09 | C4 | 1608h | 1608h | Mp-PROCc4 | Huawei | Chencheng@huawei.com | Rel-7 | Kimmo | 23.333 |  |  |  |
| 1029 | 327.4 | Stage 3 | 345d | 2006-02-13 A | 2007-06-08 A | 100% | 2006-02-13 | 2007-06-08 | 345d |  | finish no earlier than 2007-06-08 | C4 | 2760h | 2760h | Mp-St3c4 | Ericsson | philip.hodges@ericsson.com | Rel-7 | Kimmo | 29.333 |  |  |  |
| 1030 | 328 | Routeing of MT-SMS via the HPLMN | 71d? | 2006-12-01 A | 2007-03-09 A | 100% | 2006-12-01 | 2007-03-09 | 71d? |  | finish no earlier than 2007-03-09 | C4,C1 | 568h | 568h | SMSviaH | Vodafone | Nick.Russell@vodafone.com | Rel-7 | Kimmo | 23.040, 29.002 |  |  |  |
| 1031 | 329 | Mobile Termination whilst the MS is moving to another MSC | 60d? | 2007-03-09 A | 2007-05-31 A | 100% | 2007-03-09 | 2007-05-31 | 60d? |  | start no earlier than 2007-03-09 | C4 | 480h | 480h | MTmovMS | Alcatel-Lucent | bruno.landais@alcatel-lucent.fr | Rel-7 | Kimmo | 23.008, 23.012, 23.018, 23.078, 23.079, 29.002 |  |  |  |
| 1032 | 330 | ISIM API for Java Card | 620d? | 2005-03-14 A | 2007-07-27 A | 100% | 2005-03-14 | 2007-07-27 | 620d? |  | finish no earlier than 2007-07-27 | C6 | 4960h | 4960h | APIJAVA | Sun | Sebastian Hans | Rel-7 | Xavier | 31.103, 102 241 |  |  |  |
| 1033 | 331 | Rel-7 (U)SIM API Testing | 206d? | 2009-05-30 | 2010-03-12 |  | 2009-05-30 | 2010-03-12 | 206d? | 656d | finish no earlier than 2010-03-12 | C6 | 1648h |  | USIM_API_test | Sagem Orga | gerrit.hartbrod@sagem-orga.com | Rel-7 | Xavier | 31.213 |  | PCG-23 | CP-44 |
| 1034 | 332 | High speed interface between the UICC and the ME | 311d? | 2006-09-22 A | 2007-11-30 A | 100% | 2006-09-22 | 2007-11-30 | 311d? |  | finish no earlier than 2007-11-30 | C6 | 2488h | 2488h | HSI | Gemalto | jacques.seif@GEMALTO.COM | Rel-7 | Xavier | 31.101 |  |  |  |
| 1035 | 333 | Video Codec Performance Requirements | 634d? | 2005-01-03 A | 2007-06-07 A | 100% | 2005-01-03 | 2007-06-07 | 634d? |  | finish no earlier than 2007-06-07 | S4 | 5072h | 5072h | VICPer | Siemens | juergen.pandel@siemens.com | Rel-7 | Paolo | 26.234, 26.235, 26.346, 26.140, 26.902 |  |  |  |
| 1036 | 334 | Dynamic and Interactive Multimedia Scenes | 583d? | 2005-03-15 A | 2007-06-07 A | 100% | 2005-03-15 | 2007-06-07 | 583d? |  | finish no earlier than 2007-06-07 | S4 | 4664h | 4664h | DIMS | Streamezzo | gaelle.martin-cocher@streamezzo.com | Rel-7 | Paolo | 26.140, 26.142, 26.234, 26.244, 23.346 |  |  |  |
| 1037 | 335 | 3G-324M Video Telephony Call Setup Times Improvements | 341d? | 2005-06-08 A | 2006-09-27 A | 100% | 2005-06-08 | 2006-09-27 | 341d? |  | finish no earlier than 2006-09-27 | S4 | 2728h | 2728h | VTCSTI | Vodafone | edward.hall@vodafone.co.uk | Rel-7 | Paolo | 26.911 |  |  |  |

Notes:
- 1014: -
- 1015: -
- 1016: -
- 1017: TR 24.930: Signalling flows for the session setup in the IM CN subsystem based on Session Initiation Protocol (SIP)
- 1018: Voice Group Call Service
- 1019: -
- 1020: -
- 1021: -
- 1022: -
- 1023: -
- 1024: -
- 1025: -
- 1026: -
- 1027: CP#34: CT3 not involved in Mp interface definition
- 1028: -
- 1029: -
- 1030: WID approved in CP#34
- 1031: -
- 1032: -
- 1033: Update of Rel-6 (U)SIM API for Java Card Testing UID_43007 under Rel-6 UICC/USIM enhancements and interworking UID_1800
- 1034: Following ETSI publication of TS 102 600, expected to be completed at CT6 meeting 45
- 1035: -
- 1036: -
- 1037: -

| ID | WBS | Task | Type | Duration | Start | Finish | Complete | Baseline start | Baseline finish | Baseline duration | Constraint | Resources | Work | Actual work | Text1 | Text4 | Text5 | Text6 | Text8 | Text12 |
| --- | --- | --- | --- | --- | --- | --- | --- | --- | --- | --- | --- | --- | --- | --- | --- | --- | --- | --- | --- | --- |
| 1038 | 336 | **Optimizations for Multimedia Telephony over IMS** |  | 0d? | 2005-09-28 A | 2005-09-28 A | 100% | 2005-09-28 | 2005-09-28 | 0d? |  | S4 |  |  | OMTIMS | Ericsson | olle.franceschi@ericsson.com | Rel-7 | Paolo |  |
| 1039 | 336.1 | Deleted - Characterisation of Adaptive Jitter Management Performance for VoIP Services | milestone | 0d? | 2005-09-28 A | 2005-09-28 A | 100% | 2005-09-28 | 2005-09-28 | 0d? | start no earlier than 2007-03-15 | S4 |  |  | OMTIMS-CAJMP | Lucent | dhuo@lucent.com | Rel-7 | Paolo | SP-35 |
| 1040 | 337 | End-to-End Multimedia Services Performance Metrics |  | 382d? | 2005-09-28 A | 2007-03-15 A | 100% | 2005-09-28 | 2007-03-15 | 382d? | finish no earlier than 2007-03-15 | S4 | 3056h | 3056h | E2EMSPM | China Mobile | zhangyanyf@chinamobile.com | Rel-7 | Paolo |  |
| 1041 | 338 | Packet Switched Streaming Enhancements |  | 261d? | 2006-06-08 A | 2007-06-07 A | 100% | 2006-06-08 | 2007-06-07 | 261d? | finish no earlier than 2007-06-07 | S4 | 2088h | 2088h | PSSe | Ericsson | olle.franceschi@ericsson.com | Rel-7 | Paolo |  |
| 1042 | 339 | **OAM&P Rel-7** |  | 472.86d? | 2005-09-02 A | 2007-06-26 A | 100% | 2005-09-02 | 2007-06-26 | 472.86d? |  | S5 | 82725.8h | 82725.8h | OAM7 | Huawei | Christian.Toche@huawei.com | Rel-7 | Dionisio |  |
| 1043 | 339.1 | **Network Infrastructure Management** |  | 465d? | 2005-09-02 A | 2007-06-14 A | 100% | 2005-09-02 | 2007-06-14 | 465d? |  | S5 | 41800h | 41800h | OAM7-NIM |  |  | Rel-7 | Dionisio |  |
| 1044 | 339.1.1 | Enhance NRM to accommodate NGN (IMS as basis of the Next Generation Network) |  | 465d? | 2005-09-02 A | 2007-06-14 A | 100% | 2005-09-02 | 2007-06-14 | 465d? | finish no earlier than 2007-06-14 | S5 | 3720h | 3720h | OAM7-NIM | Motorola |  | Rel-7 | Dionisio |  |
| 1045 | 339.1.2 | Co-operative Element Management interface (CO-OP) (Study + Implementation) |  | 400d? | 2005-09-02 A | 2007-03-15 A | 100% | 2005-09-02 | 2007-03-15 | 400d? | finish no earlier than 2007-03-15 | S5 | 3200h | 3200h | OAM7-NIM | Motorola |  | Rel-7 | Dionisio |  |
| 1046 | 339.1.3 | Network Management (NM) Itf-N performance criteria |  | 465d? | 2005-09-02 A | 2007-06-14 A | 100% | 2005-09-02 | 2007-06-14 | 465d? | finish no earlier than 2007-06-14 | S5 | 3720h | 3720h | OAM7-NIM | China Mobile |  | Rel-7 | Dionisio |  |
| 1047 | 339.1.4 | Delta synchronization between IRP Manager and IRP Agent (Study + Implementation) |  | 465d? | 2005-09-02 A | 2007-06-14 A | 100% | 2005-09-02 | 2007-06-14 | 465d? | finish no earlier than 2007-06-14 | S5 | 3720h | 3720h | OAM7-NIM | Siemens |  | Rel-7 | Dionisio |  |
| 1048 | 339.1.5 | Subscription Management (SuM) IRP Solution Sets |  | 330d? | 2005-09-02 A | 2006-12-07 A | 100% | 2005-09-02 | 2006-12-07 | 330d? | finish no earlier than 2006-12-07 | S5 | 2640h | 2640h | OAM7-NIM | Ericsson |  | Rel-7 | Dionisio |  |
| 1049 | 339.1.6 | Integration Reference Point (IRP) Security Management |  | 400d? | 2005-09-02 A | 2007-03-15 A | 100% | 2005-09-02 | 2007-03-15 | 400d? | finish no earlier than 2007-03-15 | S5 | 3200h | 3200h | OAM7-NIM | Huawei | Christian.Toche@huawei.com | Rel-7 | Dionisio |  |
| 1050 | 339.1.7 | Partial suspension of Itf-N during maintenance/testing (Study + Implementation) |  | 465d? | 2005-09-02 A | 2007-06-14 A | 100% | 2005-09-02 | 2007-06-14 | 465d? | finish no earlier than 2007-06-14 | S5 | 3720h | 3720h | OAM7-NIM | Siemens |  | Rel-7 | Dionisio |  |
| 1051 | 339.1.8 | Deleted - Management of Legacy Equipment |  | 336d? | 2005-09-02 A | 2006-12-15 A | 100% | 2005-09-02 | 2006-12-15 | 336d? | finish no earlier than 2006-12-15 | S5 | 2688h | 2688h | OAM7-NIM | Siemens |  | Rel-7 | Dionisio | SP-35 |
| 1052 | 339.1.9 | Deleted - Rules for Vendor Specific Extensions |  | 400d? | 2005-09-02 A | 2007-03-15 A | 100% | 2005-09-02 | 2007-03-15 | 400d? | finish no earlier than 2007-03-15 | S5 | 3200h | 3200h | OAM7-NIM | Siemens |  | Rel-7 | Dionisio | SP-35 |
| 1053 | 339.1.10 | Backward and Forward Compatibility of IRP systems |  | 465d? | 2005-09-02 A | 2007-06-14 A | 100% | 2005-09-02 | 2007-06-14 | 465d? | finish no earlier than 2007-06-14 | S5 | 3720h | 3720h | OAM7-NIM | Ericsson |  | Rel-7 | Dionisio |  |
| 1054 | 339.1.11 | Repeater Network Resource Model (NRM) definition |  | 214d? | 2006-02-13 A | 2006-12-07 A | 100% | 2006-02-13 | 2006-12-07 | 214d? | finish no earlier than 2006-12-07 | S5 | 1712h | 1712h | OAM7-NIM | China Mobile |  | Rel-7 | Dionisio |  |
| 1055 | 339.1.12 | UTRAN radio channel power monitoring |  | 284d? | 2006-02-13 A | 2007-03-15 A | 100% | 2006-02-13 | 2007-03-15 | 284d? | finish no earlier than 2007-03-15 | S5 | 2272h | 2272h | OAM7-NIM | China Mobile |  | Rel-7 | Dionisio |  |
| 1056 | 339.1.13 | Notification XML Schema |  | 71d? | 2006-12-07 A | 2007-03-15 A | 100% | 2006-12-07 | 2007-03-15 | 71d? | finish no earlier than 2007-03-15 | S5 | 568h | 568h | OAM7-NIM | Huawei | Christian.Toche@huawei.com | Rel-7 | Dionisio |  |
| 1057 | 339.2 | **Performance Management** |  | 465d? | 2005-09-02 A | 2007-06-14 A | 100% | 2005-09-02 | 2007-06-14 | 465d? |  | S5 | 22992h | 22992h | OAM7-PM |  |  | Rel-7 | Dionisio |  |
| 1058 | 339.2.1 | Performance measurements definition for CN CS |  | 400d? | 2005-09-02 A | 2007-03-15 A | 100% | 2005-09-02 | 2007-03-15 | 400d? | finish no earlier than 2007-03-15 | S5 | 3200h | 3200h | OAM7-PM | China Mobile |  | Rel-7 | Dionisio |  |
| 1059 | 339.2.2 | Enhancement UTRAN performance measurements definition |  | 465d? | 2005-09-02 A | 2007-06-14 A | 100% | 2005-09-02 | 2007-06-14 | 465d? | finish no earlier than 2007-06-14 | S5 | 3720h | 3720h | OAM7-PM | China Mobile |  | Rel-7 | Dionisio |  |
| 1060 | 339.2.3 | Add TDD specific counters in Performance measurement |  | 330d? | 2005-09-02 A | 2006-12-07 A | 100% | 2005-09-02 | 2006-12-07 | 330d? | finish no earlier than 2006-12-15 | S5 | 2640h | 2640h | OAM7-PM | CATT |  | Rel-7 | Dionisio |  |
| 1061 | 339.2.4 | ATM bearer network Performance measurements |  | 400d? | 2005-09-02 A | 2007-03-15 A | 100% | 2005-09-02 | 2007-03-15 | 400d? | finish no earlier than 2007-03-15 | S5 | 3200h | 3200h | OAM7-PM | ZTE |  | Rel-7 | Dionisio |  |
| 1062 | 339.2.5 | Performance measurements definition for IMS |  | 465d? | 2005-09-02 A | 2007-06-14 A | 100% | 2005-09-02 | 2007-06-14 | 465d? | finish no earlier than 2007-06-14 | S5 | 3720h | 3720h | OAM7-PM | China Mobile |  | Rel-7 | Dionisio |  |
| 1063 | 339.2.6 | HSDPA performance measurements |  | 349d? | 2006-02-13 A | 2007-06-14 A | 100% | 2006-02-13 | 2007-06-14 | 349d? | finish no earlier than 2007-06-14 | S5 | 2792h | 2792h | OAM7-PM | China Mobile |  | Rel-7 | Dionisio |  |

Notes:
- 1038: - / Text3: 26.235, 26.236
- 1039: SP-35 stopped
- 1040: - / Text3: 26.944
- 1041: - / Text3: 26.234, 26.244
- 1042: -
- 1043: -
- 1044: - / Text3: 32.731/2/3/5, 32.631/2/3/5
- 1045: - / Text3: 32.806, 32.814, 32.101
- 1046: - / Text3: 32.811
- 1047: - / Text3: 32.391/2/3/5
- 1048: - / Text3: 32.307/317/607/667/665, 32.101, 32.175
- 1049: - / Text3: 32.372/3/5, 32.111,32.30x,32.32x,32.33x,32.34x,32.35x,32.36x,32.41x,32.60x,32.61x,32.66x
- 1050: - / Text3: 32.381/2/3/5
- 1051: Request to TSG#35 to STOP the WI / Text3: new 32.xxx
- 1052: Request to TSG#35 to STOP the WI / Text3: 32.62n; For n = 1 to 5
- 1053: - / Text3: 32.154
- 1054: - / Text3: 32.721/2/3/5
- 1055: - / Text3: 32.405, 32.64n; For n = 1 to 5
- 1056: 12/2006 SP#34 WID approved / Text3: New 32.325/345/365/415, CR to 32.335/615/665
- 1057: -
- 1058: - / Text3: 32.407, 32.408
- 1059: - / Text3: 32.405
- 1060: - / Text3: 32.405
- 1061: - / Text3: No impact on 32.404, 32.405, 32.406, 32.407
- 1062: - / Text3: 32.404,32.409,32.437, 32.632/3/4/5
- 1063: - / Text3: 32.405

| ID | WBS | Task | Type | Duration | Start | Finish | Complete | Baseline start | Baseline finish | Baseline duration | Constraint | Resources | Work | Actual work | Text1 | Text4 | Text6 | Text8 | Text12 | Text5 | Text11 | Text9 |
| --- | --- | --- | --- | --- | --- | --- | --- | --- | --- | --- | --- | --- | --- | --- | --- | --- | --- | --- | --- | --- | --- | --- |
| 1064 | 44.5 | **Trace Management** |  | 472.86d? | 2005-09-02 A | 2007-06-26 A | 100% | 2005-09-02 | 2007-06-26 | 472.86d? |  | S5 | 14150.9h | 14150.9h | OAM7-Trace | Vodafone | Rel-7 | Dionisio |  |  |  |  |
| 1065 | 339.3.1 | End-to-end Service Level tracing for IMS |  | 350d? | 2005-11-11 A | 2007-03-15 A | 100% | 2005-11-11 | 2007-03-15 | 350d? | finish no earlier than 2007-03-15 | S5 | 2800h | 2800h | OAM7-Trace | Vodafone | Rel-7 | Dionisio | SP-31 |  |  |  |
| 1066 | 339.3.2 | Trace record content for UTRAN TDD |  | 330d? | 2005-09-02 A | 2006-12-07 A | 100% | 2005-09-02 | 2006-12-07 | 330d? | finish no earlier than 2006-12-07 | S5 | 2640h | 2640h | OAM7-Trace | Nokia | Rel-7 | Dionisio |  |  |  |  |
| 1067 | 339.3.3 | IRP for Subscriber and Equipment Trace Management |  | 465d? | 2005-09-02 A | 2007-06-14 A | 100% | 2005-09-02 | 2007-06-14 | 465d? | finish no earlier than 2007-06-14 | S5 | 3720h | 3720h | OAM7-Trace | Nokia | Rel-7 | Dionisio |  |  |  |  |
| 1068 | 339.3.4 | Deleted - SIP enhancements for trace | milestone | 0d? | 2007-06-15 A | 2007-06-26 A | 100% | 2007-06-15 | 2007-06-26 | 0d? | start no earlier than 2007-06-15 | C1 |  |  | OAM7-Trace |  | Rel-7 | Frederic | CP-32 |  |  |  |
| 1069 | 339.3.5 | Deleted - duplicated with UID 35063 - IRP for Subscriber and Equipment Trace Management |  | 336d? | 2005-09-02 A | 2006-12-15 A | 100% | 2005-09-02 | 2006-12-15 | 336d? | finish no earlier than 2006-12-15 | S5 | 2688h | 2688h | OAM7-Trace | Nokia | Rel-7 | Dionisio | SP-33 |  |  |  |
| 1070 | 340 | **Charging Management small Enhancements Rel-7** |  | 279d? | 2006-05-22 A | 2007-06-14 A | 100% | 2006-05-22 | 2007-06-14 | 279d? |  | S5 | 5952h | 5952h | CH7 | Orange | Rel-7 | Dionisio |  | alain.bibas@orange-ft.com |  |  |
| 1071 | 340.1 | Alternate Charged Party (ACP) for IMS |  | 279d? | 2006-05-22 A | 2007-06-14 A | 100% | 2006-05-22 | 2007-06-14 | 279d? | finish no earlier than 2007-06-14 | S5 | 2232h | 2232h | CH7-IMS-ACP | Lucent | Rel-7 | Dionisio |  | njmazzarella@alcatel-lucent.com |  |  |
| 1072 | 340.2 | Align 3GPP Charging with OMA PoC Enabler Release 2.0 |  | 186d? | 2006-09-28 A | 2007-06-14 A | 100% | 2006-09-28 | 2007-06-14 | 186d? | finish no earlier than 2007-06-14 | S5 | 1488h | 1488h | CH7-PoC | Siemens | Rel-7 | Dionisio |  | Gerald GÖRMER |  |  |
| 1073 | 8.5 | **Multiple Input Multiple Output antennas (MIMO)** |  | 1177d? | 2003-03-14 A | 2007-09-17 A | 100% | 2003-03-14 | 2007-09-17 | 1177d? |  | R1 | 40272h | 40272h | MIMO | Alcatel-Lucent | Rel-7 | Patrick |  | hchuang@Alcatel-Lucent.com | RP-070037, RP-070531 |  |
| 1074 | 341.1 | MIMO - Physical layer |  | 915d? | 2003-09-12 A | 2007-03-15 A | 100% | 2003-09-12 | 2007-03-15 | 915d? | finish no earlier than 2007-03-15 | R1 | 7320h | 7320h | MIMO-Phys | Alcatel-Lucent | Rel-7 | Patrick |  | hchuang@Alcatel-Lucent.com | RP-070037 |  |
| 1075 | 341.2 | MIMO - Layer 2,3 aspects |  | 915d? | 2003-09-12 A | 2007-03-15 A | 100% | 2003-09-12 | 2007-03-15 | 915d? | finish no earlier than 2007-03-15 | R2 | 7320h | 7320h | MIMO-L23 | Alcatel-Lucent | Rel-7 | Joern |  | hchuang@Alcatel-Lucent.com | RP-070037 |  |
| 1076 | 341.3 | MIMO - Iub/Iur Protocol Aspects |  | 1045d? | 2003-03-14 A | 2007-03-15 A | 100% | 2003-03-14 | 2007-03-15 | 1045d? | finish no earlier than 2007-03-15 | R3 | 8360h | 8360h | MIMO-IurIub | Alcatel-Lucent | Rel-7 | Juha |  | hchuang@Alcatel-Lucent.com | RP-070037 |  |
| 1077 | 341.4 | MIMO - RF Radio Transmission/Reception, System Performance Requirements and Conformance Testing |  | 982d? | 2003-12-12 A | 2007-09-17 A | 100% | 2003-12-12 | 2007-09-17 | 982d? | finish no earlier than 2007-09-17 | R4 | 7856h | 7856h | MIMO-RF | Alcatel-Lucent | Rel-7 | Issam |  | ngm@Alcatel-Lucent.com | RP-070531 |  |
| 1078 | 342 | **Rel-7 Improvements of the Radio Interface** |  | 709d? | 2004-09-15 A | 2007-06-04 A | 100% | 2004-09-15 | 2007-06-04 | 709d? |  | RP | 29696h | 29696h | RInImp |  | Rel-7 | Issam |  |  |  |  |
| 1079 | 342.1 | Extended UMTS 1.7/2.1 GHz |  | 198d? | 2006-03-15 A | 2006-12-15 A | 100% | 2006-03-15 | 2006-12-15 | 198d? | finish no earlier than 2006-12-15 | R4 | 1584h | 1584h | RInImp-UMTS1721Ext | Ericsson | Rel-7 | Issam |  | Johan Sköld (johan.skold@ericsson.com) | RP-060681 |  |
| 1080 | 342.2 | UMTS 2.6 GHz 7.68 Mcps TDD |  | 67d? | 2006-06-15 A | 2006-09-15 A | 100% | 2006-06-15 | 2006-09-15 | 67d? | finish no earlier than 2006-09-15 | R4 | 536h | 536h | RInImp-UMTS26VHCRTDD | IPWireless | Rel-7 | Issam |  | Shin Horng Wong (shwong@ipwireless.com) | RP-060451 |  |
| 1081 | 342.3 | UMTS 2.6 GHz |  | 195d? | 2004-09-15 A | 2005-06-14 A | 100% | 2004-09-15 | 2005-06-14 | 195d? | finish no earlier than 2005-06-14 | R4 | 1560h | 1560h | RInImp-UMTS2600 | Nokia | Rel-7 | Issam |  | jussi.numminen@nokia.com | RP-050184 |  |
| 1082 | 342.4 | UMTS 2.6 GHz TDD |  | 261d? | 2004-12-15 A | 2005-12-14 A | 100% | 2004-12-15 | 2005-12-14 | 261d? | finish no earlier than 2005-12-15 | R4 | 2088h | 2088h | RInImp-UMTS2600TDD | IPWireless | Rel-7 | Issam |  | Shin Horng Wong (shwong@ipwireless.com) | RP-050661 |  |
| 1083 | 342.5 | UMTS 900 MHz |  | 261d? | 2004-12-15 A | 2005-12-14 A | 100% | 2004-12-15 | 2005-12-14 | 261d? | finish no earlier than 2005-12-15 | R4 | 2088h | 2088h | RInImp-UMTS900 | Nortel | Rel-7 | Issam |  | Yannick Li (yli@nortelnetworks.com) | RP-050662 |  |
| 1084 | 342.6 | UMTS 1700 MHz |  | 197d? | 2005-03-15 A | 2005-12-14 A | 100% | 2005-03-15 | 2005-12-14 | 197d? | finish no earlier than 2005-12-15 | R4 | 1576h | 1576h | RInImp-UMTS1700 | NTT DoCoMo | Rel-7 | Issam |  | Takehiro Nakamura (nakamurata@nttdocomo.co.jp) | RP-050824 |  |
| 1085 | 342.7 | UE Antenna Performance Evaluation Method and Requirements |  | 644d? | 2004-12-15 A | 2007-06-04 A | 100% | 2004-12-15 | 2007-06-04 | 644d? | finish no earlier than 2007-06-04 | R4 | 5152h | 5152h | RInImp-UEAnt | TeliaSonera | Rel-7 | Issam |  | Christian.Bergljung@TeliaSonera.com | RP-070281 |  |
| 1086 | 342.8 | Improved Performance Requirements for HSDPA UE based on Rx Diversity (type 1) & LMMSE equalizer (type 2) | milestone | 0d? | 2005-03-15 A | 2005-03-15 A | 100% | 2005-03-15 | 2005-03-15 | 0d? | finish no earlier than 2005-03-15 | R4 |  |  | RInImp-HSPerf-Type3 | Cingular | Rel-7 | Issam |  | Marc Grant | RP-060015 |  |
| 1087 | 342.9 | **Additional minimum UE performance requirement for non-HSDPA channels based on type 1 enhanced receiver (Rx Diversity)** |  | 327d? | 2005-09-15 A | 2006-12-15 A | 100% | 2005-09-15 | 2006-12-15 | 327d? |  | R4 | 7344h | 7344h | RInImp-RxDiv | Qualcomm Europe | Rel-7 | Issam |  | Serge Willenegger (sergew@qualcomm.com) |  |  |
| 1088 | 342.9.1 | Additional minimum UE performance requirement for DL physical channels in support of DCH/HS-DSCH operation based on type 1 enhanced receiver (RX-Diversity) |  | 195d? | 2005-09-15 A | 2006-06-14 A | 100% | 2005-09-15 | 2006-06-14 | 195d? | finish no earlier than 2006-06-15 | R4 | 1560h | 1560h | RInImp-RxDiv-DCH | Cingular | Rel-7 | Issam |  | Marc Grant | RP-060235 |  |
| 1089 | 342.9.2 | Additional minimum UE performance requirement for downlink physical channels in support of MTCH and MCCH operation based on type 1 enhanced receiver (Rx-Diversity) |  | 198d? | 2006-03-15 A | 2006-12-15 A | 100% | 2006-03-15 | 2006-12-15 | 198d? | finish no earlier than 2006-12-15 | R4 | 1584h | 1584h | RInImp-RxDiv-MBMS | Qualcomm Europe | Rel-7 | Issam |  | Serge Willenegger (sergew@qualcomm.com) | RP-060678 |  |
| 1090 | 342.9.3 | Additional minimum UE performance requirement for downlink physical channels in support of E-DCH operation based on type 1 enhanced receiver (Rx-Diversity) |  | 198d? | 2006-03-15 A | 2006-12-15 A | 100% | 2006-03-15 | 2006-12-15 | 198d? | finish no earlier than 2006-12-15 | R4 | 1584h | 1584h | RInImp-RxDiv-EDCH | Qualcomm Europe | Rel-7 | Issam |  | Serge Willenegger (sergew@qualcomm.com) | RP-060679 |  |
| 1091 | 342.10 | Deleted Improved support of gaming over HSDPA/EDCH |  | 262d? | 2005-12-15 A | 2006-12-15 A | 100% | 2005-12-15 | 2006-12-15 | 262d? | finish no earlier than 2006-12-15 | R2 | 2096h | 2096h | RInImp-Gaming | Cingular | Rel-7 | Joern | RP-34 | Don Zelmer (dz1069@att.com) | RP-060680 |  |
| 1092 | 342.11 | Deleted (not approved at PCG) - UMTS 2.6 GHz FDD DL External | milestone | 0d? | 2005-09-15 A | 2005-09-15 A | 100% | 2005-09-15 | 2005-09-15 | 0d? | finish no earlier than 2005-09-15 | R4 |  |  | RInImp-UMTS2600Ext | T-mobile | Rel-7 | Issam | RP-31 | han.van.bussel@t-mobile.de |  | PCG-16 |

Notes:
- 1064: -
- 1065: 07/2005: OMA (Stage 1), Stage 2/3 SA5, CT1/3/4 / Text3: CR 32.101, 32.421/2/3.
- 1066: - / Text3: CR 32.421/2/3.
- 1067: - / Text3: 32.441/2/3/5, CRs 32.632/3/5
- 1068: combined with UID 11067
- 1069: - / Text3: 32.421,32.422,32.423. 3 new 32.4x1,2,3
- 1070: -
- 1071: - / Text3: 32.240, 32.260, 32.298, 32.299
- 1072: 09/2006 SP#33 WID approved / Text3: 32.240, 32.272, 32.299, 32.298
- 1073: Completed Sep 2007; SR in RP-070037and RP-070531 / Text3: 25.876, 25.996
- 1074: Completed Sep 2007; SR in RP-070037 / Text3: 25.211, 25.212, 25.213, 25.214, 25.215, 25.221
- 1075: Completed Sep 2007; SR in RP-070037 / Text3: 25.876
- 1076: Completed Sep 2007; SR in RP-070037
- 1077: Completed Sep 2007; SR in RP-070531
- 1078: Generic feature
- 1079: SR in RP-060681. Introduction of Band X (Extended UMTS 1.7/2.1 GHz) in 25.307 / Text3: 25.806, 25.101, 25.104, 25.133, 24.141, 25.331, 25.306, 25.307, 25.423, 25.461, 25.463, 34.121
- 1080: Completed Sep 2006; SR in RP-060451 / Text3: 25.102, 25.105, 25.123, 25.113, 25.142, 34.124
- 1081: SR in RP-050184. Introduction of UMTS2600 internal band, Band VII in 25.307 / Text3: 25.101, 25.104, 25.133, 25.141, 25.331, 25.942, 25.306, 25.307, 34.121
- 1082: SR in RP-050661 / Text3: 25.102, 25.105, 25.113, 25.123, 25.142, 25.331, 25.942, 25.306, 25.307, 34.122, 34.124
- 1083: SR in RP-050662. Introduction of UMTS 900 (Band VIII) in 25.307 / Text3: 25.101, 25.104, 25.113, 25.133, 25.141, 25.331, 25.942, 25.306, 25.307, 34.121
- 1084: SR in RP-050824 / Text3: 25.101, 25.104, 25.113, 25.133, 25.141, 25.306, 25.307, 25.331, 34.121
- 1085: RP#36 (May 2007) completed. SR in RP-070281 / Text3: 25.101, 25.963
- 1086: Completed Mar 2006, SR in RP-060015 / Text3: 25.101
- 1087: - / Text3: 25.101
- 1088: Completed Jun 2006, SR in RP-060235 / Text3: 25.101
- 1089: Completed Dec 2006, SR in RP-060678 / Text3: 25.101
- 1090: Completed Dec 2006, SR in RP-060679 / Text3: 25.101
- 1091: RP#34 (Dec 2006) stopped. SR in RP-060680
- 1092: This item was conditionnaly approved pending decision of PCG 16 who decided not to approve it / Text3: 25.101, 25.104, 25.133, 25.141, 25.331, 25.942, 25.306, 25.307, 34.121

| ID | WBS | Task | Duration | Start | Finish | Complete | Baseline start | Baseline finish | Baseline duration | Constraint | Deadline | Resources | Work | Actual work | Text1 | Text6 | Text8 | Text4 | Text5 | Text10 | Text11 |
| --- | --- | --- | --- | --- | --- | --- | --- | --- | --- | --- | --- | --- | --- | --- | --- | --- | --- | --- | --- | --- | --- |
| 1093 | 343 | **Rel-7 Improvements of the Radio Interface - UE Conformance Testing** | 741d? | 2005-11-11 A | 2008-09-12 A | 100% | 2005-11-11 | 2008-09-12 | 741d? |  |  | R5 | 17568h | 17568h | RInImp-UEConTest | Rel-7 | Ingbert |  |  |  |  |
| 1094 | 16.5.1 | UE Conformance Test for UMTS 2600 MHz | 146d | 2005-11-11 A | 2006-06-02 A | 100% | 2005-11-11 | 2006-06-02 | 146d | finish no earlier than 2006-06-02 | 2006-06-02 | R5 | 1168h | 1168h | RInImp-UMTS2600_Test | Rel-7 | Ingbert | Nokia | Aleksi.Heino@nokia.com | Fri 7/11/05 |  |
| 1095 | 16.5.1 | UE Conformance Test for UMTS 900 MHz (band VIII) | 146d | 2005-11-11 A | 2006-06-02 A | 100% | 2005-11-11 | 2006-06-02 | 146d | finish no earlier than 2006-06-02 | 2006-06-02 | R5 | 1168h | 1168h | RInImp-UMTS900_Test | Rel-7 | Ingbert | Qualcomm Europe | hanye@qualcomm.com | Fri 11/03/05 |  |
| 1096 | 343.3 | Conformance Test Aspects – Improved Performance of HSDPA Receiver type 3 | 191d? | 2006-03-10 A | 2006-12-01 A | 100% | 2006-03-10 | 2006-12-01 | 191d? | finish no earlier than 2006-12-01 |  | R5 | 1528h | 1528h | RInImp-HSPerf-Type3_Test | Rel-7 | Ingbert | Motorola | carolyn.taylor@motorola.com |  |  |
| 1097 | 343.4 | UE antenna Over The Air (OTA) conformance testing | 518d? | 2006-09-20 A | 2008-09-12 A | 100% | 2006-09-20 | 2008-09-12 | 518d? | finish no earlier than 2008-09-12 |  | R5 | 4144h | 4144h | RInImp-UEAnt_Test | Rel-7 | Ingbert | Nokia | Aleksi.Heino@nokia.com |  | RP-080535 |
| 1098 | 343.5 | UE conformance testing for FDD Inter-Band Operation | 131d? | 2006-06-02 A | 2006-12-01 A | 100% | 2006-06-02 | 2006-12-01 | 131d? | finish no earlier than 2006-12-01 |  | R5 | 1048h | 1048h | RInImp-InterBand_Test | Rel-7 | Ingbert | NEC, Motorola | Jacob.John@motorola.com |  |  |
| 1099 | 343.6 | Conformance Test Aspects – Extended UMTS 1.7/2.1 GHz | 131d? | 2006-12-01 A | 2007-06-01 A | 100% | 2006-12-01 | 2007-06-01 | 131d? | finish no earlier than 2007-06-01 |  | R5 | 1048h | 1048h | RInImp-UEConTest_UMTS1721Ext | Rel-7 | Ingbert | Motorola | carolyn.taylor@motorola.com |  |  |
| 1100 | 343.7 | Conformance Test Aspects – Minimum UE performance requirement for downlink physical channels in support of E-DCH operation based on type 1 enhanced receiver (Rx-Diversity) | 136d? | 2007-06-01 A | 2007-12-07 A | 100% | 2007-06-01 | 2007-12-07 | 136d? | finish no earlier than 2007-12-07 |  | R5 | 1088h | 1088h | RInImp-UEConTest_RxDivEDCH | Rel-7 | Ingbert | Motorola | carolyn.taylor@motorola.com |  |  |
| 1101 | 343.8 | Conformance Test Aspects – Minimum UE performance requirement for downlink physical channels in support of MTCGH and MCCH operation based on type 1 enhanced receiver (Rx-Diversity) | 201d? | 2007-06-01 A | 2008-03-07 A | 100% | 2007-06-01 | 2008-03-07 | 201d? | finish no earlier than 2008-03-07 |  | R5 | 1608h | 1608h | RInImp-UEConTest_RxDivMBMS | Rel-7 | Ingbert | Ericsson | leif.mattisson@ericsson.com |  | RP-080056 |
| 1102 | 344 | **Rel-7 RAN improvements** | 653d? | 2004-12-15 A | 2007-06-15 A | 100% | 2004-12-15 | 2007-06-15 | 653d? |  |  | RP | 29920h | 29920h | RANimp | Rel-7 |  |  |  |  |  |
| 1103 | 344.1 | Optimization of channelisation code utilisation for 1.28 Mcps TDD | 523d? | 2004-12-15 A | 2006-12-15 A | 100% | 2004-12-15 | 2006-12-15 | 523d? | finish no earlier than 2006-12-15 |  | R1 | 4184h | 4184h | RANimp-RABSE-CodOptLCRTDD | Rel-7 | Patrick | UTStarcom | Ka Leong Lo (kaleong.lo@UTSTAR.COM) |  | RP-060682 |
| 1104 | 344.2 | Delay optimization for procedures applicable to CS and PS Connections | 394d? | 2005-03-15 A | 2006-09-15 A | 100% | 2005-03-15 | 2006-09-15 | 394d? | finish no earlier than 2006-09-15 |  | R2 | 3152h | 3152h | RANimp-DelayOpt | Rel-7 | Joern | Nokia | juho.pirskanen@nokia.com |  | RP-060453 |
| 1105 | 344.3 | Improved support of IMS Realtime Services using HSDPA/HSUPA | 197d? | 2005-03-15 A | 2005-12-14 A | 100% | 2005-03-15 | 2005-12-14 | 197d? | start no earlier than 2005-03-15 |  | R2 | 1576h | 1576h | RANimp-IMSRealTime | Rel-7 | Joern | Cingular | Don Zelmer (dz1069@att.com) |  | RP-050667 |
| 1106 | 344.4 | UE Performance Requirements for MBMS (TDD) | 328d? | 2005-03-15 A | 2006-06-15 A | 100% | 2005-03-15 | 2006-06-15 | 328d? | finish no earlier than 2006-06-15 |  | R4 | 2624h | 2624h | MBMS-RAN-RF-TDD | Rel-7 | Issam | IPwireless | shwong@ipwireless.com |  | RP-060477 |
| 1107 | 344.5 | Continuous connectivity for packet data users | 524d? | 2005-03-14 A | 2007-03-15 A | 100% | 2005-03-14 | 2007-03-15 | 524d? | finish no earlier than 2007-03-15 |  | R1 | 4192h | 4192h | RANimp-CPC | Rel-7 | Patrick | Siemens | Joern.Krause@siemens.com |  | RP-070033 |
| 1108 | 344.6 | Extended WCDMA Cell Range | 198d? | 2006-03-15 A | 2006-12-15 A | 100% | 2006-03-15 | 2006-12-15 | 198d? | finish no earlier than 2006-12-15 |  | R3 | 1584h | 1584h | RANimp-ExtCell | Rel-7 | Juha | Ericsson | Muhammad Kazmi |  | RP-060685 |
| 1109 | 344.7 | 7.68 Mcps TDD Enhanced Uplink | 198d? | 2006-03-15 A | 2006-12-15 A | 100% | 2006-03-15 | 2006-12-15 | 198d? | finish no earlier than 2006-12-15 |  | R1 | 1584h | 1584h | RANimp-VHCRTDD-EDCH | Rel-7 | Patrick | IPwireless | nanderson@ipwireless.com |  | RP-060684 |
| 1110 | 344.8 | Enhanced CELL_FACH State in FDD | 181d? | 2006-09-25 A | 2007-06-04 A | 100% | 2006-09-25 | 2007-06-04 | 181d? | finish no earlier than 2007-06-04 |  | R2 | 1448h | 1448h | RANimp-EnhState | Rel-7 | Joern | Nokia | juho.pirskanen@nokia.com |  | RP-070286 |
| 1111 | 344.9 | 64QAM for HSDPA (FDD) | 110d? | 2006-12-15 A | 2007-06-04 A | 100% | 2006-12-15 | 2007-06-04 | 110d? | finish no earlier than 2007-06-04 |  | R1 | 880h | 880h | RANimp-64QamDownlink | Rel-7 | Patrick | Ericsson | Johan.Bergman@ericsson.com |  | RP-070287 |
| 1112 | 344.10 | Improved L2 support for high data rates | 122d? | 2006-12-15 A | 2007-06-04 A | 100% | 2006-12-15 | 2007-06-04 | 122d? | finish no earlier than 2007-06-04 |  | R2 | 976h | 976h | RANimp-L2DataRates | Rel-7 | Joern | Ericsson | Janne.Peisa@ericsson.com |  | RP-070289 |
| 1113 | 344.11 | Introduction of 16QAM in HSUPA (FDD) | 110d? | 2006-12-15 A | 2007-06-04 A | 100% | 2006-12-15 | 2007-06-04 | 110d? | finish no earlier than 2007-06-04 |  | R1 | 880h | 880h | RANimp-16QamUplink | Rel-7 | Patrick | Nokia | Karri.Ranta-aho@nsn.com |  | RP-070288 |
| 1114 | 344.12 | **Interface to control Tower Mounted Amplifiers (TMAs)** | 101d? | 2007-01-26 A | 2007-06-15 A | 100% | 2007-01-26 | 2007-06-15 | 101d? |  |  | R3 | 1616h | 1616h | RANImp-TMA | Rel-7 | Juha | Vodafone | alexej.kulakov@vodafone.com |  | RP-070140 |
| 1115 | 344.12.1 | OAM aspects to Interface to control TMAs | 101d? | 2007-01-26 A | 2007-06-15 A | 100% | 2007-01-26 | 2007-06-15 | 101d? | finish no earlier than 2007-06-15 |  | S5 | 808h | 808h | RANImp-TMA-OAM | Rel-7 | Dionisio | Vodafone | Adrian.Neal@vodafone.com |  |  |
| 1116 | 345 | **Rel-7 RAN improvements - UE Conformance Testing** | 784d? | 2006-09-20 A | 2009-09-18 A | 100% | 2006-09-20 | 2009-09-18 | 784d? |  |  | R5 | 25472h | 25472h | RANimp-UEConTest | Rel-7 | Ingbert |  |  |  |  |
| 1117 | 345.1 | Conformance Test Aspects - 3.84 Mcps and 7.68 Mcps TDD Enhanced Uplink | 518d? | 2006-09-20 A | 2008-09-12 A | 100% | 2006-09-20 | 2008-09-12 | 518d? | finish no earlier than 2008-09-12 |  | R5 | 4144h | 4144h | RANimp-UEConTest_EDCHTDH | Rel-7 | Ingbert | IPWireless | tspeight@ipwireless.com |  | RP-080536 |
| 1118 | 345.2 | Conformance Test Aspects – 64QAM for HSDPA (FDD) | 257d? | 2007-03-09 A | 2008-03-03 A | 100% | 2007-03-09 | 2008-03-03 | 257d? | finish no earlier than 2008-03-03 |  | R5 | 2056h | 2056h | RANimp-UEConTest_64QamDownlink | Rel-7 | Ingbert | Ericsson | leif.mattisson@ericsson.com |  | RP-080059 |
| 1119 | 345.3 | Conformance Test Aspects – 16QAM for HSUPA (FDD) | 321d? | 2007-03-09 A | 2008-05-30 A | 100% | 2007-03-09 | 2008-05-30 | 321d? | finish no earlier than 2008-05-30 |  | R5 | 2568h | 2568h | RANimp-UEConTest_16QamUplink | Rel-7 | Ingbert | Motorola | carolyn.taylor@motorola.com |  | RP-080281 |
| 1120 | 345.4 | Conformance Test Aspects – Improved L2 support for high data rates | 321d? | 2007-03-09 A | 2008-05-30 A | 100% | 2007-03-09 | 2008-05-30 | 321d? | finish no earlier than 2008-05-30 |  | R5 | 2568h | 2568h | RANimp-UEConTest_L2DataRates | Rel-7 | Ingbert | Ericsson | leif.mattisson@ericsson.com |  | RP-080256 |
| 1121 | 345.5 | Conformance Test Aspects – Continuous connectivity for packet data users | 321d? | 2007-03-09 A | 2008-05-30 A | 100% | 2007-03-09 | 2008-05-30 | 321d? | finish no earlier than 2008-05-30 |  | R5 | 2568h | 2568h | RANimp-UEConTest_CPC | Rel-7 | Ingbert | Nokia | jarkko.hellsten@nokia.com |  | RP-080282 |
| 1122 | 345.6 | Conformance Test Aspects – Enhanced CELL_FACH state in FDD | 662d? | 2007-03-09 A | 2009-09-18 A | 100% | 2007-03-09 | 2009-09-18 | 662d? | finish no earlier than 2009-09-18 |  | R5 | 5296h | 5296h | RANimp-UEConTest_EnhancedCellFACHState | Rel-7 | Ingbert | Nokia | jarkko.hellsten@nokia.com |  | RP-090711 |

Notes:
- 1093: 05/08: Linked to Feature UID_20028 (RInImp)
- 1094: - / Text3: 34.108, 34.121
- 1095: - / Text3: 34.108, 34.121
- 1096: - / Text3: 34.121, 34.108
- 1097: SR in RP-080535. RP#41 completed (GERAN aspects might need to be included later) / Text3: 34.114
- 1098: - / Text3: 34.108, 34.123-1, 34.123-2, 34.123-3
- 1099: - / Text3: 34.108, 34.121-1, 34.121-2
- 1100: -
- 1101: SR in RP-080056
- 1102: Generic feature
- 1103: Completed Dec 2006; SR in RP-060682
- 1104: Completed Sep 2006; SR in RP-060453 / Text3: 25.815, 25.321, 25.322, 25.331
- 1105: Closed Dec 2005; SR in RP-050667
- 1106: Completed Sep 2006; SR in RP-060477 / Text3: 25.102, 25.123
- 1107: Completed at Mar 2007; SR in RP-070033 / Text3: 25.903, 25.201, 25.211, 25.212, 25.214, 25.308, 25.321, 25.331, 25.423, 25.433, 25.101, 25.133
- 1108: Completed Dec 2006; SR in RP-060685 / Text3: 25.133, 25.423, 25.425, 25.433, 25.435, 25.453, 25.331
- 1109: Completed Dec 2006; SR in RP-060684 / Text3: 25.201, 25.202, 25.221, 25.222, 25.223, 25.224, 25.225, 25.331, 23.321, 25.306, 25.302, 25.401, 25.420, 25.423, 25.427, 25.433, 25.102, 25.105, 25.142
- 1110: Completed May 2007; SR in RP-070286 / Text3: 25.308, 25.304, 25.306, 25.321, 25.331, 25.433, 25.435, 25.423, 25.425,
- 1111: Completed May 2007; SR in RP-070287 / Text3: 25.308, 25.211, 25.212, 25.213, 25.306, 25.331, 25.433, 25.435, 25.423, 25.425, 25.101, 25.104, 25.141
- 1112: Completed May 2007; SR in RP-070289 / Text3: 25.301, 25.308,25.306, 25.321, 25.322, 25.331, 25.433, 25.435, 25.423, 25.425, 25.999
- 1113: Completed May 2007; SR in RP-070288 / Text3: 25.319, 25.101, 25.104, 25.133, 25.141, 25.211, 25.212, 25.213, 25.214, 25.306, 25.321, 25.331, 25.423, 25.433
- 1114: Completed Mar 2007; SR in RP-070140
- 1115: SP#36 Jun 2007 completed / Text3: 32.642/3/5 – Align with RAN 25.466
- 1116: 05/08: Linked to Feature UID_20029 (RANimp)
- 1117: SR in RP-080536. RP#41 completed / Text3: 34.108, 34.122, 34.123-1, 34.123-2, 34.123-3
- 1118: SR in RP-080059. RP#39 completed. / Text3: 34.108, 34.121-1, 34.121-2, 34.123-1, 34.123-2, 34.123-3
- 1119: SR in RP-080281. RP#40 completed / Text3: 34.108, 34.121-1, 34.121-2, 34.123-1, 34.123-2, 34.123-3
- 1120: SR in RP-080256. RP#40 completed / Text3: 34.108, 34.123-1, 34.123-2, 34.123-3
- 1121: SR in RP-080282. RP#40 completed / Text3: 34.108, 34.121-1, 34.121-2, 34.123-1, 34.123-2, 34.123-3
- 1122: RP#45 completed / Text3: 34.108, 34.123-1, 34.123-2, 34.123-3

| ID | WBS | Task | Type | Duration | Start | Finish | Complete | Baseline start | Baseline finish | Baseline duration | Constraint | Resources | Work | Actual work | Text1 | Text4 | Text5 | Text6 | Text11 | Text8 | Text12 |
| --- | --- | --- | --- | --- | --- | --- | --- | --- | --- | --- | --- | --- | --- | --- | --- | --- | --- | --- | --- | --- | --- |
| 1123 | 346 | **7.68 Mcps TDD option** |  | 457d? | 2004-09-15 A | 2006-06-15 A | 100% | 2004-09-15 | 2006-06-15 | 457d? |  | RP | 19824h | 19824h | VHCRTDD | IPwireless | Martin Beale (mbeale@ipwireless.com) | Rel-7 | RP-060684 |  |  |
| 1124 | 346.1 | VHCRTDD: Stage 2 |  | 391d? | 2004-09-15 A | 2006-03-15 A | 100% | 2004-09-15 | 2006-03-15 | 391d? | finish no earlier than 2006-03-15 | R1 | 3128h | 3128h | VHCRTDD-Stage2 | IPwireless | Martin Beale (mbeale@ipwireless.com) | Rel-7 |  | Patrick |  |
| 1125 | 346.2 | VHCRTDD: Physical Layer |  | 391d? | 2004-09-15 A | 2006-03-15 A | 100% | 2004-09-15 | 2006-03-15 | 391d? | finish no earlier than 2006-03-15 | R1 | 3128h | 3128h | VHCRTDD-Phys | IPwireless | Martin Beale (mbeale@ipwireless.com) | Rel-7 |  | Patrick |  |
| 1126 | 346.3 | VHCRTDD: Layer 2 and layer 3 protocol aspects |  | 391d? | 2004-09-15 A | 2006-03-15 A | 100% | 2004-09-15 | 2006-03-15 | 391d? | finish no earlier than 2006-03-15 | R2 | 3128h | 3128h | VHCRTDD-L23 | IPwireless | drichards@ipwireless.com | Rel-7 |  | Joern |  |
| 1127 | 346.4 | VHCRTDD: UTRAN Iub/Iur Protocol Aspects |  | 391d? | 2004-09-15 A | 2006-03-15 A | 100% | 2004-09-15 | 2006-03-15 | 391d? | finish no earlier than 2006-03-15 | R3 | 3128h | 3128h | VHCRTDD-IurIub | IPwireless | Peter Legg (plegg@ipwireless.com) | Rel-7 |  | Juha |  |
| 1128 | 346.5 | VHCRTDD: RF Radio Transmission/ Reception, System Performance Requirements and Conformance Testing |  | 457d? | 2004-09-15 A | 2006-06-15 A | 100% | 2004-09-15 | 2006-06-15 | 457d? | finish no earlier than 2006-06-15 | R4 | 3656h | 3656h | VHCRTDD-RF | IPwireless | Shin Horng Wong (shwong@ipwireless.com) | Rel-7 |  | Issam |  |
| 1129 | 347 | **3.84 Mcps TDD Enhanced Uplink** |  | 394d? | 2005-03-15 A | 2006-09-15 A | 100% | 2005-03-15 | 2006-09-15 | 394d? |  | RP | 18384h | 18384h | EDCHTDD | IPwireless | nanderson@ipwireless.com | Rel-7 | RP-060684 |  |  |
| 1130 | 347.1 | EDCHTDD: Stage 2 |  | 328d? | 2005-03-15 A | 2006-06-15 A | 100% | 2005-03-15 | 2006-06-15 | 328d? | finish no earlier than 2006-06-15 | R2 | 2624h | 2624h | EDCHTDD-Stage2 | IPwireless | nanderson@ipwireless.com | Rel-7 |  | Joern |  |
| 1131 | 347.2 | EDCHTDD: Physical Layer |  | 394d? | 2005-03-15 A | 2006-09-15 A | 100% | 2005-03-15 | 2006-09-15 | 394d? | finish no earlier than 2006-09-15 | R1 | 3152h | 3152h | EDCHTDD-Phys | IPwireless | nanderson@ipwireless.com | Rel-7 |  | Patrick |  |
| 1132 | 347.3 | EDCHTDD: Layer 2 and 3 Protocol Aspects |  | 394d? | 2005-03-15 A | 2006-09-15 A | 100% | 2005-03-15 | 2006-09-15 | 394d? | finish no earlier than 2006-09-15 | R2 | 3152h | 3152h | EDCHTDD-L23 | IPwireless | drichards@ipwireless.com | Rel-7 |  | Joern |  |
| 1133 | 347.4 | EDCHTDD: UTRAN Iub/Iur Protocol Aspects |  | 394d? | 2005-03-15 A | 2006-09-15 A | 100% | 2005-03-15 | 2006-09-15 | 394d? | finish no earlier than 2006-09-15 | R3 | 3152h | 3152h | EDCHTDD-IurIub | Interdigital | jim.miller@interdigital.com | Rel-7 |  | Juha |  |
| 1134 | 347.5 | EDCHTDD: RF Radio Transmission/ Reception, System Performance Requirements and Conformance Testing |  | 394d? | 2005-03-15 A | 2006-09-15 A | 100% | 2005-03-15 | 2006-09-15 | 394d? | finish no earlier than 2006-09-15 | R4 | 3152h | 3152h | EDCHTDD-RF | IPwireless | Shin Horng Wong (shwong@ipwireless.com) | Rel-7 |  | Issam |  |
| 1135 | 348 | **1.28 Mcps TDD Enhanced Uplink** |  | 328d? | 2006-03-15 A | 2007-06-15 A | 100% | 2006-03-15 | 2007-06-15 | 328d? |  | RP | 11536h | 11536h | LCRTDD-EDCH | CATT | Haijing Hu | Rel-7 | RP-070296 |  |  |
| 1136 | 348.1 | 1.28 Mcps TDD Enhanced Uplink: Physical Layer |  | 262d? | 2006-03-15 A | 2007-03-15 A | 100% | 2006-03-15 | 2007-03-15 | 262d? | finish no earlier than 2007-03-15 | R1 | 2096h | 2096h | LCRTDD-EDCH-Phys | CATT | Ke Wang | Rel-7 |  | Patrick |  |
| 1137 | 348.2 | 1.28 Mcps TDD Enhanced Uplink: Layer 2 and 3 Protocol Aspects |  | 262d? | 2006-03-15 A | 2007-03-15 A | 100% | 2006-03-15 | 2007-03-15 | 262d? | finish no earlier than 2007-03-15 | R2 | 2096h | 2096h | LCRTDD-EDCH-L23 | CATT | Haiyang Quan | Rel-7 |  | Joern |  |
| 1138 | 348.3 | 1.28 Mcps TDD Enhanced Uplink: UTRAN Iub/Iur Protocol Aspects |  | 262d? | 2006-03-15 A | 2007-03-15 A | 100% | 2006-03-15 | 2007-03-15 | 262d? | finish no earlier than 2007-03-15 | R3 | 2096h | 2096h | LCRTDD-EDCH-IubIur | CATT | Yincheng Zhang | Rel-7 |  | Juha |  |
| 1139 | 348.4 | 1.28 Mcps TDD Enhanced Uplink: RF Radio Transmission/ Reception, System Performance Requirements and Conformance Testing |  | 328d? | 2006-03-15 A | 2007-06-15 A | 100% | 2006-03-15 | 2007-06-15 | 328d? | finish no earlier than 2007-06-15 | R4 | 2624h | 2624h | LCRTDD-EDCH-RF | CATT | Yuexia Song | Rel-7 |  | Issam |  |
| 1140 | 349 | 1.28 Mcps TDD Enhanced Uplink - UE Conformance Testing |  | 257d? | 2007-09-20 A | 2008-09-12 A | 100% | 2007-09-20 | 2008-09-12 | 257d? | finish no earlier than 2008-09-11 | R5 | 624h | 624h | LCRTDD-EDCH-UEConTest | CATT | chenxiaozhong@datangmobile.cn | Rel-7 | RP-080539 | Ingbert |  |
| 1141 | 350 | MS Antenna Performance Evaluation Method and Requirements |  | 731d? | 2005-01-28 A | 2007-11-16 A | 100% | 2005-01-28 | 2007-11-16 | 731d? | finish no earlier than 2007-11-16 | GP | 5848h | 5848h | APEMR | TeliaSonera | Ulf.Tegth@teliasonera.com | Rel-7 |  | Paolo |  |
| 1142 | 351 | **Lower 700 MHz Inclusion in the GERAN Specifications** |  | 390d? | 2005-01-03 A | 2006-06-30 A | 100% | 2005-01-03 | 2006-06-30 | 390d? |  | GP | 7632h | 7632h | GSM710 | UTC | dcotton@mtview.union-tel.com | Rel-7 |  | Paolo |  |
| 1143 | 351.1 | Inclusion of the 698 – 746 MHz band into GERAN core specifications |  | 129d? | 2005-01-03 A | 2005-06-30 A | 100% | 2005-01-03 | 2005-06-30 | 129d? | finish no earlier than 2005-06-30 | G1 | 1032h | 1032h | GSM710-core |  |  | Rel-7 |  | Paolo |  |
| 1144 | 351.2 | G1 aspects of GSM710 |  | 217.5d? | 2005-08-31 A | 2006-06-30 A | 100% | 2005-08-31 | 2006-06-30 | 217.5d? | finish no earlier than 2006-06-30 | G1 | 1740h | 1740h | GSM-710-test |  |  | Rel-7 |  | Paolo |  |
| 1145 | 351.3 | G3 aspects of GSM710 |  | 217.5d? | 2005-08-31 A | 2006-06-30 A | 100% | 2005-08-31 | 2006-06-30 | 217.5d? | finish no earlier than 2006-06-30 | G3new | 1740h | 1740h | GSM-710-test |  |  | Rel-7 |  | Ingbert |  |
| 1146 | 352 | **Support of Conversational Services in A/Gb mode via the PS domain** |  | 626d? | 2005-04-08 A | 2007-08-31 A | 100% | 2005-04-08 | 2007-08-31 | 626d? |  | GP | 15442.8h | 15442.8h | SCSAGB | Ericsson | gunnar.hedby@ericsson.com | Rel-7 |  | Paolo |  |
| 1147 | 352.1 | Minimise the transfer delay between the SGSN and the MS |  | 604.95d? | 2005-04-08 A | 2007-08-31 A | 100% | 2005-04-08 | 2007-08-31 | 604.95d? | finish no earlier than 2007-08-31 | GP | 4839.6h | 4839.6h | SCSAGB-MTD | Ericsson | gunnar.hedby@ericsson.com | Rel-7 |  | Paolo |  |
| 1148 | 352.2 | Definition of radio resource management functionality |  | 626d? | 2005-04-08 A | 2007-08-31 A | 100% | 2005-04-08 | 2007-08-31 | 626d? | finish no earlier than 2007-08-31 | G1 | 5008h | 5008h | SCSAGB-RRM | Ericsson | gunnar.hedby@ericsson.com | Rel-7 |  | Paolo |  |
| 1149 | 352.3 | Support of Conversational Services in A/Gb mode via the PS domain – RLC Non-Persistent mode |  | 101d? | 2006-06-30 A | 2006-11-17 A | 100% | 2006-06-30 | 2006-11-17 | 101d? | finish no earlier than 2006-11-17 | G2 | 808h | 808h | SCSAGB-RLCNP | Ericsson | gunnar.hedby@ericsson.com | Rel-7 |  | Gert |  |
| 1150 | 352.4 | Deleted- Radio Channel Support | milestone | 0d? | 2006-07-17 A | 2006-07-17 A | 100% | 2006-07-17 | 2006-07-17 | 0d? | start no earlier than 2006-07-17 | G2 |  |  | SCSAGB-RCHS | Ericsson | gunnar.hedby@ericsson.com | Rel-7 |  | Gert | SP-32 |
| 1151 | 352.5 | Deleted- Modifications to FLO | milestone | 0d? | 2006-07-17 A | 2006-07-17 A | 100% | 2006-07-17 | 2006-07-17 | 0d? | start no earlier than 2006-07-17 | G2 |  |  | SCSAGB-FLO | Ericsson | gunnar.hedby@ericsson.com | Rel-7 |  | Gert | SP-32 |

Notes:
- 1123: Completed Dec 2006, SR in RP-060684
- 1124: Feature completed and closed at RP#33 with the presentation of the test WI / Text3: 25.202
- 1125: Feature completed and closed at RP#33 with the presentation of the test WI / Text3: 25.221, 25.222, 25.223, 25.224,25.225
- 1126: Feature completed and closed at RP#33 with the presentation of the test WI / Text3: 25.301, 25.302, 25.305, 25.306, 25.321, 25.331
- 1127: Feature completed and closed at RP#33 with the presentation of the test WI / Text3: 25.401, 25.420, 25.423, 25.425, 25.427, 25.430, 25.433, 25.435
- 1128: Feature completed and closed at RP#33 with the presentation of the test WI / Text3: 25.102, 25.105, 25.123, 25.133, 25.142
- 1129: Completed Dec 2006, SR in RP-060684
- 1130: -
- 1131: - / Text3: 25.201, 25.221,25.222, 25.223, 25.224, 25.225
- 1132: - / Text3: 25.301, 25.302, 25.306, 25.321, 25.331
- 1133: - / Text3: 25.401, 25.420, 25.423, 25.427, 25.430, 25.433, 25.435
- 1134: - / Text3: 25.102, 25.105, 25.123, 25.142
- 1135: Completed May 2007; SR in RP-070038 and RP-070296
- 1136: - / Text3: 25.201, 25.221, 25.222, 25.223, 25.224, 25.225
- 1137: - / Text3: 25.301, 25.302, 25.306, 25.321, 25.331
- 1138: - / Text3: 25.401, 25.420, 25.423, 25.425, 25.427, 25.430, 25.433, 25.435
- 1139: - / Text3: 25.102, 25.105, 25.123, 25.142
- 1140: UID_350046->350146. 05/08: Linked to Feature UID_20055 (LCRTDD-EDCH). SR in RP-080539. RP#41 completed / Text3: 34.108, 34.122, 34.123-1/2/3
- 1141: GP#36 completed for R7 / Text3: 25.914, 25.144, 45.005
- 1142: - / Text3: 24.008, 43.022, 44.018, 44.118, 45, 001, 45.005, 51.010, 51.021
- 1143: Completed / Text3: 24.008, 43.022, 44.018, 44.118, 45, 001, 45.005,
- 1144: - / Text3: 51.021
- 1145: - / Text3: 51.010
- 1146: Originally started Nov. 2003 as GP-030443
- 1147: -
- 1148: -
- 1149: - / Text3: 43.955, 43.064, 44.060, 45.001, 45.002, 45.003, 45.005, 45.010, 51.010, 51.021
- 1150: -
- 1151: -

| ID | WBS | Task | Duration | Start | Finish | Complete | Baseline start | Baseline finish | Baseline duration | Constraint | Resources | Work | Actual work | Text1 | Text4 | Text5 | Text6 | Text8 | Text12 |
| --- | --- | --- | --- | --- | --- | --- | --- | --- | --- | --- | --- | --- | --- | --- | --- | --- | --- | --- | --- |
| 1152 | 353 | **Addition of new frequency band to GSM (T-GSM810)** | 626d? | 2005-04-08 A | 2007-08-31 A | 100% | 2005-04-08 | 2007-08-31 | 626d? |  | GP | 12112h | 12112h | TGSM810 | Huawei | chende@huawei.com | Rel-7 | Paolo |  |
| 1153 | 353.1 | Changes to core specification | 106d? | 2005-04-08 A | 2005-09-02 A | 100% | 2005-04-08 | 2005-09-02 | 106d? | finish no earlier than 2005-09-02 | GP | 848h | 848h | TGSM810-Core | Huawei | chende@huawei.com | Rel-7 | Paolo |  |
| 1154 | 353.2 | Changes to MS testing specification | 626d? | 2005-04-08 A | 2007-08-31 A | 100% | 2005-04-08 | 2007-08-31 | 626d? | finish no earlier than 2007-08-31 | G3new | 5008h | 5008h | TGSM810-MStest | Huawei | chende@huawei.com | Rel-7 | Ingbert |  |
| 1155 | 353.3 | Changes to BTS testing specification | 156d? | 2005-04-08 A | 2005-11-11 A | 100% | 2005-04-08 | 2005-11-11 | 156d? | finish no earlier than 2005-11-11 | G1 | 1248h | 1248h | TGSM810-BTStest | Huawei | chende@huawei.com | Rel-7 | Paolo |  |
| 1156 | 354 | **Handover of dedicated and shared resources while in Dual Transfer Mode** | 421d? | 2005-04-08 A | 2006-11-17 A | 100% | 2005-04-08 | 2006-11-17 | 421d? |  | GP | 12672h | 12672h | HODSRDTM | Nokia | rami.vaittinen@nokia.com | Rel-7 | Paolo |  |
| 1157 | 354.1 | Handover of dedicated and shared resources while in Dual Transfer Mode | 321d? | 2005-04-08 A | 2006-06-30 A | 100% | 2005-04-08 | 2006-06-30 | 321d? | finish no earlier than 2006-06-30 | G2 | 2568h | 2568h | HODSRDTM-G2 | Nokia | rami.vaittinen@nokia.com | Rel-7 | Gert |  |
| 1158 | 354.2 | Deleted - MS Conformance Testing | 421d? | 2005-04-08 A | 2006-11-17 A | 100% | 2005-04-08 | 2006-11-17 | 421d? | finish no earlier than 2006-11-17 | G3new | 3368h | 3368h | HODSRDTM-Mstest | Nokia | rami.vaittinen@nokia.com | Rel-7 | Ingbert | GP-32 |
| 1159 | 354.3 | Deleted - BTS conformance testing | 421d? | 2005-04-08 A | 2006-11-17 A | 100% | 2005-04-08 | 2006-11-17 | 421d? | finish no earlier than 2006-11-17 | G1 | 3368h | 3368h | HODSRDTM-BTStest | Nokia | rami.vaittinen@nokia.com | Rel-7 | Paolo | GP-32 |
| 1160 | 355 | **Mobile Station Receive Diversity (DARP Phase II)** | 526d? | 2005-11-11 A | 2007-11-16 A | 100% | 2005-11-11 | 2007-11-16 | 526d? |  | GP | 16360h | 16360h | MSRD2 | Nokia | kent.pedersen@nokia.com | Rel-7 | Paolo |  |
| 1161 | 355.1 | Performance Requirements for Mobile Station Receive Diversity, DARP Phase II | 331d? | 2005-11-11 A | 2007-02-16 A | 100% | 2005-11-11 | 2007-02-16 | 331d? | finish no earlier than 2007-02-16 | GP | 2648h | 2648h | MSRD2-PerfReq | Nokia | kent.pedersen@nokia.com | Rel-7 | Paolo |  |
| 1162 | 355.2 | Capability signalling of Mobile Station Receive Diversity, DARP Phase II | 331d? | 2005-11-11 A | 2007-02-16 A | 100% | 2005-11-11 | 2007-02-16 | 331d? | finish no earlier than 2007-02-16 | GP | 2648h | 2648h | MSRD2-CapSig | Nokia | kent.pedersen@nokia.com | Rel-7 | Paolo |  |
| 1163 | 355.3 | Test Scenarios for Mobile Station Receive Diversity, DARP Phase II | 331d? | 2005-11-11 A | 2007-02-16 A | 100% | 2005-11-11 | 2007-02-16 | 331d? | finish no earlier than 2007-02-16 | GP | 2648h | 2648h | MSRD2-TestSc | Nokia | kent.pedersen@nokia.com | Rel-7 | Paolo |  |
| 1164 | 355.4 | MS conformance test of DARP Phase II (MSRD) | 526d? | 2005-11-11 A | 2007-11-16 A | 100% | 2005-11-11 | 2007-11-16 | 526d? | finish no earlier than 2007-11-16 | GP | 4208h | 4208h | MSRD2-Msconf | Nokia | kent.pedersen@nokia.com | Rel-7 | Ingbert |  |
| 1165 | 356 | **Downlink Dual Carrier** | 421d? | 2006-01-20 A | 2007-08-31 A | 100% | 2006-01-20 | 2007-08-31 | 421d? |  | GP | 7664h | 7664h | GDCDL | Nokia Siemens Networks | leonardo.provvedi@roke.co.uk | Rel-7 | Paolo |  |
| 1166 | 356.1 | Downlink Dual Carrier Stage 2 | 116d? | 2006-01-20 A | 2006-06-30 A | 100% | 2006-01-20 | 2006-06-30 | 116d? | finish no earlier than 2006-06-30 | G1 | 928h | 928h | GDCDL-Stage2 | Nokia Siemens Networks | leonardo.provvedi@roke.co.uk | Rel-7 | Paolo |  |
| 1167 | 356.2 | Downlink Dual Carrier Stage 3 | 421d? | 2006-01-20 A | 2007-08-31 A | 100% | 2006-01-20 | 2007-08-31 | 421d? | finish no earlier than 2007-08-31 | G1 | 3368h | 3368h | GDCDL-Stage2 | Nokia Siemens Networks | leonardo.provvedi@roke.co.uk | Rel-7 | Paolo |  |
| 1168 | 357 | **Downlink Dual Carrier – MS Conformance Test** | 947d? | 2006-01-20 A | 2009-09-04 A | 100% | 2006-01-20 | 2009-09-04 | 947d? |  | G3new | 11150.6h | 11150.6h | GDCDL-Stage3 | Nokia Siemens Networks | leonardo.provvedi@roke.co.uk | Rel-7 | Ingbert |  |
| 1169 | 357.1 | Downlink Dual Carrier – MS Conformance Test | 446.82d? | 2006-01-20 A | 2009-09-04 A | 100% | 2006-01-20 | 2009-09-04 | 446.82d? | finish no earlier than 2009-09-04 | G3new | 3574.6h | 3574.6h | GDCDL-Stage3 | Nokia Siemens Networks | leonardo.provvedi@roke.co.uk | Rel-7 | Ingbert |  |
| 1170 | 358 | Support of SIGTRAN in GERAN | 116d? | 2006-01-20 A | 2006-06-30 A | 100% | 2006-01-20 | 2006-06-30 | 116d? | finish no earlier than 2006-06-30 | G3new | 928h | 928h | GDCDL-MStest | Ericsson | peter.ostrup@ericsson.com | Rel-7 | Ingbert |  |
| 1171 | 359 | **Latency Reductions** | 306d? | 2006-06-30 A | 2007-08-31 A | 100% | 2006-06-30 | 2007-08-31 | 306d? |  | GP | 7344h | 7344h | LATRED | Ericsson | Hakan.Persson@Ericsson.com | Rel-7 | Paolo |  |
| 1172 | 359.1 | Improved Ack/Nack reporting | 306d? | 2006-06-30 A | 2007-08-31 A | 100% | 2006-06-30 | 2007-08-31 | 306d? | finish no earlier than 2007-08-31 | G2 | 2448h | 2448h | LATRED-ACKNAR | Ericsson | Hakan.Persson@Ericsson.com | Rel-7 | Gert |  |
| 1173 | 359.2 | Reduced TTI | 306d? | 2006-06-30 A | 2007-08-31 A | 100% | 2006-06-30 | 2007-08-31 | 306d? | finish no earlier than 2007-08-31 | G2 | 2448h | 2448h | LATRED-REDTTI | Ericsson | Hakan.Persson@Ericsson.com | Rel-7 | Gert |  |
| 1174 | 360 | PS Handover between GERAN/UTRAN mode and GAN Mode | 166d? | 2006-06-30 A | 2007-02-16 A | 100% | 2006-06-30 | 2007-02-16 | 166d? | finish no earlier than 2007-02-16 | G2 | 1328h | 1328h | GUGAN | Ericsson | John.Diachina@Ericsson.com | Rel-7 | Gert |  |
| 1175 | 361 | **Higher Uplink performance for GERAN Evolution** | 516d? | 2006-09-08 A | 2008-08-29 A | 100% | 2006-09-08 | 2008-08-29 | 516d? |  | GP | 15440h | 15440h | HUGE | Nokia Siemens Networks, Ericsson | eddie.riddington@nokia.com, stefan.g.eriksson@ericsson.com | Rel-7 | Paolo |  |
| 1176 | 361.1 | Stage 2 of HUGE | 261d? | 2006-09-08 A | 2007-09-07 A | 100% | 2006-09-08 | 2007-09-07 | 261d? | finish no earlier than 2007-09-07 | G1 | 2088h | 2088h | HUGE-Stage2 | Nokia Siemens Networks, Ericsson | eddie.riddington@nokia.com, stefan.g.eriksson@ericsson.com | Rel-7 | Paolo |  |
| 1177 | 361.2 | Layer 1 Support of HUGE | 381d? | 2006-09-08 A | 2008-02-22 A | 100% | 2006-09-08 | 2008-02-22 | 381d? | finish no earlier than 2008-02-22 | G1 | 3048h | 3048h | HUGE-Layer1 | Nokia Siemens Networks, Ericsson | eddie.riddington@nokia.com, stefan.g.eriksson@ericsson.com | Rel-7 | Paolo |  |
| 1178 | 361.3 | Layer 2/3 Support of HUGE | 256d? | 2006-09-08 A | 2007-08-31 A | 100% | 2006-09-08 | 2007-08-31 | 256d? | finish no earlier than 2007-08-31 | G2 | 2048h | 2048h | HUGE-Layer23 | Nokia Siemens Networks, Ericsson | eddie.riddington@nokia.com, stefan.g.eriksson@ericsson.com | Rel-7 | Gert |  |
| 1179 | 361.4 | Performance requirements | 516d? | 2006-09-08 A | 2008-08-29 A | 100% | 2006-09-08 | 2008-08-29 | 516d? | finish no earlier than 2008-08-29 | G1 | 4128h | 4128h | HUGE-Perfreq | Nokia Siemens Networks, Ericsson | eddie.riddington@nokia.com, stefan.g.eriksson@ericsson.com | Rel-7 | Paolo |  |

Notes:
- 1152: - / Text3: 45.005, 45.050, 24.008, 45.008, 45.001, 43.022, 43.030, 44.018, 44.060, 51.010-1, 51.021
- 1153: - / Text3: 45.005, 45.050, 24.008, 45.008, 45.001, 43.022, 43.030, 44.018, 44.060
- 1154: - / Text3: 51010-1
- 1155: - / Text3: 51021
- 1156: GP#30 completed. Started at GP#24
- 1157: GP#30 completed / Text3: 43.055, 44.018, 44.060
- 1158: Stopped, no work done. 12/2008 Marked as stopped ("deleted") / Text3: 51-010
- 1159: Stopped, no work done. 12/2008 Marked as stopped ("deleted") / Text3: 51.026
- 1160: GP#36 completed / Text3: 24.008, 45.005, 51.010
- 1161: GP#33 completed / Text3: 45.005
- 1162: GP#33 completed / Text3: 24.008
- 1163: GP#33 completed / Text3: 45.005
- 1164: GP#36 completed / Text3: 51.010
- 1165: GP#35 completed
- 1166: GP#30 completed / Text3: 43.055, 43.064
- 1167: GP#35 completed / Text3: 24.008, 44.018, 44.060, 45.001, 45.002, 45.005, 45.008
- 1168: GP#43 completed / Text3: 51.010
- 1169: GP#43 completed / Text3: 51.010
- 1170: GP#30 completed / Text3: 48.001, 48.006, 43.059, 49.031
- 1171: GP#35 completed / Text3: 45.001, 45.002, 45.003, 45.005, 45.010, 43.055, 43.064, 44.060, 51.010-1, 51.021
- 1172: GP#35 completed / Text3: 45.001, 45.002, 45.003, 45.005, 45.010, 43.055, 43.064, 44.060, 51.010-1, 51.021
- 1173: GP#35 completed / Text3: 45.001, 45.002, 45.003, 45.005, 45.010, 43.055, 43.064, 44.060, 51.010-1, 51.021
- 1174: GP#33 completed / Text3: 43.318, 44.318, 43.129, 25.306, 24.008, 44.060, 25.331, 51.010
- 1175: GP#39 completed. SP#42 split core from testing specification work.
- 1176: GP#35 completed / Text3: 43.055, 43.064
- 1177: GP#37 completed / Text3: 45.001, 45.002, 45.003, 45.004, 45.008
- 1178: GP#35 completed / Text3: 24.008, 44.018, 44.060
- 1179: GP#39 completed / Text3: 45.005

| ID | WBS | Task | Type | Duration | Start | Finish | Complete | Remaining | Baseline start | Baseline finish | Baseline duration | Total slack | Constraint | Resources | Work | Actual work | Text1 | Text4 | Text5 | Text6 | Text8 | Text12 |
| --- | --- | --- | --- | --- | --- | --- | --- | --- | --- | --- | --- | --- | --- | --- | --- | --- | --- | --- | --- | --- | --- | --- |
| 1180 | 362 | **HUGE Conformance Testing** |  | 912d? | 2006-09-08 A | 2010-03-05 | 57% | 392.6d? | 2006-09-08 | 2010-03-05 | 912d? | 661d |  | G1,G3new | 20832h | 8066h | HUGE | Nokia Siemens Networks, Ericsson | eddie.riddington@nokia.com, stefan.g.eriksson@ericsson.com | Rel-7 | Paolo |  |
| 1181 | 362.1 | HUGE - MS Conformance Test |  | 911d? | 2006-09-08 A | 2010-03-05 | 20% | 728.8d? | 2006-09-08 | 2010-03-05 | 911d? | 661d | finish no earlier than 2010-03-05 | G3new | 7288h | 1457.6h | HUGE-Mstest | Nokia Siemens Networks, Ericsson | eddie.riddington@nokia.com, stefan.g.eriksson@ericsson.com | Rel-7 | Ingbert |  |
| 1182 | 362.2 | HUGE - BTS Conformance Test |  | 782d? | 2006-09-08 A | 2009-09-04 A | 100% |  | 2006-09-08 | 2009-09-04 | 782d? |  | finish no earlier than 2009-09-04 | G1 | 6248h | 6248h | HUGE-BTStest | Nokia Siemens Networks, Ericsson | eddie.riddington@nokia.com, stefan.g.eriksson@ericsson.com | Rel-7 | Paolo |  |
| 1183 | 363 | **REduced symbol Duration, Higher Order modulation and Turbo coding (RED HOT) for downlink** |  | 391d? | 2006-11-17 A | 2008-05-16 A | 100% |  | 2006-11-17 | 2008-05-16 | 391d? |  |  | GP | 7904h | 7904h | REDHOT | Ericsson, Nokia Siemens Networks, Marvell | stefan.g.eriksson@ericsson.com | Rel-7 | Paolo |  |
| 1184 | 363.1 | Stage 2 for REDHOT |  | 206d? | 2006-11-17 A | 2007-08-31 A | 100% |  | 2006-11-17 | 2007-08-31 | 206d? |  | finish no earlier than 2007-08-31 | G1 | 1648h | 1648h | REDHOT-Stage2 | Ericsson, Nokia Siemens Networks, Marvell | stefan.g.eriksson@ericsson.com | Rel-7 | Paolo |  |
| 1185 | 363.2 | Stage 3 for REDHOT |  | 391d? | 2006-11-17 A | 2008-05-16 A | 100% |  | 2006-11-17 | 2008-05-16 | 391d? |  | finish no earlier than 2008-05-16 | G1 | 3128h | 3128h | REDHOT-Stage3 | Ericsson, Nokia Siemens Networks, Marvell | stefan.g.eriksson@ericsson.com | Rel-7 | Paolo |  |
| 1186 | 364 | **REDHOT Conformance Testing** |  | 862d? | 2006-11-17 A | 2010-03-05 | 54% | 392.69d? | 2006-11-17 | 2010-03-05 | 862d? | 661d |  | G1,G3new | 18992h | 6926h | REDHOT | Ericsson, Nokia Siemens Networks, Marvell | stefan.g.eriksson@ericsson.com | Rel-7 | Paolo |  |
| 1187 | 364.1 | REDHOT - MS Conformance Tests |  | 861d? | 2006-11-17 A | 2010-03-05 | 20% | 688.8d? | 2006-11-17 | 2010-03-05 | 861d? | 661d | finish no earlier than 2010-03-05 | G3new | 6888h | 1377.6h | REDHOT-Mstest | Ericsson | stefan.g.eriksson@ericsson.com | Rel-7 | Ingbert |  |
| 1188 | 364.2 | BTS Conformance Tests |  | 651d? | 2006-11-17 A | 2009-05-15 A | 100% |  | 2006-11-17 | 2009-05-15 | 651d? |  | finish no earlier than 2009-05-15 | G1 | 5208h | 5208h | REDHOT-BTStest | Ericsson, Nokia Siemens Networks, Marvell | stefan.g.eriksson@ericsson.com | Rel-7 | Paolo |  |
| 1189 | 365 | (Small) Technical Enhancements and Improvements for Rel-7 | milestone | 0d? | 2007-03-26 A | 2007-03-26 A | 100% |  | 2007-03-26 | 2007-03-26 | 0d? |  | start no earlier than 2007-03-26 | All |  |  | TEI7 |  |  | Rel-7 |  |  |
| 1190 | 366 | **Deleted - PS domain and IMS support for IMS Emergency sessions** |  | 63.69d? | 2006-06-23 A | 2006-09-21 A | 100% |  | 2006-06-23 | 2006-09-21 | 63.69d? |  |  | S2 |  |  | IMS-EMER | Nokia | curt.c.wong@nokia.com | Rel-7 | Maurice | SP-30 |
| 1191 | 366.1 | Deleted - IMS aspects to support IMS Emergency sessions | milestone | 0d? | 2006-06-23 A | 2006-09-21 A | 100% |  | 2006-06-23 | 2006-09-21 | 0d? |  | start no earlier than 2006-06-23 | S2 |  |  | IMS-EMER | Nokia | curt.c.wong@nokia.com | Rel-7 | Maurice | SP-30 |
| 1192 | 366.2 | Deleted - PS domain aspects to support IMS Emergency sessions | milestone | 0d? | 2006-06-23 A | 2006-09-21 A | 100% |  | 2006-06-23 | 2006-09-21 | 0d? |  | start no earlier than 2006-06-23 | S2 |  |  | IMS-EMER | Nokia | curt.c.wong@nokia.com | Rel-7 | Maurice | SP-30 |
| 1193 | 367 | Deleted - Covered by SI - Personal Network (PN) and Personal Area Network (PAN) | milestone | 0d? | 2005-12-08 A | 2005-12-20 A | 100% |  | 2005-12-08 | 2005-12-20 | 0d? |  | start no earlier than 2005-12-08 | S1 |  |  | PNPAN | Vodafone | armin.toepfer@vodafone.com | Rel-7 | Alain | SP-30 |
| 1194 | 368 | Deleted - Covered by SI - Multimedia Telephony Capabilities for IMS | milestone | 0d? | 2005-12-08 A | 2005-12-20 A | 100% |  | 2005-12-08 | 2005-12-20 | 0d? |  | start no earlier than 2005-12-08 | S1 |  |  | MITE | Ericsson | peter.bleckert@ericsson.com | Rel-7 | Alain | SP-30 |
| 1195 | 369 | Deleted - Covered by SI - Transferring of emergency Call data | milestone | 0d? | 2005-12-08 A | 2005-12-08 A | 100% |  | 2005-12-08 | 2005-12-08 | 0d? |  | start no earlier than 2005-12-08 | S1 |  |  | eCALL | Motorola | steven.vardy@motorola.com | Rel-7 | Alain | SP-30 |
| 1196 | 370 | Deleted - Covered by SI - MBMS Enhancements | milestone | 0d? | 2005-12-08 A | 2005-12-08 A | 100% |  | 2005-12-08 | 2005-12-08 | 0d? |  | start no earlier than 2005-12-08 | S1 |  |  | MBMSE | China Mobile | liuhongyfw@chinamobile.com | Rel-7 | Alain | SP-30 |
| 1197 | 371 | **Deleted - VoIMS bearer related enhancements** |  | 0d? | 2006-07-21 A | 2006-07-21 A | 100% |  | 2006-07-21 | 2006-07-21 | 0d? |  |  | S2 |  |  | VoIMS |  |  | Rel-7 | Maurice | SP-32 |
| 1198 | 371.1 | Deleted - FS on enhancement of radio performance for VoIMS | milestone | 0d? | 2006-07-21 A | 2006-07-21 A | 100% |  | 2006-07-21 | 2006-07-21 | 0d? |  | start no earlier than 2006-07-21 | S2 |  |  | VoIMS | Nortel | Laurence Lautier (lautierl@nortel.com) | Rel-7 | Maurice | SP-32 |
| 1199 | 372 | Release 7 Studies |  | 1d? | 2000-01-03 | 2000-01-03 |  |  | 2000-01-03 | 2000-01-03 | 1d? | 3317d |  | CP,GP,RP,SP | 8h |  |  |  |  | Rel-7 |  |  |
| 1200 | 373 | **Study on Multimedia Telephony Capabilities for IMS** |  | 276d? | 2005-07-11 A | 2006-07-31 A | 100% |  | 2005-07-11 | 2006-07-31 | 276d? |  |  | S1 | 4353.6h | 4353.6h | MITE | Ericsson | peter.bleckert@ericsson.com | Rel-7 | Alain |  |
| 1201 | 373.1 | Deleted covered by UID_31082 - Study of (MITe) - IMS Multimedia Telephony Communication Enabler and supplementary services |  | 276d? | 2005-07-11 A | 2006-07-31 A | 100% |  | 2005-07-11 | 2006-07-31 | 276d? |  | start no earlier than 2005-07-11 | S1 | 2208h | 2208h | MITE | Ericsson | peter.bleckert@ericsson.com | Rel-7 | Alain | SP-28 |
| 1202 | 374 | Study on Behaviour of Multi system UEs |  | 384d? | 2004-06-28 A | 2005-12-15 A | 100% |  | 2004-06-28 | 2005-12-15 | 384d? |  | start no earlier than 2004-06-28 | S1 | 3072h | 3072h | BMSU | Qualcomm Europe | dwilliams@qualcomm.com | Rel-7 | Alain |  |
| 1203 | 375 | Study on Combining CS calls and IMS sessions |  | 189d? | 2004-06-28 A | 2005-03-17 A | 100% |  | 2004-06-28 | 2005-03-17 | 189d? |  | start no earlier than 2004-06-28 | S1 | 1512h | 1512h | IRTSD-CS_IMS |  | Robert Frank | Rel-7 | Alain |  |
| 1204 | 376 | Study on All-IP Network |  | 188d? | 2004-06-28 A | 2005-03-16 A | 100% |  | 2004-06-28 | 2005-03-16 | 188d? |  | start no earlier than 2004-06-28 | S1 | 1504h | 1504h | FS_AIPN | NTT DoCoMo | c.masyu@nttdocomo.co.jp | Rel-7 | Alain |  |
| 1205 | 377 | Study on Videotelephony teleservice |  | 231d? | 2005-03-01 A | 2006-01-17 A | 100% |  | 2005-03-01 | 2006-01-17 | 231d? |  |  | S1 | 1848h | 1848h | VidTel | T-Mobile | kurt.bischinger@t-mobile.at | Rel-7 | Alain |  |
| 1206 | 378 | Study on Network Selection Principles |  | 193d? | 2005-03-15 A | 2005-12-08 A | 100% |  | 2005-03-15 | 2005-12-08 | 193d? |  |  | S1 | 1544h | 1544h | NetSel | O2 | chris.friel@o2.com | Rel-7 | Alain |  |
| 1207 | 379 | Study on Multimedia Priority Service |  | 851d? | 2003-03-28 A | 2006-06-30 A | 100% |  | 2003-03-28 | 2006-06-30 | 851d? |  | finish no earlier than 2005-12-16 | S1 | 6808h | 6808h | PRIOR-MM | Telcordia | jgarraha@telcordia.com | Rel-7 | Alain |  |
| 1208 | 380 | Study on Transferring of emergency Call data |  | 190d? | 2005-07-11 A | 2006-03-31 A | 100% |  | 2005-07-11 | 2006-03-31 | 190d? |  | finish no earlier than 2005-12-08 | S1 | 1520h | 1520h | eCALL | Motorola | steven.vardy@motorola.com | Rel-7 | Alain |  |
| 1209 | 381 | Study on Enhancement of E2E QoS |  | 281.4d? | 2004-06-28 A | 2005-09-15 A | 100% |  | 2004-06-28 | 2005-09-15 | 281.4d? |  | finish no earlier than 2005-12-01 | S2 | 2251.2h | 2251.2h | QoS7 | Huawei | Robert Jaksa | Rel-7 | Maurice |  |
| 1210 | 382 | Study on Bandwidth Saving at Nb Interface with IP transport |  | 261d? | 2006-03-10 A | 2007-03-09 A | 100% |  | 2006-03-10 | 2007-03-09 | 261d? |  | finish no earlier than 2007-03-09 | C3 | 2088h | 2088h | BSNbIP | Siemens | Thomas.Belling@nsn.com | Rel-7 | Gwiho |  |
| 1211 | 383 | Study on Routeing of MT-SMS via the HPLMN |  | 301d? | 2005-10-07 A | 2006-12-01 A | 100% |  | 2005-10-07 | 2006-12-01 | 301d? |  | finish no earlier than 2006-12-01 | C4 | 2408h | 2408h | SMS7 | Vodafone | Nick.Russell@vodafone.com | Rel-7 | Kimmo |  |
| 1212 | 384 | Study on the TCAPsec Gateway concept |  | 96d? | 2005-10-28 A | 2006-03-10 A | 100% |  | 2005-10-28 | 2006-03-10 | 96d? |  | finish no earlier than 2006-03-10 | C4 | 768h | 768h | SEC7-TCAP | Siemens | Ulrich.wiehe@gksag.de | Rel-7 | Kimmo |  |
| 1213 | 385 | Study on using M2PA in 3GPP network |  | 318d? | 2006-03-22 A | 2007-06-08 A | 100% |  | 2006-03-22 | 2007-06-08 | 318d? |  | finish no earlier than 2007-06-08 | C4 | 2544h | 2544h | FS-M2PA | China Mobile | zhaoyuyi@chinamobile.com | Rel-7 | Kimmo |  |

Notes:
- 1180: GP#40 Target completion 05/08=>11/08=>02/09. SP#42 split core from testing specification work.
- 1181: GP#44 target 02/10=>03/10 / Text3: 51.010
- 1182: GP#43 completed / Text3: 51.021
- 1183: GP#38 completed. SP#42 split core from testing specification work.
- 1184: GP#35 completed / Text3: 43.055, 43.064
- 1185: GP#38 completed / Text3: 24.008, 44.018, 44.060, 45.001, 45.002, 45.003, 45.004, 45.005, 45.008
- 1186: GP#40 completion target 05/08=>11/08=>02/09. SP#42 split core from testing specification work.
- 1187: GP#44 completion 02/10=>03/10 / Text3: 51.010
- 1188: GP#42 completed / Text3: 51.021
- 1189: - / Text3: CP-070260
- 1190: Approved at SP#29 / Text3: 23.867, 23.abc, 23.060, 23.002, 23.271
- 1191: Approved at SP#29 / Text3: 23.867, 23.abc, 23.060, 23.002, 23.271
- 1192: Approved at SP#29 / Text3: 23.867, 23.abc, 23.060, 23.002, 23.271
- 1193: -
- 1194: -
- 1195: -
- 1196: -
- 1197: Created by MCC to group all VoIMS related items, after consultation of chairs
- 1198: WID approved SP#28: SA2#52: CLOSED - To be removed from the work plan / Text3: 23.807
- 1199: -
- 1200: Spin-off Feature UID_7038 (MTSI) / Text3: 22.973
- 1201: Duplicate entry with 31082 / Text3: 22.973
- 1202: - / Text3: 22.936
- 1203: - / Text3: 22.979
- 1204: 25/07/08 Moved as FS to Rel-7 out of the stopped Rel-8 Feature UID_31067 Deleted - All-IP Network (AIPN) / Text3: 22.978
- 1205: - / Text3: 22.903
- 1206: Spin-off Feature Network selection enhancements (NSP-CR) UID_7041 / Text3: 22.811
- 1207: Spin-off Feature PRIOR UID_340044 / Text3: 22.953
- 1208: - / Text3: 22.967
- 1209: - / Text3: 23.802
- 1210: Moved to FS at CT32 (in line with slides) / Text3: 29.814
- 1211: Previously known as "Study of a SMS Centre for MT SMS" / Text3: 23.840
- 1212: TR 29.800 content moved to TS 29.204 under implementation WI UID_310005 TCAPsec Gateway / Text3: 29.800
- 1213: - / Text3: 29.801

| ID | WBS | Task | Type | Duration | Start | Finish | Complete | Baseline start | Baseline finish | Baseline duration | Total slack | Constraint | Resources | Work | Actual work | Text1 | Text3 | Text4 | Text5 | Text6 | Text8 | Text11 | Text12 |
| --- | --- | --- | --- | --- | --- | --- | --- | --- | --- | --- | --- | --- | --- | --- | --- | --- | --- | --- | --- | --- | --- | --- | --- |
| 1214 | 386 | **Study on Support of (G)MSC-S - (G)MSC-S Nc Interface based on the SIP-I protocol** |  | 350d? | 2006-05-15 A | 2007-09-14 A | 100% | 2006-05-15 | 2007-09-14 | 350d? |  |  | C4 | 7800h | 7800h | NcSIP | 29.802 | Vodafone | david.hutton@vodafone.com | Rel-7 | Kimmo |  |  |
| 1215 | 386.1 | CT4 aspects of NcSIP |  | 275d? | 2006-05-15 A | 2007-06-01 A | 100% | 2006-05-15 | 2007-06-01 | 275d? |  | finish no earlier than 2007-06-01 | C4 | 2200h | 2200h | NcSIP | 29.802 | Vodafone | david.hutton@vodafone.com | Rel-7 | Kimmo |  |  |
| 1216 | 386.2 | CT3 aspects of NcSIP |  | 350d? | 2006-05-15 A | 2007-09-14 A | 100% | 2006-05-15 | 2007-09-14 | 350d? |  | finish no earlier than 2007-09-14 | C3 | 2800h | 2800h | NcSIP | 29.802 | Ericsson | ragnar.huslende@ericsson.com | Rel-7 | Gwiho |  |  |
| 1217 | 387 | Study on SOAP/HTTP IRP Solution Sets |  | 330d? | 2005-09-02 A | 2006-12-07 A | 100% | 2005-09-02 | 2006-12-07 | 330d? |  | finish no earlier than 2006-12-07 | S5 | 2640h | 2640h | OAM7-NIM-XML | 32.809 | Nortel |  | Rel-7 | Dionisio |  |  |
| 1218 | 388 | Study on Itf-N Implementation Conformance Statement (ICS) template |  | 400d? | 2005-09-02 A | 2007-03-15 A | 100% | 2005-09-02 | 2007-03-15 | 400d? |  | finish no earlier than 2007-03-15 | S5 | 3200h | 3200h | OAM7-NIM-ICS | 32.812 | China Mobile |  | Rel-7 | Dionisio |  |  |
| 1219 | 389 | Study on IRP Information Model |  | 400d? | 2005-09-02 A | 2007-03-15 A | 100% | 2005-09-02 | 2007-03-15 | 400d? |  | finish no earlier than 2007-03-15 | S5 | 3200h | 3200h | OAM7-NIM-IM | 32.810 | Motorola |  | Rel-7 | Dionisio |  |  |
| 1220 | 390 | Study on Evolved UTRA and UTRAN |  | 458d? | 2004-12-15 A | 2006-09-15 A | 100% | 2004-12-15 | 2006-09-15 | 458d? |  | finish no earlier than 2006-09-15 | RP | 3664h | 3664h | RANFS-Evo | 25.912 | NTT DoCoMo | nakamurata@NTTDOCOMO.CO.JP | Rel-7 | Issam | RP-060472 |  |
| 1221 | 391 | Study on Performance Evaluation of the UE behaviour in high speed trains with speeds up to 350 kmph |  | 328d? | 2005-03-15 A | 2006-06-15 A | 100% | 2005-03-15 | 2006-06-15 | 328d? |  | finish no earlier than 2006-06-15 | R4 | 2624h | 2624h | RANFS-HSTrains | none | Vodafone | Mike.vogel@vodafone.com,tim.frost@vodafone.com | Rel-7 | Issam | RP-060412 |  |
| 1222 | 392 | Study on UTRA Tower Mounted Amplifier (FDD) |  | 195d? | 2005-06-15 A | 2006-03-14 A | 100% | 2005-06-15 | 2006-03-14 | 195d? |  | finish no earlier than 2006-03-15 | R4 | 1560h | 1560h | RANFS-TMA | 25.818 | Ericsson | Klas.Sjerling@ericsson.com | Rel-7 | Issam | RP-060035 |  |
| 1223 | 393 | Study on Continuous connectivity for packet data users |  | 132d? | 2005-03-15 A | 2005-09-14 A | 100% | 2005-03-15 | 2005-09-14 | 132d? |  | finish no earlier than 2005-09-15 | R1 | 1056h | 1056h | RANFS-cont-packet | none | Siemens | joerg.gustrau@siemens.com | Rel-7 | Patrick | RP-050427 |  |
| 1224 | 394 | Study on Improvement of the Multimedia Broadcast Multicast Service (MBMS) in UTRAN |  | 262d? | 2005-12-15 A | 2006-12-15 A | 100% | 2005-12-15 | 2006-12-15 | 262d? |  | finish no earlier than 2006-12-15 | R2 | 2096h | 2096h | RANFS-MBMSImp | 25.905 | LG Electronics | leego@lge.com | Rel-7 | Joern | RP-060692 |  |
| 1225 | 395 | Study on Performance Improvements in Small Cells using HSDPA/EDCH |  | 131d? | 2005-12-15 A | 2006-06-15 A | 100% | 2005-12-15 | 2006-06-15 | 131d? |  | finish no earlier than 2006-06-15 | R4 | 1048h | 1048h | SMALLCELLS | none | Cingular | Marc Grant | Rel-7 | Issam | RP-060263 |  |
| 1226 | 396 | Study on Further Improved Performance Requirements for UMTS/HSDPA UE (FDD) |  | 383d? | 2005-12-15 A | 2007-06-04 A | 100% | 2005-12-15 | 2007-06-04 | 383d? |  | finish no earlier than 2007-06-04 | R4 | 3064h | 3064h | RANFS-IC | 25.963 | Cingular | Marc Grant | Rel-7 | Issam | RP-070499 |  |
| 1227 | 397 | Study on Scope of future FDD HSPA Evolution |  | 394d? | 2006-03-15 A | 2007-09-17 A | 100% | 2006-03-15 | 2007-09-17 | 394d? |  | finish no earlier than 2007-09-17 | RP | 3152h | 3152h | RANFS-HSPAEvo | 25.999 | Cingular | Don Zelmer (dz1069@att.com) | Rel-7 | Issam | RP-070533 |  |
| 1228 | 398 | Study on Dynamically reconfiguring a FDD UE receiver to reduce power consumption when desired Quality of Service is met | milestone | 0d? | 2007-06-22 A | 2007-06-22 A | 100% | 2007-06-22 | 2007-06-22 | 0d? |  |  | R4 |  |  | FSUEPow | 25.906 | Nokia | Chris.callender@nokia.com, tiina.s.koskinen@nokia.com | Rel-7 | Issam | RP-070534 |  |
| 1229 | 399 | Study on Future GERAN Evolution |  | 486d? | 2005-04-08 A | 2007-02-16 A | 100% | 2005-04-08 | 2007-02-16 | 486d? |  | finish no earlier than 2007-02-16 | GP | 3888h | 3888h | FGE | 45.912 | Nokia | eddie.riddington@nokia.com | Rel-7 | Paolo |  |  |
| 1230 | 400 | Study on GAN Enhancements | milestone | 0d? | 2007-08-31 A | 2007-08-31 A | 100% | 2007-08-31 | 2007-08-31 | 0d? |  | start no earlier than 2007-08-31 | GP |  |  | EGAN | 43.902 | T-Mobile | janne.linkola@t-mobile.com | Rel-7 | Paolo |  |  |
| 1231 | 401 | Deleted - covered by UID33027 - IMS security extensions | milestone | 0d? | 2005-12-08 A | 2005-12-08 A | 100% | 2005-12-08 | 2005-12-08 | 0d? |  | start no earlier than 2005-12-08 | S3 |  |  | IMS-SE |  | Ericsson | Bengt.Sahlin@ericsson.com | Rel-7 | Dionisio |  | SP-30 |
| 1232 | 402 | Deleted - covered by 32108 - Study of work on an LCS architecture for I-WLAN | milestone | 0d? | 2006-12-08 A | 2006-12-08 A | 100% | 2006-12-08 | 2006-12-08 | 0d? |  | start no earlier than 2006-12-08 | S2 |  |  | IMS-SE |  | LG Electronics | Donghee Shim dhshim@lge.com ; phede@lge.com | Rel-7 | Maurice |  | SP-33 |
| 1233 | 403 | **Deleted: Study on applicability of GALILEO for LCS** |  | 0d? | 2005-06-30 A | 2005-06-30 A | 100% | 2005-06-30 | 2005-06-30 | 0d? |  |  | S2 |  |  | Galileo |  |  |  | Rel-7 | Maurice |  | SP-25 |
| 1234 | 403.1 | Deleted - TR on Stage 2 | milestone | 0d? | 2005-06-30 A | 2005-06-30 A | 100% | 2005-06-30 | 2005-06-30 | 0d? |  | finish no earlier than 2005-06-30 | S2 |  |  | Galileo |  |  |  | Rel-7 | Maurice |  | SP-25 |
| 1235 | 403.2 | Deleted - GERAN review of the TR | milestone | 0d? | 2005-06-30 A | 2005-06-30 A | 100% | 2005-06-30 | 2005-06-30 | 0d? |  | start no earlier than 2005-06-30 | GP |  |  | Galileo |  |  |  | Rel-7 | Paolo |  | SP-26 |
| 1236 | 16.7 | **Deleted - IMS Local services** |  | 0d? | 2006-01-06 A | 2006-01-06 A | 100% | 2006-01-06 | 2006-01-06 | 0d? |  |  | S2 |  |  | IMSLocal | 23.228 |  |  | Rel-7 | Maurice |  | SP-28 |
| 1237 | 16.7.1 | Deleted - Stage 2 | milestone | 0d | 2006-01-06 A | 2006-01-06 A | 100% | 2006-01-06 | 2006-01-06 | 0d |  | start no earlier than 2006-01-06 | S2 |  |  | IMSLocal |  |  |  | Rel-7 | Maurice |  | SP-26 |
| 1238 | 404.2 | Deleted - Stage 3 for IMS Local services | milestone | 0d? | 2006-01-06 A | 2006-01-06 A | 100% | 2006-01-06 | 2006-01-06 | 0d? |  | finish no earlier than 2006-01-06 | C1 |  |  | IMSLocal |  | Lucent | Keith Drage (drage@alcatel-lucent.com) | Rel-7 | Frederic |  | SP-25 |
| 1239 | 405 | Deleted - IMS Phase 3 | milestone | 0d? | 2006-01-06 A | 2006-01-06 A | 100% | 2006-01-06 | 2006-01-06 | 0d? |  | start no earlier than 2006-01-06 | S2 |  |  |  |  |  |  | Rel-7 | Maurice |  | SP-25 |
| 1240 | 406 | Deleted - Improvements of Radio Interface | milestone | 0d? | 2004-09-15 A | 2004-09-15 A | 100% | 2004-09-15 | 2004-09-15 | 0d? |  | start no earlier than 2004-09-15 | RP |  |  | RInImp |  |  |  | Rel-7 | Issam |  | SP-24 |
| 1241 | 407 | Deleted: Generic User Profile Phase 2 | milestone | 0d | 2005-08-08 A | 2006-06-30 A | 100% | 2005-08-08 | 2006-06-30 | 0d |  |  | C4 |  |  |  |  |  |  | Rel-7 | Kimmo |  | SP-27 |
| 1242 | 30.4 | Deleted - Stage 3 - Common objects | milestone | 0d | 2005-08-08 A | 2006-06-30 A | 100% | 2005-08-08 | 2006-06-30 | 0d |  | finish no earlier than 2006-06-30 | C4 |  |  |  | 24.241 |  |  | Rel-7 | Kimmo |  | SP-27 |
| 1243 | 409 | Delete was duplicated- Study of Customised Alerting Tone (CAT) Requirements | milestone | 0d? | 2006-06-30 A | 2006-06-30 A | 100% | 2006-06-30 | 2006-06-30 | 0d? |  | start no earlier than 2006-06-30 | S1 |  |  | CAT |  |  |  | Rel-7 | Alain |  | SP-31 |
| 1244 | 410 | Deleted - FS of enhanced support of Video Telephony | milestone | 0d? | 2006-06-30 A | 2006-06-30 A | 100% | 2006-06-30 | 2006-06-30 | 0d? |  | start no earlier than 2006-06-30 | GP |  |  | VIDGER |  | Ericsson | stefan.g.eriksson@ericsson.com | Rel-7 | Paolo |  | SP-32 |
| 1245 | 411 | Deleted (moved to Rel8) - Study on Transferring of emergency call data – in-band modem solution | milestone | 0d? | 2007-06-22 A | 2007-06-22 A | 100% | 2007-06-22 | 2007-06-22 | 0d? |  | start no earlier than 2007-06-22 | S4 |  |  | eCALLIBMS | 26.967 | Airbiquity | lhong@airbiquity.com | Rel-7 | Paolo |  | SP-38 |
| 1246 | 412 | Deleted - covered by UID 20053 - Study on Interference Cancellation for UTRA FDD UE |  | 1d? | 2007-03-28 A | 2007-03-28 A | 100% | 2007-03-28 | 2007-03-28 | 1d? |  | start no earlier than 2007-03-28 | R4 | 8h | 8h | RANFS-InterfCanc |  |  |  | Rel-7 | Issam |  | SP-38 |
| 1247 | 413 | Deleted - Study of Personal Network and Personal Area Network | milestone | 0d? | 2006-10-20 A | 2006-10-20 A | 100% | 2006-10-20 | 2006-10-20 | 0d? |  | finish no earlier than 2006-10-20 | S1 |  |  | PNPAN |  |  |  | Rel-7 | Alain |  | SP-31 |
| 1248 | 414 | Deleted - Study on IMS with real time services deployment |  | 316d? | 2004-06-28 A | 2005-09-12 A | 100% | 2004-06-28 | 2005-09-12 | 316d? |  |  | S1 | 2528h | 2528h | IRTSD |  |  |  | Rel-7 | Alain |  | SP-30 |
| 1249 | 415 | Deleted - Study on Stage 2 (IMS services using CS bearers) |  | 316d? | 2004-06-28 A | 2005-09-12 A | 100% | 2004-06-28 | 2005-09-12 | 316d? |  | finish no earlier than 2005-09-12 | S2 | 2528h | 2528h | IRTSD-IMSCS | 23.899 | Nortel | Mark Watson | Rel-7 | Maurice |  | SP-30 |
| 1250 | 416 | Deleted - Study on IMS enhancements and optimizations for real time communication. |  | 430d? | 2005-10-10 A | 2007-06-01 A | 100% | 2005-10-10 | 2007-06-01 | 430d? |  | finish no earlier than 2007-06-01 | S2 | 3440h | 3440h | IMS-RT | 23.818 | Ericsson | stephen.terrill@ericsson.com | Rel-7 | Maurice |  | SP-35 |
| 1251 | 417 | Deleted - Study on Terminating Session handling |  | 255d? | 2006-01-09 A | 2006-12-29 A | 100% | 2006-01-09 | 2006-12-29 | 255d? |  | finish no earlier than 2006-12-29 | S2 | 2040h | 2040h | CSIterm | 23.819 | Samsung |  | Rel-7 | Maurice |  | SP-32 |
| 1252 | 418 | Deleted - Study on IRP usage scenarios |  | 330d? | 2005-09-02 A | 2006-12-07 A | 100% | 2005-09-02 | 2006-12-07 | 330d? |  | finish no earlier than 2006-12-07 | S5 | 2640h | 2640h | OAM-Study | 32.8xy | Lucent |  | Rel-7 | Dionisio |  | SP-32 |
| 1253 | 419 | Release 6 Features |  | 1d? | 2000-01-03 | 2000-01-03 |  | 2000-01-03 | 2000-01-03 | 1d? | 3317d |  | NP,GP, RP,SP,TP | 8h |  |  |  |  |  | Rel-6 |  |  |  |

Notes:
- 1214: -
- 1215: -
- 1216: -
- 1217: SP#34 completed
- 1218: SP#35 completed
- 1219: SP#35 completed
- 1220: RP#33 (Sep 2006) completed. SR in RP-060472
- 1221: RP#32 (Jun 2006) completed. SR in RP-060412
- 1222: RP#31 (Mar 2006) completed. SR in RP-060035
- 1223: RP#29 (Sep 2006) completed. SR in RP-050427
- 1224: RP#34 (Dec 2006) completed. SR in RP-060692
- 1225: RP#32 (Jun 2006) closed (no progress). SR in RP-060263
- 1226: RP#36 (May 2007) completed. SR in RP-070499
- 1227: RP#37 (Sep 2007) completed. SR in RP-070533
- 1228: RP#37 (Sep 2007) completed. SR in RP-070534
- 1229: GP#33 completed
- 1230: GP#35 completed
- 1231: -
- 1232: S2#52: Entry created
- 1233: -
- 1234: -
- 1235: -
- 1236: -
- 1237: DAB - Not yet required in SA2 as it exists in previous releases
- 1238: -
- 1239: -
- 1240: Stage 2 description of Interim conclusion
- 1241: Created at TSG#27 by A. Sultan because of the move to Rel-7 of "Common Objects".
- 1242: No progress in CN4#26. This have to be moved to Rel-7. It was deleted from WID
- 1243: Awaiting MCC SA3 input
- 1244: FS CLOSED at G#28 (no input)
- 1245: SP-38 stopped
- 1246: Deleted. Same as FS on Further Improved Performance Requirements for UMTS/HSDPA UE (FDD)
- 1247: Moved from FS section Feb 06
- 1248: -
- 1249: SP-30: S2 has no intention for TR completion
- 1250: abandoned at 65%
- 1251: SP#32 Jun 2006 Study abandoned => spin-off Implementation work UID_320029
- 1252: -
- 1253: -

| ID | WBS | Task | Duration | Start | Finish | Complete | Baseline start | Baseline finish | Baseline duration | Constraint | Resources | Work | Actual work | Text1 | Text6 | Text8 | Text4 | Text5 | Text3 | Text10 | Text12 |
| --- | --- | --- | --- | --- | --- | --- | --- | --- | --- | --- | --- | --- | --- | --- | --- | --- | --- | --- | --- | --- | --- |
| 1254 | 8 | **Rel-6 Improvements of Radio Interface** | 1393d? | 2000-08-14 A | 2005-12-14 A | 100% | 2000-08-14 | 2005-12-14 | 1393d? |  | RP | 38664h | 38664h | RInImp | Rel-6 | Issam |  |  |  |  |  |
| 1255 | 420.1 | Improved support of IMS Realtime Services using HSDPA/EDCH | 197d? | 2005-03-15 A | 2005-12-14 A | 100% | 2005-03-15 | 2005-12-14 | 197d? | finish no earlier than 2005-12-14 | R2 | 1576h | 1576h | RInImp-IMSRealTime | Rel-6 | Joern | Cingular | Don Zelmer (dz1069@att.com) |  |  |  |
| 1256 | 420.2 | Improving Receiver Performance Requirements for the FDD UE | 401d | 2002-03-08 A | 2003-09-19 A | 100% | 2002-03-08 | 2003-09-19 | 401d | start no earlier than 2002-03-08 | R4 | 3208h | 3208h | RInImp-UERecPerf | Rel-6 | Issam | Intel | shimon.moshavi@INTEL.COM | 25.101 |  |  |
| 1257 | 8.2 | **Base station classification** | 603d | 2000-08-14 A | 2002-12-04 A | 100% | 2000-08-14 | 2002-12-04 | 603d |  | R4 | 9648h | 9648h | RInImp-BSClass | Rel-6 | Issam |  |  |  |  |  |
| 1258 | 8.2.1 | FDD Base station classification | 603d | 2000-08-14 A | 2002-12-04 A | 100% | 2000-08-14 | 2002-12-04 | 603d | finish no earlier than 2002-12-04 | R4 | 4824h | 4824h | RInImp-BSClass-FDD | Rel-6 | Issam | Nokia | antti.toskala@nokia.com | 25.104, 25.141 |  |  |
| 1259 | 420.4 | UMTS-850 | 266d | 2002-12-06 A | 2003-12-12 A | 100% | 2002-12-06 | 2003-12-12 | 266d | finish no earlier than 2003-12-15 | R4 | 2128h | 2128h | RInImp-UMTS850 | Rel-6 | Issam | Cingular | Don Zelmer (dz1069@att.com) | 25.101, 25.104, 25.133, 25.141, 25.307, 25.331, 25.942 |  |  |
| 1260 | 420.5 | DS-CDMA introduction in the 800 MHz band | 196d | 2003-03-14 A | 2003-12-12 A | 100% | 2003-03-14 | 2003-12-12 | 196d | finish no earlier than 2003-12-15 | R4 | 1568h | 1568h | RInImp-UMTS800 | Rel-6 | Issam | NTT DoCoMo | Takehiro Nakamura (nakamurata@nttdocomo.co.jp) | 25.101, 25.104, 25.133, 25.141, 25.307, 25.331 |  |  |
| 1261 | 420.6 | UMTS 1.7/2.1 GHz | 261d | 2003-03-14 A | 2004-03-12 A | 100% | 2003-03-14 | 2004-03-12 | 261d | finish no earlier than 2004-03-15 | R4 | 2088h | 2088h | RInImp-UMTS1721 | Rel-6 | Issam | Nokia | jussi.numminen@NOKIA.COM | 25.101, 25.104, 25.133, 25.141, 25.307, 25.331 |  |  |
| 1262 | 420.7 | **Improved Receiver Performance Requirements for HSDPA** | 392d? | 2003-12-15 A | 2005-06-14 A | 100% | 2003-12-15 | 2005-06-14 | 392d? |  | R4 | 7304h | 7304h | RInImp-HSPerf | Rel-6 | Issam | Nokia | jussi.numminen@NOKIA.COM |  |  |  |
| 1263 | 420.7.1 | Improved Minimum Performance Requirements for HSDPA UE categories 7 and 8 | 195d? | 2004-09-15 A | 2005-06-14 A | 100% | 2004-09-15 | 2005-06-14 | 195d? | finish no earlier than 2005-06-14 | R4 | 1560h | 1560h | RInImp-HSPerf-10code | Rel-6 | Issam | Nokia | jussi.numminen@nokia.com | 25.101 |  |  |
| 1264 | 420.7.2 | Performance Requirements of Receive Diversity for HSDPA | 326d | 2003-12-15 A | 2005-03-14 A | 100% | 2003-12-15 | 2005-03-14 | 326d | finish no earlier than 2005-03-14 | R4 | 2608h | 2608h | RInImp-HSPerf-RxDiv | Rel-6 | Issam | NTT DoCoMo | Takehiro Nakamura (nakamurata@nttdocomo.co.jp) | 25.101 |  |  |
| 1265 | 421 | **Rel-6 RAN Feasibility Studies** | 1196d? | 2000-08-14 A | 2005-03-14 A | 100% | 2000-08-14 | 2005-03-14 | 1196d? |  | RP | 43048h | 43048h |  | Rel-6 |  |  |  |  |  |  |
| 1266 | 421.1 | FS of the improved access to UE measurement data for CRNC to support TDD RRM | 270d? | 2002-12-06 A | 2003-12-18 A | 100% | 2002-12-06 | 2003-12-18 | 270d? | finish no earlier than 2003-09-19 | R3 | 2160h | 2160h | RANimp-RRMopt-FSUEMsD | Rel-6 | Juha | Interdigital | jim.miller@interdigital.com | 25.801, 25.423 | SP-24 |  |
| 1267 | 421.2 | FS on Radio link performance enhancements | 1067d | 2000-08-14 A | 2004-09-14 A | 100% | 2000-08-14 | 2004-09-14 | 1067d | finish no earlier than 2004-09-14 | R1 | 8536h | 8536h | RInImp-Rlperf | Rel-6 | Patrick | Nokia | antti.toskala@nokia.com | 25.899 |  |  |
| 1268 | 421.3 | FS on Improvement of inter-frequency and inter-system measurements for 1.28 Mcps TDD | 461d | 2001-12-14 A | 2003-09-19 A | 100% | 2001-12-14 | 2003-09-19 | 461d | start no earlier than 2001-12-14 | R1 | 3688h | 3688h | RInImp-IfIsMLCR | Rel-6 | Patrick | Samsung | Li Xiao Qiang (xqli@samsung.co.kr) | 25.888 |  |  |
| 1269 | 421.4 | FS for the analysis of OFDM for UTRAN enhancement | 526d | 2002-06-10 A | 2004-06-14 A | 100% | 2002-06-10 | 2004-06-14 | 526d | start no earlier than 2002-06-10 | R1 | 4208h | 4208h | RInImp-FSOFDM | Rel-6 | Patrick | Nortel | Sarah Boumendil | 25.892 |  |  |
| 1270 | 421.5 | FS on Uplink Enhancements for Dedicated Transport Channels | 396d | 2002-09-06 A | 2004-03-12 A | 100% | 2002-09-06 | 2004-03-12 | 396d | finish no earlier than 2004-03-12 | R1 | 3168h | 3168h | RInImp-FSUpDTrCh | Rel-6 | Patrick | Nokia | Karri.Ranta-aho@nsn.com | 25.896 |  |  |
| 1271 | 421.6 | FS on Analysis on Higher Chip Rates for UTRA TDD evolutions | 528d | 2002-09-06 A | 2004-09-14 A | 100% | 2002-09-06 | 2004-09-14 | 528d | finish no earlier than 2004-09-14 | R1 | 4224h | 4224h | RInImp-FSVHCRTDD | Rel-6 | Patrick | IPWireless | mbeale@ipwireless.com | 25.895 |  |  |
| 1272 | 421.7 | FS on Low Output Powers for general purpose FDD BSs | 128d | 2003-06-13 A | 2004-03-12 A | 100% | 2003-06-13 | 2004-03-12 | 128d | finish no earlier than 2004-03-12 | R3 | 1024h | 1024h | RInImp-FSLoPw | Rel-6 | Juha | Telefonica | Ana Burgos (burgos_a@tsm.es) | 25.807 |  |  |
| 1273 | 421.8 | FS on Uplink enhancements for UTRA TDD | 462d | 2003-06-06 A | 2005-03-14 A | 100% | 2003-06-06 | 2005-03-14 | 462d | finish no earlier than 2005-03-14 | R1 | 3696h | 3696h | RInImp-FSUpEnhTDD | Rel-6 | Patrick | Interdigital | Marian.Rudolf@InterDigital.com | 25.804 |  |  |
| 1274 | 8.8 | FS on UE antenna efficiency test methods performance requirements (2) | 131d | 2002-03-08 A | 2002-09-06 A | 100% | 2002-03-08 | 2002-09-06 | 131d | finish no earlier than 2002-09-06 | R4 | 1048h | 1048h | RInImp-UEAnTM2 | Rel-6 | Issam | Allgon | Alf Ahlström |  |  |  |
| 1275 | 9.4 | Deleted - FS on the evolution of the UTRAN architecture | 592d | 2002-09-09 A | 2004-12-14 A | 100% | 2002-09-09 | 2004-12-14 | 592d | finish no earlier than 2004-12-15 | R3 | 4736h | 4736h | RANimp-FSEvo | Rel-6 | Juha | Nokia | woonhee.hwang@nsn.com, Antti.Toskala@nokia.com |  |  | RP-26 |
| 1276 | 422 | **FDD Enhanced Uplink** | 393d | 2004-03-15 A | 2005-09-14 A | 100% | 2004-03-15 | 2005-09-14 | 393d |  | RP | 14128h | 14128h | EDCH | Rel-6 |  | Ericsson | Joakim Bergström |  |  |  |
| 1277 | 422.1 | FDD Enhanced Uplink - Stage 2 | 197d | 2004-03-15 A | 2004-12-14 A | 100% | 2004-03-15 | 2004-12-14 | 197d | finish no earlier than 2004-12-14 | R2 | 1576h | 1576h | EDCH-Stage2 | Rel-6 | Joern |  |  | 25.309 |  |  |
| 1278 | 422.2 | FDD Enhanced Uplink - Physical Layer | 261d | 2004-03-15 A | 2005-03-14 A | 100% | 2004-03-15 | 2005-03-14 | 261d | finish no earlier than 2005-03-14 | R1 | 2088h | 2088h | EDCH-Phys | Rel-6 | Patrick | Nokia | Karri.Ranta-aho@nsn.com | 25.211, 25.212, 25.213, 25.214, 25.215 |  |  |
| 1279 | 422.3 | FDD Enhanced Uplink - Layer 2 and 3 Protocol Aspects | 261d | 2004-03-15 A | 2005-03-14 A | 100% | 2004-03-15 | 2005-03-14 | 261d | finish no earlier than 2005-03-14 | R2 | 2088h | 2088h | EDCH-L23 | Rel-6 | Joern | Ericsson | Joakim Bergström | 25.301, 25.302, 25.306, 25.321, 25.331 |  |  |
| 1280 | 422.4 | FDD Enhanced Uplink - UTRAN Iub/Iur Protocol Aspects | 261d | 2004-03-15 A | 2005-03-14 A | 100% | 2004-03-15 | 2005-03-14 | 261d | finish no earlier than 2005-03-14 | R3 | 2088h | 2088h | EDCH-IurIub | Rel-6 | Juha | Nortel | Saso Stojanovski | 25.401, 25.420, 25.423, 25.430, 25.433 |  |  |
| 1281 | 422.5 | FDD Enhanced Uplink - RF Radio Transmission/ Reception, System Performance Requirements and Conformance Testing | 393d | 2004-03-15 A | 2005-09-14 A | 100% | 2004-03-15 | 2005-09-14 | 393d | finish no earlier than 2005-09-15 | R4 | 3144h | 3144h | EDCH-RF | Rel-6 | Issam | Ericsson | thomas.unshelm@ERICSSON.COM | 25.101, 25.104, 25.133, 25.141 |  |  |

Notes:
- 1254: This is a generic feature without particular end date
- 1255: -
- 1256: -
- 1257: -
- 1258: -
- 1259: Introduction of UMTS850 (Band V) in 25.307
- 1260: Introduction of UMTS800 in 25.307
- 1261: Introduction of UMTS1700/2100 (Band IV)
- 1262: -
- 1263: Approved at RP#25 as RP-040375
- 1264: -
- 1265: -
- 1266: -
- 1267: Study finished at RP#25
- 1268: -
- 1269: -
- 1270: -
- 1271: Study finished at RP#25
- 1272: -
- 1273: -
- 1274: The RInImp-UEAnTM FS was re-opened at TSG RP#15 upon request from WG4
- 1275: Study Closed, work will continue within the FS on evolved UTRA and UTRAN
- 1276: -
- 1277: -
- 1278: -
- 1279: -
- 1280: -
- 1281: -

| ID | WBS | Task | Type | Duration | Start | Finish | Complete | Baseline start | Baseline finish | Baseline duration | Constraint | Resources | Work | Actual work | Text1 | Text6 | Text3 | Text4 | Text5 | Text8 | Text12 | Text10 |
| --- | --- | --- | --- | --- | --- | --- | --- | --- | --- | --- | --- | --- | --- | --- | --- | --- | --- | --- | --- | --- | --- | --- |
| 1282 | 423 | **Rel-6 RAN improvements** |  | 656d? | 2002-09-09 A | 2005-03-14 A | 100% | 2002-09-09 | 2005-03-14 | 656d? |  | RP | 28312h | 28312h | RANimp | Rel-6 |  |  |  |  |  |  |
| 1283 | 9.2 | **RAB support enhancement** |  | 522d? | 2003-03-14 A | 2005-03-14 A | 100% | 2003-03-14 | 2005-03-14 | 522d? |  | R2 | 9360h | 9360h | RANimp-RABSE | Rel-6 | 25.862 | Nokia | Jussi Kähtävä (juha.mikola@nokia.com) | Joern |  |  |
| 1284 | 423.1.1 | Optimization of downlink channelisation code utilisation |  | 262d | 2004-03-12 A | 2005-03-14 A | 100% | 2004-03-12 | 2005-03-14 | 262d | finish no earlier than 2005-03-14 | R1 | 2096h | 2096h | RANimp-RABSE-CodeOptFDD | Rel-6 |  | Nortel | Sarah Boumendil | Patrick |  |  |
| 1285 | 423.1.2 | optimization of channelisation code utilisation for 3.84 Mcps TDD |  | 261d | 2004-03-15 A | 2005-03-14 A | 100% | 2004-03-15 | 2005-03-14 | 261d | finish no earlier than 2005-03-15 | R1 | 2088h | 2088h | RANimp-RABSE-CodOptTDD | Rel-6 |  | IPWireless | Nicholas Anderson | Patrick |  |  |
| 1286 | 423.1.3 | HS-DPCCH ACK/NACK Enhancement |  | 65d? | 2004-09-15 A | 2004-12-14 A | 100% | 2004-09-15 | 2004-12-14 | 65d? | finish no earlier than 2004-12-15 | R1 | 520h | 520h | RANimp-RABSE-ACKNACK | Rel-6 | 25.212, 25.214, 24.331, 25.433 | Nokia | Jussi Kähtävä (juha.mikola@nokia.com) | Patrick |  |  |
| 1287 | 423.1.4 | Deleted - Iu enhancements for IMS support in RAN |  | 320d? | 2003-03-14 A | 2004-06-03 A | 100% | 2003-03-14 | 2004-06-03 | 320d? | start no earlier than 2003-03-14 | R3 | 2560h | 2560h | RANimp-RABSE-IuEnhIMS | Rel-6 |  | Nortel | Philippe.Godin@nortelnetworks.com | Juha | RP-24 |  |
| 1288 | 423.1.5 | Deleted - Improvement of RRM across RNS and RNS/BSS | milestone | 0d? | 2003-12-05 A | 2003-12-05 A | 100% | 2003-12-05 | 2003-12-05 | 0d? | finish no earlier than 2003-12-05 | R3 |  |  | RANimp-RRM1 | Rel-6 |  | Nokia | antti.toskala@nokia.com | Juha | RP-23 |  |
| 1289 | 9.1 | Beamforming Enhancements |  | 66d | 2003-09-19 A | 2003-12-19 A | 100% | 2003-09-19 | 2003-12-19 | 66d | finish no earlier than 2004-03-12 | R1 | 528h | 528h | RANimp-BFE | Rel-6 | 24.215, 25.423, 25.425, 25.433, 25.435 | Nokia | Jussi Kähtävä (juha.mikola@nokia.com) | Patrick |  |  |
| 1290 | 423.3 | **Rel6 RRM optimization for Iur and Iub** |  | 126d | 2003-09-19 A | 2004-03-12 A | 100% | 2003-09-19 | 2004-03-12 | 126d |  | R3 | 2016h | 2016h | RANimp-RRMopt | Rel-6 |  | Ericsson | Gert-Jan.van.Lieshout@eln.ericsson.se | Juha |  |  |
| 1291 | 423.3.1 | Improved access to UE measurement data for CRNC to support TDD RRM |  | 126d | 2003-09-19 A | 2004-03-12 A | 100% | 2003-09-19 | 2004-03-12 | 126d | finish no earlier than 2004-03-15 | R3 | 1008h | 1008h | RANimp-RRMopt-UEMsD | Rel-6 | 25.423 | Interdigital | jim.miller@interdigital.com | Juha | RP-22 |  |
| 1292 | 423.4 | **Remote Control of Electrical Tilting Antennas** |  | 395d? | 2003-03-14 A | 2004-09-16 A | 100% | 2003-03-14 | 2004-09-16 | 395d? |  | R3 | 7464h | 7464h | RANimp-TiltAnt | Rel-6 |  | Vodafone | Andreas.Hauser@vodafone.com | Juha |  |  |
| 1293 | 423.4.1 | Tilting Antenna - RAN aspects |  | 393d? | 2003-03-14 A | 2004-09-14 A | 100% | 2003-03-14 | 2004-09-14 | 393d? | finish no earlier than 2004-09-14 | R3 | 3144h | 3144h | RANimp-TiltAnt | Rel-6 | 25.460, 25.461, 25.462, 25.463 | Vodafone | Andreas.Hauser@vodafone.com | Juha |  |  |
| 1294 | 423.4.2 | OAM&P impacts |  | 145d | 2004-02-27 A | 2004-09-16 A | 100% | 2004-02-27 | 2004-09-16 | 145d | finish no earlier than 2004-09-16 | S5 | 1160h | 1160h | RANimp-TiltAnt-OAM | Rel-6 | 32.804, 32.64x | Vodafone | Adrian.Neal@vodafone.com | Dionisio |  | SP-24 |
| 1295 | 423.5 | Network Assisted Cell Change (NACC) from UTRAN to GERAN - network-side aspects |  | 462d? | 2002-09-09 A | 2004-06-15 A | 100% | 2002-09-09 | 2004-06-15 | 462d? | finish no earlier than 2004-06-15 | R3 | 3696h | 3696h | RANimp-NACC | Rel-6 |  | Vodafone | Brendan.McWilliams@gb.vodafone.co.uk | Juha |  |  |
| 1296 | 12 | **Location Services enhancements 2** |  | 1024d? | 2001-01-15 A | 2004-12-16 A | 100% | 2001-01-15 | 2004-12-16 | 1024d? |  | S2,S5,N4,RP | 78152h | 78152h | LCS2 | Rel-6 | 23.271 |  |  | Maurice |  |  |
| 1297 | 12.1 | **Improvement on Le interface** |  | 653d? | 2002-06-17 A | 2004-12-15 A | 100% | 2002-06-17 | 2004-12-15 | 653d? |  | S2 | 9872h | 9872h | LCS2 | Rel-6 |  |  |  | Maurice |  |  |
| 1298 | 424.1.1 | Stage 2 |  | 331d? | 2002-06-17 A | 2003-09-22 A | 100% | 2002-06-17 | 2003-09-22 | 331d? | start no earlier than 2002-06-17 | S2 | 2648h | 2648h | LCS2 | Rel-6 |  |  |  | Maurice |  |  |
| 1299 | 424.1.2 | Stage 3 - impacts MLP (Mobile Location Protocol) |  | 250d? | 2004-01-01 A | 2004-12-15 A | 100% | 2004-01-01 | 2004-12-15 | 250d? | finish no earlier than 2004-12-15 | OMA | 2000h | 2000h | LCS2 | Rel-6 |  |  | OMA-LIAISON@mail.openmobilealliance.org |  |  |  |
| 1300 | 12.2 | **Enhanced support for anonymity and user privacy** |  | 638d? | 2002-07-08 A | 2004-12-15 A | 100% | 2002-07-08 | 2004-12-15 | 638d? |  | S2 | 9144h | 9144h | LCS2 | Rel-6 |  |  |  | Maurice |  |  |
| 1301 | 424.2.1 | Stage 2 |  | 255d? | 2002-07-08 A | 2003-06-27 A | 100% | 2002-07-08 | 2003-06-27 | 255d? | finish no earlier than 2003-06-27 | S2 | 2040h | 2040h | LCS2 | Rel-6 |  |  |  | Maurice |  |  |
| 1302 | 424.2.2 | Stage 3 - impacts MLP and RLP |  | 250d? | 2004-01-01 A | 2004-12-15 A | 100% | 2004-01-01 | 2004-12-15 | 250d? | finish no earlier than 2004-12-15 | OMA | 2000h | 2000h | LCS2 | Rel-6 |  |  | OMA-LIAISON@mail.openmobilealliance.org |  |  |  |
| 1303 | 12.3 | **Enhanced inter-GMLC interface** |  | 648d? | 2002-06-24 A | 2004-12-15 A | 100% | 2002-06-24 | 2004-12-15 | 648d? |  | S2 | 9704h | 9704h | LCS2 | Rel-6 |  |  |  | Maurice |  |  |
| 1304 | 424.3.1 | Stage 2 |  | 315d? | 2002-06-24 A | 2003-09-05 A | 100% | 2002-06-24 | 2003-09-05 | 315d? | finish no earlier than 2003-09-05 | S2 | 2520h | 2520h | LCS2 | Rel-6 |  |  |  | Maurice |  |  |
| 1305 | 424.3.2 | Stage 3 - definition of RLP and PCP |  | 250d? | 2004-01-01 A | 2004-12-15 A | 100% | 2004-01-01 | 2004-12-15 | 250d? | finish no earlier than 2004-12-15 | OMA | 2000h | 2000h | LCS2 | Rel-6 |  |  | OMA-LIAISON@mail.openmobilealliance.org |  |  |  |

Notes:
- 1282: Generic feature
- 1283: building block without particular end date
- 1284: -
- 1285: WIDS modified in RP#26, RP-040551
- 1286: Approved at RP#25 as RP-040390
- 1287: Closed RP#24 due to the lack of progress
- 1288: abandoned RP-23
- 1289: -
- 1290: -
- 1291: -
- 1292: -
- 1293: Finished at RP#25
- 1294: SP#25 09/2004 completed
- 1295: -
- 1296: -
- 1297: -
- 1298: -
- 1299: Updated according to SP-040232
- 1300: -
- 1301: -
- 1302: Updated according to SP-040232
- 1303: -
- 1304: -
- 1305: Updated according to SP-040232

| ID | WBS | Task | Type | Duration | Start | Finish | Complete | Baseline start | Baseline finish | Baseline duration | Constraint | Resources | Work | Actual work | Text1 | Text6 | Text8 | Text5 | Text4 | Text12 |
| --- | --- | --- | --- | --- | --- | --- | --- | --- | --- | --- | --- | --- | --- | --- | --- | --- | --- | --- | --- | --- |
| 1306 | 12.4 | **Location Services support for IMS public identities** |  | 473d? | 2003-02-24 A | 2004-12-15 A | 100% | 2003-02-24 | 2004-12-15 | 473d? |  | S2 | 7704h | 7704h | LCS2 | Rel-6 | Maurice |  |  |  |
| 1307 | 424.4.1 | Stage 2 |  | 240d? | 2003-02-24 A | 2004-01-23 A | 100% | 2003-02-24 | 2004-01-23 | 240d? | finish no earlier than 2004-01-23 | S2 | 1920h | 1920h | LCS2 | Rel-6 | Maurice |  |  |  |
| 1308 | 424.4.2 | Stage 3 - impacts MLP, RLP and PCP |  | 250d? | 2004-01-01 A | 2004-12-15 A | 100% | 2004-01-01 | 2004-12-15 | 250d? | finish no earlier than 2004-12-15 | OMA | 2000h | 2000h | LCS2 | Rel-6 |  | OMA-LIAISON@mail.openmobilealliance.org |  |  |
| 1309 | 12.5 | **New area event for location service triggering reports** |  | 663d? | 2002-06-03 A | 2004-12-15 A | 100% | 2002-06-03 | 2004-12-15 | 663d? |  | S2 | 11416h | 11416h | LCS2 | Rel-6 | Maurice |  |  |  |
| 1310 | 424.5.1 | Stage 2 |  | 280d? | 2002-06-03 A | 2003-06-27 A | 100% | 2002-06-03 | 2003-06-27 | 280d? | finish no earlier than 2003-06-27 | S2 | 2240h | 2240h | LCS2 | Rel-6 | Maurice |  |  |  |
| 1311 | 424.5.2 | Stage 3 for UE-CN signalling |  | 234d? | 2003-10-09 A | 2004-08-31 A | 100% | 2003-10-09 | 2004-08-31 | 234d? | start no earlier than 2003-10-09 | N4 | 1872h | 1872h | LCS2 | Rel-6 | Kimmo |  |  |  |
| 1312 | 424.5.3 | Stage 3 - impacts MLP, RLP and PCP |  | 250d? | 2004-01-01 A | 2004-12-15 A | 100% | 2004-01-01 | 2004-12-15 | 250d? | finish no earlier than 2004-12-15 | OMA | 2000h | 2000h | LCS2 | Rel-6 |  | OMA-LIAISON@mail.openmobilealliance.org |  |  |
| 1313 | 12.7 | **UE positioning** |  | 957d? | 2001-01-15 A | 2004-09-14 A | 100% | 2001-01-15 | 2004-09-14 | 957d? |  | RP | 18480h | 18480h | LCS2-UEpos | Rel-6 | Issam |  |  |  |
| 1314 | 12.8 | Open SMLC-SRNC Interface within the UTRAN to support UTRAN Rel4 positioning methods |  | 700d? | 2001-01-15 A | 2003-09-19 A | 100% | 2001-01-15 | 2003-09-19 | 700d? | finish no earlier than 2003-09-19 | R2 | 5600h | 5600h | LCS-Rel4Pos | Rel-6 | Joern | Meik.Kottkamp@siemens.com | Siemens |  |
| 1315 | 424.6.2 | A-GPS minimum performance specification |  | 333d? | 2003-06-06 A | 2004-09-14 A | 100% | 2003-06-06 | 2004-09-14 | 333d? | finish no earlier than 2004-09-14 | R4 | 2664h | 2664h | LCS-UEPos-AGPSPerf | Rel-6 | Issam | donglin.shen@attws.com | AT&T Wireless |  |
| 1316 | 12.7.2 | FS on Enhancements to OTDOA Positioning using advanced blanking methods |  | 320d | 2002-07-01 A | 2003-09-19 A | 100% | 2002-07-01 | 2003-09-19 | 320d | finish no earlier than 2003-09-19 | R2 | 2560h | 2560h | LCS2-UEpos-FSBlank | Rel-6 | Joern | david.bartlett@cursor-system.com | Cambridge Positioning Systems |  |
| 1317 | 424.6.4 | Deleted - UE positioning enhancements - other methods | milestone | 0d? | 2003-09-26 A | 2003-09-26 A | 100% | 2003-09-26 | 2003-09-26 | 0d? | finish no earlier than 2003-09-26 | R2 |  |  | LCS2-UEpos-enh | Rel-6 | Joern | Meik.Kottkamp@siemens.com | Siemens | RP-24 |
| 1318 | 424.7 | LCS charging |  | 455d? | 2003-03-21 A | 2004-12-16 A | 100% | 2003-03-21 | 2004-12-16 | 455d? | start no earlier than 2003-03-21 | S5 | 3640h | 3640h | LCS2-CH | Rel-6 | Dionisio | alain.bibas@orange-ft.com | France Telecom |  |
| 1319 | 14 | **Rel-6 Security enhancements** |  | 1018d? | 2001-01-03 A | 2004-11-26 A | 100% | 2001-01-03 | 2004-11-26 | 1018d? |  | S3 | 28824h | 28824h | SEC1 | Rel-6 | Dionisio | Peter.Howard@vodafone.com | Vodafone |  |
| 1320 | 14.1 | **Enhanced HE control of security (including positive authentication reporting)** |  | 712d | 2001-01-03 A | 2003-09-25 A | 100% | 2001-01-03 | 2003-09-25 | 712d |  | S3 | 14064h | 14064h | SEC1 | Rel-6 | Dionisio | Peter.Howard@vodafone.com | Vodafone |  |
| 1321 | 14.1.1 | Deleted - SEC1 Stage 2 (Enhanced HE control of security) |  | 378d | 2001-01-03 A | 2002-06-14 A | 100% | 2001-01-03 | 2002-06-14 | 378d | finish no earlier than 2002-06-14 | S3 | 3024h | 3024h | SEC1 | Rel-6 | Dionisio |  |  | SP-16 |
| 1322 | 14.1.3 | **Network domain security** |  | 334d | 2002-06-17 A | 2003-09-25 A | 100% | 2002-06-17 | 2003-09-25 | 334d |  | S3 | 5344h | 5344h | SEC1-NDS | Rel-6 | Dionisio | Geir-myrdahl.koien@telenor.com | Telenor |  |
| 1323 | 14.1.3.1 | IP network layer security (NDS/IP) |  | 334d | 2002-06-17 A | 2003-09-25 A | 100% | 2002-06-17 | 2003-09-25 | 334d | finish no earlier than 2003-09-25 | S3 | 2672h | 2672h | SEC1-NDS-IP | Rel-6 | Dionisio |  |  |  |
| 1324 | 425.2 | Network Domain Security; Authentication Framework (NDS/AF) |  | 521d? | 2002-02-15 A | 2004-02-13 A | 100% | 2002-02-15 | 2004-02-13 | 521d? | finish no earlier than 2004-02-13 | S3 | 4168h | 4168h | SEC1-NDS-AF | Rel-6 | Dionisio | tommi.viitanen@nokia.com | Nokia |  |
| 1325 | 425.3 | Key Management of group keys for Voice Group Call Services |  | 306d | 2003-09-26 A | 2004-11-26 A | 100% | 2003-09-26 | 2004-11-26 | 306d | finish no earlier than 2004-11-26 | S3 | 2448h | 2448h | SECGKYV | Rel-6 | Dionisio | benno.tietz@vodafone.com | Vodafone |  |
| 1326 | 16 | **IMS Phase 2** |  | 1395d? | 2000-08-28 A | 2005-12-30 A | 100% | 2000-08-28 | 2005-12-30 | 1395d? |  | S1,S2,S3,S5,NP | 130248h | 130248h | IMS2 | Rel-6 | Alain |  |  |  |
| 1327 | 426.1 | Enhancements to the Cx and Sh interfaces |  | 323d? | 2003-06-06 A | 2004-08-31 A | 100% | 2003-06-06 | 2004-08-31 | 323d? | finish no earlier than 2004-08-31 | N4 | 2584h | 2584h | IMS2-CCR | Rel-6 | Kimmo |  |  |  |
| 1328 | 16.12 | **IMS Group Management** |  | 715d? | 2002-03-14 A | 2004-12-08 A | 100% | 2002-03-14 | 2004-12-08 | 715d? |  | S1 | 12680h | 12680h | IMSGM | Rel-6 | Alain | juha.kalliokulju@nokia.com | Nokia |  |
| 1329 | 16.12.1 | Stage 1 - TS on IMS group management |  | 193d | 2002-03-14 A | 2002-12-09 A | 100% | 2002-03-14 | 2002-12-09 | 193d | finish no earlier than 2002-12-09 | S1 | 1544h | 1544h | IMSGM | Rel-6 | Alain | juha.kalliokulju@nokia.com | Nokia |  |
| 1330 | 426.2.2 | Stage 2 |  | 158d? | 2003-05-26 A | 2003-12-31 A | 100% | 2003-05-26 | 2003-12-31 | 158d? | finish no earlier than 2003-12-31 | S2 | 1264h | 1264h | IMSGM | Rel-6 | Maurice |  |  |  |
| 1331 | 426.2.3 | Stage 3 for IMS Group management (e.g. chat) |  | 519d? | 2002-12-13 A | 2004-12-08 A | 100% | 2002-12-13 | 2004-12-08 | 519d? | finish no earlier than 2004-12-08 | N1 | 4152h | 4152h | IMSGM | Rel-6 | Frederic | Keith Drage (drage@alcatel-lucent.com) | Lucent |  |

Notes:
- 1306: -
- 1307: -
- 1308: Updated according to SP-040232
- 1309: -
- 1310: -
- 1311: 31/10/2003 work has started. Current stage 3 fullfills the requirements of stage 2. ......
- 1312: Updated according to SP-040232
- 1313: -
- 1314: - / Text3: 25.305, 25.401, 25.450, 25.452, 25.453
- 1315: Finished at RP#25 / Text3: 25.171
- 1316: -
- 1317: building block without particular end date
- 1318: SP#26 12/2004 completed / Text3: 32.271
- 1319: Added BB UE authentication and rapporteur added.
- 1320: Added by SP-000575 without any dates. 18/10/00: Change of WI title, added hyperlink rapporteur new end date 03/01. New end date and correct Release to be decided S3#18
- 1321: New end date and correct Release to be decided S3#18. Marked as stopped 12/2008
- 1322: WID approved for Rel-6 at SP#17. Completed 2004-12
- 1323: Should be complete after SA3#27. Completed 2004-12 / Text3: 33.210
- 1324: WID approved SP#19. Work started after FS approved SP#18
- 1325: Approved TSG#21. Completed 2004-12 / Text3: 42.068, 43.068, 44.068, 42.069, 43.069, 44.069, 31.102, 24.008, 48.008, 42.009, 43.020
- 1326: Not yet available: verbally approved at SA15, actual WID to be provided at SA16 by Lucent / Text3: 23.228
- 1327: Shared public user identities need to be solved. If email approval CR is accepted. Work 100% done....
- 1328: -
- 1329: -
- 1330: -
- 1331: Depends on CN decision on CPCP in Rel-6. Complete, if unresolved IETF dependencies are dropped (-> LS to CN plenary)

| ID | WBS | Task | Type | Duration | Start | Finish | Complete | Baseline start | Baseline finish | Baseline duration | Constraint | Resources | Work | Actual work | Text6 | Text8 | Text4 | Text5 | Text1 | Text3 | Text12 |
| --- | --- | --- | --- | --- | --- | --- | --- | --- | --- | --- | --- | --- | --- | --- | --- | --- | --- | --- | --- | --- | --- |
| 1332 | 426.3 | **IMS Conferencing** |  | 548d? | 2002-11-04 A | 2004-12-08 A | 100% | 2002-11-04 | 2004-12-08 | 548d? |  | N1 | 10960h | 10960h | Rel-6 | Frederic |  |  |  |  |  |
| 1333 | 426.3.1 | Stage 2 |  | 303d? | 2002-11-04 A | 2003-12-31 A | 100% | 2002-11-04 | 2003-12-31 | 303d? | finish no earlier than 2003-12-31 | S2 | 2424h | 2424h | Rel-6 | Maurice |  |  |  |  |  |
| 1334 | 426.3.2 | Stage 3 |  | 519d? | 2002-12-13 A | 2004-12-08 A | 100% | 2002-12-13 | 2004-12-08 | 519d? | finish no earlier than 2004-12-08 | N1 | 4152h | 4152h | Rel-6 | Frederic | Lucent | Keith Drage (drage@alcatel-lucent.com) |  |  |  |
| 1335 | 16.11 | **IMS Messaging** |  | 992d? | 2002-03-14 A | 2005-12-30 A | 100% | 2002-03-14 | 2005-12-30 | 992d? |  | S1 | 23912h | 23912h | Rel-6 | Alain | Nokia | juha.kalliokulju@nokia.com | IMSM |  |  |
| 1336 | 16.11.1 | TR on support of messaging in the IMS |  | 193d | 2002-03-14 A | 2002-12-09 A | 100% | 2002-03-14 | 2002-12-09 | 193d | finish no earlier than 2002-12-09 | S1 | 1544h | 1544h | Rel-6 | Alain | Nokia | juha.kalliokulju@nokia.com | IMSM-TR |  |  |
| 1337 | 426.4.2 | Stage 1 22.340 |  | 23d? | 2002-11-11 A | 2002-12-11 A | 100% | 2002-11-11 | 2002-12-11 | 23d? | finish no earlier than 2002-12-11 | S1 | 184h | 184h | Rel-6 | Alain | Nokia | juha.kalliokulju@nokia.com | IMSM-TS | 22.340 |  |
| 1338 | 426.4.3 | CRs to 22.140 & 22.228 |  | 263d? | 2002-03-14 A | 2003-03-17 A | 100% | 2002-03-14 | 2003-03-17 | 263d? | finish no earlier than 2003-03-17 | S1 | 2104h | 2104h | Rel-6 | Alain | Nokia | juha.kalliokulju@nokia.com | IMSM-CR | 22.140,22.228 |  |
| 1339 | 16.11.3 | Stage 2 |  | 477d | 2002-11-04 A | 2004-08-31 A | 100% | 2002-11-04 | 2004-08-31 | 477d | finish no earlier than 2004-08-31 | S2 | 3816h | 3816h | Rel-6 | Maurice |  |  |  |  |  |
| 1340 | 426.4.5 | Stage 3 for IMS Messaging |  | 519d? | 2002-12-13 A | 2004-12-08 A | 100% | 2002-12-13 | 2004-12-08 | 519d? | finish no earlier than 2004-12-08 | N1 | 4152h | 4152h | Rel-6 | Frederic | Lucent | Keith Drage (drage@alcatel-lucent.com) |  |  |  |
| 1341 | 426.4.6 | SIP/SIMPLE Instant messaging |  | 522d? | 2004-01-01 A | 2005-12-30 A | 100% | 2004-01-01 | 2005-12-30 | 522d? | finish no earlier than 2005-06-30 | OMA | 4176h | 4176h | Rel-6 |  |  | OMA-LIAISON@mail.openmobilealliance.org |  |  |  |
| 1342 | 426.5 | **Additional SIP Capabilities support not covered by Rel-5** |  | 680d? | 2002-11-11 A | 2005-06-17 A | 100% | 2002-11-11 | 2005-06-17 | 680d? |  | N1 | 13392h | 13392h | Rel-6 | Frederic |  |  |  |  |  |
| 1343 | 426.5.1 | Stage 2 for add SIP cap (e.g. forking) |  | 335d? | 2002-11-11 A | 2004-02-20 A | 100% | 2002-11-11 | 2004-02-20 | 335d? | finish no earlier than 2004-02-20 | S2 | 2680h | 2680h | Rel-6 | Maurice |  |  |  |  |  |
| 1344 | 426.5.2 | Stage 3 for Additional SIP Capabilities |  | 454d? | 2002-12-13 A | 2004-09-08 A | 100% | 2002-12-13 | 2004-09-08 | 454d? | finish no earlier than 2004-09-08 | N1 | 3632h | 3632h | Rel-6 | Frederic | Lucent | Keith Drage (drage@alcatel-lucent.com) |  |  |  |
| 1345 | 426.5.3 | Procedured associated with IMS-ALG |  | 205d? | 2004-09-06 A | 2005-06-17 A | 100% | 2004-09-06 | 2005-06-17 | 205d? | start no earlier than 2004-09-06 | N1 | 1640h | 1640h | Rel-6 | Frederic |  |  |  |  |  |
| 1346 | 426.6 | Review additional SIP Capabilities against IMS |  | 454d? | 2002-12-13 A | 2004-09-08 A | 100% | 2002-12-13 | 2004-09-08 | 454d? | finish no earlier than 2004-09-08 | N1 | 3632h | 3632h | Rel-6 | Frederic | Lucent | Keith Drage (drage@alcatel-lucent.com) |  |  |  |
| 1347 | 16.5 | **Interworking between IMS and IP networks** |  | 1118d? | 2000-08-28 A | 2004-12-08 A | 100% | 2000-08-28 | 2004-12-08 | 1118d? |  | N3 | 31712h | 31712h | Rel-6 | Gwiho | BT | nigel.holland@bt.com | IMS-CCR-IWIP | 23.821, 29.061, 29.162 |  |
| 1348 | 16.5.1 | Interworking for 3GPP_SIP and IETF_SIP |  | 730d | 2000-08-28 A | 2003-06-13 A | 100% | 2000-08-28 | 2003-06-13 | 730d | finish no earlier than 2003-06-13 | N3 | 5840h | 5840h | Rel-6 | Gwiho | Siemens | Thomas.Belling@nsn.com |  | New 29.962 |  |
| 1349 | 16.5.2 | Interworking for IPv6 to IPv4 |  | 1118d | 2000-08-28 A | 2004-12-08 A | 100% | 2000-08-28 | 2004-12-08 | 1118d | finish no earlier than 2004-12-08 | N3 | 8944h | 8944h | Rel-6 | Gwiho |  |  |  | 29.163 |  |
| 1350 | 426.7.3 | Interworking for IPv6 to IPv4 (SIP / SDP aspects) |  | 87d? | 2004-05-11 A | 2004-09-08 A | 100% | 2004-05-11 | 2004-09-08 | 87d? | finish no earlier than 2004-09-08 | N1 | 696h | 696h | Rel-6 | Frederic |  |  |  |  |  |
| 1351 | 16.8.1 | stage 3 of interworking with non-IMS IP networks |  | 911d | 2001-03-14 A | 2004-09-08 A | 100% | 2001-03-14 | 2004-09-08 | 911d | finish no earlier than 2004-09-08 | N1 | 7288h | 7288h | Rel-6 | Frederic |  |  |  |  |  |
| 1352 | 16.6.1 | Interworking between IMS and CS networks |  | 929d? | 2000-08-28 A | 2004-03-18 A | 100% | 2000-08-28 | 2004-03-18 | 929d? | finish no earlier than 2004-03-18 | N3 | 7432h | 7432h | Rel-6 | Gwiho | Vodafone | Brendan.McWilliams@gb.vodafone.co.uk | IMS-CCR-IWCS | 29.163, 29.061, 24.228, and new CN4 specification |  |
| 1353 | 16.10 | Mn interface (IM-MGW to MGCF) enhancements (CN4 Part) |  | 418d | 2001-08-07 A | 2004-09-01 A | 100% | 2001-08-07 | 2004-09-01 | 418d | finish no earlier than 2004-09-01 | N4 | 3344h | 3344h | Rel-6 | Kimmo |  |  | IMS-CCR-Mn |  |  |
| 1354 | 426.10 | Study of subscriber and operators relationship in IMS and related ISIM requirements for Rel 6” |  | 20d? | 2002-11-15 A | 2002-12-12 A | 100% | 2002-11-15 | 2002-12-12 | 20d? | finish no earlier than 2002-12-12 | S1 | 160h | 160h | Rel-6 | Alain | Nokia | juha.kalliokulju@nokia.com |  |  |  |
| 1355 | 426.11 | Lawful Interception in the 3GPP Rel-6 architecture |  | 269d? | 2002-12-09 A | 2003-12-18 A | 100% | 2002-12-09 | 2003-12-18 | 269d? | finish no earlier than 2003-12-18 | S3 | 2152h | 2152h | Rel-6 | Dionisio | Reg TP | berthold.wilhelm@regtp.de | SEC1-LI | 33.106, 33.107, 33.108 |  |
| 1356 | 426.12 | IMS Subscription and access scenarios |  | 130d? | 2002-12-16 A | 2003-06-13 A | 100% | 2002-12-16 | 2003-06-13 | 130d? | start no earlier than 2002-12-16 | S1 | 1040h | 1040h | Rel-6 | Alain |  |  |  | 22.800 |  |
| 1357 | 426.13 | IMS charging |  | 455d? | 2003-03-21 A | 2004-12-16 A | 100% | 2003-03-21 | 2004-12-16 | 455d? | finish no earlier than 2004-12-16 | S5 | 3640h | 3640h | Rel-6 | Dionisio | Ericsson | Patrik TEPPO | IMS2-CH | 32.260 |  |
| 1358 | 426.14 | IMS Management objects |  | 306d? | 2004-09-03 A | 2005-11-04 A | 100% | 2004-09-03 | 2005-11-04 | 306d? | finish no earlier than 2005-03-04 | N1 | 2448h | 2448h | Rel-6 | Frederic |  |  |  | 24.167 |  |
| 1359 | 426.15 | Deleted - Stage 2 of IMS Phase 2 | milestone | 0d? | 2003-09-19 A | 2003-09-19 A | 100% | 2003-09-19 | 2003-09-19 | 0d? | finish no earlier than 2003-09-19 | S2 |  |  | Rel-6 | Maurice |  |  | IMS2 |  | SP-21 |

Notes:
- 1332: -
- 1333: -
- 1334: Depends on CN decision on IETF dependencies in Rel-6. Higher figure if CPCP is dropped (-> LS to CN plenary)
- 1335: -
- 1336: -
- 1337: -
- 1338: -
- 1339: -
- 1340: -
- 1341: Updated according to SP-040232
- 1342: -
- 1343: -
- 1344: -
- 1345: -
- 1346: -
- 1347: [DAB 14.02.02] - end date pushed back to March 2003
- 1348: [DAB - 20.08.03] - CN Part of TR Complete @ CN#20
- 1349: -
- 1350: -
- 1351: -
- 1352: [DAB - 25.05.04] - CN3 consider this work to be complete
- 1353: TISPAN issue is open
- 1354: -
- 1355: -
- 1356: -
- 1357: SP#26 12/2004 completed
- 1358: -
- 1359: -

| ID | WBS | Task | Type | Duration | Start | Finish | Complete | Baseline start | Baseline finish | Baseline duration | Constraint | Resources | Work | Actual work | Text1 | Text4 | Text5 | Text6 | Text8 | Text3 | Text10 | Text12 |
| --- | --- | --- | --- | --- | --- | --- | --- | --- | --- | --- | --- | --- | --- | --- | --- | --- | --- | --- | --- | --- | --- | --- |
| 1360 | 427 | **3GPP Enablers for services like Push to Talk over Cellular (PoC)** |  | 459d? | 2003-09-08 A | 2005-06-09 A | 100% | 2003-09-08 | 2005-06-09 | 459d? |  | S2,S4,S5 | 10696h | 10696h | PoC | Ericsson | Shabnam Sultana | Rel-6 | Maurice |  |  |  |
| 1361 | 427.1 | Feasibility Study |  | 322d? | 2003-09-08 A | 2004-11-30 A | 100% | 2003-09-08 | 2004-11-30 | 322d? | finish no earlier than 2004-11-30 | S2 | 2576h | 2576h | PoC | Ericsson | Shabnam Sultana | Rel-6 | Maurice | 23.979 | SP-24 |  |
| 1362 | 427.2 | Dependencies on OMA PoC |  | 303d? | 2004-01-01 A | 2005-02-28 A | 100% | 2004-01-01 | 2005-02-28 | 303d? | finish no earlier than 2004-12-30 | OMA | 2424h | 2424h | PoC |  | OMA-LIAISON@mail.openmobilealliance.org | Rel-6 |  |  | SP-24 |  |
| 1363 | 427.3 | Selection of one or more PoC codec(s) for PoC |  | 69d? | 2004-09-13 A | 2004-12-16 A | 100% | 2004-09-13 | 2004-12-16 | 69d? | start no earlier than 2004-09-13 | S4 | 552h | 552h | PoC |  |  | Rel-6 | Paolo | 26.235, 26.236 | SP-25 |  |
| 1364 | 427.4 | PoC charging |  | 184d? | 2004-09-27 A | 2005-06-09 A | 100% | 2004-09-27 | 2005-06-09 | 184d? | finish no earlier than 2005-06-09 | S5 | 1472h | 1472h | PoC-CH | Siemens | Gerald GÖRMER | Rel-6 | Dionisio | 32.272 |  |  |
| 1365 | 428 | Study on Interworking aspects and migration scenarios for IPv4 based IMS Implementations |  | 210d? | 2003-09-08 A | 2004-06-25 A | 100% | 2003-09-08 | 2004-06-25 | 210d? | finish no earlier than 2004-06-25 | S2 | 1680h | 1680h | IPv4IMS | Siemens | Alexander Milinski | Rel-6 | Maurice | 23.981 |  |  |
| 1366 | 16.3 | **Interoperability and Commonality between IMS using different "IP-connectivity Networks"** |  | 325d? | 2002-09-16 A | 2003-12-12 A | 100% | 2002-09-16 | 2003-12-12 | 325d? |  | S2 | 9176h | 9176h | IMSCOOP |  |  | Rel-6 | Maurice | 23.864 |  |  |
| 1367 | 16.3.1 | Stage 2 for Interoperability |  | 272d | 2002-09-16 A | 2003-09-30 A | 100% | 2002-09-16 | 2003-09-30 | 272d | finish no earlier than 2003-09-30 | S2 | 2176h | 2176h | IMSCOOP | Nokia | balazs.bertenyi@nsn.com | Rel-6 | Maurice | 23.864 |  |  |
| 1368 | 429.2 | Stage 2 for commonality |  | 265d? | 2002-09-16 A | 2003-09-19 A | 100% | 2002-09-16 | 2003-09-19 | 265d? | start no earlier than 2002-09-16 | S2 | 2120h | 2120h | IMSCOOP | Nokia | balazs.bertenyi@nsn.com | Rel-6 | Maurice | 23.864 |  |  |
| 1369 | 16.3.2 | Stage 3 |  | 305d | 2002-10-14 A | 2003-12-12 A | 100% | 2002-10-14 | 2003-12-12 | 305d | finish no earlier than 2003-12-12 | N1 | 2440h | 2440h | IMSCOOP | Lucent | Keith Drage (drage@alcatel-lucent.com) | Rel-6 | Frederic |  |  |  |
| 1370 | 17 | **Support of Push Services** |  | 823d | 2001-01-03 A | 2004-02-27 A | 100% | 2001-01-03 | 2004-02-27 | 823d |  | S1 | 11390.6h | 11390.6h | PUSH | NTT Comware | Yoshinori Kitada | Rel-6 | Alain | 23.976 |  |  |
| 1371 | 17.1 | Stage 1 |  | 378d | 2001-01-03 A | 2002-06-14 A | 100% | 2001-01-03 | 2002-06-14 | 378d | finish no earlier than 2002-06-14 | S1 | 3024h | 3024h | PUSH |  |  | Rel-6 | Alain |  |  |  |
| 1372 | 17.3 | TR 23.976 on Push Architecture |  | 340d | 2002-11-11 A | 2004-02-27 A | 100% | 2002-11-11 | 2004-02-27 | 340d | finish no earlier than 2004-02-27 | S2 | 2720h | 2720h | PUSH | RIM | Nick Alfano | Rel-6 | Maurice | 23.976 |  |  |
| 1373 | 18 | **Multimedia Messaging (MMS) enhancements** |  | 865d? | 2002-08-15 A | 2005-12-07 A | 100% | 2002-08-15 | 2005-12-07 | 865d? |  | T2,S1,S4,S5,OMA | 31936h | 31936h | MMS6 | Siemens | Josef.Laumen@SAL.SIEMENS.DE | Rel-6 | Kimmo |  |  |  |
| 1374 | 18.1 | **Definition of service requirements** |  | 286d? | 2002-11-15 A | 2003-12-19 A | 100% | 2002-11-15 | 2003-12-19 | 286d? |  | S1 | 4576h | 4576h | MMS6-SR |  |  | Rel-6 | Alain | 22.140 |  |  |
| 1375 | 431.1.1 | Definition of service requirements charging |  | 286d? | 2002-11-15 A | 2003-12-19 A | 100% | 2002-11-15 | 2003-12-19 | 286d? | finish no earlier than 2003-12-20 | S1 | 2288h | 2288h | MMS6-SR | Siemens | Josef.Laumen@SAL.SIEMENS.DE | Rel-6 | Alain | 22.140 |  |  |
| 1376 | 18.2 | Technical realization |  | 591d | 2002-09-06 A | 2004-12-10 A | 100% | 2002-09-06 | 2004-12-10 | 591d | finish no earlier than 2004-12-10 | T2 | 4728h | 4728h | MMS6 | Siemens | Josef.Laumen@SAL.SIEMENS.DE | Rel-6 | Kimmo | 23.140 |  |  |
| 1377 | 18.3 | OMA dependencies |  | 446d | 2003-08-15 A | 2005-04-29 A | 100% | 2003-08-15 | 2005-04-29 | 446d | finish no earlier than 2004-12-10 | OMA | 3568h | 3568h | MMS6 |  |  | Rel-6 | Kimmo | OMA specs |  |  |
| 1378 | 18.4 | MMS formats and codecs |  | 865d | 2002-08-15 A | 2005-12-07 A | 100% | 2002-08-15 | 2005-12-07 | 865d | finish no earlier than 2005-12-07 | S4 | 6920h | 6920h | MMS6-Codec | Nokia | roberto.castagno@nokia.com | Rel-6 | Paolo | 26.140, 26.936 |  |  |
| 1379 | 431.5 | Handling of private addressing schemes in MMS |  | 263d | 2003-12-10 A | 2004-12-10 A | 100% | 2003-12-10 | 2004-12-10 | 263d | finish no earlier than 2004-12-10 | T2 | 2104h | 2104h | MMS6 | T-Mobile | Steffen.Habermann@T-MOBILE.DE | Rel-6 | Kimmo | 23.140 |  |  |
| 1380 | 431.6 | MMS charging |  | 390d? | 2003-03-21 A | 2004-09-16 A | 100% | 2003-03-21 | 2004-09-16 | 390d? | start no earlier than 2003-03-21 | S5 | 3120h | 3120h | MMS6-CH |  |  | Rel-6 | Dionisio | 32.270 |  |  |
| 1381 | 431.7 | Deleted - FS Multiple MMS Relay/Server Architecture | milestone | 0d | 2004-12-10 A | 2004-12-10 A | 100% | 2004-12-10 | 2004-12-10 | 0d | finish no earlier than 2004-12-10 | T2 |  |  | MMS6 | Telefónica Móviles | Juan Gorospe (gorospe_j@tsm.es) | Rel-6 | Kimmo | probably Annex to 23.140 |  | TP-26 |
| 1382 | 19 | **Rel-6 MExE enhancements** |  | 326d | 2002-03-08 A | 2003-06-06 A | 100% | 2002-03-08 | 2003-06-06 | 326d |  | T2 | 7328h | 7328h | MEXE6 |  |  | Rel-6 | Kimmo |  |  |  |
| 1383 | 19.1 | MExE Rel-6 Improvements and Investigations |  | 264d | 2002-03-08 A | 2003-03-12 A | 100% | 2002-03-08 | 2003-03-12 | 264d | finish no earlier than 2003-03-12 | T2 | 2112h | 2112h | MEXE6-ENHANC | TTPCom | Lars Brenk ( (lsb_ttpcom@HOTMAIL.COM) | Rel-6 |  |  |  |  |
| 1384 | 19.2 | MExE Run-Time Independent Framework Feasibility Study |  | 326d | 2002-03-08 A | 2003-06-06 A | 100% | 2002-03-08 | 2003-06-06 | 326d | finish no earlier than 2003-06-06 | T2 | 2608h | 2608h | MEXE6-RTIF | Intel | Aaron.Cohen@intel.com | Rel-6 |  | 22.857 |  |  |
| 1385 | 21 | Subscription Management |  | 650d | 2002-09-20 A | 2005-03-17 A | 100% | 2002-09-20 | 2005-03-17 | 650d | finish no earlier than 2005-03-17 | S5 | 5200h | 5200h | SuM | T-Mobile | istvan.aba@t-mobile.at | Rel-6 | Dionisio | 32.140/1, 32.171/2/5, 32.803 |  |  |

Notes:
- 1360: -
- 1361: -
- 1362: Updated according to SP-040232
- 1363: Completed
- 1364: SP#28 06/2005 completed
- 1365: -
- 1366: -
- 1367: No contributions assumed that no more will be done in 3GPP hence work may need to be done in 3GPP2
- 1368: -
- 1369: -
- 1370: Changed from FS to actual support of Push
- 1371: -
- 1372: -
- 1373: -
- 1374: -
- 1375: -
- 1376: -
- 1377: -
- 1378: -
- 1379: -
- 1380: SP#25 09/2004 completed
- 1381: originally it was intended to create a FS TR but most likely the work will become an Annex of 23.140
- 1382: -
- 1383: -
- 1384: -
- 1385: SP#27 03/2005 completed

| ID | WBS | Task | Duration | Start | Finish | Complete | Baseline start | Baseline finish | Baseline duration | Constraint | Resources | Work | Actual work | Text1 | Text4 | Text5 | Text6 | Text8 | Text3 |
| --- | --- | --- | --- | --- | --- | --- | --- | --- | --- | --- | --- | --- | --- | --- | --- | --- | --- | --- | --- |
| 1386 | 22 | **Presence Capability** | 1233d? | 2001-03-19 A | 2005-12-07 A | 100% | 2001-03-19 | 2005-12-07 | 1233d? |  | S1 | 37112h | 37112h | PRESNC | Motorola | Mark Cataldo | Rel-6 | Alain |  |
| 1387 | 22.1 | Stage 1 | 610d | 2001-03-19 A | 2003-07-18 A | 100% | 2001-03-19 | 2003-07-18 | 610d | finish no earlier than 2003-07-18 | S1 | 4880h | 4880h | PRESNC |  |  | Rel-6 | Alain | 22.141 |
| 1388 | 22.2 | Stage 2 | 268d | 2001-09-12 A | 2002-09-20 A | 100% | 2001-09-12 | 2002-09-20 | 268d | finish no earlier than 2002-09-20 | S2 | 2144h | 2144h | PRESNC | Nokia | balazs.bertenyi@nsn.com | Rel-6 | Maurice |  |
| 1389 | 22.3 | Stage 3 | 703d | 2002-04-01 A | 2004-12-08 A | 100% | 2002-04-01 | 2004-12-08 | 703d | finish no earlier than 2004-12-08 | N1 | 5624h | 5624h | PRESNC | Lucent | Keith Drage (drage@alcatel-lucent.com) | Rel-6 | Frederic |  |
| 1390 | 434.4 | Stage 3 (CN3 Part Pk interface) | 770d? | 2002-04-01 A | 2005-03-11 A | 100% | 2002-04-01 | 2005-03-11 | 770d? | finish no earlier than 2005-03-11 | N3 | 6160h | 6160h | PRESNC |  |  | Rel-6 | Gwiho |  |
| 1391 | 434.5 | Media Codecs and Formats for IMS Messaging and Presence | 650d? | 2003-06-12 A | 2005-12-07 A | 100% | 2003-06-12 | 2005-12-07 | 650d? | finish no earlier than 2005-12-07 | S4 | 5200h | 5200h | PRESNC-COFIMP | Nokia | harri.honko@nokia.com | Rel-6 | Paolo | 26.141, 26.936 |
| 1392 | 22.4 | Security issues | 79d | 2002-08-26 A | 2002-12-12 A | 100% | 2002-08-26 | 2002-12-12 | 79d | finish no earlier than 2002-12-12 | S3 | 632h | 632h | PRESNC |  |  | Rel-6 | Dionisio |  |
| 1393 | 434.7 | SIMPLE Presence | 326d? | 2004-01-01 A | 2005-03-31 A | 100% | 2004-01-01 | 2005-03-31 | 326d? | finish no earlier than 2004-12-30 | OMA | 2608h | 2608h | PRESNC |  | OMA-LIAISON@mail.openmobilealliance.org | Rel-6 |  |  |
| 1394 | 25 | **Enhanced A/Gb feasibility study** | 51d? | 2002-08-30 A | 2002-11-08 A | 100% | 2002-08-30 | 2002-11-08 | 51d? |  | GP | 3264h | 3264h | AGbEnFS | Vodafone | jose-luis.carrizo@vodafone.co.uk | Rel-6 | Paolo | None |
| 1395 | 25.1 | **Feasibility study on A/Gb enhancements** | 51d? | 2002-08-30 A | 2002-11-08 A | 100% | 2002-08-30 | 2002-11-08 | 51d? |  | G2 | 2856h | 2856h | AGbEnFS-FS | Vodafone | jose-luis.carrizo@vodafone.co.uk | Rel-6 | Gert | None |
| 1396 | 25.1.1 | Requirements for the support of conversational services | 51d | 2002-08-30 A | 2002-11-08 A | 100% | 2002-08-30 | 2002-11-08 | 51d | finish no earlier than 2002-11-08 | GP | 408h | 408h | AGbEnFS-FS |  |  | Rel-6 | Paolo | None |
| 1397 | 435.1.2 | Identification of the different building blocks for the provision of conversational services on the existing A/Gb protocol stack | 51d? | 2002-08-30 A | 2002-11-08 A | 100% | 2002-08-30 | 2002-11-08 | 51d? | finish no earlier than 2002-11-08 | GP | 408h | 408h | AGbEnFS-FS |  |  | Rel-6 | Paolo | None |
| 1398 | 435.1.3 | Outline of impact and feasibility of these building blocks and their different solutions | 51d? | 2002-08-30 A | 2002-11-08 A | 100% | 2002-08-30 | 2002-11-08 | 51d? | finish no earlier than 2002-11-08 | GP | 408h | 408h | AGbEnFS-FS |  |  | Rel-6 | Paolo | None |
| 1399 | 25.1.4 | Impact on 3GPP architecture and requirement to co-ordinatge with other TSGs (CN, SA) | 51d | 2002-08-30 A | 2002-11-08 A | 100% | 2002-08-30 | 2002-11-08 | 51d | finish no earlier than 2002-11-08 | GP | 408h | 408h | AGbEnFS-FS |  |  | Rel-6 | Paolo | None |
| 1400 | 25.1.5 | Standardisation effort | 51d | 2002-08-30 A | 2002-11-08 A | 100% | 2002-08-30 | 2002-11-08 | 51d | finish no earlier than 2002-11-08 | GP | 408h | 408h | AGbEnFS-FS |  |  | Rel-6 | Paolo | None |
| 1401 | 25.1.6 | Dependency to other features | 51d | 2002-08-30 A | 2002-11-08 A | 100% | 2002-08-30 | 2002-11-08 | 51d | finish no earlier than 2002-11-08 | GP | 408h | 408h | AGbEnFS-FS |  |  | Rel-6 | Paolo | None |
| 1402 | 26 | **Flexible Layer One for GERAN** | 1171d | 2000-01-03 A | 2004-06-25 A | 100% | 2000-01-03 | 2004-06-25 | 1171d |  | GP | 71551h | 71551h | FLOGER | Nokia | benoist.sebire@nokia.com | Rel-6 | Paolo |  |
| 1403 | 26.1 | **Realisation of a Flexible Layer One** | 1126d | 2000-01-03 A | 2004-04-23 A | 100% | 2000-01-03 | 2004-04-23 | 1126d |  | GP | 42816h | 42816h | FLOGER-Real | Nokia | benoist.sebire@nokia.com | Rel-6 | Paolo |  |
| 1404 | 26.1.1 | Technical Report | 471d | 2002-04-19 A | 2004-02-06 A | 100% | 2002-04-19 | 2004-02-06 | 471d | finish no earlier than 2004-02-06 | GP | 3768h | 3768h | FLOGER-Real |  |  | Rel-6 | Paolo |  |
| 1405 | 26.1.2 | Architecture in 45.001 and 43.051 | 526d | 2002-04-19 A | 2004-04-23 A | 100% | 2002-04-19 | 2004-04-23 | 526d | finish no earlier than 2004-04-23 | G1 | 4208h | 4208h | FLOGER-Real |  |  | Rel-6 |  |  |
| 1406 | 26.1.3 | Multiplexing in 45.002 | 526d | 2002-04-19 A | 2004-04-23 A | 100% | 2002-04-19 | 2004-04-23 | 526d | finish no earlier than 2004-04-23 | G1 | 4208h | 4208h | FLOGER-Real |  |  | Rel-6 |  |  |
| 1407 | 26.1.4 | Channel Coding in 45.003 | 526d | 2002-04-19 A | 2004-04-23 A | 100% | 2002-04-19 | 2004-04-23 | 526d | finish no earlier than 2004-04-23 | G1 | 4208h | 4208h | FLOGER-Real |  |  | Rel-6 |  |  |
| 1408 | 26.1.5 | Performance Requirements in 45.005 | 1126d | 2000-01-03 A | 2004-04-23 A | 100% | 2000-01-03 | 2004-04-23 | 1126d | finish no earlier than 2004-04-23 | G1 | 9000h | 9000h | FLOGER-Real |  |  | Rel-6 |  |  |
| 1409 | 26.1.6 | Radio subsystem link control in 45.008 | 526d | 2002-04-19 A | 2004-04-23 A | 100% | 2002-04-19 | 2004-04-23 | 526d | finish no earlier than 2004-04-23 | G1 | 4208h | 4208h | FLOGER-Real |  |  | Rel-6 |  |  |
| 1410 | 26.1.7 | Requirements in 44.004 | 526d | 2002-04-19 A | 2004-04-23 A | 100% | 2002-04-19 | 2004-04-23 | 526d | finish no earlier than 2004-04-23 | G2 | 4208h | 4208h | FLOGER-Real |  |  | Rel-6 | Gert |  |

Notes:
- 1386: merged "Presence Service Enhancements" (UID31028, PRES1) to this feature as no answer was provided on why Presence and Presence Encmts had same target completion date
- 1387: -
- 1388: -
- 1389: Dependency to 2 IETF drafts, no known work at the moment
- 1390: No Contributions so far - only requires a little work
- 1391: -
- 1392: LSs handled in SA3. WID approved SP#17 Contribution at S3#25 & following e-mail discussion. Marked as closed 12/2008 (was marked 90% complete)
- 1393: Updated according to SP-040232
- 1394: -
- 1395: -
- 1396: -
- 1397: -
- 1398: -
- 1399: -
- 1400: -
- 1401: -
- 1402: -
- 1403: -
- 1404: -
- 1405: -
- 1406: -
- 1407: -
- 1408: -
- 1409: -
- 1410: -

| ID | WBS | Task | Type | Duration | Start | Finish | Complete | Baseline start | Baseline finish | Baseline duration | Constraint | Resources | Work | Actual work | Text1 | Text4 | Text5 | Text6 | Text8 | Text12 | Text3 |
| --- | --- | --- | --- | --- | --- | --- | --- | --- | --- | --- | --- | --- | --- | --- | --- | --- | --- | --- | --- | --- | --- |
| 1411 | 26.2 | **Signalling and protocol support for a Flexible Layer One** |  | 571d | 2002-04-19 A | 2004-06-25 A | 100% | 2002-04-19 | 2004-06-25 | 571d |  | G2 | 13704h | 13704h | FLOGER-SigPro | Nokia | benoist.sebire@nokia.com | Rel-6 | Gert |  |  |
| 1412 | 26.2.1 | Modifications to RLC/MAC in 44.060 and 44.160 |  | 571d | 2002-04-19 A | 2004-06-25 A | 100% | 2002-04-19 | 2004-06-25 | 571d | finish no earlier than 2004-06-25 | G2 | 4568h | 4568h | FLOGER-SigPro |  |  | Rel-6 | Gert |  |  |
| 1413 | 26.2.2 | Modifications to RRC in 44.118 and 44.018 |  | 571d | 2002-04-19 A | 2004-06-25 A | 100% | 2002-04-19 | 2004-06-25 | 571d | finish no earlier than 2004-06-25 | G2 | 4568h | 4568h | FLOGER-SigPro |  |  | Rel-6 | Gert |  |  |
| 1414 | 26.3 | **Security for a Flexible Layer One** |  | 356d | 2002-04-19 A | 2003-08-29 A | 100% | 2002-04-19 | 2003-08-29 | 356d |  | S3, G2 | 5663.03h | 5663.03h | FLOGER-SecFLO | Nokia | benoist.sebire@nokia.com | Rel-6 | Dionisio |  |  |
| 1415 | 26.3.1 | Ciphering in 44.160,44.118, 44.060 and 44.018 |  | 356d | 2002-04-19 A | 2003-08-29 A | 100% | 2002-04-19 | 2003-08-29 | 356d | finish no earlier than 2003-08-29 | S3, G2 | 2848h | 2848h | FLOGER-SecFLO |  |  | Rel-6 | Dionisio |  |  |
| 1416 | 26.4 | **Deleted - GERAN MS Conformance test for the Flexible Layer One - DELETE** |  | 0d | 2004-02-06 A | 2004-02-06 A | 100% | 2004-02-06 | 2004-02-06 | 0d |  | G4,G5 |  |  | FLOGER-Msconf | Nokia | benoist.sebire@nokia.com | Rel-6 | Paolo | GP-27 |  |
| 1417 | 26.4.1 | Deleted at TSG #27 - MS Test in 51.010 | milestone | 0d | 2004-02-06 A | 2004-02-06 A | 100% | 2004-02-06 | 2004-02-06 | 0d | finish no earlier than 2004-02-06 | G4,G5 |  |  | FLOGER-Msconf |  |  | Rel-6 | Paolo | GP-22 |  |
| 1418 | 26.5 | **Deleted - GERAN BTS Conformance test for the Flexible Layer One - DELETE** |  | 0d | 2004-02-06 A | 2004-02-06 A | 100% | 2004-02-06 | 2004-02-06 | 0d |  | G3new |  |  | FLOGER-BTSconf | Nokia | benoist.sebire@nokia.com | Rel-6 | Ingbert | GP-27 |  |
| 1419 | 26.5.1 | Deleted at TGS #27 - BTS Test in 51.021 - DELETE | milestone | 0d | 2004-02-06 A | 2004-02-06 A | 100% | 2004-02-06 | 2004-02-06 | 0d | finish no earlier than 2004-02-06 | G3new |  |  | FLOGER-BTSconf |  |  | Rel-6 | Ingbert | GP-22 |  |
| 1420 | 27 | Uplink TDOA feasibility study |  | 151d | 2001-11-30 A | 2002-06-28 A | 100% | 2001-11-30 | 2002-06-28 | 151d | finish no earlier than 2002-06-28 | GP | 1208h | 1208h | TDOAF | TruePosition | Bob Gross (rlgross@trueposition.com) | Rel-6 | Paolo |  | 45.811 |
| 1421 | 28 | **Multimedia Broadcast and Multicast Service** |  | 1781d? | 2001-05-11 A | 2008-03-07 A | 100% | 2001-05-11 | 2008-03-07 | 1781d? |  | S1,S2,S4,S5,T1,RP,GP | 158712h | 158712h | MBMS |  |  | Rel-6 | Alain |  |  |
| 1422 | 28.1 | Stage 1 |  | 232d | 2001-05-11 A | 2002-04-01 A | 100% | 2001-05-11 | 2002-04-01 | 232d | finish no earlier than 2002-04-01 | S1 | 1856h | 1856h | MBMS |  |  | Rel-6 | Alain |  | 22.146, 22.101 |
| 1423 | 28.2 | **Stage 2** |  | 648d | 2001-09-24 A | 2004-03-17 A | 100% | 2001-09-24 | 2004-03-17 | 648d |  | S2 | 10408h | 10408h | MBMS |  |  | Rel-6 | Maurice |  |  |
| 1424 | 28.2.1 | TR on Architectural Study |  | 240d | 2001-09-24 A | 2002-08-23 A | 100% | 2001-09-24 | 2002-08-23 | 240d | finish no earlier than 2002-08-23 | S2 | 1920h | 1920h | MBMS |  |  | Rel-6 | Maurice |  | 23.846 |
| 1425 | 28.2.2 | Stage 2 Specification Work |  | 413d | 2002-08-19 A | 2004-03-17 A | 100% | 2002-08-19 | 2004-03-17 | 413d | finish no earlier than 2004-03-17 | S2 | 3304h | 3304h | MBMS |  |  | Rel-6 | Maurice |  | 23.246 |
| 1426 | 28.3 | **Introduction of MBMS in RAN** |  | 967d? | 2002-01-01 A | 2005-09-14 A | 100% | 2002-01-01 | 2005-09-14 | 967d? |  | R2 | 15992h | 15992h | MBMS-RAN | Nokia | juho.pirskanen@nokia.com | Rel-6 | Joern |  | 25.346, 25.304, 25.321, 25.322, 25.323, 25.331 |
| 1427 | 438.3.1 | Introduction of MBMS in RAN (physical & upper layers, access network interfaces) |  | 771d? | 2002-01-01 A | 2004-12-14 A | 100% | 2002-01-01 | 2004-12-14 | 771d? | finish no earlier than 2004-12-14 | R2 | 6168h | 6168h | MBMS-RAN | Nokia | juho.pirskanen@nokia.com | Rel-6 | Joern |  | 25.346, 25.304, 25.321, 25.322, 25.323 |
| 1428 | 438.3.2 | UE Performance Requirements for MBMS |  | 261d? | 2004-09-15 A | 2005-09-14 A | 100% | 2004-09-15 | 2005-09-14 | 261d? | finish no earlier than 2005-09-15 | R4 | 2088h | 2088h | MBMS-RAN-RF | Ericsson | Torgny.Palenius@ericsson.com | Rel-6 | Issam |  | 25.101, 25.133 |
| 1429 | 28.4 | Support of the MBMS in CN protocols |  | 647d | 2002-06-18 A | 2004-12-08 A | 100% | 2002-06-18 | 2004-12-08 | 647d | finish no earlier than 2004-12-08 | N1 | 5176h | 5176h | MBMS |  |  | Rel-6 | Frederic |  |  |
| 1430 | 438.5 | Gmb interface for MBMS (CN3 part) |  | 334d | 2003-08-29 A | 2004-12-08 A | 100% | 2003-08-29 | 2004-12-08 | 334d | finish no earlier than 2004-12-08 | N3 | 2672h | 2672h | MBMS |  |  | Rel-6 | Gwiho |  | 29.061 |
| 1431 | 28.5 | Security Aspects of MBMS |  | 710d | 2002-07-01 A | 2005-03-18 A | 100% | 2002-07-01 | 2005-03-18 | 710d | finish no earlier than 2005-03-18 | S3 | 5680h | 5680h | MBMS |  | adrian.escott@three.co.uk | Rel-6 | Dionisio |  |  |
| 1432 | 28.6 | **Support of MBMS in GERAN** |  | 892d? | 2001-08-30 A | 2005-01-28 A | 100% | 2001-08-30 | 2005-01-28 | 892d? |  | GP | 71040h | 71040h | MBMS-GERAN |  |  | Rel-6 | Paolo |  |  |
| 1433 | 28.6.1 | Impact on the logical and physical channels |  | 631d | 2002-08-30 A | 2005-01-28 A | 100% | 2002-08-30 | 2005-01-28 | 631d | finish no earlier than 2005-01-28 | GP | 5048h | 5048h | MBMS-GERAN |  |  | Rel-6 | Paolo |  |  |
| 1434 | 28.6.4 | Re-synchronisation at cell change |  | 631d | 2002-08-30 A | 2005-01-28 A | 100% | 2002-08-30 | 2005-01-28 | 631d | finish no earlier than 2005-01-28 | G2 | 5048h | 5048h | MBMS-GERAN |  |  | Rel-6 | Gert |  |  |
| 1435 | 438.7.3 | Simultaneous support of MBMS services |  | 631d? | 2002-08-30 A | 2005-01-28 A | 100% | 2002-08-30 | 2005-01-28 | 631d? | finish no earlier than 2005-01-28 | GP | 5048h | 5048h | MBMS-GERAN |  |  | Rel-6 | Paolo |  |  |
| 1436 | 438.7.4 | Simultaneous support of MBMS and non-MBMS services |  | 892d? | 2001-08-30 A | 2005-01-28 A | 100% | 2001-08-30 | 2005-01-28 | 892d? | finish no earlier than 2005-01-28 | GP | 7136h | 7136h | MBMS-GERAN |  |  | Rel-6 | Paolo |  |  |
| 1437 | 438.7.5 | Resynchronisation at cell change |  | 892d? | 2001-08-30 A | 2005-01-28 A | 100% | 2001-08-30 | 2005-01-28 | 892d? | finish no earlier than 2005-01-28 | GP | 7136h | 7136h | MBMS-GERAN |  |  | Rel-6 | Paolo |  |  |
| 1438 | 28.6.5 | Decision making process between point-to-point or pont-to-multipoint configurations |  | 631d | 2002-08-30 A | 2005-01-28 A | 100% | 2002-08-30 | 2005-01-28 | 631d | finish no earlier than 2005-01-28 | GP | 5048h | 5048h | MBMS-GERAN |  |  | Rel-6 | Paolo |  |  |
| 1439 | 28.6.6 | MBMS channel allocations procedures to multiple MSs |  | 631d | 2002-08-30 A | 2005-01-28 A | 100% | 2002-08-30 | 2005-01-28 | 631d | finish no earlier than 2005-01-28 | GP | 5048h | 5048h | MBMS-GERAN |  |  | Rel-6 | Paolo |  |  |
| 1440 | 28.6.7 | Changes to the Gb interface |  | 631d | 2002-08-30 A | 2005-01-28 A | 100% | 2002-08-30 | 2005-01-28 | 631d | finish no earlier than 2005-01-28 | GP | 5048h | 5048h | MBMS-GERAN |  |  | Rel-6 | Paolo |  |  |
| 1441 | 28.6.8 | GERAN specific changes to the Iu-ps interface |  | 631d | 2002-08-30 A | 2005-01-28 A | 100% | 2002-08-30 | 2005-01-28 | 631d | finish no earlier than 2005-01-28 | GP | 5048h | 5048h | MBMS-GERAN |  |  | Rel-6 | Paolo |  |  |
| 1442 | 28.6.9 | Interaction between MBMS and Iu-flex |  | 631d | 2002-08-30 A | 2005-01-28 A | 100% | 2002-08-30 | 2005-01-28 | 631d | finish no earlier than 2005-01-28 | GP | 5048h | 5048h | MBMS-GERAN |  |  | Rel-6 | Paolo |  |  |
| 1443 | 28.6.10 | Security aspects |  | 631d | 2002-08-30 A | 2005-01-28 A | 100% | 2002-08-30 | 2005-01-28 | 631d | finish no earlier than 2005-01-28 | GP | 5048h | 5048h | MBMS-GERAN |  |  | Rel-6 | Paolo |  |  |
| 1444 | 438.7.12 | MBMS-GERAN - MS conformance tests |  | 786d? | 2002-01-25 A | 2005-01-28 A | 100% | 2002-01-25 | 2005-01-28 | 786d? | finish no earlier than 2005-01-28 | G3new | 6288h | 6288h | MBMS-GERAN |  |  | Rel-6 | Ingbert |  |  |
| 1445 | 438.7.13 | Deleted - MS conformance tests - G5 | milestone | 0d? | 2003-06-27 A | 2003-06-27 A | 100% | 2003-06-27 | 2003-06-27 | 0d? | start no earlier than 2003-06-27 | G5 |  |  | MBMS-GERAN |  |  | Rel-6 | Paolo | GP-19 |  |

Notes:
- 1411: -
- 1412: -
- 1413: -
- 1414: -
- 1415: -
- 1416: -
- 1417: -
- 1418: -
- 1419: -
- 1420: -
- 1421: Title renamed at SP#13
- 1422: This may or may not be a separate stage 1. In the meantime, CRs are proposed for 22.101
- 1423: -
- 1424: -
- 1425: -
- 1426: -
- 1427: Was "Introduction of MBMS in RAN" before RP#25. Created w/o WIDS after RAN approved the WT for RF aspects.Take WIDS from the parent BB
- 1428: Approved at RP#25 as RP-040370
- 1429: -
- 1430: -
- 1431: WID approved SP#17. 2004-12: Expected completion March 2005
- 1432: -
- 1433: -
- 1434: -
- 1435: -
- 1436: -
- 1437: -
- 1438: -
- 1439: -
- 1440: -
- 1441: -
- 1442: -
- 1443: -
- 1444: -
- 1445: -

| ID | WBS | Task | Type | Duration | Start | Finish | Complete | Baseline start | Baseline finish | Baseline duration | Constraint | Deadline | Resources | Work | Actual work | Text1 | Text6 | Text8 | Text4 | Text5 | Text10 | Text12 |
| --- | --- | --- | --- | --- | --- | --- | --- | --- | --- | --- | --- | --- | --- | --- | --- | --- | --- | --- | --- | --- | --- | --- |
| 1446 | 28.1 | **MBMS User Services** |  | 743d? | 2003-05-13 A | 2006-03-16 A | 100% | 2003-05-13 | 2006-03-16 | 743d? |  |  | S1 | 13576h | 13576h | MBMS | Rel-6 | Alain |  |  |  |  |
| 1447 | 28.1 | MBMS User Services Stage 1 |  | 233d | 2003-05-13 A | 2004-04-01 A | 100% | 2003-05-13 | 2004-04-01 | 233d | start no earlier than 2003-05-13 |  | S1 | 1864h | 1864h | MBMS | Rel-6 | Alain |  |  |  |  |
| 1448 | 438.8.2 | Definition of MBMS user services, media codecs, formats and transport/application protocols using MBMS |  | 721d? | 2003-06-12 A | 2006-03-16 A | 100% | 2003-06-12 | 2006-03-16 | 721d? | finish no earlier than 2006-03-16 |  | S4 | 5768h | 5768h | MBMS-TSMBMS | Rel-6 | Paolo | Nokia | igor.curcio@nokia.com |  |  |
| 1449 | 438.9 | MBMS charging |  | 108d? | 2005-01-11 A | 2005-06-09 A | 100% | 2005-01-11 | 2005-06-09 | 108d? | start no earlier than 2005-01-11 |  | S5 | 864h | 864h | MBMS-CH | Rel-6 | Dionisio |  |  |  |  |
| 1450 | 438.10 | **MBMS UE Conformance Testing** |  | 521d? | 2006-03-10 A | 2008-03-07 A | 100% | 2006-03-10 | 2008-03-07 | 521d? |  |  | R5,T1 | 17200h | 17200h | MBMS-UEConTest | Rel-6 | Ingbert |  |  |  |  |
| 1451 | 16.5.1 | RF/RRM Conformance Test Aspects – MBMS (FDD) |  | 461d | 2006-06-02 A | 2008-03-07 A | 100% | 2006-06-02 | 2008-03-07 | 461d | finish no earlier than 2008-03-07 | 2006-06-02 | R5,T1 | 3688h | 3688h | MBMS-RAN-RF_Test | Rel-6 | Ingbert | Ericsson | leif.mattisson@ericsson.com | Fri 11/03/05 |  |
| 1452 | 438.10.2 | Conformance Test Aspects - MBMS for 3.84 Mcps and 7.68 Mcps TDD |  | 318d? | 2006-09-20 A | 2007-12-07 A | 100% | 2006-09-20 | 2007-12-07 | 318d? | finish no earlier than 2007-12-07 |  | R5,T1 | 2544h | 2544h | MBMS-UEConTest_TDH | Rel-6 | Ingbert | IPWireless | Timothy Speight (tspeight@ipwireless.com) |  |  |
| 1453 | 438.10.3 | Signalling Conformance Test Aspects – MBMS for LCR TDD |  | 318d? | 2006-09-20 A | 2007-12-07 A | 100% | 2006-09-20 | 2007-12-07 | 318d? | finish no earlier than 2007-12-07 |  | R5,T1 | 2544h | 2544h | MBMS-UEConTest_SIGTDL | Rel-6 | Ingbert | DATANG | zhaojian@datangmobile.cn |  |  |
| 1454 | 438.10.4 | Conformance Test Aspects – MBMS |  | 396d? | 2006-03-10 A | 2007-09-14 A | 100% | 2006-03-10 | 2007-09-14 | 396d? | finish no earlier than 2007-09-14 |  | R5,T1 | 3168h | 3168h | MBMS_Test | Rel-6 | Ingbert | Qualcomm Europe | Shubhang Vora (svora@qualcomm.com) |  |  |
| 1455 | 16.5.1 | Conformance Test Aspects - 1.28 Mcps TDD MBMS RF/RRM |  | 136d | 2007-06-01 A | 2007-12-07 A | 100% | 2007-06-01 | 2007-12-07 | 136d | finish no earlier than 2007-12-07 | 2006-06-02 | R5,T1 | 1088h | 1088h | MBMS-UEConTest_RFTDL | Rel-6 | Ingbert | Datang Mobile | chenxiaozhong@datangmobile.cn | Fri 11/03/05 |  |
| 1456 | 29 | **Speech Recognition and Speech Enabled Services** |  | 1105d? | 2001-10-08 A | 2005-12-30 A | 100% | 2001-10-08 | 2005-12-30 | 1105d? |  |  | S1 | 20176h | 20176h | SRSES | Rel-6 | Alain |  |  |  |  |
| 1457 | 29.1 | Speech Enabled Services Based on Distributed Speech Recognition (DSR) |  | 115d | 2001-10-08 A | 2002-03-15 A | 100% | 2001-10-08 | 2002-03-15 | 115d | finish no earlier than 2002-03-15 |  | S1 | 920h | 920h | DSR | Rel-6 | Alain | Qualcomm Europe | Dwilliams@qualcomm.com |  |  |
| 1458 | 29.2 | TR on Architectural impacts |  | 212d | 2003-05-12 A | 2004-03-02 A | 100% | 2003-05-12 | 2004-03-02 | 212d | finish no earlier than 2004-03-02 |  | S2 | 1696h | 1696h | SRSES | Rel-6 |  |  |  |  |  |
| 1459 | 439.3 | Codec Work to Support Speech Recognition Framework for Automated Voice Services |  | 568d? | 2002-10-15 A | 2004-12-16 A | 100% | 2002-10-15 | 2004-12-16 | 568d? | finish no earlier than 2004-12-16 |  | S4 | 4544h | 4544h | SRSES-Codec | Rel-6 | Paolo | Motorola | David Pearce (bdp003@motorola.com) |  |  |
| 1460 | 439.4 | Multimodal support |  | 522d? | 2004-01-01 A | 2005-12-30 A | 100% | 2004-01-01 | 2005-12-30 | 522d? | finish no earlier than 2005-06-30 |  | OMA | 4176h | 4176h | SRSES | Rel-6 |  |  | OMA-LIAISON@mail.openmobilealliance.org | SP-24 |  |
| 1461 | 439.5 | Deleted - SES codec negotiation at Session Description Protocol (SDP) | milestone | 0d? | 2003-06-04 A | 2003-06-04 A | 100% | 2003-06-04 | 2003-06-04 | 0d? | start no earlier than 2003-06-04 |  | N1 |  |  | SRSES | Rel-6 | Frederic |  |  |  | NP-23 |
| 1462 | 30 | **Generic User Profile Rel-6** |  | 889d | 2001-10-08 A | 2005-03-03 A | 100% | 2001-10-08 | 2005-03-03 | 889d |  |  | S1 | 24295.8h | 24295.8h | GUP | Rel-6 | Alain |  |  |  |  |
| 1463 | 30.1 | Stage 1 - Requirements |  | 430d | 2001-10-08 A | 2003-05-30 A | 100% | 2001-10-08 | 2003-05-30 | 430d | finish no earlier than 2002-12-09 |  | S1 | 3440h | 3440h | GUP | Rel-6 | Alain | T-Mobile | kurt.bischinger@t-mobile.at |  |  |
| 1464 | 30.3 | Stage 2 - Architecture |  | 355d | 2002-01-28 A | 2003-06-06 A | 100% | 2002-01-28 | 2003-06-06 | 355d | finish no earlier than 2003-06-06 |  | S2 | 2840h | 2840h | GUP | Rel-6 | Maurice | Nokia | harri.o.koskinen@nokia.com |  |  |
| 1465 | 30.2 | Stage 2 - Data Description Method |  | 586d | 2002-12-05 A | 2005-03-03 A | 100% | 2002-12-05 | 2005-03-03 | 586d | finish no earlier than 2005-03-03 |  | N4 | 4688h | 4688h | GUP | Rel-6 | Kimmo | T-Mobile | kurt.bischinger@t-mobile.at |  |  |
| 1466 | 30.5 | Stage 3 - Network |  | 468.98d | 2003-05-19 A | 2005-03-03 A | 100% | 2003-05-19 | 2005-03-03 | 468.98d | finish no earlier than 2005-03-03 |  | N4 | 3751.83h | 3751.83h | GUP | Rel-6 | Kimmo |  |  |  |  |
| 1467 | 30.6 | Security Aspects |  | 308d | 2002-07-16 A | 2003-09-18 A | 100% | 2002-07-16 | 2003-09-18 | 308d | finish no earlier than 2003-09-18 |  | S3 | 2464h | 2464h | GUP | Rel-6 | Dionisio | Lucent | Owen, Bradley (bvowen@lucent.com) |  |  |
| 1468 | 31 | **Digital Rights Management** |  | 690d? | 2001-10-08 A | 2004-05-28 A | 100% | 2001-10-08 | 2004-05-28 | 690d? |  |  | S1 | 10152h | 10152h | DRM | Rel-6 | Alain |  |  |  |  |
| 1469 | 31.1 | Requirements |  | 179d | 2001-10-08 A | 2002-06-13 A | 100% | 2001-10-08 | 2002-06-13 | 179d | finish no earlier than 2002-06-13 |  | S1 | 1432h | 1432h | DRM | Rel-6 | Alain | Openwave | nicholas.wood@openwave.com |  |  |
| 1470 | 441.2 | Stage 2 |  | 107d? | 2004-01-01 A | 2004-05-28 A | 100% | 2004-01-01 | 2004-05-28 | 107d? | finish no earlier than 2004-05-28 |  | OMA | 856h | 856h | DRM | Rel-6 |  |  | OMA-LIAISON@mail.openmobilealliance.org | SP-24 |  |
| 1471 | 441.3 | Stage 3 |  | 107d? | 2004-01-01 A | 2004-05-28 A | 100% | 2004-01-01 | 2004-05-28 | 107d? | finish no earlier than 2004-05-28 |  | OMA | 856h | 856h | DRM | Rel-6 |  |  | OMA-LIAISON@mail.openmobilealliance.org | SP-24 |  |
| 1472 | 31.3 | Security |  | 186d | 2002-06-17 A | 2003-03-03 A | 100% | 2002-06-17 | 2003-03-03 | 186d | finish no earlier than 2003-03-03 |  | OMA | 1488h | 1488h | DRM | Rel-6 |  |  |  |  |  |
| 1473 | 441.5 | Deleted - Monitoring of Stages 2 and 3 progress (actual work to be done by OMA) | milestone | 0d? | 2003-03-21 A | 2003-03-21 A | 100% | 2003-03-21 | 2003-03-21 | 0d? | start no earlier than 2002-08-19 |  | S1 |  |  | DRM | Rel-6 | Alain |  |  |  | SP-19 |

Notes:
- 1446: - / Text3: 22.246
- 1447: - / Text3: 22.246
- 1448: TR26.946 tbc by March 06 / Text3: 26.346, 26.936, 26.946
- 1449: SP#28 06/2005 completed / Text3: 32.273
- 1450: BB place holder for a number of RAN5 Tasks. Moved in from the Stoyan/Testing WP / Text3: 34.108, 34.109, 34.121-1, 34.121-2, 34.122, 34.123-1, 34.123-2, 34.123-3
- 1451: TS 34.109 is under RAN2; RAN5 need to identify possible new requirements on UE test loop functionality to enable testing / Text3: 34.108, 34.109, 34.121-1, 34.121-2
- 1452: - / Text3: 34.108, 34.122, 34.123-1, 34.123-2, 34.123-3
- 1453: - / Text3: 34.108, 34.123-1, 34.123-2, 34.123-3
- 1454: - / Text3: 34.108, 34.123-1, 34.123-2, 34.123-3
- 1455: - / Text3: 34.108, 34.109, 34.122
- 1456: -
- 1457: - / Text3: 22.941, 23.207, 22.243
- 1458: - / Text3: 23.877
- 1459: - / Text3: 26.235, 26.236, 26.243, 26.177, 26.943
- 1460: -
- 1461: Abandoned NP-23
- 1462: -
- 1463: - / Text3: 22.240, 22.228
- 1464: - / Text3: 23.240
- 1465: TR approved in CN#26 / Text3: 23.241
- 1466: 17 May no activity in CN4............ / Text3: 29.240
- 1467: WID approved SP#17. SA WG3 progress slow, depends on progress in other groups. / Text3: 33.102, 33.203, 33.210
- 1468: Foreseen start and completion dates introduced by MCC (no indication at all on the WID)
- 1469: -
- 1470: -
- 1471: -
- 1472: SA3 acknowledge role in WI at SA3#20. Active contribution S3#24, S3#25. S3 WID approved SP#17
- 1473: Replaced by UID 60005 and 60006

| ID | WBS | Task | Duration | Start | Finish | Complete | Baseline start | Baseline finish | Baseline duration | Constraint | Resources | Work | Actual work | Text1 | Text4 | Text5 | Text6 | Text8 | Text3 | Text10 |
| --- | --- | --- | --- | --- | --- | --- | --- | --- | --- | --- | --- | --- | --- | --- | --- | --- | --- | --- | --- | --- |
| 1474 | 32 | **WLAN-UMTS Interworking Rel-6** | 1495d? | 2000-01-03 A | 2005-09-22 A | 100% | 2000-01-03 | 2005-09-22 | 1495d? |  | S1 | 48472h | 48472h | WLAN | Telenor | frederic.paint@telenor.com | Rel-6 | Alain |  |  |
| 1475 | 32.1 | Technical Report | 901d? | 2000-01-03 A | 2003-06-13 A | 100% | 2000-01-03 | 2003-06-13 | 901d? | finish no earlier than 2003-06-13 | S1 | 7200h | 7200h | WLAN-TR | Telenor | frederic.paint@telenor.com | Rel-6 | Alain | 22.934, 22.101, 22.105 |  |
| 1476 | 442.2 | **Stage 1** | 375d? | 2003-01-06 A | 2004-06-11 A | 100% | 2003-01-06 | 2004-06-11 | 375d? |  | S1 | 3920h | 3920h | WLAN-TS | Telenor | frederic.paint@telenor.com | Rel-6 | Alain | 22.234 | SP-24 |
| 1477 | 442.2.1 | Global stage 1 | 375d? | 2003-01-06 A | 2004-06-11 A | 100% | 2003-01-06 | 2004-06-11 | 375d? | finish no earlier than 2004-06-11 | S1 | 3000h | 3000h | WLAN-TS | Telenor | frederic.paint@telenor.com | Rel-6 | Alain | 22.234 | SP-24 |
| 1478 | 32.2 | Architecture Definition for scenarii 2 and 3 | 571d | 2002-03-25 A | 2004-05-31 A | 100% | 2002-03-25 | 2004-05-31 | 571d | finish no earlier than 2004-05-31 | S2 | 4568h | 4568h | WLAN |  |  | Rel-6 | Maurice | 23.234 |  |
| 1479 | 32.3 | Security | 125d | 2002-09-30 A | 2003-03-21 A | 100% | 2002-09-30 | 2003-03-21 | 125d | finish no earlier than 2003-03-21 | S3 | 1000h | 1000h | WLAN | Ericsson | luis.lopez-soria@ece.ericsson.se | Rel-6 | Dionisio | 21.133, 33.106, 33.107, 33.108, 33.200, 33.203, 33.210 |  |
| 1480 | 442.5 | Stage 3 - CN4 aspects | 334d? | 2003-05-23 A | 2004-09-01 A | 100% | 2003-05-23 | 2004-09-01 | 334d? | finish no earlier than 2004-09-01 | N4 | 2672h | 2672h | WLAN-IW | Nokia | raquel.rodriguez@nokia.com | Rel-6 | Kimmo | 29.234, 29.061 |  |
| 1481 | 442.6 | Stage 3 - CN3 aspects (Wi Interface for Scenario 3) | 355d? | 2003-05-23 A | 2004-09-30 A | 100% | 2003-05-23 | 2004-09-30 | 355d? | start no earlier than 2003-05-23 | N3 | 2840h | 2840h | WLAN |  |  | Rel-6 | Gwiho | 29.161 | SP-24 |
| 1482 | 442.7 | Stage 3 for scenario 2 | 339d? | 2003-05-23 A | 2004-09-08 A | 100% | 2003-05-23 | 2004-09-08 | 339d? | finish no earlier than 2004-09-08 | N1 | 2712h | 2712h | WLAN |  |  | Rel-6 | Frederic |  |  |
| 1483 | 442.8 | Stage 3 for scenario 3 | 404d? | 2003-05-23 A | 2004-12-08 A | 100% | 2003-05-23 | 2004-12-08 | 404d? | finish no earlier than 2004-12-08 | N1 | 3232h | 3232h | WLAN |  |  | Rel-6 | Frederic |  | SP-24 |
| 1484 | 442.9 | WLAN charging | 655d? | 2003-03-21 A | 2005-09-22 A | 100% | 2003-03-21 | 2005-09-22 | 655d? | finish no earlier than 2005-09-22 | S5 | 5240h | 5240h | WLAN-CH | Nokia | Benni ALEXANDER | Rel-6 | Dionisio | 32.252 |  |
| 1485 | 442.10 | USIM enhancements for WLAN Interworking | 391d? | 2003-09-05 A | 2005-03-04 A | 100% | 2003-09-05 | 2005-03-04 | 391d? | finish no earlier than 2005-03-04 | T3 | 3128h | 3128h | WLAN | Axalto | Jabellan@axalto.com | Rel-6 |  |  |  |
| 1486 | 33 | **Priority Service** | 347d? | 2002-05-30 A | 2003-09-26 A | 100% | 2002-05-30 | 2003-09-26 | 347d? |  | S1 | 6464h | 6464h | PRIOR1 | Telcordia | Biplab K. Pramanik (bpramani@telcordia.com) | Rel-6 | Alain |  |  |
| 1487 | 33.1 | Feasibility Study | 1d | 2002-06-14 A | 2002-06-14 A | 100% | 2002-06-14 | 2002-06-14 | 1d | finish no earlier than 2002-06-14 | S1 | 8h | 8h | PRIOR-FS | Telcordia | Biplab K. Pramanik (bpramani@telcordia.com) | Rel-6 | Alain | 22.950 |  |
| 1488 | 33.2 | Stage 1 - Requirements | 340d | 2002-05-30 A | 2003-09-17 A | 100% | 2002-05-30 | 2003-09-17 | 340d | finish no earlier than 2003-09-17 | S1 | 2720h | 2720h | PRIOR-SR | Telcordia | James J. Garrahan (bpramani@telcordia.com) | Rel-6 | Alain |  |  |
| 1489 | 443.3 | Priority service implementation guide | 131d? | 2003-03-28 A | 2003-09-26 A | 100% | 2003-03-28 | 2003-09-26 | 131d? | finish no earlier than 2003-09-26 | S1 | 1048h | 1048h | PRIOR1 | Telcordia | Biplab K. Pramanik (bpramani@telcordia.com) | Rel-6 | Alain | 22.952 |  |
| 1490 | 34 | **Network Sharing** | 498d? | 2003-01-20 A | 2004-12-15 A | 100% | 2003-01-20 | 2004-12-15 | 498d? |  | S1 | 16608h | 16608h | NTShar | T-Mobile | michele.zarri@t-mobile.co.uk | Rel-6 | Alain |  |  |
| 1491 | 34.1 | Technical Report | 240d? | 2003-01-20 A | 2003-12-19 A | 100% | 2003-01-20 | 2003-12-19 | 240d? |  | S1 | 1920h | 1920h | NTShar-TR | T-Mobile | michele.zarri@t-mobile.co.uk | Rel-6 | Alain | 22.951 |  |
| 1492 | 444.2 | Stage 1 - CRs to implement Network Sharing | 240d? | 2003-01-20 A | 2003-12-19 A | 100% | 2003-01-20 | 2003-12-19 | 240d? | finish no earlier than 2003-12-19 | S1 | 1920h | 1920h | NTSharCR | T-Mobile | michele.zarri@t-mobile.co.uk | Rel-6 | Alain | 22.011, 22.101, 22.115, 22.129 |  |
| 1493 | 444.3 | Stage 2 | 372d? | 2003-02-27 A | 2004-07-30 A | 100% | 2003-02-27 | 2004-07-30 | 372d? | finish no earlier than 2004-07-30 | S2 | 2976h | 2976h | NTShar | T-Mobile | michele.zarri@t-mobile.co.uk | Rel-6 | Maurice | 23.002, 23.060, 23.221, 23.236, new 23.251 |  |
| 1494 | 444.4 | Network sharing - stage 3 | 404d? | 2003-05-23 A | 2004-12-08 A | 100% | 2003-05-23 | 2004-12-08 | 404d? | finish no earlier than 2004-12-08 | N1 | 3232h | 3232h | NTShar | T-Mobile | michele.zarri@t-mobile.co.uk | Rel-6 | Frederic | 23.008, 23.122, 24.007, 24.008, 29.018 |  |
| 1495 | 444.5 | Enhancement of the support of network sharing in the UTRAN | 324d | 2003-09-19 A | 2004-12-15 A | 100% | 2003-09-19 | 2004-12-15 | 324d | finish no earlier than 2004-12-15 | R2 | 2592h | 2592h | NTShar-UTRANEnh | TeliaSonera | Anders.Dahlen@TeliaSonera.com | Rel-6 | Joern | 25.401, 25.413, 25.331, 25.304 |  |
| 1496 | 35 | **QoS Improvements** | 628d? | 2002-07-15 A | 2004-12-08 A | 100% | 2002-07-15 | 2004-12-08 | 628d? |  | S2,N3 | 13128h | 13128h | QoS1 | Nokia |  | Rel-6 | Maurice | 23.107, 23.207, 23.221 |  |
| 1497 | 35.1 | FS on Dynamic Policy control enhancements for end-to-end QoS | 465d | 2002-07-15 A | 2004-04-23 A | 100% | 2002-07-15 | 2004-04-23 | 465d | finish no earlier than 2004-04-23 | S2 | 3720h | 3720h | QoS1 | Nortel | Claire Mousset | Rel-6 | Maurice | 23.917 withdrawn (Contents all in 23.207) |  |
| 1498 | 445.2 | Definition of the Gq interface | 214d? | 2003-07-01 A | 2004-04-23 A | 100% | 2003-07-01 | 2004-04-23 | 214d? | finish no earlier than 2004-04-23 | S2 | 1712h | 1712h | QoS1 |  | Janne Rinne | Rel-6 |  | 23.207 |  |
| 1499 | 445.3 | Gq interface specification for Dynamic Policy control enhancements – Stage 3 | 334d | 2003-08-29 A | 2004-12-08 A | 100% | 2003-08-29 | 2004-12-08 | 334d | finish no earlier than 2004-12-08 | N3 | 2672h | 2672h | QoS1 | Nokia | Anna.Sillanpaai@nokia.com | Rel-6 | Gwiho | 29.207, 29.208, 29.209 |  |

Notes:
- 1474: -
- 1475: -
- 1476: -
- 1477: -
- 1478: -
- 1479: Active contribution S3#24, S3#25. WID approved SP#17
- 1480: WID approved at CN#19
- 1481: -
- 1482: -
- 1483: -
- 1484: SP#28: delayed 09/2005. WT also under SA5 BB 35017 Charging Management for Bearer level
- 1485: -
- 1486: -
- 1487: -
- 1488: -
- 1489: -
- 1490: -
- 1491: -
- 1492: -
- 1493: -
- 1494: -
- 1495: -
- 1496: -
- 1497: -
- 1498: -
- 1499: [DAB - 25.05.04] - Delayed to Sept - possibly Dec 2004

| ID | WBS | Task | Type | Duration | Start | Finish | Complete | Baseline start | Baseline finish | Baseline duration | Constraint | Resources | Work | Actual work | Text1 | Text4 | Text5 | Text6 | Text8 | Text10 | Text12 |
| --- | --- | --- | --- | --- | --- | --- | --- | --- | --- | --- | --- | --- | --- | --- | --- | --- | --- | --- | --- | --- | --- |
| 1500 | 36 | **Subscriber certificates** |  | 728d? | 2002-02-25 A | 2004-12-08 A | 100% | 2002-02-25 | 2004-12-08 | 728d? |  | S3,S2,N1,N4,T3,OMA | 12888h | 12888h | SEC1-SC | Nokia | valtteri.niemi@nokia.com | Rel-6 | Dionisio |  |  |
| 1501 | 36.1 | Stage 1 |  | 144d | 2002-02-25 A | 2002-09-12 A | 100% | 2002-02-25 | 2002-09-12 | 144d | finish no earlier than 2002-09-12 | S3 | 1152h | 1152h | SEC1-SC | Nokia | valtteri.niemi@nokia.com | Rel-6 | Dionisio |  |  |
| 1502 | 36.2 | Architecture review |  | 24d | 2002-10-14 A | 2002-11-14 A | 100% | 2002-10-14 | 2002-11-14 | 24d | finish no earlier than 2002-11-14 | S2 | 192h | 192h | SEC1-SC | Nokia |  | Rel-6 | Maurice |  |  |
| 1503 | 446.3 | Stage 3 |  | 313d? | 2003-09-19 A | 2004-11-30 A | 100% | 2003-09-19 | 2004-11-30 | 313d? | finish no earlier than 2004-11-30 | N4,T3 | 2504h | 2504h | SEC1-SC | Nokia | Lauri Laitinen | Rel-6 | Kimmo |  |  |
| 1504 | 446.4 | Stage 3 Ua & Ub interfaces |  | 288d? | 2003-11-03 A | 2004-12-08 A | 100% | 2003-11-03 | 2004-12-08 | 288d? | finish no earlier than 2004-12-08 | N1 | 2304h | 2304h | SEC1-SC | Nokia |  | Rel-6 | Frederic |  |  |
| 1505 | 446.5 | OMA dependencies on Subscriber certificates |  | 114d? | 2004-01-01 A | 2004-06-08 A | 100% | 2004-01-01 | 2004-06-08 | 114d? | finish no earlier than 2004-06-08 | OMA | 912h | 912h | SEC1-SC | Nokia | OMA-LIAISON@mail.openmobilealliance.org | Rel-6 |  | SP-24 |  |
| 1506 | 447 | **Rel-6 OSA enhancements** |  | 616d? | 2002-10-31 A | 2005-03-10 A | 100% | 2002-10-31 | 2005-03-10 | 616d? |  | N5 | 22576h | 22576h | OSA3 | Alcatel | Chelo.Abarca@alcatel.fr | Rel-6 | Kimmo |  |  |
| 1507 | 447.1 | Scope of the Open Service Access Release 6 |  | 66d? | 2003-03-28 A | 2003-06-27 A | 100% | 2003-03-28 | 2003-06-27 | 66d? | finish no earlier than 2003-06-27 | S1 | 528h | 528h | OSA3 |  |  | Rel-6 | Alain |  |  |
| 1508 | 447.2 | OSA Stage 2 |  | 150d? | 2004-08-13 A | 2005-03-10 A | 100% | 2004-08-13 | 2005-03-10 | 150d? | finish no earlier than 2005-03-10 | N5 | 1200h | 1200h | OSA3 |  |  | Rel-6 | Kimmo |  |  |
| 1509 | 447.3 | Multi Media Messaging function |  | 487d? | 2002-10-31 A | 2004-09-10 A | 100% | 2002-10-31 | 2004-09-10 | 487d? | finish no earlier than 2004-09-10 | N5 | 3896h | 3896h | OSA3 |  |  | Rel-6 | Kimmo |  |  |
| 1510 | 447.4 | Policy management extensions |  | 292d? | 2002-10-31 A | 2003-12-12 A | 100% | 2002-10-31 | 2003-12-12 | 292d? | finish no earlier than 2003-12-12 | N5 | 2336h | 2336h | OSA3 |  |  | Rel-6 | Kimmo |  |  |
| 1511 | 447.5 | TS on Presence and Availability Management (from the PRESNC WI) |  | 367d? | 2002-10-31 A | 2004-03-26 A | 100% | 2002-10-31 | 2004-03-26 | 367d? | finish no earlier than 2004-03-26 | N5 | 2936h | 2936h | OSA3 |  |  | Rel-6 | Kimmo |  |  |
| 1512 | 447.6 | OSA interfaces at different levels of abstractions (Parlay X, Web services) |  | 305d? | 2003-07-14 A | 2004-09-10 A | 100% | 2003-07-14 | 2004-09-10 | 305d? | finish no earlier than 2004-09-10 | N5 | 2440h | 2440h | OSA3 |  |  | Rel-6 | Kimmo |  |  |
| 1513 | 447.7 | Introduction of migration support mechanism |  | 290d? | 2002-10-31 A | 2003-12-10 A | 100% | 2002-10-31 | 2003-12-10 | 290d? | finish no earlier than 2003-12-12 | N5 | 2320h | 2320h | OSA3 |  |  | Rel-6 | Kimmo |  |  |
| 1514 | 447.8 | Framework Function for Federation |  | 225d? | 2003-02-03 A | 2003-12-12 A | 100% | 2003-02-03 | 2003-12-12 | 225d? | finish no earlier than 2003-12-12 | N5 | 1800h | 1800h | OSA3 |  |  | Rel-6 | Kimmo |  |  |
| 1515 | 447.9 | OMA potential overlaps with 3GPP OSA Stage 3 (Web services) |  | 196d? | 2003-12-18 A | 2004-09-16 A | 100% | 2003-12-18 | 2004-09-16 | 196d? | start no earlier than 2003-12-18 | OMA | 1568h | 1568h | OSA3 |  |  | Rel-6 |  | SP-24 |  |
| 1516 | 447.10 | Deleted - TR on Presence and Availability Management (from the PRESNC WI) | milestone | 0d? | 2004-09-17 A | 2004-09-17 A | 100% | 2004-09-17 | 2004-09-17 | 0d? | start no earlier than 2004-09-17 | N5 |  |  | OSA3 |  |  | Rel-6 | Kimmo |  | NP-24 |
| 1517 | 39 | **Addition of frequency bands to GSM (TAPS)** |  | 676d | 2002-06-28 A | 2005-01-28 A | 100% | 2002-06-28 | 2005-01-28 | 676d |  | GP | 16640h | 16640h | TAPS | Nokia | Torben Themsen | Rel-6 | Paolo |  |  |
| 1518 | 39.1 | **Addition of frequency bands to GSM – Changes to core specs** |  | 26d | 2002-11-15 A | 2002-12-20 A | 100% | 2002-11-15 | 2002-12-20 | 26d |  | G1 | 416h | 416h | TAPS-Specs | Nokia | Torben Themsen | Rel-6 | Paolo |  |  |
| 1519 | 39.1.1 | Changes to core specs |  | 26d | 2002-11-15 A | 2002-12-20 A | 100% | 2002-11-15 | 2002-12-20 | 26d | finish no earlier than 2002-12-20 | G1 | 208h | 208h | TAPS-Specs | Nokia | Torben Themsen | Rel-6 | Paolo |  |  |
| 1520 | 39.2 | **Deleted - Addition of frequency bands to GSM – Changes for conformance tests** |  | 676d | 2002-06-28 A | 2005-01-28 A | 100% | 2002-06-28 | 2005-01-28 | 676d |  | G4 | 10816h | 10816h | TAPS-Conf | Nokia | Torben Themsen | Rel-6 | Paolo |  | GP-23 |
| 1521 | 39.2.1 | Deleted - 51.010-1 Add testing |  | 676d | 2002-06-28 A | 2005-01-28 A | 100% | 2002-06-28 | 2005-01-28 | 676d | finish no earlier than 2005-01-28 | G4 | 5408h | 5408h | TAPS-Conf | Nokia | Torben Themsen | Rel-6 | Paolo |  | GP-23 |
| 1522 | 40 | **Seamless support of streaming services in A/Gb mode** |  | 1426d? | 2000-01-03 A | 2005-06-17 A | 100% | 2000-01-03 | 2005-06-17 | 1426d? |  | GP | 53096h | 53096h | SSStrea | Vodafone | José Luis Carrizo Martínez | Rel-6 | Paolo |  |  |
| 1523 | 40.1 | **Identification of requirements for streaming** |  | 46d? | 2003-06-27 A | 2003-08-29 A | 100% | 2003-06-27 | 2003-08-29 | 46d? |  | G1 | 736h | 736h | SSStrea | Vodafone | José Luis Carrizo Martínez | Rel-6 | Paolo |  |  |
| 1524 | 449.1.1 | Requirements |  | 46d? | 2003-06-27 A | 2003-08-29 A | 100% | 2003-06-27 | 2003-08-29 | 46d? | finish no earlier than 2003-08-29 | G1 | 368h | 368h | SSStrea | Vodafone | José Luis Carrizo Martínez | Rel-6 | Paolo |  |  |

Notes:
- 1500: Approved at SP#14. May require BBs from CN1, CN4, SA5 and T3
- 1501: Contribution received S3#24, S3#25 / Text3: 33.220, 33.221, 33.222, 33.246
- 1502: -
- 1503: Finished in CN4#26 / Text3: 23.003, 23.008, 29.109, 29.230, T3 31.102, 31.103, 31.111
- 1504: - / Text3: 24.109
- 1505: Updated according to SP-040420
- 1506: CN#25: Updated WID NP-040351 replaces NP-040144. / Text3: 22.127, 23.198, 29.198, 29.199, 29.998
- 1507: -
- 1508: Inherited by CN5 from SA2 at TSG#25 Sep 2004. SA2's 23.127 (OSA/VHE Stage 2) replaced from Rel-6 onwards by a new CN5 TS 23.198 (Stage 2 OSA-only). / Text3: 23.198 OSA Stage 2-ONLY replaces 23.127 (OSA/VHE) from Rel-6 onwards
- 1509: - / Text3: 29.198-15
- 1510: - / Text3: 29.198, 29.998
- 1511: N5#26: Split WI into TS & TR. / Text3: 29.198-14
- 1512: - / Text3: 29.199
- 1513: - / Text3: 29.198, 29.998
- 1514: - / Text3: 29.198, 29.998
- 1515: TSG#25 Approved CN5 29.199 Parlay X Web services. Ongoing 3GPP/OMA co-ordination to avoid OMA producing conflicting/OVERLAPING specs (NP-040283/SP-040493).
- 1516: N5#26:TR Completion 09/04; consistent with CN1 delayed Rel-6 completion.
- 1517: -
- 1518: -
- 1519: -
- 1520: -
- 1521: -
- 1522: -
- 1523: -
- 1524: -

| ID | WBS | Task | Duration | Start | Finish | Complete | Baseline start | Baseline finish | Baseline duration | Constraint | Resources | Work | Actual work | Text1 | Text4 | Text5 | Text6 | Text8 | Text12 | Text3 |
| --- | --- | --- | --- | --- | --- | --- | --- | --- | --- | --- | --- | --- | --- | --- | --- | --- | --- | --- | --- | --- |
| 1525 | 40.2 | **Performance study of cell change mechanisms** | 956d? | 2000-01-03 A | 2003-08-29 A | 100% | 2000-01-03 | 2003-08-29 | 956d? |  | G1 | 30568h | 30568h | SSStrea | Vodafone | José Luis Carrizo Martínez | Rel-6 | Paolo |  |  |
| 1526 | 449.2.1 | Performance of NACC | 956d? | 2000-01-03 A | 2003-08-29 A | 100% | 2000-01-03 | 2003-08-29 | 956d? | finish no earlier than 2003-08-29 | G1 | 7640h | 7640h | SSStrea | Vodafone | José Luis Carrizo Martínez | Rel-6 | Paolo |  |  |
| 1527 | 449.2.2 | Performance of cell change in DTM for the PS domain | 956d? | 2000-01-03 A | 2003-08-29 A | 100% | 2000-01-03 | 2003-08-29 | 956d? | finish no earlier than 2003-08-29 | G1 | 7640h | 7640h | SSStrea | Vodafone | José Luis Carrizo Martínez | Rel-6 | Paolo |  |  |
| 1528 | 449.2.3 | Handover | 956d? | 2000-01-03 A | 2003-08-29 A | 100% | 2000-01-03 | 2003-08-29 | 956d? | finish no earlier than 2003-08-29 | G1 | 7640h | 7640h | SSStrea | Vodafone | José Luis Carrizo Martínez | Rel-6 | Paolo |  |  |
| 1529 | 40.3 | **Reduction of service interruption times and packet loss during mobility procedures** | 516d? | 2003-06-27 A | 2005-06-17 A | 100% | 2003-06-27 | 2005-06-17 | 516d? |  | G2 | 10800h | 10800h | SSStrea | Vodafone | José Luis Carrizo Martínez | Rel-6 | Gert |  |  |
| 1530 | 449.3.1 | optimizations of existing mechanisms/procedures | 106d? | 2003-06-27 A | 2003-11-21 A | 100% | 2003-06-27 | 2003-11-21 | 106d? | finish no earlier than 2003-11-21 | G2 | 848h | 848h | SSStrea | Vodafone | José Luis Carrizo Martínez | Rel-6 | Gert |  |  |
| 1531 | 449.3.2 | Inter-system NACC | 106d? | 2003-06-27 A | 2003-11-21 A | 100% | 2003-06-27 | 2003-11-21 | 106d? | finish no earlier than 2003-11-21 | G2 | 848h | 848h | SSStrea | Vodafone | José Luis Carrizo Martínez | Rel-6 | Gert |  |  |
| 1532 | 449.3.3 | PS Handover (within GERAN and between GERAN and UTRAN) | 516d? | 2003-06-27 A | 2005-06-17 A | 100% | 2003-06-27 | 2005-06-17 | 516d? | finish no earlier than 2003-11-21 | G2 | 4128h | 4128h | SSStrea | Vodafone | José Luis Carrizo Martínez | Rel-6 | Gert |  |  |
| 1533 | 449.3.4 | Dependency to other features | 106d? | 2003-06-27 A | 2003-11-21 A | 100% | 2003-06-27 | 2003-11-21 | 106d? | finish no earlier than 2003-11-21 | G2 | 848h | 848h | SSStrea | Vodafone | José Luis Carrizo Martínez | Rel-6 | Gert |  |  |
| 1534 | 40.5 | **Deleted - MS conformance testing** | 31d? | 2003-12-19 A | 2004-01-30 A | 100% | 2003-12-19 | 2004-01-30 | 31d? |  | G3new | 248h | 248h | SSStrea | Vodafone | José Luis Carrizo Martínez | Rel-6 | Ingbert | GP-27 |  |
| 1535 | 449.4.1 | Deleted - MS conformance tests | 31d? | 2003-12-19 A | 2004-01-30 A | 100% | 2003-12-19 | 2004-01-30 | 31d? | finish no earlier than 2004-01-30 | G4,G5 | 248h | 248h | SSStrea | Vodafone | José Luis Carrizo Martínez | Rel-6 | Ingbert | GP-27 |  |
| 1536 | 449.5 | GERAN A/Gb mode security enhancements | 612d? | 2002-09-26 A | 2005-01-28 A | 100% | 2002-09-26 | 2005-01-28 | 612d? | finish no earlier than 2005-01-28 | S3 | 4896h | 4896h | SSStrea | Vodafone | peter.howard@vodafone.com | Rel-6 | Dionisio |  | 33.102 |
| 1537 | 41 | Performance characterisation of default codecs for PS conversational multimedia application | 455d | 2002-09-13 A | 2004-06-10 A | 100% | 2002-09-13 | 2004-06-10 | 455d | finish no earlier than 2004-06-10 | S4 | 3640h | 3640h | CODCAR | Nokia | pasi.s.ojala@nokia.com | Rel-6 | Paolo |  | 26.935 |
| 1538 | 43 | Study on Privacy Capability | 83d | 2003-11-10 A | 2004-03-03 A | 100% | 2003-11-10 | 2004-03-03 | 83d | start no earlier than 2003-11-10 | S1 | 664h | 664h | PrivCap | Lucent | Liz Daniel | Rel-6 | Alain |  | 22.949 |
| 1539 | 44 | **OAM&P Rel-6** | 652d? | 2002-09-12 A | 2005-03-11 A | 100% | 2002-09-12 | 2005-03-11 | 652d? |  | S5 | 30819.5h | 30819.5h | OAM | Motorola |  | Rel-6 | Dionisio |  |  |
| 1540 | 44.1 | Principles, high level Requirements and Architecture | 526d | 2002-09-12 A | 2004-09-16 A | 100% | 2002-09-12 | 2004-09-16 | 526d | finish no earlier than 2004-09-16 | S5 | 4208h | 4208h | OAM-AR | Motorola |  | Rel-6 | Dionisio |  | 32.101, 32.102 |
| 1541 | 44.2 | Performance Management | 591d | 2002-09-12 A | 2004-12-16 A | 100% | 2002-09-12 | 2004-12-16 | 591d | finish no earlier than 2004-12-16 | S5 | 4728h | 4728h | OAM-PM | Nortel |  | Rel-6 | Dionisio |  | 32.401/3, 52.402, 32.411/2/3, 32.432/5/6 |
| 1542 | 44.4 | Network Infrastructure Management | 591d | 2002-09-12 A | 2004-12-16 A | 100% | 2002-09-12 | 2004-12-16 | 591d | finish no earlier than 2004-12-16 | S5 | 4728h | 4728h | OAM-NIM | Ericsson | thomas.tovinger@ericsson.com | Rel-6 | Dionisio |  | 32.15x, 32.3/6/7xy |
| 1543 | 44.5 | **Trace Management Rel-6** | 646d? | 2002-09-20 A | 2005-03-11 A | 100% | 2002-09-20 | 2005-03-11 | 646d? |  | S5 | 12061.9h | 12061.9h | OAM-Trace | Nokia | kari.t.ronka@nokia.com | Rel-6 | Dionisio |  | 32.42x, 52.008 |
| 1544 | 452.4.1 | Subscriber and UE trace management | 585d | 2002-09-20 A | 2004-12-16 A | 100% | 2002-09-20 | 2004-12-16 | 585d | finish no earlier than 2004-12-16 | S5 | 4680h | 4680h | OAM-Trace | Nokia | kari.t.ronka@nokia.com | Rel-6 | Dionisio |  | 32.421/2/3, 52.008 |
| 1545 | 452.4.2 | Subscriber and equipment trace in UTRAN | 268d? | 2003-06-06 A | 2004-06-15 A | 100% | 2003-06-06 | 2004-06-15 | 268d? | finish no earlier than 2004-06-15 | R3 | 2144h | 2144h | OAM-Trace-RAN | Nortel | Yann Sehedi (sehedic@nortelnetworks.com) | Rel-6 | Juha |  | 25.413, 25.420, 25.423 |
| 1546 | 452.4.3 | Trace Management, Stage3 | 193.74d? | 2004-06-09 A | 2005-03-11 A | 100% | 2004-06-09 | 2005-03-11 | 193.74d? | finish no earlier than 2005-03-11 | N4 | 1549.92h | 1549.92h | OAM-Trace | Nokia | seppo.kauntola@nokia.com | Rel-6 | Kimmo |  | 23.205, 29.232, 29.060, 29.002, 29.228 |
| 1547 | 453 | **Charging Management** | 666d? | 2002-11-21 A | 2005-06-09 A | 100% | 2002-11-21 | 2005-06-09 | 666d? |  | S5 | 55320h | 55320h | CH | T-Mobile | karl-heinz.nenner@t-mobile.de | Rel-6 | Dionisio |  | 32.2xy |
| 1548 | 453.1 | Charging architecture and principles | 390d? | 2003-03-21 A | 2004-09-16 A | 100% | 2003-03-21 | 2004-09-16 | 390d? | start no earlier than 2003-03-21 | S5 | 3120h | 3120h | CH |  |  | Rel-6 | Dionisio |  | 32.240 |
| 1549 | 453.2 | Charging Data Record (CDR) file format and transfer | 260d? | 2003-03-21 A | 2004-03-18 A | 100% | 2003-03-21 | 2004-03-18 | 260d? | start no earlier than 2003-03-21 | S5 | 2080h | 2080h | CH |  |  | Rel-6 | Dionisio |  | 32.297 |
| 1550 | 453.3 | CDR parameter description | 580d? | 2003-03-21 A | 2005-06-09 A | 100% | 2003-03-21 | 2005-06-09 | 580d? | finish no earlier than 2005-06-09 | S5 | 4640h | 4640h | CH |  |  | Rel-6 | Dionisio |  | 32.298 |
| 1551 | 453.4 | Diameter charging applications | 390d? | 2003-03-21 A | 2004-09-16 A | 100% | 2003-03-21 | 2004-09-16 | 390d? | start no earlier than 2003-03-21 | S5 | 3120h | 3120h | CH |  |  | Rel-6 | Dionisio |  | 32.299 |
| 1552 | 453.5 | Online Charging System (OCS) architecture study | 130d? | 2003-03-21 A | 2003-09-18 A | 100% | 2003-03-21 | 2003-09-18 | 130d? | start no earlier than 2003-03-21 | S5 | 1040h | 1040h | CH |  |  | Rel-6 | Dionisio |  | 32.815 |
| 1553 | 453.6 | OCS: Applications and interfaces | 455d? | 2003-03-21 A | 2004-12-16 A | 100% | 2003-03-21 | 2004-12-16 | 455d? | start no earlier than 2003-03-21 | S5 | 3640h | 3640h | CH |  |  | Rel-6 | Dionisio |  | 32.296 |

Notes:
- 1525: -
- 1526: -
- 1527: -
- 1528: -
- 1529: Completed at GERP#17
- 1530: -
- 1531: -
- 1532: -
- 1533: -
- 1534: Marked as stopped 10/2009
- 1535: Marked as stopped 10/2009
- 1536: Possible changes to 33.102 or new specification needed
- 1537: -
- 1538: -
- 1539: SP#26: Updated WID SP-040766 was SP-020445. Completion delayed 12/04->03/05 due to OAM-Trace in CN1/4.
- 1540: SP#25 09/2004 completed
- 1541: SP#26 12/2004 completed
- 1542: SP#26 12/2004 completed
- 1543: SP#26 12/2004 SA5 completed 12/04. Signalling Based Trace Activation for IMS (SIP) moved to Rel-7. Reason: CN1 cannot complete 24.229 trace without IETF dependency => estimate 05/2005.
- 1544: SP#26 12/2004 completed
- 1545: -
- 1546: -
- 1547: SP#28 Target 09/2005 for WLAN Charging 32.252
- 1548: SP#25 09/2004 completed
- 1549: SP#23 03/2004 completed
- 1550: SP#28 06/2005 completed
- 1551: SP#25 09/2004 completed
- 1552: SP#21 09/2003 completed
- 1553: SP#26 12/2004 completed

| ID | WBS | Task | Duration | Start | Finish | Complete | Baseline start | Baseline finish | Baseline duration | Constraint | Resources | Work | Actual work | Text1 | Text4 | Text5 | Text6 | Text8 | Text10 | Text12 |
| --- | --- | --- | --- | --- | --- | --- | --- | --- | --- | --- | --- | --- | --- | --- | --- | --- | --- | --- | --- | --- |
| 1554 | 453.7 | **Charging Management for Bearer level** | 390d? | 2003-03-21 A | 2004-09-16 A | 100% | 2003-03-21 | 2004-09-16 | 390d? |  | S5 | 11440h | 11440h | CH-BC | Nokia | Benni ALEXANDER | Rel-6 | Dionisio |  |  |
| 1555 | 453.7.1 | CS domain charging | 260d? | 2003-03-21 A | 2004-03-18 A | 100% | 2003-03-21 | 2004-03-18 | 260d? | start no earlier than 2003-03-21 | S5 | 2080h | 2080h | CH |  |  | Rel-6 | Dionisio |  |  |
| 1556 | 453.7.2 | PS domain charging | 390d? | 2003-03-21 A | 2004-09-16 A | 100% | 2003-03-21 | 2004-09-16 | 390d? | start no earlier than 2003-03-21 | S5 | 3120h | 3120h | CH |  |  | Rel-6 | Dionisio |  |  |
| 1557 | 453.7.3 | CDR transfer | 390d? | 2003-03-21 A | 2004-09-16 A | 100% | 2003-03-21 | 2004-09-16 | 390d? | start no earlier than 2003-03-21 | S5 | 3120h | 3120h | CH |  |  | Rel-6 | Dionisio |  |  |
| 1558 | 453.8 | Charging Management for the IMS | 455d? | 2003-03-21 A | 2004-12-16 A | 100% | 2003-03-21 | 2004-12-16 | 455d? | finish no earlier than 2004-12-16 | S5 | 3640h | 3640h | IMS2-CH | Ericsson | Patrik TEPPO | Rel-6 | Dionisio |  |  |
| 1559 | 453.9 | Charging Management for the Service domain | 580d? | 2003-03-21 A | 2005-06-09 A | 100% | 2003-03-21 | 2005-06-09 | 580d? | finish no earlier than 2005-06-09 | S5 | 4640h | 4640h | CH | Siemens | Gerald GÖRMER | Rel-6 | Dionisio |  |  |
| 1560 | 453.10 | **Overall architectural aspects of IP flow based bearer level charging** | 602d? | 2002-11-21 A | 2005-03-11 A | 100% | 2002-11-21 | 2005-03-11 | 602d? |  | S2 | 12632h | 12632h | CH-FBC |  |  | Rel-6 | Maurice |  |  |
| 1561 | 453.10.1 | Overall definition of FBC architecture | 334d? | 2002-11-21 A | 2004-03-02 A | 100% | 2002-11-21 | 2004-03-02 | 334d? | start no earlier than 2002-11-21 | S2 | 2672h | 2672h | CH-FBC |  |  | Rel-6 | Maurice | SP-24 |  |
| 1562 | 453.10.2 | Study on providing policy control with FBC | 130d? | 2004-02-02 A | 2004-07-30 A | 100% | 2004-02-02 | 2004-07-30 | 130d? | start no earlier than 2004-02-01 | S2 | 1040h | 1040h | CH-FBC |  |  | Rel-6 | Maurice | SP-24 |  |
| 1563 | 453.10.3 | Gx interface for flow based charging | 223d? | 2004-02-02 A | 2004-12-08 A | 100% | 2004-02-02 | 2004-12-08 | 223d? | start no earlier than 2004-02-01 | N3 | 1784h | 1784h | CH-FBC | Nokia | juha.a.rasanen@nokia.com | Rel-6 | Gwiho | SP-25 |  |
| 1564 | 453.10.4 | Rx interface for flow based charging | 290d? | 2004-02-02 A | 2005-03-11 A | 100% | 2004-02-02 | 2005-03-11 | 290d? | finish no earlier than 2005-03-11 | N3 | 2320h | 2320h | CH-FBC | Nortel | Javier Gonzalez Gallego | Rel-6 | Gwiho | SP-25 |  |
| 1565 | 13 | **Rel-6 UICC/USIM enhancements and interworking** | 1164d? | 2000-09-25 A | 2005-03-10 A | 100% | 2000-09-25 | 2005-03-10 | 1164d? |  | T3 | 43088h | 43088h | USAT1 |  |  | Rel-6 | Xavier |  |  |
| 1566 | 13.1 | **UICC API** | 777d | 2002-03-20 A | 2005-03-10 A | 100% | 2002-03-20 | 2005-03-10 | 777d |  | T3 | 15024h | 15024h | USAT1-API |  |  | Rel-6 | Xavier |  |  |
| 1567 | 13.1.1 | Java API Test specification | 59d | 2002-03-20 A | 2002-06-10 A | 100% | 2002-03-20 | 2002-06-10 | 59d | finish no earlier than 2002-09-20 | T3 | 472h | 472h | USAT1-API | Microelectrónica Española | Mario Pérez | Rel-6 | Xavier |  |  |
| 1568 | 454.1.2 | 2G/3G Java Card™ API based applet interworking | 255d | 2003-03-17 A | 2004-03-05 A | 100% | 2003-03-17 | 2004-03-05 | 255d | finish no earlier than 2004-02-19 | T3 | 2040h | 2040h | USAT1-API | Oberthur Card Systems | Stéphane Andrau | Rel-6 | Xavier |  |  |
| 1569 | 454.1.3 | (U)SIM API for Java Card Testing | 519d | 2003-03-17 A | 2005-03-10 A | 100% | 2003-03-17 | 2005-03-10 | 519d | finish no earlier than 2005-03-10 | T3 | 4152h | 4152h | USAT1-API | Axalto | Christophe Begassat (cbegassat@axalto.com) | Rel-6 | Xavier |  |  |
| 1570 | 13.1.2 | Deleted - Java API Test specification (TS 43.019 Rel-5) | 268d | 2002-05-30 A | 2003-06-09 A | 100% | 2002-05-30 | 2003-06-09 | 268d | finish no earlier than 2003-09-17 | T3 | 2144h | 2144h | USAT1-API | Microelectrónica Española | Mario Pérez | Rel-6 | Xavier |  | TP-20 |
| 1571 | 454.2 | **Rel-6 USIM toolkit enhancements** | 1160d? | 2000-09-25 A | 2005-03-04 A | 100% | 2000-09-25 | 2005-03-04 | 1160d? |  | T3 | 21848h | 21848h | USAT1-API-MULTOS | Aspects Software | Neil Livingston | Rel-6 | Xavier |  |  |
| 1572 | 454.2.1 | **C SIM API** | 525d | 2000-09-25 A | 2002-09-27 A | 100% | 2000-09-25 | 2002-09-27 | 525d |  | T3 | 9960h | 9960h | USAT1-API-MULTOS | Aspects Software | Neil Livingston | Rel-6 | Xavier |  |  |
| 1573 | 454.2.1.1 | Specification | 525d | 2000-09-25 A | 2002-09-27 A | 100% | 2000-09-25 | 2002-09-27 | 525d | finish no earlier than 2002-09-27 | T3 | 4200h | 4200h | USAT1-API-MULTOS | Aspects Software | Neil Livingston | Rel-6 | Xavier |  |  |
| 1574 | 454.2.1.2 | Test specification | 195d | 2001-01-01 A | 2001-09-28 A | 100% | 2001-01-01 | 2001-09-28 | 195d | finish no earlier than 2001-09-28 | T3 | 1560h | 1560h | USAT1-API-MULTOS | Aspects Software | Neil Livingston | Rel-6 | Xavier |  |  |
| 1575 | 454.2.2 | USIM application toolkit Conformance Test Specification for Mobile Equipments | 326d? | 2003-12-05 A | 2005-03-04 A | 100% | 2003-12-05 | 2005-03-04 | 326d? | start no earlier than 2003-12-05 | T3 | 2608h | 2608h | USAT1-API-MULTOS | Gemplus | Eric.laffont@gemplus.com | Rel-6 | Xavier |  |  |
| 1576 | 455 | **Packet Switched Streaming Services Rel-6** | 798d? | 2002-11-18 A | 2005-12-07 A | 100% | 2002-11-18 | 2005-12-07 | 798d? |  | S4,S1 | 13304h | 13304h | PSSrel6 | Ericsson | olle.franceschi@ericsson.com | Rel-6 | Paolo |  |  |
| 1577 | 455.1 | Stage 1 | 86d? | 2002-11-18 A | 2003-03-17 A | 100% | 2002-11-18 | 2003-03-17 | 86d? | finish no earlier than 2003-03-17 | S1 | 688h | 688h | PSSrel6 | Ericsson |  | Rel-6 | Alain |  |  |
| 1578 | 455.2 | Stage 3 | 779d? | 2002-12-13 A | 2005-12-07 A | 100% | 2002-12-13 | 2005-12-07 | 779d? | finish no earlier than 2005-12-07 | S4 | 6232h | 6232h | PSSrel6-Stage3 | Ericsson | olle.franceschi@ericsson.com | Rel-6 | Paolo |  |  |
| 1579 | 456 | AMR-WB extension for high audio quality | 779d | 2002-12-13 A | 2005-12-07 A | 100% | 2002-12-13 | 2005-12-07 | 779d | finish no earlier than 2005-12-07 | S4 | 6232h | 6232h | AMRWB+ | Nokia | janne.m.vainio@nokia.com | Rel-6 | Paolo |  |  |
| 1580 | 457 | Codec Enhancements for Packet Switched Conversational Multimedia Applications | 198d? | 2004-03-16 A | 2004-12-16 A | 100% | 2004-03-16 | 2004-12-16 | 198d? | finish no earlier than 2004-12-16 | S4 | 1584h | 1584h | CEPSCM | Nokia | miska.hannuksela@nokia.com | Rel-6 | Paolo |  |  |
| 1581 | 458 | 3G-324M Improvements | 198d? | 2004-03-16 A | 2004-12-16 A | 100% | 2004-03-16 | 2004-12-16 | 198d? | finish no earlier than 2004-12-16 | S4 | 1584h | 1584h | 3G-324MI | Ericsson | bo.burman@ericsson.com | Rel-6 | Paolo |  |  |
| 1582 | 459 | Single Antenna Receiver Interference Cancellation (SAIC) | 420.92d? | 2002-11-15 A | 2004-06-25 A | 100% | 2002-11-15 | 2004-06-25 | 420.92d? | finish no earlier than 2004-08-27 | GP,G1 | 3367.36h | 3367.36h | SAIC | Cingular | Marc Grant | Rel-6 | Paolo |  |  |

Notes:
- 1554: SP#28 Target 09/2005 for WLAN Charging 32.252
- 1555: SP#23 03/2004 completed / Text3: 32.250
- 1556: SP#25 09/2004 completed / Text3: 32.251
- 1557: SP#25 09/2004 completed / Text3: 32.295
- 1558: SP#26 12/2004 completed / Text3: 32.260
- 1559: SP#26: Updated WID SP-040778 was SP-030050. Target completion 06/2005. Consisting of MMS-CH, LCS-CH, WLAN-CH, POC-CH, MBMS-CH / Text3: 32.252, 32.270, 32.271, 32.272
- 1560: - / Text3: 23.125
- 1561: -
- 1562: -
- 1563: - / Text3: 29.210
- 1564: - / Text3: 29.209
- 1565: -
- 1566: 8/3/2001: test spec is based on R99 core spec, so deleted from Workplan
- 1567: -
- 1568: -
- 1569: - / Text3: 31.213
- 1570: MOVED to Rel-5 WP
- 1571: -
- 1572: - / Text3: 31.101, 31.102, 31.103, 31.111, 31.113, new 31.115, 31.116
- 1573: -
- 1574: -
- 1575: - / Text3: 31.124
- 1576: -
- 1577: 2nd resp SA4 / Text3: 22.233
- 1578: TR tbc by Sept. 05 / Text3: 26.233, 26.234, 26.244, 26.245, 26.246, 26.401, 26.402, 26.403, 26.404, 26.405, 26.406, 26.410, 26.411, 26.412, 26.273, 26.290, 26.304, 26.412, 26.274, 26.936
- 1579: TR tbc by Sept. 05 / Text3: 26.290, 26.304, 26.273, 26.274, 26.412, 26.936
- 1580: - / Text3: 26.235, 26.236
- 1581: - / Text3: 26.111, 26.911
- 1582: - / Text3: 45.903

| ID | WBS | Task | Type | Duration | Start | Finish | Complete | Baseline start | Baseline finish | Baseline duration | Constraint | Resources | Work | Actual work | Text1 | Text3 | Text4 | Text5 | Text6 | Text8 | Text12 |
| --- | --- | --- | --- | --- | --- | --- | --- | --- | --- | --- | --- | --- | --- | --- | --- | --- | --- | --- | --- | --- | --- |
| 1583 | 460 | **Enhancement of dialled service for CAMEL** |  | 199d | 2003-03-28 A | 2003-12-31 A | 100% | 2003-03-28 | 2003-12-31 | 199d |  | S1,N2,N4 | 3184h | 3184h | EDCAMEL | 22.078 | Samsung | Craig Bishop | Rel-6 | Alain |  |
| 1584 | 460.1 | Stages 2 and 3 |  | 199d | 2003-03-28 A | 2003-12-31 A | 100% | 2003-03-28 | 2003-12-31 | 199d | finish no earlier than 2003-09-19 | N2,N4 | 1592h | 1592h | EDCAMEL | 23.008, 23.016, 23.018, 23.078, 29.002, 29.078 | Samsung | Richard Brook | Rel-6 | Kimmo |  |
| 1585 | 461 | Study on Bandwidth and resource savings in CS networks |  | 273d? | 2003-06-01 A | 2004-06-16 A | 100% | 2003-06-01 | 2004-06-16 | 273d? | finish no earlier than 2004-06-16 | S2 | 2184h | 2184h | BARS | 23.977 |  |  | Rel-6 | Maurice |  |
| 1586 | 462 | FS on (U)SIM Security Reuse by Peripheral Devices on Local Interfaces |  | 127d? | 2003-07-03 A | 2003-12-26 A | 100% | 2003-07-03 | 2003-12-26 | 127d? | finish no earlier than 2003-12-26 | S3 | 1016h | 1016h |  | 33.817 | Toshiba | Raziq Yaqub (ryaqub@tari.toshiba.com) | Rel-6 | Dionisio |  |
| 1587 | 463 | **Multiple TBF in A/Gb mode** |  | 736d? | 2002-04-05 A | 2005-01-28 A | 100% | 2002-04-05 | 2005-01-28 | 736d? |  | GP,G2 | 17600h | 17600h | MULTBF |  | Ericsson | gunnar.mildh@era.ericsson.se | Rel-6 | Paolo |  |
| 1588 | 463.1 | **Multiple TBF in A/Gb mode** |  | 366d? | 2002-04-05 A | 2003-08-29 A | 100% | 2002-04-05 | 2003-08-29 | 366d? |  | GP,G2 | 11712h | 11712h | MULTBF-Agbmode |  | Ericsson | gunnar.mildh@era.ericsson.se | Rel-6 | Paolo |  |
| 1589 | 463.1.1 | Multiple TBF Concept paper |  | 366d? | 2002-04-05 A | 2003-08-29 A | 100% | 2002-04-05 | 2003-08-29 | 366d? | finish no earlier than 2003-08-29 | GP,G2 | 2928h | 2928h | MULTBF-Agbmode |  |  |  | Rel-6 | Paolo |  |
| 1590 | 463.1.2 | Multiple TBF Stage 2 (43.064) CRs |  | 366d? | 2002-04-05 A | 2003-08-29 A | 100% | 2002-04-05 | 2003-08-29 | 366d? | finish no earlier than 2003-08-29 | GP,G2 | 2928h | 2928h | MULTBF-Agbmode |  |  |  | Rel-6 | Paolo |  |
| 1591 | 463.1.3 | Multiple TBF Stage 3 (44.060) CRs |  | 366d? | 2002-04-05 A | 2003-08-29 A | 100% | 2002-04-05 | 2003-08-29 | 366d? | finish no earlier than 2003-08-29 | GP,G2 | 2928h | 2928h | MULTBF-Agbmode |  |  |  | Rel-6 | Paolo |  |
| 1592 | 463.2 | Deleted - Multiple TBF in A/Gb mode – MS testing | milestone | 0d? | 2005-01-28 A | 2005-01-28 A | 100% | 2005-01-28 | 2005-01-28 | 0d? | start no earlier than 2005-01-28 | G3new |  |  | MULTBF-Testing |  | Ericsson | gunnar.mildh@era.ericsson.se | Rel-6 | Paolo | GP-27 |
| 1593 | 464 | **Alignment between the test-regimes for GERAN capable MS** |  | 526d? | 2003-08-29 A | 2005-09-02 A | 100% | 2003-08-29 | 2005-09-02 | 526d? |  | G3new | 4208h | 4208h | ALTERE |  | Ericsson | Toubassi | Rel-6 | Ingbert |  |
| 1594 | 464.1 | Determine the controversial test cases in the different test regimes and align them with 3GPP GERAN test specifications. Such test cases to be added to TS 51.010. |  | 526d? | 2003-08-29 A | 2005-09-02 A | 100% | 2003-08-29 | 2005-09-02 | 526d? | finish no earlier than 2005-09-02 | G3new | 4208h | 4208h | ALTERE-TC |  |  |  | Rel-6 | Ingbert |  |
| 1595 | 465 | Addition of U-TDOA in the CS domain |  | 111d? | 2003-11-21 A | 2004-04-23 A | 100% | 2003-11-21 | 2004-04-23 | 111d? | finish no earlier than 2004-04-23 | GP | 888h | 888h | UTDOACS |  | TruePosition | Bob Gross, Rhys Robinson (rlgross@trueposition.com) | Rel-6 | Paolo |  |
| 1596 | 466 | Addition of U-TDOA in the PS domain |  | 361d? | 2003-06-27 A | 2004-11-12 A | 100% | 2003-06-27 | 2004-11-12 | 361d? | finish no earlier than 2004-11-12 | GP | 2888h | 2888h | UTDOAPS |  | TruePosition | Bob Gross, Rhys Robinson (rlgross@trueposition.com) | Rel-6 | Paolo |  |
| 1597 | 467 | **Downlink Advanced Receiver Performance** |  | 466d? | 2003-11-21 A | 2005-09-02 A | 100% | 2003-11-21 | 2005-09-02 | 466d? |  | GP | 19160h | 19160h | DARP |  | Nokia | tommy.bysted@nokia.com | Rel-6 | Paolo |  |
| 1598 | 467.1 | DARP test scenarios |  | 201d? | 2003-11-21 A | 2004-08-27 A | 100% | 2003-11-21 | 2004-08-27 | 201d? | finish no earlier than 2004-08-27 | GP | 1608h | 1608h | DARP-TS |  | Nokia | tommy.bysted@nokia.com | Rel-6 | Paolo |  |
| 1599 | 467.2 | **DARP for GMSK modulated voice services** |  | 201d? | 2004-02-06 A | 2004-11-12 A | 100% | 2004-02-06 | 2004-11-12 | 201d? |  | GP | 4824h | 4824h | DARP-GMSK |  | Nokia | tommy.bysted@nokia.com | Rel-6 | Paolo |  |
| 1600 | 467.2.1 | Performance requirements in 45.005 |  | 201d? | 2004-02-06 A | 2004-11-12 A | 100% | 2004-02-06 | 2004-11-12 | 201d? | finish no earlier than 2004-11-12 | GP | 1608h | 1608h | DARP-GMSK-Perf |  |  |  | Rel-6 | Paolo |  |
| 1601 | 467.2.2 | Radio subsystem link control in 45.008 |  | 201d? | 2004-02-06 A | 2004-11-12 A | 100% | 2004-02-06 | 2004-11-12 | 201d? | finish no earlier than 2004-11-12 | GP | 1608h | 1608h | DARP-GMSK-LC |  |  |  | Rel-6 | Paolo |  |
| 1602 | 467.3 | **DARP for GPRS and EGPRS MCS1-MCS4** |  | 201d? | 2004-02-06 A | 2004-11-12 A | 100% | 2004-02-06 | 2004-11-12 | 201d? |  | GP | 4824h | 4824h | DARP-GPRSE |  | Nokia | tommy.bysted@nokia.com | Rel-6 | Paolo |  |
| 1603 | 467.3.1 | Performance requirements in 45.005 |  | 201d? | 2004-02-06 A | 2004-11-12 A | 100% | 2004-02-06 | 2004-11-12 | 201d? | finish no earlier than 2004-11-12 | GP | 1608h | 1608h | DARP-GPRSE-Perf |  |  |  | Rel-6 | Paolo |  |
| 1604 | 467.3.2 | Radio subsystem link control in 45.008 |  | 201d? | 2004-02-06 A | 2004-11-12 A | 100% | 2004-02-06 | 2004-11-12 | 201d? | finish no earlier than 2004-11-12 | GP | 1608h | 1608h | DARP-GPRSE-LC |  |  |  | Rel-6 | Paolo |  |
| 1605 | 467.4 | DARP Capability signalling |  | 256d? | 2003-11-21 A | 2004-11-12 A | 100% | 2003-11-21 | 2004-11-12 | 256d? | finish no earlier than 2004-11-12 | GP | 2048h | 2048h | DARP-CAPSIG |  | Nokia | tommy.bysted@nokia.com | Rel-6 | Paolo |  |
| 1606 | 467.5 | GERAN MS Conformance test for DARP |  | 266d? | 2004-08-27 A | 2005-09-02 A | 100% | 2004-08-27 | 2005-09-02 | 266d? | finish no earlier than 2005-06-24 | G3new | 2128h | 2128h | ARP-ConfTest |  | Nokia | tommy.bysted@nokia.com | Rel-6 | Ingbert |  |

Notes:
- 1583: -
- 1584: -
- 1585: -
- 1586: Approved TSG#20
- 1587: GP#17 Nov 2003 Moved from Rel-5 UID_50058 MULTBF (Only Multiple TBF Concept paper produced in Rel-5)
- 1588: -
- 1589: -
- 1590: -
- 1591: -
- 1592: -
- 1593: -
- 1594: -
- 1595: Completed, except for potential LMU performance specs
- 1596: -
- 1597: -
- 1598: -
- 1599: -
- 1600: -
- 1601: -
- 1602: -
- 1603: -
- 1604: -
- 1605: -
- 1606: -

| ID | WBS | Task | Type | Duration | Start | Finish | Complete | Baseline start | Baseline finish | Baseline duration | Constraint | Resources | Work | Actual work | Text1 | Text4 | Text5 | Text6 | Text8 | Text12 | Text3 | Text10 |
| --- | --- | --- | --- | --- | --- | --- | --- | --- | --- | --- | --- | --- | --- | --- | --- | --- | --- | --- | --- | --- | --- | --- |
| 1607 | 468 | **Reduction of PS service interruption in Dual Transfer Mode** |  | 416d? | 2003-11-21 A | 2005-06-24 A | 100% | 2003-11-21 | 2005-06-24 | 416d? |  | G2 | 8360h | 8360h | PSintDTM | Siemens | toby.proctor@roke.co.uk | Rel-6 | Gert |  |  |  |
| 1608 | 468.1 | Use case and requirement definition |  | 111d? | 2003-11-21 A | 2004-04-23 A | 100% | 2003-11-21 | 2004-04-23 | 111d? | finish no earlier than 2004-04-23 | G2 | 888h | 888h | PSintDTM-Req | Siemens | toby.proctor@roke.co.uk | Rel-6 | Gert |  |  |  |
| 1609 | 468.2 | Performance Study of Current Procedures |  | 111d? | 2003-11-21 A | 2004-04-23 A | 100% | 2003-11-21 | 2004-04-23 | 111d? | start no earlier than 2003-11-21 | G2 | 888h | 888h | PSintDTM-Perf | Siemens | toby.proctor@roke.co.uk | Rel-6 | Gert |  |  |  |
| 1610 | 468.3 | Reduction of service interruption times and packet loss during Dual Transfer Mode and mobility procedures |  | 146d? | 2004-04-23 A | 2004-11-12 A | 100% | 2004-04-23 | 2004-11-12 | 146d? | finish no earlier than 2004-11-12 | G2 | 1168h | 1168h | PSintDTM-Reduct | Siemens | toby.proctor@roke.co.uk | Rel-6 | Gert |  |  |  |
| 1611 | 468.4 | Deleted - MS Conformance testing - Reduction of PS service interruption in DTM |  | 261d? | 2004-06-25 A | 2005-06-24 A | 100% | 2004-06-25 | 2005-06-24 | 261d? | finish no earlier than 2005-06-24 | G3new | 2088h | 2088h | PSintDTM-ConfMS |  |  | Rel-6 | Ingbert | GP-25 |  |  |
| 1612 | 468.5 | Deleted - BTS Conformance testing - Reduction of PS service interruption in DTM | milestone | 0d? | 2005-06-24 A | 2005-06-24 A | 100% | 2005-06-24 | 2005-06-24 | 0d? | finish no earlier than 2005-06-24 | G3new |  |  | PSintDTM-ConfBTS |  |  | Rel-6 | Ingbert | GP-25 |  |  |
| 1613 | 469 | CAMEL prepay interworking with SCUDIF |  | 216.3d | 2003-12-08 A | 2004-10-05 A | 100% | 2003-12-08 | 2004-10-05 | 216.3d |  | N4,N3,S1 | 1730.4h | 1730.4h | SCCAMEL | Nokia | Keijo.Palviainen@Nokia.Com | Rel-6 | Kimmo |  | 22.078, 23.078, 29.078, 29.002, 23.172 |  |
| 1614 | 470 | **Circuit Switched Video and Voice Service Improvements** |  | 430d? | 2004-01-12 A | 2005-09-02 A | 100% | 2004-01-12 | 2005-09-02 | 430d? |  | S2,C1 | 9256h | 9256h | CS_VSS | Vodafone | John Watson | Rel-6 | Alain |  |  |  |
| 1615 | 470.1 | Deleted - Stage 1 - Requirements |  | 199d | 2004-01-12 A | 2004-10-14 A | 100% | 2004-01-12 | 2004-10-14 | 199d | finish no earlier than 2004-10-14 | S1 | 1592h | 1592h | CS_VSS | Vodafone | John Watson | Rel-6 | Alain | SP-26 | 22.101 |  |
| 1616 | 470.2 | Stage 2 Study on architecture alternatives |  | 244d? | 2004-01-12 A | 2004-12-16 A | 100% | 2004-01-12 | 2004-12-16 | 244d? | finish no earlier than 2004-08-13 | S2 | 1952h | 1952h | CS_VSS | Vodafone | Chris Pudney | Rel-6 | Maurice |  | 23.903 | SP-24 |
| 1617 | 470.3 | Deleted - Stage 2 description on Redial |  | 164d? | 2004-05-03 A | 2004-12-16 A | 100% | 2004-05-03 | 2004-12-16 | 164d? | finish no earlier than 2004-12-16 | S2 | 1312h | 1312h | CS_VSS | Vodafone | Chris Pudney | Rel-6 | Maurice | SP-26 |  | SP-24 |
| 1618 | 470.4 | Switching between voice and video call - Redial solution |  | 120d? | 2005-01-03 A | 2005-06-17 A | 100% | 2005-01-03 | 2005-06-17 | 120d? | start no earlier than 2005-01-03 | C1 | 960h | 960h | CS_VSS | Vodafone |  | Rel-6 | Frederic |  | 23.009, 24.008 |  |
| 1619 | 470.5 | Deleted - CS_VSS - GERAN2 Part | milestone | 0d | 2005-09-02 A | 2005-09-02 A | 100% | 2005-09-02 | 2005-09-02 | 0d | start no earlier than 2005-09-02 | G2 |  |  | CS_VSS | Vodafone |  | Rel-6 | Gert | GP-26 |  |  |
| 1620 | 470.6 | Deleted - CS_VSS - CN3 Part | milestone | 0d? | 2004-10-14 A | 2004-10-14 A | 100% | 2004-10-14 | 2004-10-14 | 0d? | start no earlier than 2004-10-14 | N3 |  |  | CS_VSS | Vodafone |  | Rel-6 | Gwiho | TP-26 |  |  |
| 1621 | 471 | Network Domain Security; MAP application layer security (NDS/MAPsec) |  | 127d? | 2004-07-06 A | 2004-12-29 A | 100% | 2004-07-06 | 2004-12-29 | 127d? | finish no earlier than 2003-12-26 | S3 | 1016h | 1016h | MAPSEC | Vodafone | Peter.Howard@vodafone.com | Rel-6 | Dionisio |  |  |  |
| 1622 | 472 | FS on Security for early IMS |  | 127d? | 2004-10-01 A | 2005-03-28 A | 100% | 2004-10-01 | 2005-03-28 | 127d? | finish no earlier than 2003-12-26 | S3 | 1016h | 1016h | SEC-IMS | Vodafone | Peter.Howard@vodafone.com | Rel-6 | Dionisio |  | 33.978 |  |
| 1623 | 473 | Reorganisation of CS Data Specifications |  | 14d? | 2004-11-19 A | 2004-12-08 A | 100% | 2004-11-19 | 2004-12-08 | 14d? | finish no earlier than 2004-12-24 | N3 | 112h | 112h | CS Data | Siemens | Thomas.Belling@nsn.com | Rel-6 | Gwiho |  | 23.910, 29.007, new 23.202 |  |
| 1624 | 474 | **Generic Access to A/Gb Interface (GAAI)** |  | 411d? | 2004-06-25 A | 2006-01-20 A | 100% | 2004-06-25 | 2006-01-20 | 411d? |  | GP | 9160h | 9160h | GAAI | Motorola |  | Rel-6 | Paolo |  |  |  |
| 1625 | 474.1 | FS on GAAI |  | 46d? | 2004-06-25 A | 2004-08-27 A | 100% | 2004-06-25 | 2004-08-27 | 46d? | finish no earlier than 2004-08-27 | GP | 368h | 368h | GAAG | Motorola |  | Rel-6 | Paolo |  | 43.901 |  |
| 1626 | 474.2 | GAAI – Stage 2 |  | 161d? | 2004-08-27 A | 2005-04-08 A | 100% | 2004-08-27 | 2005-04-08 | 161d? | finish no earlier than 2005-04-08 | GP | 1288h | 1288h | GAAI-Stage2 | Ericsson | jari.vikberg@ericsson.com | Rel-6 | Paolo |  | 43.318 |  |
| 1627 | 474.3 | GAAI – Stage 3 |  | 161d? | 2004-08-27 A | 2005-04-08 A | 100% | 2004-08-27 | 2005-04-08 | 161d? | finish no earlier than 2005-04-08 | GP | 1288h | 1288h | GAAI-Stage3 |  |  | Rel-6 | Paolo |  | 44.318 |  |
| 1628 | 474.4 | MS Conformance Test for GAAI |  | 366d? | 2004-08-27 A | 2006-01-20 A | 100% | 2004-08-27 | 2006-01-20 | 366d? | finish no earlier than 2006-01-20 | GP | 2928h | 2928h | GAAI-CT |  |  | Rel-6 | Ingbert |  |  |  |
| 1629 | 475 | **Support of PS Handover for GERAN A/Gb mode** |  | 473d? | 2003-11-03 A | 2005-08-24 A | 100% | 2003-11-03 | 2005-08-24 | 473d? |  | GP,G2 | 11352h | 11352h | SPSHAGB | Ericsson | gunnar.hedby@ericsson.com | Rel-6 | Paolo |  |  |  |
| 1630 | 475.1 | Stage 2 |  | 473d? | 2003-11-03 A | 2005-08-24 A | 100% | 2003-11-03 | 2005-08-24 | 473d? | finish no earlier than 2005-09-02 | GP,G2 | 3784h | 3784h | SPSHAGB-Stage2 | Ericsson | gunnar.hedby@ericsson.com | Rel-6 | Paolo |  | 43.129 |  |
| 1631 | 475.2 | PS handover |  | 473d? | 2003-11-03 A | 2005-08-24 A | 100% | 2003-11-03 | 2005-08-24 | 473d? | finish no earlier than 2005-09-02 | GP,G2 | 3784h | 3784h | SPSHAGB-PSHO | Ericsson | gunnar.hedby@ericsson.com | Rel-6 | Paolo |  |  |  |
| 1632 | 475.3 | Definition of radio resource management functionality |  | 473d? | 2003-11-03 A | 2005-08-24 A | 100% | 2003-11-03 | 2005-08-24 | 473d? | finish no earlier than 2005-09-02 | GP,G2 | 3784h | 3784h | SPSHAGB-RRM | Ericsson | gunnar.hedby@ericsson.com | Rel-6 | Paolo |  |  |  |

Notes:
- 1607: -
- 1608: -
- 1609: -
- 1610: -
- 1611: -
- 1612: -
- 1613: -
- 1614: -
- 1615: -
- 1616: -
- 1617: -
- 1618: -
- 1619: -
- 1620: -
- 1621: Approved TSG#24. Marked as closed 12/2008 (was marked 20% complete)
- 1622: SP#24 approved WID. SP#27 completed. SP#46 TR abandoned from Rel-9 onwards
- 1623: Created at TSG#27 as 100 % complete
- 1624: -
- 1625: Feasibility Study
- 1626: -
- 1627: -
- 1628: Marked as closed 12/2008 (was marked 90% complete)
- 1629: Replaces SCSAGB- Originally Started Nov 2003 as GP-030443
- 1630: Replaces SCSAGB-Stage2
- 1631: Replaces SCSAGB-PSH
- 1632: Replaces SCSAGB-RRM

| ID | WBS | Task | Type | Duration | Start | Finish | Complete | Baseline start | Baseline finish | Baseline duration | Total slack | Constraint | Resources | Work | Actual work | Text1 | Text6 | Text3 | Text8 | Text4 | Text5 | Text12 |
| --- | --- | --- | --- | --- | --- | --- | --- | --- | --- | --- | --- | --- | --- | --- | --- | --- | --- | --- | --- | --- | --- | --- |
| 1633 | 476 | **small Technical Enhancements and Improvements for Rel-6** |  | 503d? | 2006-06-02 A | 2008-05-06 A | 100% | 2006-06-02 | 2008-05-06 | 503d? |  |  | All | 4024h | 4024h | TEI6 | Rel-6 |  |  |  |  |  |
| 1634 | 476.1 | Small Technical Enhancements and Improvements for Rel-6 Conformance Testing |  | 503d? | 2006-06-02 A | 2008-05-06 A | 100% | 2006-06-02 | 2008-05-06 | 503d? |  | start no earlier than 2006-06-02 | R5,T1 | 4024h | 4024h | TEI6_Test | Rel-6 | 34.108,34.121-1/2,34.122,34.123-1/2/3 | Ingbert |  |  |  |
| 1635 | 477 | Deleted - Study of Feature Interactions Requirements | milestone | 0d? | 2004-10-01 A | 2004-10-01 A | 100% | 2004-10-01 | 2004-10-01 | 0d? |  | finish no earlier than 2004-10-01 | S1 |  |  | FINTER | Rel-6 |  | Alain |  |  |  |
| 1636 | 478 | Deleted - Enhancements of VGCS in public networks for communication of public authority officials |  | 7d? | 2005-08-24 A | 2005-09-02 A | 100% | 2005-08-24 | 2005-09-02 | 7d? |  | start no earlier than 2005-08-24 | GP,G2 | 56h | 56h | EVGCS | Rel-6 | 44.018, 44.068, 48.008 | Paolo | Siemens | kenneth.isaacs@roke.co.uk | GP-26 |
| 1637 | 479 | **Deleted - Support of Conversational Services in A/Gb mode via the PS domain** |  | 64d? | 2003-11-21 A | 2004-02-19 A | 100% | 2003-11-21 | 2004-02-19 | 64d? |  |  | GP | 512h | 512h | SCSAGB | Rel-6 |  | Paolo | Ericsson | David Bladsjö (david.bladsjo@ericsson.com) |  |
| 1638 | 479.1 | Delete - Creation of a TR | milestone | 0d? | 2003-11-21 A | 2003-11-21 A | 100% | 2003-11-21 | 2003-11-21 | 0d? |  | start no earlier than 2003-11-21 | GP |  |  | SCSAGB-TR | Rel-6 |  | Paolo | Ericsson | David Bladsjö (david.bladsjo@ericsson.com) | GP-17 |
| 1639 | 479.2 | Delete - Stage 2 | milestone | 0d? | 2003-11-21 A | 2003-11-21 A | 100% | 2003-11-21 | 2003-11-21 | 0d? |  | finish no earlier than 2003-11-21 | GP |  |  | SCSAGB-Stage2 | Rel-6 |  | Paolo | Ericsson | David Bladsjö (david.bladsjo@ericsson.com) | GP-17 |
| 1640 | 479.3 | Delete - Radio Channel Support | milestone | 0d? | 2003-11-21 A | 2003-11-21 A | 100% | 2003-11-21 | 2003-11-21 | 0d? |  | finish no earlier than 2003-11-21 | GP |  |  | SCSAGB-RCS | Rel-6 |  | Paolo | Ericsson | David Bladsjö (david.bladsjo@ericsson.com) | GP-17 |
| 1641 | 479.4 | Delete - Definition of radio resource management functionality | milestone | 0d? | 2003-11-21 A | 2003-11-21 A | 100% | 2003-11-21 | 2003-11-21 | 0d? |  | finish no earlier than 2003-11-21 | GP,G2 |  |  | SCSAGB-RRM | Rel-6 |  | Paolo | Ericsson | David Bladsjö (david.bladsjo@ericsson.com) | GP-17 |
| 1642 | 479.5 | Delete, replaced by 50561 - PS Handover |  | 64d | 2003-11-21 A | 2004-02-19 A | 100% | 2003-11-21 | 2004-02-19 | 64d |  | start no earlier than 2003-11-21 | GP,GP, N1 | 512h | 512h | SCSAGB-PSH | Rel-6 |  | Paolo | Ericsson | David Bladsjö (david.bladsjo@ericsson.com) | GP-18 |
| 1643 | 479.6 | Delete - Modifications to FLO | milestone | 0d? | 2003-11-21 A | 2003-11-21 A | 100% | 2003-11-21 | 2003-11-21 | 0d? |  | finish no earlier than 2003-11-21 | GP,G2 |  |  | SCSAGB-FLO | Rel-6 |  | Paolo | Ericsson | David Bladsjö (david.bladsjo@ericsson.com) | RP-29 |
| 1644 | 480 | Deleted - Rel-6 Evolutions of the transport in the UTRAN | milestone | 0d | 2003-12-31 A | 2003-12-31 A | 100% | 2003-12-31 | 2003-12-31 | 0d |  | start no earlier than 2003-12-31 | RP |  |  | ETRAN | Rel-6 |  | Issam | Alcatel | Francois Courau | RP-22 |
| 1645 | 481 | Release 5 Features |  | 1d? | 2000-01-03 | 2000-01-03 |  | 2000-01-03 | 2000-01-03 | 1d? | 3317d |  | NP,GP, RP,SP,TP | 8h |  |  | Rel-5 |  |  |  |  |  |
| 1646 | 75 | IP transport in the UTRAN |  | 445d | 2000-07-17 A | 2002-03-29 A | 100% | 2000-07-17 | 2002-03-29 | 445d |  | finish no earlier than 2002-03-29 | R3 | 3560h | 3560h | ETRAN-IPtrans | Rel-5 |  | Juha | Alcatel | Nicolas Drevon |  |
| 1647 | 76 | FS on Usage of SUA |  | 205d | 2001-03-12 A | 2001-12-21 A | 100% | 2001-03-12 | 2001-12-21 | 205d |  | finish no earlier than 2001-12-21 | N4 | 1640h | 1640h | SS7IP | Rel-5 |  | Kimmo |  |  |  |
| 1648 | 77 | **High Speed Downlink Packet Access** |  | 570d | 2001-04-02 A | 2003-06-06 A | 100% | 2001-04-02 | 2003-06-06 | 570d |  |  | R2 | 15272h | 15272h | HSDPA | Rel-5 |  | Joern | Motorola | Ravi Kuchibhotla |  |
| 1649 | 77.1 | Physical Layer |  | 257d | 2001-04-05 A | 2002-03-29 A | 100% | 2001-04-05 | 2002-03-29 | 257d |  | finish no earlier than 2002-03-29 | R1 | 2056h | 2056h | HSDPA-Phys | Rel-5 |  | Patrick | Motorola | Amitava Ghosh |  |
| 1650 | 77.2 | Layer 2 and 3 aspects |  | 257d | 2001-04-05 A | 2002-03-29 A | 100% | 2001-04-05 | 2002-03-29 | 257d |  | finish no earlier than 2002-03-29 | R2 | 2056h | 2056h | HSDPA-L23 | Rel-5 |  | Joern | Motorola | Ravi Kuchibhotla |  |
| 1651 | 77.3 | Iub/Iur protocol aspects |  | 260d | 2001-04-02 A | 2002-03-29 A | 100% | 2001-04-02 | 2002-03-29 | 260d |  | finish no earlier than 2002-03-29 | R3 | 2080h | 2080h | HSDPA-IubIur | Rel-5 |  | Juha | Motorola | Mike Diesen |  |
| 1652 | 77.4 | RF Radio Transmission/ Reception, System Performance Requirements and Conformance Testing |  | 565d | 2001-04-09 A | 2003-06-06 A | 100% | 2001-04-09 | 2003-06-06 | 565d |  | finish no earlier than 2003-06-06 | R4 | 4520h | 4520h | HSDPA-RF | Rel-5 |  | Issam | Motorola | Howard Benn |  |
| 1653 | 78 | **Rel-5 Improvements of Radio Interface** |  | 535d | 2000-08-14 A | 2002-08-30 A | 100% | 2000-08-14 | 2002-08-30 | 535d |  |  | RP | 30376h | 30376h | RInImp | Rel-5 |  |  |  |  |  |
| 1654 | 78.1 | **Base station classification** |  | 480d | 2000-08-14 A | 2002-06-14 A | 100% | 2000-08-14 | 2002-06-14 | 480d |  |  | R4 | 9208h | 9208h | RInImp-BSClass | Rel-5 |  | Issam | Nokia | antti.toskala@nokia.com |  |
| 1655 | 78.1.1 | TDD Base station classification |  | 410d | 2000-08-14 A | 2002-03-08 A | 100% | 2000-08-14 | 2002-03-08 | 410d |  | finish no earlier than 2002-03-08 | R4 | 3280h | 3280h | RInImp-BSClass-TDD | Rel-5 |  | Issam | Nokia | antti.toskala@nokia.com |  |
| 1656 | 78.1.2 | Base Station Classification for 1.28 Mcps TDD option |  | 261d | 2001-06-15 A | 2002-06-14 A | 100% | 2001-06-15 | 2002-06-14 | 261d |  | finish no earlier than 2002-06-14 | R4 | 2088h | 2088h | RInImp-BSClass-LCRTDD | Rel-5 |  | Issam | Siemens | Meik.Kottkamp@siemens.com |  |
| 1657 | 78.2 | Enhancement on the DSCH hard split mode |  | 271d | 2001-03-16 A | 2002-03-29 A | 100% | 2001-03-16 | 2002-03-29 | 271d |  | finish no earlier than 2002-03-29 | R1 | 2168h | 2168h | RInImp-DSCHhsp | Rel-5 |  | Patrick | Samsung | Jaeyoel KIM |  |
| 1658 | 78.3 | Hybrid ARQ II/III |  | 355d | 2000-08-21 A | 2001-12-28 A | 100% | 2000-08-21 | 2001-12-28 | 355d |  | finish no earlier than 2001-12-28 | R2 | 2840h | 2840h | RInImp-HARQ | Rel-5 |  | Joern | Siemens | A. Sitte | RP-14 |
| 1659 | 78.4 | FS on USTS |  | 355d | 2000-08-14 A | 2001-12-21 A | 100% | 2000-08-14 | 2001-12-21 | 355d |  | finish no earlier than 2001-12-21 | R1 | 2840h | 2840h | RInImp-USTS | Rel-5 |  | Patrick | SK Telecom | D. Kim |  |
| 1660 | 78.5 | FS on UE antenna efficiency test method performance requirements |  | 255d | 2000-09-25 A | 2001-09-14 A | 100% | 2000-09-25 | 2001-09-14 | 255d |  | finish no earlier than 2001-09-14 | R4 | 2040h | 2040h | RInImp-UEAnTM | Rel-5 |  | Issam | Allgon | O. Edvardsson |  |
| 1661 | 78.6 | FS on the re-introduction of the downlink SIR measurement |  | 200d | 2001-03-12 A | 2001-12-14 A | 100% | 2001-03-12 | 2001-12-14 | 200d |  | finish no earlier than 2001-12-14 | R4 | 1600h | 1600h | RInImp-SIR | Rel-5 |  | Issam | Ericsson | Torgny.Palenius@ericsson.com |  |
| 1662 | 78.7 | FS on mitigating the effect of CPICH interference at the UE |  | 255d | 2001-03-19 A | 2002-03-08 A | 100% | 2001-03-19 | 2002-03-08 | 255d |  | finish no earlier than 2002-03-08 | R4 | 2040h | 2040h | RInImp-CPICH_Intf | Rel-5 |  | Issam | Intel | shimon.moshavi@INTEL.COM |  |

Notes:
- 1633: "Joker" WI, to be used for a Rel 6 CR not related to any feature and with very limited impact on the system. Moved in from Stoyan/Testing WP
- 1634: "Joker" WI, to be used for small modifications applicable to Rel 4 conformance testing
- 1635: SP-23 - To be abandoned?
- 1636: GP#26 moved to Rel-7 as UID_11045 Enhancements of VGCS in public networks for communication of public authority officials
- 1637: -
- 1638: -
- 1639: Started
- 1640: Not started
- 1641: Not started
- 1642: Started
- 1643: Not started
- 1644: Generic feature
- 1645: -
- 1646: -
- 1647: -
- 1648: -
- 1649: -
- 1650: -
- 1651: -
- 1652: -
- 1653: -
- 1654: -
- 1655: -
- 1656: -
- 1657: -
- 1658: Stopped at RP#14; work on this task was performed as part of High Speed Downlink Packet Access feature
- 1659: -
- 1660: -
- 1661: -
- 1662: -

| ID | WBS | Task | Duration | Start | Finish | Complete | Baseline start | Baseline finish | Baseline duration | Constraint | Resources | Work | Actual work | Text6 | Text8 | Text12 | Text1 | Text4 | Text5 | Text3 |
| --- | --- | --- | --- | --- | --- | --- | --- | --- | --- | --- | --- | --- | --- | --- | --- | --- | --- | --- | --- | --- |
| 1663 | 78.8 | **Deleted - Conformance Test Spec. improvements in Radio Interface** | 140d | 2002-02-18 A | 2002-08-30 A | 100% | 2002-02-18 | 2002-08-30 | 140d |  | T1 | 3360h | 3360h | Rel-5 | Ingbert | TP-22 |  |  |  |  |
| 1664 | 78.8.1 | Deleted - Testing improvement of inter-frequency and inter-system measurement | 140d | 2002-02-18 A | 2002-08-30 A | 100% | 2002-02-18 | 2002-08-30 | 140d | finish no earlier than 2002-08-30 | T1 | 1120h | 1120h | Rel-5 | Ingbert | TP-22 |  |  |  |  |
| 1665 | 78.8.2 | Deleted - Testing Hybrid ARQ II/III | 140d | 2002-02-18 A | 2002-08-30 A | 100% | 2002-02-18 | 2002-08-30 | 140d | finish no earlier than 2002-08-30 | T1 | 1120h | 1120h | Rel-5 | Ingbert | TP-22 |  |  |  |  |
| 1666 | 79 | **Rel-5 RAN improvements** | 772d? | 2001-03-16 A | 2004-03-01 A | 100% | 2001-03-16 | 2004-03-01 | 772d? |  | RP | 39984h | 39984h | Rel-5 |  |  | RANimp |  |  |  |
| 1667 | 79.1 | **RRM optimization for Iur and Iub** | 318d | 2001-03-16 A | 2002-06-04 A | 100% | 2001-03-16 | 2002-06-04 | 318d |  | R3 | 8904h | 8904h | Rel-5 | Juha |  | RANimp-RRMopt | Ericsson | Gert-Jan.van.Lieshout@eln.ericsson.se |  |
| 1668 | 79.1.1 | Iur common transport channel efficiency optimization | 271d | 2001-03-16 A | 2002-03-29 A | 100% | 2001-03-16 | 2002-03-29 | 271d | finish no earlier than 2002-03-29 | R3 | 2168h | 2168h | Rel-5 | Juha |  | RANimp-RRMopt-ctc | Ericsson | Shahrokh Amirijoo |  |
| 1669 | 79.1.2 | Iur neighbouring cell reporting efficiency optimization | 271d | 2001-03-16 A | 2002-03-29 A | 100% | 2001-03-16 | 2002-03-29 | 271d | finish no earlier than 2002-03-29 | R3 | 2168h | 2168h | Rel-5 | Juha |  | RANimp-RRMopt-ncr | Ericsson | Shahrokh Amirijoo |  |
| 1670 | 79.1.3 | FS Introduction of direct transport bearers between SRNC and Node-B | 253d | 2001-06-15 A | 2002-06-04 A | 100% | 2001-06-15 | 2002-06-04 | 253d | finish no earlier than 2002-06-28 | R3 | 2024h | 2024h | Rel-5 | Juha |  | RAN-imp-RRMopt-DTB | Ericsson | Risto Sepponen |  |
| 1671 | 79.2 | RL Timing Adjustment | 271d | 2001-03-16 A | 2002-03-29 A | 100% | 2001-03-16 | 2002-03-29 | 271d | finish no earlier than 2002-03-29 | R3 | 2168h | 2168h | Rel-5 | Juha |  | RANimp-RLTA | Ericsson | Elena Voltolina |  |
| 1672 | 79.3 | Separation of resource reservation and radio link activation | 271d | 2001-03-16 A | 2002-03-29 A | 100% | 2001-03-16 | 2002-03-29 | 271d | finish no earlier than 2002-03-29 | R3 | 2168h | 2168h | Rel-5 | Juha |  | RANimp-SepRR | Ericsson | Gert-Jan.van.Lieshout@eln.ericsson.se |  |
| 1673 | 79.4 | FS SRNS Relocation Procedure Enhancement | 318d | 2001-06-15 A | 2002-09-03 A | 100% | 2001-06-15 | 2002-09-03 | 318d | finish no earlier than 2002-09-06 | R3 | 2544h | 2544h | Rel-5 | Juha |  | RANimp-SRNS | Nokia | Olivier Guyot |  |
| 1674 | 79.5 | FS Improvement of Radio Resource Management across RNS and RNS/PSS | 201d | 2001-03-16 A | 2001-12-21 A | 100% | 2001-03-16 | 2001-12-21 | 201d | finish no earlier than 2001-12-21 | R3 | 1608h | 1608h | Rel-5 | Juha |  | RANimp-ImpRRM | Nokia | antti.toskala@nokia.com |  |
| 1675 | 79.6 | Re-arrangements of Iub transport bearers | 271d | 2001-03-16 A | 2002-03-29 A | 100% | 2001-03-16 | 2002-03-29 | 271d | finish no earlier than 2002-03-29 | R3 | 2168h | 2168h | Rel-5 | Juha |  | RANimp-TTPS | Nokia | antti.toskala@nokia.com |  |
| 1676 | 79.7 | RAB support enhancement for Rel-5 | 325d | 2001-04-02 A | 2002-06-28 A | 100% | 2001-04-02 | 2002-06-28 | 325d | finish no earlier than 2002-06-28 | R2 | 2600h | 2600h | Rel-5 | Joern |  | RANimp-RABSE5 | Nokia | Juha Mikola |  |
| 1677 | 79.8 | Beamforming requirements for UE | 61d | 2001-09-21 A | 2001-12-14 A | 100% | 2001-09-21 | 2001-12-14 | 61d | finish no earlier than 2001-12-14 | R1 | 488h | 488h | Rel-5 | Patrick |  | RANimp-BFR-UE | Nokia | Jussi Kähtävä (juha.mikola@nokia.com) |  |
| 1678 | 79.9 | Support of Site Selection Diversity Transmission in UTRAN | 123d | 2001-12-14 A | 2002-06-04 A | 100% | 2001-12-14 | 2002-06-04 | 123d | finish no earlier than 2002-06-04 | R1 | 984h | 984h | Rel-5 | Patrick |  | RANimp-SSDT | NEC |  |  |
| 1679 | 79.10 | Node B Synchronisation for 1.28 Mcps TDD | 271d | 2001-03-16 A | 2002-03-29 A | 100% | 2001-03-16 | 2002-03-29 | 271d | finish no earlier than 2002-03-29 | R1 | 2168h | 2168h | Rel-5 | Patrick |  | RANimp-NBSLCR | CATT | Jinling HU |  |
| 1680 | 79.12 | **Deleted - Conformance Test Aspects - RAN Improvements** | 565d? | 2002-01-01 A | 2004-03-01 A | 100% | 2002-01-01 | 2004-03-01 | 565d? |  | T1 | 8008h | 8008h | Rel-5 | Ingbert |  |  |  |  | 0% |
| 1681 | 79.12.1 | Deleted - Testing Radio access bearer support enhancements | 175d | 2002-01-01 A | 2002-09-02 A | 100% | 2002-01-01 | 2002-09-02 | 175d | finish no earlier than 2002-09-02 | T1 | 1400h | 1400h | Rel-5 | Ingbert | TP-22 |  |  |  |  |
| 1682 | 486.11.2 | Deleted - General changes to TS34.121 and TS34.122 corresponding to release 5 | 261d? | 2003-03-03 A | 2004-03-01 A | 100% | 2003-03-03 | 2004-03-01 | 261d? | finish no earlier than 2004-03-01 | T1 | 2088h | 2088h | Rel-5 | Ingbert |  | RANimp-test |  |  | 34.108, 34.121, 34.122 |
| 1683 | 80 | UTRAN Sharing in Connected Mode | 197d | 2001-12-03 A | 2002-09-03 A | 100% | 2001-12-03 | 2002-09-03 | 197d | finish no earlier than 2002-09-06 | R3 | 1576h | 1576h | Rel-5 | Juha |  | NETSHARE | Ericsson | Martin Israelsson |  |
| 1684 | 81 | **Provisioning of IP-based multimedia services** | 1089d | 2000-01-03 A | 2004-03-03 A | 100% | 2000-01-03 | 2004-03-03 | 1089d |  | S1,S2,S5 | 187156h | 187156h | Rel-5 | Alain |  | IMS | Openwave | Mark Cataldo |  |
| 1685 | 81.1 | **Call control and roaming to support IMS in UMTS** | 641d | 2000-01-03 A | 2002-06-14 A | 100% | 2000-01-03 | 2002-06-14 | 641d |  | S2 | 82528h | 82528h | Rel-5 | Maurice |  | IMS-CCR | Lucent | Liz Daniel |  |
| 1686 | 81.1.1 | Stage 1 | 215d | 2000-02-21 A | 2000-12-15 A | 100% | 2000-02-21 | 2000-12-15 | 215d | finish no earlier than 2000-09-21 | S1 | 1720h | 1720h | Rel-5 | Alain |  | IMS-CCR | Motorola | Mark Cataldo | 22.228 |
| 1687 | 81.1.2 | Stage 2 (Architecture and Main flows) | 246d | 2000-04-14 A | 2001-03-23 A | 100% | 2000-04-14 | 2001-03-23 | 246d | finish no earlier than 2001-03-23 | S2 | 1968h | 1968h | Rel-5 | Maurice |  | IMS-CCR | Lucent | Liz Daniel | 23.228 |
| 1688 | 81.1.3 | Impact on MM/CC/SM | 400d | 2000-08-28 A | 2002-03-08 A | 100% | 2000-08-28 | 2002-03-08 | 400d | finish no earlier than 2002-03-08 | N1 | 3200h | 3200h | Rel-5 | Frederic |  | IMS-CCR-IWMM | Lucent | Keith Drage (drage@alcatel-lucent.com) |  |

Notes:
- 1663: Marked as stopped 12/2008
- 1664: start/finish dates set...Marked as stopped 12/2008
- 1665: start/finish dates set...Marked as stopped 12/2008
- 1666: -
- 1667: -
- 1668: -
- 1669: -
- 1670: FS was closed and introduction of WI not agreed at RAN #16
- 1671: -
- 1672: -
- 1673: -
- 1674: FS was closed and WI was introduced at RAN #14
- 1675: -
- 1676: RFC 3095 context relocation
- 1677: -
- 1678: RP-020356
- 1679: -
- 1680: Marked as stopped 12/2008
- 1681: duration set to 6 months (was 0)...Marked as stopped 12/2008
- 1682: Marked as stopped 12/2008
- 1683: Formerly 'Shared Network support in connected mode', renamed at RAN #16.
- 1684: S1 WI proposed S1-000290 / TR22.976, WI Rapporteur, Mark Cataldo, Motorola
- 1685: -
- 1686: Issues include e.g.: Roaming requirements, Requirements on supplementary services, Interworking requirements
- 1687: Issues include e.g.: Mobile IP, RAB selection principles, Optimized VoIP bearer mechanisms, SIP multimedia protocol
- 1688: Per 26/2-02: This is understood to be the PCO & TFT CRs which CN1 provides to TSGN #15 for approval. If this is correct understanding, then the task is 100 % complete.

| ID | WBS | Task | Duration | Start | Finish | Complete | Baseline start | Baseline finish | Baseline duration | Constraint | Resources | Work | Actual work | Text1 | Text3 | Text4 | Text5 | Text6 | Text8 |
| --- | --- | --- | --- | --- | --- | --- | --- | --- | --- | --- | --- | --- | --- | --- | --- | --- | --- | --- | --- |
| 1689 | 81.1.4 | **SIP Call Control protocol for the IMS** | 641d | 2000-01-03 A | 2002-06-14 A | 100% | 2000-01-03 | 2002-06-14 | 641d |  | N1 | 70808h | 70808h | IMS-CCR | 24.228, 24.229, 23.218 | Lucent | Keith Drage (drage@alcatel-lucent.com) | Rel-5 | Frederic |
| 1690 | 81.1.4.1 | IMS signalling flows | 385d | 2000-10-02 A | 2002-03-22 A | 100% | 2000-10-02 | 2002-03-22 | 385d | finish no earlier than 2002-03-22 | N1 | 3080h | 3080h | IMS-CCR | 24.228 |  |  | Rel-5 | Frederic |
| 1691 | 81.1.4.2 | IMS stage 3 | 385d | 2000-10-02 A | 2002-03-22 A | 100% | 2000-10-02 | 2002-03-22 | 385d | finish no earlier than 2002-03-22 | N1 | 3080h | 3080h | IMS-CCR | 24.229 |  |  | Rel-5 | Frederic |
| 1692 | 81.1.4.3 | IMS Session Handling; stage 2 | 385d | 2000-10-02 A | 2002-03-22 A | 100% | 2000-10-02 | 2002-03-22 | 385d | finish no earlier than 2002-03-22 | N1 | 3080h | 3080h | IMS-CCR | 23.218 |  |  | Rel-5 | Frederic |
| 1693 | 81.1.4.4 | **Main IETF dependencies** | 636d | 2000-01-03 A | 2002-06-07 A | 100% | 2000-01-03 | 2002-06-07 | 636d |  | NP | 45400h | 45400h | IMS |  |  |  | Rel-5 | Kimmo |
| 1694 | 81.1.4.4.1 | IETF: RFC 3261 (Session Initiation Protocol) | 346d | 2000-11-24 A | 2002-03-22 A | 100% | 2000-11-24 | 2002-03-22 | 346d | finish no earlier than 2002-03-22 | N1 | 2768h | 2768h | IMS |  |  |  | Rel-5 | Frederic |
| 1695 | 81.1.4.4.2 | IETF: RFC 3262 (Reliability of provisional responses) | 346d | 2000-11-24 A | 2002-03-22 A | 100% | 2000-11-24 | 2002-03-22 | 346d | finish no earlier than 2002-03-22 | N1 | 2768h | 2768h | IMS |  |  |  | Rel-5 | Frederic |
| 1696 | 81.1.4.4.3 | IETF: RFC 3312 (Without COMET)(Integration of resource management and SIP) | 382d | 2000-11-24 A | 2002-05-13 A | 100% | 2000-11-24 | 2002-05-13 | 382d | finish no earlier than 2002-05-13 | N1 | 3056h | 3056h | IMS |  |  |  | Rel-5 | Frederic |
| 1697 | 81.1.4.4.4 | IETF: RFC 3323 (SIP extensions for caller identity and privacy) | 382d | 2000-11-24 A | 2002-05-13 A | 100% | 2000-11-24 | 2002-05-13 | 382d | finish no earlier than 2002-05-13 | N1 | 3056h | 3056h | IMS |  |  |  | Rel-5 | Frederic |
| 1698 | 81.1.4.4.5 | IETF: RFC 3313 (SIP extensions for media authorization) | 382d | 2000-11-24 A | 2002-05-13 A | 100% | 2000-11-24 | 2002-05-13 | 382d | finish no earlier than 2002-05-13 | N1 | 3056h | 3056h | IMS |  |  |  | Rel-5 | Frederic |
| 1699 | 81.1.4.4.6 | IETF: RFC 3265 (specific event notification) | 346d | 2000-11-24 A | 2002-03-22 A | 100% | 2000-11-24 | 2002-03-22 | 346d | finish no earlier than 2002-03-22 | N1 | 2768h | 2768h | IMS |  |  |  | Rel-5 | Frederic |
| 1700 | 81.1.4.4.7 | IETF: RFC editor Queue (refer method) | 401d | 2000-11-24 A | 2002-06-07 A | 100% | 2000-11-24 | 2002-06-07 | 401d | finish no earlier than 2002-06-07 | N1 | 3208h | 3208h | IMS |  |  |  | Rel-5 | Frederic |
| 1701 | 81.1.4.4.8 | IETF: RFC editor Queue (DHCP options for SIP servers) | 382d | 2000-11-24 A | 2002-05-13 A | 100% | 2000-11-24 | 2002-05-13 | 382d | finish no earlier than 2002-05-13 | N1 | 3056h | 3056h | IMS |  |  |  | Rel-5 | Frederic |
| 1702 | 81.1.4.4.10 | IETF: RFC 3267 (AMR and AMR WB RTP and SDP) | 346d | 2000-11-24 A | 2002-03-22 A | 100% | 2000-11-24 | 2002-03-22 | 346d | finish no earlier than 2002-03-22 | N1 | 2768h | 2768h | IMS |  |  |  | Rel-5 | Frederic |
| 1703 | 81.1.4.4.11 | IETF: RFC 3266 (IPv6 support within SDP) | 581d | 2000-01-03 A | 2002-03-22 A | 100% | 2000-01-03 | 2002-03-22 | 581d | finish no earlier than 2002-03-22 | N1 | 4640h | 4640h | IMS |  |  |  | Rel-5 | Frederic |
| 1704 | 81.1.4.4.12 | IETF: RFC 3311 (The Update method) | 382d | 2000-11-24 A | 2002-05-13 A | 100% | 2000-11-24 | 2002-05-13 | 382d | finish no earlier than 2002-05-13 | N1 | 3056h | 3056h | IMS |  |  |  | Rel-5 | Frederic |
| 1705 | 81.1.4.4.13 | IETF: RFC 3324 (Network Asserted Identity) | 382d | 2000-11-24 A | 2002-05-13 A | 100% | 2000-11-24 | 2002-05-13 | 382d | finish no earlier than 2002-05-13 | N1 | 3056h | 3056h | IMS |  |  |  | Rel-5 | Frederic |
| 1706 | 81.1.4.4.14 | IETF: RFC editor Queue (Various 3GPP Private Extensions) | 382d | 2000-11-24 A | 2002-05-13 A | 100% | 2000-11-24 | 2002-05-13 | 382d | finish no earlier than 2002-05-13 | N1 | 3056h | 3056h | IMS |  |  |  | Rel-5 | Frederic |
| 1707 | 81.1.4.5 | **Addressing** | 380d | 2000-10-09 A | 2002-03-22 A | 100% | 2000-10-09 | 2002-03-22 | 380d |  | S2 | 7744h | 7744h | IMS |  |  |  | Rel-5 | Maurice |
| 1708 | 81.1.4.5.1 | Architectural issues | 235d | 2000-10-09 A | 2001-08-31 A | 100% | 2000-10-09 | 2001-08-31 | 235d | finish no earlier than 2001-03-16 | S2 | 1880h | 1880h | IMS |  |  |  | Rel-5 | Maurice |
| 1709 | 81.1.4.5.2 | Impact on HSS | 353d | 2000-11-15 A | 2002-03-22 A | 100% | 2000-11-15 | 2002-03-22 | 353d | finish no earlier than 2002-03-22 | N4 | 2824h | 2824h | IMS |  |  |  | Rel-5 | Kimmo |
| 1710 | 81.1.4.6 | **Service Examples (Work stopped)** | 304d | 2001-04-17 A | 2002-06-14 A | 100% | 2001-04-17 | 2002-06-14 | 304d |  | S1 | 4864h | 4864h | IMS-Sex | 22.928 | Motorola | Mark Cataldo | Rel-5 | Alain |
| 1711 | 81.1.4.6.1 | IMS Framework Report (work stopped) | 304d | 2001-04-17 A | 2002-06-14 A | 100% | 2001-04-17 | 2002-06-14 | 304d | finish no earlier than 2002-06-14 | S1 | 2432h | 2432h | IMS-FrWk | 22.941 | SBC | Randolph Wohlert (rwohlert@tri.sbc.com) | Rel-5 | Alain |
| 1712 | 81.2 | **Access Security for IMS** | 190d | 2001-10-08 A | 2002-06-28 A | 100% | 2001-10-08 | 2002-06-28 | 190d |  | S3 | 4120h | 4120h | IMS-ASEC |  | Ericsson | krister.boman@emw.ericsson.se | Rel-5 | Dionisio |
| 1713 | 81.2.2 | IMS impacts on UICC (ISIM application) | 185d | 2001-10-08 A | 2002-06-21 A | 100% | 2001-10-08 | 2002-06-21 | 185d | finish no earlier than 2002-06-21 | T3 | 1480h | 1480h |  |  | Vodafone | Jeremy Norris | Rel-5 |  |
| 1714 | 81.2.3 | SIP extensions for Integrity protection | 140d | 2001-12-17 A | 2002-06-28 A | 100% | 2001-12-17 | 2002-06-28 | 140d | finish no earlier than 2002-06-28 | N1 | 1120h | 1120h |  |  |  |  | Rel-5 | Frederic |
| 1715 | 81.3 | Security Aspects of Requirement for Network Configuration Independence | 130d | 2001-07-02 A | 2001-12-28 A | 100% | 2001-07-02 | 2001-12-28 | 130d | finish no earlier than 2001-12-28 | S3 | 1040h | 1040h | SEC1-NCI |  | AT&T Wireless | hugh.shieh@attws.com | Rel-5 | Dionisio |
| 1716 | 81.4 | Lawful interception | 410d | 2000-09-04 A | 2002-03-29 A | 100% | 2000-09-04 | 2002-03-29 | 410d | finish no earlier than 2002-03-29 | S3 | 3280h | 3280h | IMS-LI |  | Reg TP | berthold.wilhelm@regtp.de | Rel-5 | Dionisio |
| 1717 | 81.5 | Charging and OAM&P for IMS | 383d | 2000-12-25 A | 2002-06-12 A | 100% | 2000-12-25 | 2002-06-12 | 383d | finish no earlier than 2002-06-12 | S5 | 3064h | 3064h | IMS-OAM | 32-series | VoiceStream, Motorola |  | Rel-5 | Dionisio |

Notes:
- 1689: TSGN_10 approved the change:CN1 - SA2 SIP joint meeting spotted one more place for improvement: work tasks with ID 1998 and 1278 are actually subtasks under of single CN1 WT. One WI has been approved for the CN1 WT with title "SIP Call Control protocol...
- 1690: TS 24.228...
- 1691: TS 24.229...
- 1692: TS 23.218...
- 1693: -
- 1694: -
- 1695: -
- 1696: -
- 1697: -
- 1698: -
- 1699: -
- 1700: -
- 1701: -
- 1702: -
- 1703: -
- 1704: -
- 1705: -
- 1706: -
- 1707: -
- 1708: -
- 1709: 17th May, KK: This is cover by 29.228 & 29228. Work complete.
- 1710: -
- 1711: -
- 1712: TS33.203 will be presented for info at SP#14 and is scheduled for approval at SP#15. Dependencies on IETF exist. Approved SP#15
- 1713: -
- 1714: Per 26/2-02: CN1 is not aware of any requirements and is not doing anything on this task.
- 1715: Incorporated into IMS access security TS (33.203) which will be presented for info at SP#14 and is scheduled for approval at SP#15.Editors notes removed SP#16&17
- 1716: Rel-5 33.106 and 33.107 approved at SP#12.Revised WID including new Rel-5 specification (33.108) scheduled for approval at SP#14. 33.108 approved SP#16. CR at SP#17
- 1717: -

| ID | WBS | Task | Duration | Start | Finish | Complete | Baseline start | Baseline finish | Baseline duration | Constraint | Resources | Work | Actual work | Text1 | Text3 | Text4 | Text5 | Text6 | Text8 |
| --- | --- | --- | --- | --- | --- | --- | --- | --- | --- | --- | --- | --- | --- | --- | --- | --- | --- | --- | --- |
| 1718 | 81.6 | **Multimedia codecs and protocols for conversational PS services** | 568d | 2000-07-26 A | 2002-09-27 A | 100% | 2000-07-26 | 2002-09-27 | 568d |  | S4 | 15640h | 15640h | IMS-CODEC | 26.235, 26.236 | Toshiba, Nokia | B. Aronson (Toshiba), pasi.s.ojala@nokia.com | Rel-5 | Paolo |
| 1719 | 81.6.1 | Codecs | 427d | 2000-07-26 A | 2002-03-14 A | 100% | 2000-07-26 | 2002-03-14 | 427d | finish no earlier than 2001-03-21 | S4 | 3416h | 3416h |  | 26.235, 26.236 |  |  | Rel-5 | Paolo |
| 1720 | 81.6.2 | Transport protocols | 1d | 2002-03-12 A | 2002-03-12 A | 100% | 2002-03-12 | 2002-03-12 | 1d | finish no earlier than 2002-03-12 | S4 | 8h | 8h | IMS-CODEC | 26.236 | Nokia | P. Ojala | Rel-5 | Paolo |
| 1721 | 81.6.4 | recommendation for QoS parameter values for various media types | 195d | 2001-12-31 A | 2002-09-27 A | 100% | 2001-12-31 | 2002-09-27 | 195d | finish no earlier than 2002-09-27 | S4 | 1560h | 1560h |  |  |  |  | Rel-5 | Paolo |
| 1722 | 81.6.5 | IETF: RFC 3310 (HTTP Digest Authentication using AKA) | 382d | 2000-11-24 A | 2002-05-13 A | 100% | 2000-11-24 | 2002-05-13 | 382d | finish no earlier than 2002-05-13 | N1 | 3056h | 3056h |  |  |  |  | Rel-5 | Frederic |
| 1723 | 81.6.6 | IETF: RFC 3329 (Security mechanism agreement for SIP connections) | 382d | 2000-11-24 A | 2002-05-13 A | 100% | 2000-11-24 | 2002-05-13 | 382d | finish no earlier than 2002-05-13 | N1 | 3056h | 3056h |  |  |  |  | Rel-5 | Frederic |
| 1724 | 81.7 | **SIP message compression** | 185d | 2001-09-24 A | 2002-06-07 A | 100% | 2001-09-24 | 2002-06-07 | 185d |  | S2 | 3128h | 3128h |  |  |  |  | Rel-5 | Maurice |
| 1725 | 81.7.1 | Stage 2 | 25d | 2001-09-24 A | 2001-10-26 A | 100% | 2001-09-24 | 2001-10-26 | 25d | finish no earlier than 2001-10-26 | S2 | 200h | 200h |  |  |  |  | Rel-5 | Maurice |
| 1726 | 81.7.2 | Compression signalling | 181d | 2001-09-28 A | 2002-06-07 A | 100% | 2001-09-28 | 2002-06-07 | 181d | finish no earlier than 2002-06-07 | N1 | 1448h | 1448h |  |  |  |  | Rel-5 | Frederic |
| 1727 | 81.8 | **Stage 3 description of IMS interfaces** | 383d | 2001-03-14 A | 2002-08-30 A | 100% | 2001-03-14 | 2002-08-30 | 383d |  | NP | 29531.6h | 29531.6h |  |  |  |  | Rel-5 | Kimmo |
| 1728 | 81.8.1 | Cx interface (HSS to CSCF) | 135.95d | 2001-03-14 A | 2002-06-07 A | 100% | 2001-03-14 | 2002-06-07 | 135.95d | finish no earlier than 2002-06-07 | N4 | 1087.58h | 1087.58h |  |  |  |  | Rel-5 | Kimmo |
| 1729 | 81.8.2 | Mp interface (MRFC - MRFP) enhancements | 258d | 2001-03-14 A | 2002-03-08 A | 100% | 2001-03-14 | 2002-03-08 | 258d | finish no earlier than 2002-06-07 | N4 | 2064h | 2064h |  |  |  |  | Rel-5 | Kimmo |
| 1730 | 81.8.3 | Mw interface (CSCF to P-CSCF) | 323d | 2001-03-14 A | 2002-06-07 A | 100% | 2001-03-14 | 2002-06-07 | 323d | finish no earlier than 2002-06-07 | N1 | 2584h | 2584h |  |  |  |  | Rel-5 | Frederic |
| 1731 | 81.8.4 | Mr interface (CSCF to MRF) | 273d | 2001-03-14 A | 2002-03-29 A | 100% | 2001-03-14 | 2002-03-29 | 273d | finish no earlier than 2002-03-29 | N1 | 2184h | 2184h |  |  |  |  | Rel-5 | Frederic |
| 1732 | 81.8.5 | Dx interface (I-CSCF to SLF) | 323d | 2001-03-14 A | 2002-06-07 A | 100% | 2001-03-14 | 2002-06-07 | 323d | finish no earlier than 2002-06-07 | N4 | 2584h | 2584h |  |  |  |  | Rel-5 | Kimmo |
| 1733 | 81.8.6 | Go interface (GGSN to PCF) | 323d | 2001-03-14 A | 2002-06-07 A | 100% | 2001-03-14 | 2002-06-07 | 323d | finish no earlier than 2002-06-07 | N3 | 2584h | 2584h |  |  |  |  | Rel-5 | Gwiho |
| 1734 | 81.8.7 | ISC (IMS Service Control) Interface | 323d | 2001-03-14 A | 2002-06-07 A | 100% | 2001-03-14 | 2002-06-07 | 323d | finish no earlier than 2002-06-07 | N1 | 2584h | 2584h |  |  |  |  | Rel-5 | Frederic |
| 1735 | 81.8.8 | Sh interface (HSS to AS) | 82d | 2002-02-14 A | 2002-06-07 A | 100% | 2002-02-14 | 2002-06-07 | 82d | finish no earlier than 2002-06-07 | N4 | 656h | 656h |  |  |  |  | Rel-5 | Kimmo |
| 1736 | 81.8.9 | Si interface (HSS to IM-SSF) | 162.5d | 2002-01-16 A | 2002-08-30 A | 100% | 2002-01-16 | 2002-08-30 | 162.5d | finish no earlier than 2002-06-07 | N4 | 1300h | 1300h |  |  |  |  | Rel-5 | Kimmo |
| 1737 | 81.8.10 | Gm interface (UE to CSCF) | 323d | 2001-03-14 A | 2002-06-07 A | 100% | 2001-03-14 | 2002-06-07 | 323d | finish no earlier than 2002-06-07 | N1 | 2584h | 2584h |  |  |  |  | Rel-5 | Frederic |
| 1738 | 81.8.11 | Mi interface (CSCF to BGCF) | 323d | 2001-03-14 A | 2002-06-07 A | 100% | 2001-03-14 | 2002-06-07 | 323d | finish no earlier than 2002-06-07 | N1 | 2584h | 2584h |  |  |  |  | Rel-5 | Frederic |
| 1739 | 81.8.12 | Mj interface (BGCF to MGCF) | 323d | 2001-03-14 A | 2002-06-07 A | 100% | 2001-03-14 | 2002-06-07 | 323d | finish no earlier than 2002-06-07 | N1 | 2584h | 2584h |  |  |  |  | Rel-5 | Frederic |
| 1740 | 81.8.13 | Mk interface (BGCF to BGCF) | 323d | 2001-03-14 A | 2002-06-07 A | 100% | 2001-03-14 | 2002-06-07 | 323d | finish no earlier than 2002-06-07 | N1 | 2584h | 2584h |  |  |  |  | Rel-5 | Frederic |
| 1741 | 81.9 | Support of VHE/OSA by entities and protocols of the IMS (e.g. CSCF) | 186d | 2001-09-21 A | 2002-06-07 A | 100% | 2001-09-21 | 2002-06-07 | 186d | finish no earlier than 2002-06-07 | N5 | 1488h | 1488h | IMS-ONOSA | 29.198, 29.998 | Ericsson | Ard.Jan.Moerdijk@eln.ericsson.se | Rel-5 | Kimmo |

Notes:
- 1718: -
- 1719: -
- 1720: -
- 1721: -
- 1722: -
- 1723: -
- 1724: -
- 1725: -
- 1726: -
- 1727: -
- 1728: -
- 1729: [DAB 08-03-02] - No work required in CN4
- 1730: -
- 1731: -
- 1732: CN4#11 30/11/01: No inputs received in CN4 / 14/02/02 Completed(introduced in 29.228)
- 1733: [DAB - 23/05/03] - 100 % complete
- 1734: -
- 1735: CN4#11 30/11/01: No inputs received in CN4 / CN4#12bis 14/02/02: WID approved / 17th May 100% complete. 3GPP TS 29.329 will be sent for approval in CN#16
- 1736: SA16: Part of Rel5 only if completed in September 02. Marked as closed 12/2008 (was marked 72% complete)
- 1737: -
- 1738: -
- 1739: -
- 1740: -
- 1741: -

| ID | WBS | Task | Duration | Start | Finish | Predecessors | Complete | Baseline start | Baseline finish | Baseline duration | Constraint | Resources | Work | Actual work | Text1 | Text4 | Text5 | Text6 | Text8 | Text12 | Text3 |
| --- | --- | --- | --- | --- | --- | --- | --- | --- | --- | --- | --- | --- | --- | --- | --- | --- | --- | --- | --- | --- | --- |
| 1742 | 81.10 | **CAMEL control of IMS services** | 365d | 2001-04-16 A | 2002-09-06 A |  | 100% | 2001-04-16 | 2002-09-06 | 365d |  | N2 | 9952h | 9952h | IMS-CAMEL | Lucent | Angelica Remoquillo | Rel-5 | Kimmo |  |  |
| 1743 | 81.10.1 | Stage2 work 'general' | 365d | 2001-04-16 A | 2002-09-06 A |  | 100% | 2001-04-16 | 2002-09-06 | 365d | finish no earlier than 2002-09-06 | N2 | 2920h | 2920h |  |  |  | Rel-5 | Kimmo |  |  |
| 1744 | 81.10.2 | Stage3 work 'CAP' | 175d | 2002-01-07 A | 2002-09-06 A |  | 100% | 2002-01-07 | 2002-09-06 | 175d | finish no earlier than 2002-09-06 | N2 | 1400h | 1400h |  |  |  | Rel-5 | Kimmo |  |  |
| 1745 | 81.10.3 | Stage2 work 'Si interface' | 175d | 2002-01-07 A | 2002-09-06 A |  | 100% | 2002-01-07 | 2002-09-06 | 175d | finish no earlier than 2002-09-06 | N2 | 1400h | 1400h |  |  |  | Rel-5 | Kimmo |  |  |
| 1746 | 81.10.4 | Stage3 work 'Si interface' | 82d | 2002-02-14 A | 2002-06-07 A |  | 100% | 2002-02-14 | 2002-06-07 | 82d | finish no earlier than 2002-06-07 | N4 | 656h | 656h |  |  |  | Rel-5 | Kimmo |  |  |
| 1747 | 81.10.5 | Deleted - SDM issues for CAMEL control of IMS | 82d | 2002-02-14 A | 2002-06-07 A |  | 100% | 2002-02-14 | 2002-06-07 | 82d | finish no earlier than 2002-06-07 | N4 | 656h | 656h |  |  |  | Rel-5 | Kimmo | NP-21 |  |
| 1748 | 81.11 | Pre-pay/real-time charging in IMS | 196d | 2001-06-15 A | 2002-03-15 A |  | 100% | 2001-06-15 | 2002-03-15 | 196d | finish no earlier than 2002-03-15 | S1 | 1568h | 1568h |  |  |  | Rel-5 | Alain |  |  |
| 1749 | 81.12 | **Charging** | 289d | 2001-08-06 A | 2002-09-12 A |  | 100% | 2001-08-06 | 2002-09-12 | 289d |  | S2,S5 | 6632h | 6632h | OAM-CH | T-Mobile | karl-heinz.nenner@t-mobile.de | Rel-5 | Dionisio |  | 32.225 |
| 1750 | 81.12.1 | Charging Implications of IMS architecture | 75d | 2001-08-06 A | 2001-11-16 A |  | 100% | 2001-08-06 | 2001-11-16 | 75d | finish no earlier than 2001-11-16 | S2 | 600h | 600h |  |  |  | Rel-5 | Maurice |  |  |
| 1751 | 81.12.2 | Charging management for IMS (off-line & on-line) | 214d | 2001-11-19 A | 2002-09-12 A | 1750 | 100% | 2001-11-19 | 2002-09-12 | 214d | finish no earlier than 2002-09-12 | S5 | 1712h | 1712h | OAM-CH |  |  | Rel-5 | Dionisio |  | 32.225 |
| 1752 | 86.1.6.10 | Billing, accounting and call detail record aspects | 251d | 2001-09-27 A | 2002-09-12 A |  | 100% | 2001-09-27 | 2002-09-12 | 251d | finish no earlier than 2002-09-12 | S5 | 2008h | 2008h | OAM-CH | T-Mobile | Karl-Heinz.Nenner@T-MOBILE.DE | Rel-5 | Dionisio |  | 32.225 |
| 1753 | 81.13 | **Other IETF dependencies** | 401d | 2000-11-24 A | 2002-06-07 A |  | 100% | 2000-11-24 | 2002-06-07 | 401d |  | NP | 9624h | 9624h |  |  |  | Rel-5 |  |  |  |
| 1754 | 81.13.1 | IETF: draft-ietf-aaa-diameter - should be CN4 | 401d | 2000-11-24 A | 2002-06-07 A |  | 100% | 2000-11-24 | 2002-06-07 | 401d | finish no earlier than 2002-06-07 | NP | 3208h | 3208h |  |  |  | Rel-5 |  |  |  |
| 1755 | 81.13.2 | IETF: draft-johansson-aaa-diameter-mm-app - should be CN4 | 401d | 2000-11-24 A | 2002-06-07 A |  | 100% | 2000-11-24 | 2002-06-07 | 401d | finish no earlier than 2002-06-07 | NP | 3208h | 3208h |  |  |  | Rel-5 |  |  |  |
| 1756 | 81.15 | Conformance Test Aspects - Provisioning of IMS | 205d | 2002-03-18 A | 2002-12-27 A |  | 100% | 2002-03-18 | 2002-12-27 | 205d | finish no earlier than 2002-12-27 | T1 | 1640h | 1640h | IMS-TEST |  |  | Rel-5 | Ingbert |  |  |
| 1757 | 81.16 | Testing of support for IMS - prose | 270d | 2002-09-18 A | 2003-09-30 A |  | 100% | 2002-09-18 | 2003-09-30 | 270d | finish no earlier than 2003-09-30 | T1 | 2160h | 2160h |  | Anritsu | dan.fox@eu.anritsu.com | Rel-5 | Ingbert |  | 34.108, 34.123 |
| 1758 | 81.17 | Testing of support for IMS - TTCN | 381d | 2002-09-18 A | 2004-03-03 A |  | 100% | 2002-09-18 | 2004-03-03 | 381d | finish no earlier than 2004-03-03 | T1 | 3048h | 3048h |  | Anritsu | dan.fox@eu.anritsu.com | Rel-5 | Ingbert |  | 34.108, 34.123 |
| 1759 | 82 | **Extended Transparent End-to-End PS Streaming Service** | 313d? | 2002-01-03 A | 2003-03-17 A |  | 100% | 2002-01-03 | 2003-03-17 | 313d? |  | S4 | 6224h | 6224h | PSS-E | Ericsson | olle.franceschi@ericsson.com | Rel-5 | Paolo |  | 26.233, 26.234 |
| 1760 | 82.1 | **Stage 1** | 86d? | 2002-11-18 A | 2003-03-17 A |  | 100% | 2002-11-18 | 2003-03-17 | 86d? |  | S1 | 1376h | 1376h |  | Vodafone | stephen.wolak@vodafone.com | Rel-5 | Alain |  | 22.233 |
| 1761 | 489.1.1 | Interaction with other services | 86d? | 2002-11-18 A | 2003-03-17 A |  | 100% | 2002-11-18 | 2003-03-17 | 86d? | finish no earlier than 2003-03-17 | S1 | 688h | 688h |  | Vodafone | stephen.wolak@vodafone.com | Rel-5 | Alain |  | 22.233 |
| 1762 | 82.2 | Stage 2 (version Rel5 of TS 26.234) | 51d | 2002-01-03 A | 2002-03-14 A |  | 100% | 2002-01-03 | 2002-03-14 | 51d | finish no earlier than 2002-03-26 | S4 | 408h | 408h |  |  |  | Rel-5 | Paolo |  | 26.234 |
| 1763 | 82.3 | RTP usage model | 242d | 2002-01-03 A | 2002-12-06 A |  | 100% | 2002-01-03 | 2002-12-06 | 242d | finish no earlier than 2002-12-06 | S4 | 1936h | 1936h |  |  |  | Rel-5 | Paolo |  | 26.937 |
| 1764 | 83 | **Rel-5 OSA enhancements** | 955d | 1999-04-27 A | 2002-12-20 A |  | 100% | 1999-04-27 | 2002-12-20 | 955d |  | S1 | 62480h | 62480h | OSA1 | Siemens | Joerg Swetina (joerg.swetina@nw.neclab.eu) | Rel-5 | Alain |  | 22.127, 23.127, 29.198-x, 29.998-x |
| 1765 | 83.1 | General Stage 2 for Rel5 | 194d | 2001-09-11 A | 2002-06-07 A |  | 100% | 2001-09-11 | 2002-06-07 | 194d |  | S2 | 1232h | 1232h |  |  |  | Rel-5 | Maurice |  |  |

Notes:
- 1742: SA16: Part of Rel5 only if Si completed in September 02
- 1743: DAB 12.12.01 split into cn4 and cn2 parts
- 1744: DAB 12.12.01 split into cn4 and cn2 parts
- 1745: DAB 12.12.01 split into cn4 and cn2 parts
- 1746: [DAB 08-03-02] - UID 12004 is MASTER of UID 14998 / 17 May need to be recearch possible impact on 23.008 & 23.016, changes to 29.002 are done.
- 1747: [DAB 08-03-02] - No activity on this in CN4. Marked as stopped 12/2008
- 1748: Marked as closed 12/2008 (was marked 60% complete)
- 1749: -
- 1750: -
- 1751: -
- 1752: -
- 1753: Was introduced at SP#13 by Ileana Leuca (exact position in the WP and related WG have to be defined)
- 1754: Marked as closed 12/2008 (was marked 90% complete)
- 1755: Marked as closed 12/2008 (was marked 50% complete)
- 1756: The task is a building block, individual work items are being considered but are constrained by lack of supporting companies. Marked as stopped 12/2008
- 1757: Marked as stopped 12/2008
- 1758: Marked as stopped 12/2008
- 1759: -
- 1760: 2nd resp SA4
- 1761: 2nd resp SA4. Marked as closed 12/2008 (was marked 65% complete)
- 1762: 2nd resp SA2
- 1763: Marked as closed 12/2008 (was marked 90% complete)
- 1764: -
- 1765: Marked as closed 12/2008 (was marked 47% complete)

| ID | WBS | Task | Duration | Start | Finish | Predecessors | Complete | Baseline start | Baseline finish | Baseline duration | Constraint | Resources | Work | Actual work | Text1 | Text6 | Text8 | Text3 | Text4 | Text5 |
| --- | --- | --- | --- | --- | --- | --- | --- | --- | --- | --- | --- | --- | --- | --- | --- | --- | --- | --- | --- | --- |
| 1766 | 83.2 | **OSA APIs for Multimedia Call Control** | 499d | 2000-07-11 A | 2002-06-07 A |  | 100% | 2000-07-11 | 2002-06-07 | 499d |  | S2 | 5960h | 5960h | OSA1-CSCF | Rel-5 | Maurice |  |  |  |
| 1767 | 83.2.1 | Stage 1 | 438d | 2000-07-11 A | 2002-03-14 A |  | 100% | 2000-07-11 | 2002-03-14 | 438d | finish no earlier than 2002-03-14 | S1 | 3504h | 3504h |  | Rel-5 | Alain | 22.127 | Siemens | Manfred.leitgeb@siemens.at |
| 1768 | 83.2.2 | (Multimedia) Call Control - Stages 2 and 3 | 194d | 2001-09-11 A | 2002-06-07 A |  | 100% | 2001-09-11 | 2002-06-07 | 194d | finish no earlier than 2002-06-07 | N5 | 1552h | 1552h |  | Rel-5 | Kimmo | 29.198-04 |  |  |
| 1769 | 83.3 | Generic user interaction - Stage 3 | 194d | 2001-09-11 A | 2002-06-07 A |  | 100% | 2001-09-11 | 2002-06-07 | 194d | finish no earlier than 2002-06-07 | N5 | 1552h | 1552h |  | Rel-5 | Kimmo | 29.198-05 |  |  |
| 1770 | 83.4 | Charging - Stage 3 | 194d | 2001-09-11 A | 2002-06-07 A |  | 100% | 2001-09-11 | 2002-06-07 | 194d | finish no earlier than 2002-06-07 | N5 | 1552h | 1552h |  | Rel-5 | Kimmo | 29.198-12 |  |  |
| 1771 | 83.5 | Call Control Service Mapping; Multiparty Call Control SIP - Stage 3 | 194d | 2001-09-11 A | 2002-06-07 A |  | 100% | 2001-09-11 | 2002-06-07 | 194d | finish no earlier than 2002-06-07 | N5 | 1552h | 1552h |  | Rel-5 | Kimmo | 29.998-04-4 |  |  |
| 1772 | 83.6 | WSDL APIs for SOAP/HTTP - Stage 3 | 455d | 2000-09-11 A | 2002-06-07 A |  | 100% | 2000-09-11 | 2002-06-07 | 455d | finish no earlier than 2002-06-07 | N5 | 3640h | 3640h |  | Rel-5 | Kimmo | 29.198, 29.998 |  |  |
| 1773 | 83.7 | **OSA security** | 639d | 2000-07-11 A | 2002-12-20 A |  | 100% | 2000-07-11 | 2002-12-20 | 639d |  | S3 | 15000h | 15000h | OSA1-SEC | Rel-5 | Dionisio |  | BT | colin.blanchard@bt.com |
| 1774 | 83.7.1 | Stage 1 | 349d | 2000-07-11 A | 2001-11-09 A |  | 100% | 2000-07-11 | 2001-11-09 | 349d | finish no earlier than 2001-11-09 | S1 | 2792h | 2792h |  | Rel-5 | Alain | 22.127 | Siemens | Manfred.leitgeb@siemens.at |
| 1775 | 83.7.2 | Stage 3 | 430d | 2000-10-23 A | 2002-06-14 A |  | 100% | 2000-10-23 | 2002-06-14 | 430d | finish no earlier than 2002-06-14 | S3 | 3440h | 3440h |  | Rel-5 | Dionisio |  |  |  |
| 1776 | 83.7.3 | security related SCF(s) definition | 186d | 2001-09-21 A | 2002-06-07 A |  | 100% | 2001-09-21 | 2002-06-07 | 186d | finish no earlier than 2002-06-07 | N5 | 1488h | 1488h |  | Rel-5 | Kimmo | 29.198, 29.998 | Ericsson | Ard.Jan.Moerdijk@eln.ericsson.se |
| 1777 | 83.7.4 | (possibly) changes required from supporting platforms, e.g. gsmSCF, HLR | 69d | 2000-09-11 A | 2000-12-14 A |  | 100% | 2000-09-11 | 2000-12-14 | 69d | finish no earlier than 2000-12-14 | S3 | 552h | 552h |  | Rel-5 | Dionisio |  |  |  |
| 1778 | 490.7.5 | Security (moved from Rel-6) | 202d | 2002-03-14 A | 2002-12-20 A |  | 100% | 2002-03-14 | 2002-12-20 | 202d | finish no earlier than 2002-12-20 | S3 | 1616h | 1616h |  | Rel-5 | Dionisio |  |  |  |
| 1779 | 83.8 | **Interactions OSA - e-commerce** | 815d | 1999-04-27 A | 2002-06-07 A |  | 100% | 1999-04-27 | 2002-06-07 | 815d |  | S2 | 6152h | 6152h | OSA1-ECOM | Rel-5 | Maurice |  |  |  |
| 1780 | 83.8.1 | Stage 1 | 439d | 1999-04-27 A | 2000-12-28 A |  | 100% | 1999-04-27 | 2000-12-28 | 439d | finish no earlier than 2000-12-28 | S1 | 3504h | 3504h |  | Rel-5 | Alain | 22.127 | Siemens | Joerg Swetina (joerg.swetina@nw.neclab.eu) |
| 1781 | 83.8.2 | Stages 2 and 3 | 186d | 2001-09-21 A | 2002-06-07 A |  | 100% | 2001-09-21 | 2002-06-07 | 186d | finish no earlier than 2002-06-07 | N5 | 1488h | 1488h |  | Rel-5 | Kimmo | 29.198, 29.998 | Ericsson | Ard.Jan.Moerdijk@eln.ericsson.se |
| 1782 | 83.9 | Policy Management - Stage 3 | 194d | 2001-09-11 A | 2002-06-07 A |  | 100% | 2001-09-11 | 2002-06-07 | 194d | finish no earlier than 2002-06-07 | N5 | 1552h | 1552h |  | Rel-5 | Kimmo | 29.198-13 |  |  |
| 1783 | 83.10 | Presence and Availability Management (PAM) - Stage 3 | 194d | 2001-09-11 A | 2002-06-07 A |  | 100% | 2001-09-11 | 2002-06-07 | 194d | finish no earlier than 2002-06-07 | N5 | 1552h | 1552h |  | Rel-5 | Kimmo | 29.198-14 |  |  |
| 1784 | 83.11 | **CHECK STATUS - LCS - OSA interfaces** | 455d | 2000-09-11 A | 2002-06-07 A |  | 100% | 2000-09-11 | 2002-06-07 | 455d |  | S1 | 5656h | 5656h | OSA1-LCSI | Rel-5 | Alain |  | Siemens | Joerg Swetina (joerg.swetina@nw.neclab.eu) |
| 1785 | 83.11.1 | Stage 1 | 65d | 2000-09-11 A | 2000-12-08 A |  | 100% | 2000-09-11 | 2000-12-08 | 65d | finish no earlier than 2000-12-08 | S1 | 520h | 520h |  | Rel-5 | Alain | 22.127 | Siemens | Joerg Swetina (joerg.swetina@nw.neclab.eu) |
| 1786 | 83.11.2 | Stage 2 | 1d | 2000-12-11 A | 2000-12-11 A | 1785 | 100% | 2000-12-11 | 2000-12-11 | 1d | finish no earlier than 2000-12-11 | S2 | 8h | 8h |  | Rel-5 | Maurice | 23.127 | Ericsson | Christophe GOURRAUD |
| 1787 | 83.11.3 | Stage 3 | 186d | 2001-09-21 A | 2002-06-07 A | 1786 | 100% | 2001-09-21 | 2002-06-07 | 186d | finish no earlier than 2002-06-07 | N5 | 1488h | 1488h |  | Rel-5 | Kimmo | 29.198, 29.998 | Ericsson | Ard.Jan.Moerdijk@eln.ericsson.se |
| 1788 | 490.12 | Access to User Profile | 145d | 2001-06-01 A | 2001-12-20 A |  | 100% | 2001-06-01 | 2001-12-20 | 145d | finish no earlier than 2001-12-20 | S1 | 1160h | 1160h | OSA2-UP | Rel-5 | Alain |  |  |  |
| 1789 | 490.13 | **Retrieval of Terminal capabilities** | 634d | 2000-07-11 A | 2002-12-13 A |  | 100% | 2000-07-11 | 2002-12-13 | 634d |  | S2 | 10808h | 10808h | OSA2-TC | Rel-5 | Maurice |  |  |  |
| 1790 | 490.13.1 | Stage 1 | 132d | 2000-07-11 A | 2001-01-10 A |  | 100% | 2000-07-11 | 2001-01-10 | 132d | finish no earlier than 2001-01-10 | S1 | 1056h | 1056h |  | Rel-5 | Alain | 22.127 | Siemens | Joerg Swetina (joerg.swetina@nw.neclab.eu) |
| 1791 | 490.13.2 | Stages 2 and 3 | 321d | 2001-09-21 A | 2002-12-13 A | 1790 | 100% | 2001-09-21 | 2002-12-13 | 321d | finish no earlier than 2002-12-13 | N5 | 2568h | 2568h |  | Rel-5 | Kimmo | 29.198, 29.998 | Ericsson | Ard.Jan.Moerdijk@eln.ericsson.se |
| 1792 | 490.13.3 | Provisioning of the terminal capabilities | 445d | 2001-04-02 A | 2002-12-13 A |  | 100% | 2001-04-02 | 2002-12-13 | 445d | finish no earlier than 2002-12-13 | T2 | 3560h | 3560h |  | Rel-5 |  | 23.057 |  |  |

Notes:
- 1766: For Rel5 even if completed by March
- 1767: -
- 1768: -
- 1769: -
- 1770: -
- 1771: -
- 1772: -
- 1773: CR to correct security specifications in 29.198 scheduled for approval at CN#15
- 1774: -
- 1775: Marked as closed 12/2008 (was marked 80% complete)
- 1776: -
- 1777: -
- 1778: Contribution at S3#25
- 1779: -
- 1780: Marked as closed 12/2008 (was marked 95% complete)
- 1781: -
- 1782: -
- 1783: -
- 1784: az: CN#13 - changed to Rel5
- 1785: -
- 1786: az 24/05/01: Rel4 completion 90->100%.
- 1787: -
- 1788: -
- 1789: -
- 1790: -
- 1791: -
- 1792: According to T2 SWG1 M. Cataldo this is automatically supported by the MExE support of UAProf therefore 100% complete

| ID | WBS | Task | Duration | Start | Finish | Predecessors | Complete | Baseline start | Baseline finish | Baseline duration | Constraint | Resources | Work | Actual work | Text1 | Text4 | Text5 | Text6 | Text8 | Text3 |
| --- | --- | --- | --- | --- | --- | --- | --- | --- | --- | --- | --- | --- | --- | --- | --- | --- | --- | --- | --- | --- |
| 1793 | 84 | **CAMEL phase 4** | 625d | 2000-04-17 A | 2002-09-06 A |  | 100% | 2000-04-17 | 2002-09-06 | 625d |  | S1 | 41104h | 41104h | CAMEL4 | Nokia | keijo.palviainen@nokia.com | Rel-5 | Alain |  |
| 1794 | 84.1 | Service requirements | 565d | 2000-04-17 A | 2002-06-14 A |  | 100% | 2000-04-17 | 2002-06-14 | 565d | finish no earlier than 2002-06-14 | S1 | 4520h | 4520h |  |  |  | Rel-5 | Alain |  |
| 1795 | 84.2 | Call Party Handling | 500d | 2000-07-10 A | 2002-06-07 A |  | 100% | 2000-07-10 | 2002-06-07 | 500d | finish no earlier than 2002-06-07 | N2 | 4000h | 4000h | CAMEL4-CPH |  |  | Rel-5 | Kimmo |  |
| 1796 | 84.3 | Mid call procedure for MO and MT calls | 495d | 2000-07-17 A | 2002-06-07 A |  | 100% | 2000-07-17 | 2002-06-07 | 495d | finish no earlier than 2002-06-07 | N2 | 3960h | 3960h | CAMEL4-MCP |  |  | Rel-5 | Kimmo |  |
| 1797 | 84.4 | Interactions with Optimal Routing | 430d | 2000-07-17 A | 2002-03-08 A |  | 100% | 2000-07-17 | 2002-03-08 | 430d | finish no earlier than 2002-03-08 | N2 | 3440h | 3440h | CAMEL4-IOR |  |  | Rel-5 | Kimmo |  |
| 1798 | 84.5 | Inclusion of flexible tone injection | 430d | 2000-07-17 A | 2002-03-08 A |  | 100% | 2000-07-17 | 2002-03-08 | 430d | finish no earlier than 2002-03-08 | N2 | 3440h | 3440h | CAMEL4-IFTI |  |  | Rel-5 | Kimmo |  |
| 1799 | 84.6 | CSE control over MT SMS | 430d | 2000-07-17 A | 2002-03-08 A |  | 100% | 2000-07-17 | 2002-03-08 | 430d | finish no earlier than 2002-03-08 | N2 | 3440h | 3440h | CAMEL4-CCSMS |  |  | Rel-5 | Kimmo |  |
| 1800 | 84.7 | Notification of GPRS mobility management to CSE | 331d | 2001-03-02 A | 2002-06-07 A |  | 100% | 2001-03-02 | 2002-06-07 | 331d | finish no earlier than 2002-06-07 | N2 | 2648h | 2648h | CAMEL4-NMM |  |  | Rel-5 | Kimmo |  |
| 1801 | 84.8 | Provision of location information of called subscriber | 266d | 2001-03-02 A | 2002-03-08 A |  | 100% | 2001-03-02 | 2002-03-08 | 266d | finish no earlier than 2002-03-08 | N2 | 2128h | 2128h | CAMEL4-LOCB |  |  | Rel-5 | Kimmo |  |
| 1802 | 84.9 | Inclusion of ODB data in the CSE_HLR interface | 175d | 2001-07-09 A | 2002-03-08 A |  | 100% | 2001-07-09 | 2002-03-08 | 175d | finish no earlier than 2002-03-08 | N2 | 1400h | 1400h | CAMEL4-ODB |  |  | Rel-5 | Kimmo |  |
| 1803 | 84.10 | Location information during an ongoing call (Handover DP) | 280d | 2001-05-14 A | 2002-06-07 A |  | 100% | 2001-05-14 | 2002-06-07 | 280d | finish no earlier than 2002-06-07 | N2 | 2240h | 2240h | CAMEL4-HODP |  |  | Rel-5 | Kimmo |  |
| 1804 | 84.11 | GPRS Any Time Interrogation | 240d | 2001-07-09 A | 2002-06-07 A |  | 100% | 2001-07-09 | 2002-06-07 | 240d | finish no earlier than 2002-06-07 | N2 | 1920h | 1920h | CAMEL4-ATI |  |  | Rel-5 | Kimmo |  |
| 1805 | 84.12 | Transfer of IMEI (with SW version) to CSE | 240d | 2001-07-09 A | 2002-06-07 A |  | 100% | 2001-07-09 | 2002-06-07 | 240d | finish no earlier than 2002-06-07 | N2 | 1920h | 1920h | CAMEL4-ATI |  |  | Rel-5 | Kimmo |  |
| 1806 | 84.13 | Handling of partial implementations of CAMEL4 | 131d | 2002-03-08 A | 2002-09-06 A |  | 100% | 2002-03-08 | 2002-09-06 | 131d | finish no earlier than 2002-06-07 | N2 | 1048h | 1048h | CAMEL4-SUB |  |  | Rel-5 | Kimmo |  |
| 1807 | 85 | **Rel-5 MExE enhancements** | 250d | 2001-03-26 A | 2002-03-08 A |  | 100% | 2001-03-26 | 2002-03-08 | 250d |  | T2 | 2880h | 2880h | MEXE5 |  |  | Rel-5 | Kimmo |  |
| 1808 | 85.1 | MExE Rel-5 Improvements and Investigations | 110d | 2001-03-26 A | 2002-03-08 A |  | 100% | 2001-03-26 | 2002-03-08 | 110d | finish no earlier than 2001-12-17 | T2 | 880h | 880h | MEXE5-ENHANC | Motorola | Mark Cataldo | Rel-5 |  | 22.057, 23.057 |
| 1809 | 86 | **Wideband Telephony Service - AMR** | 1036d | 2000-01-01 A | 2003-12-19 A |  | 100% | 2000-01-01 | 2003-12-19 | 1036d |  | S4 | 81496h | 81496h | AMRWB | Siemens | Imre.Varga@mch.siemens.de | Rel-5 | Paolo |  |
| 1810 | 86.1 | **Specification** | 636d | 2000-01-01 A | 2002-06-07 A |  | 100% | 2000-01-01 | 2002-06-07 | 636d |  | S4 | 19984h | 19984h |  |  |  | Rel-5 | Paolo |  |
| 1811 | 86.1.1 | Stage 1 | 125d | 2001-10-01 A | 2002-03-22 A |  | 100% | 2001-10-01 | 2002-03-22 | 125d | finish no earlier than 2002-03-22 | S1 | 1000h | 1000h |  |  |  | Rel-5 | Alain |  |
| 1812 | 86.1.2 | **Stage 2** | 77d | 2000-01-03 A | 2000-04-17 A |  | 100% | 2000-01-03 | 2000-04-17 | 77d |  | S4 | 1232h | 1232h |  |  |  | Rel-5 | Paolo |  |
| 1813 | 86.1.2.1 | Design Constraints | 27d | 2000-01-03 A | 2000-02-07 A |  | 100% | 2000-01-03 | 2000-02-07 | 27d |  | S4 [96.3%] | 208h | 208h |  |  |  | Rel-5 | Paolo |  |
| 1814 | 86.1.2.2 | General Description | 51d | 2000-02-07 A | 2000-04-17 A | 1813 | 100% | 2000-02-07 | 2000-04-17 | 51d | start no earlier than 2000-09-25 | S4 | 408h | 408h |  |  |  | Rel-5 | Paolo |  |
| 1815 | 86.1.3 | Feasibility Study | 26d | 2000-04-28 A | 2000-06-02 A | 1814 | 100% | 2000-04-28 | 2000-06-02 | 26d | finish no earlier than 2000-06-02 | S4 | 208h | 208h |  |  |  | Rel-5 | Paolo | 26.901 |
| 1816 | 86.1.4 | N1 Aspects | 66d | 2001-09-21 A | 2001-12-21 A |  | 100% | 2001-09-21 | 2001-12-21 | 66d | finish no earlier than 2001-12-21 | N1 | 528h | 528h |  |  |  | Rel-5 | Frederic |  |
| 1817 | 86.1.5 | N4 work | 83d | 2002-02-13 A | 2002-06-07 A |  | 100% | 2002-02-13 | 2002-06-07 | 83d | finish no earlier than 2002-06-07 | N4 | 664h | 664h |  |  |  | Rel-5 | Kimmo |  |

Notes:
- 1793: -
- 1794: -
- 1795: -
- 1796: -
- 1797: -
- 1798: -
- 1799: -
- 1800: -
- 1801: -
- 1802: Added on May 29, 2001
- 1803: -
- 1804: -
- 1805: -
- 1806: stage2 and stage3 CRs for approval at CN#17
- 1807: -
- 1808: -
- 1809: -
- 1810: -
- 1811: -
- 1812: -
- 1813: -
- 1814: -
- 1815: S4,TD SP-000024: TR 26.901 v.4.0.0
- 1816: Some of N1 tasks: Indication of supported codecs by the MS, Bearer cap negociation, codec indication to MS... / One common set of codec negotiation procedures will be specified as in ID1657.
- 1817: CN4#11 30/11/01: No inputs to CN4 at this meeting / 14/02/02 work started 50% reached / 17 May work is done 100%

| ID | WBS | Task | Duration | Start | Finish | Predecessors | Complete | Baseline start | Baseline finish | Baseline duration | Constraint | Resources | Work | Actual work | Text6 | Text8 | Text1 | Text3 | Text12 | Text4 | Text5 |
| --- | --- | --- | --- | --- | --- | --- | --- | --- | --- | --- | --- | --- | --- | --- | --- | --- | --- | --- | --- | --- | --- |
| 1818 | 86.1.6 | **Codec issues** | 636d | 2000-01-03 A | 2002-06-07 A |  | 100% | 2000-01-03 | 2002-06-07 | 636d |  | S4 | 9496h | 9496h | Rel-5 | Paolo |  |  |  |  |  |
| 1819 | 86.1.6.1 | Codec qualification | 86d | 2000-02-02 A | 2000-05-31 A |  | 100% | 2000-02-02 | 2000-05-31 | 86d | finish no earlier than 2000-05-31 | S4 | 688h | 688h | Rel-5 | Paolo |  |  |  |  |  |
| 1820 | 86.1.6.2 | Codec selection tests | 102d | 2000-06-01 A | 2000-10-20 A | 1819 | 100% | 2000-06-01 | 2000-10-20 | 102d | finish no earlier than 2000-10-20 | S4 | 816h | 816h | Rel-5 | Paolo |  |  |  |  |  |
| 1821 | 86.1.6.3 | Codec selection | 5d | 2000-10-23 A | 2000-10-27 A | 1820 | 100% | 2000-10-23 | 2000-10-27 | 5d | finish no earlier than 2000-10-27 | S4 | 40h | 40h | Rel-5 | Paolo |  |  |  |  |  |
| 1822 | 86.1.6.4 | TFO AMR-WB | 63d | 2001-12-18 A | 2002-03-14 A |  | 100% | 2001-12-18 | 2002-03-14 | 63d | finish no earlier than 2002-03-14 | S4 | 504h | 504h | Rel-5 | Paolo | AMRWB-TFO |  |  |  |  |
| 1823 | 86.1.6.5 | Other codec issues (verif., characterization) | 441d | 2000-09-29 A | 2002-06-07 A |  | 100% | 2000-09-29 | 2002-06-07 | 441d | finish no earlier than 2002-06-07 | S4 | 3528h | 3528h | Rel-5 | Paolo |  | 26.976 |  |  |  |
| 1824 | 86.1.6.6 | AMR-WB and narrrowband interworking | 121d | 2001-09-27 A | 2002-03-14 A |  | 100% | 2001-09-27 | 2002-03-14 | 121d | finish no earlier than 2002-03-14 | S4 | 968h | 968h | Rel-5 | Paolo | AMRWB-IWG |  |  |  |  |
| 1825 | 86.1.6.7 | Interworking with fixed broadband networks | 121d | 2001-09-27 A | 2002-03-14 A |  | 100% | 2001-09-27 | 2002-03-14 | 121d | finish no earlier than 2002-03-14 | S4 | 968h | 968h | Rel-5 | Paolo |  |  |  |  |  |
| 1826 | 86.1.6.8 | Tones and announcements | 121d | 2001-09-27 A | 2002-03-14 A |  | 100% | 2001-09-27 | 2002-03-14 | 121d | finish no earlier than 2002-03-14 | S4 | 968h | 968h | Rel-5 | Paolo |  |  |  |  |  |
| 1827 | 86.1.6.9 | Deleted - WB Conferencing and WB Voice Group calls | 1d | 2000-01-03 A | 2000-01-03 A |  | 100% | 2000-01-03 | 2000-01-03 | 1d | finish no earlier than 2000-01-03 | S1 | 8h | 8h | Rel-5 | Alain |  |  | SP-07 |  |  |
| 1828 | 86.1.8 | **Conformance tests (CRs to 34 series)** | 74d | 2000-01-01 A | 2000-04-12 A |  | 100% | 2000-01-01 | 2000-04-12 | 74d |  | T1 | 1768h | 1768h | Rel-5 | Ingbert |  |  |  |  |  |
| 1829 | 86.1.8.1 | **Terminal Acoustic Characteristics** | 74d | 2000-01-01 A | 2000-04-12 A |  | 100% | 2000-01-01 | 2000-04-12 | 74d |  | S4 | 1176h | 1176h | Rel-5 | Paolo |  |  |  |  |  |
| 1830 | 86.1.8.1.1 | Definition | 22d | 2000-01-01 A | 2000-01-31 A |  | 100% | 2000-01-01 | 2000-01-31 | 22d | finish no earlier than 2000-01-28 | S4 [95.5%] | 168h | 168h | Rel-5 | Paolo |  | 26.131 |  |  |  |
| 1831 | 86.1.8.1.2 | Test specification | 52d | 2000-02-01 A | 2000-04-12 A | 1830 | 100% | 2000-02-01 | 2000-04-12 | 52d | finish no earlier than 2000-03-13 | S4 | 416h | 416h | Rel-5 | Paolo |  | 26.132 |  |  |  |
| 1832 | 86.2 | Floating-point ANSI-C code for the AMR-WB speech codec | 123d | 2001-09-25 A | 2002-03-14 A |  | 100% | 2001-09-25 | 2002-03-14 | 123d | finish no earlier than 2002-03-14 | S4 | 984h | 984h | Rel-5 | Paolo | AMRWB-FP | 26.204 |  | Nokia | janne.m.vainio@nokia.com |
| 1833 | 86.3 | **Support of AMR-WB in GERAN: GMSK and 8PSK WB FR / HR** | 651d | 2000-01-03 A | 2002-06-28 A |  | 100% | 2000-01-03 | 2002-06-28 | 651d |  | GP | 23488h | 23488h | Rel-5 | Paolo | GAMRWB |  |  |  |  |
| 1834 | 86.3.1 | Channel coding in 45.003 | 591d | 2000-01-03 A | 2002-04-05 A |  | 100% | 2000-01-03 | 2002-04-05 | 591d |  | GP | 4720h | 4720h | Rel-5 | Paolo |  |  |  |  |  |
| 1835 | 86.3.2 | Signalling for the A interface | 391d | 2000-01-03 A | 2001-06-29 A |  | 100% | 2000-01-03 | 2001-06-29 | 391d | finish no earlier than 2001-06-29 | GP | 3120h | 3120h | Rel-5 | Paolo |  |  |  |  |  |
| 1836 | 86.3.3 | Signalling for Iu | 651d | 2000-01-03 A | 2002-06-28 A |  | 100% | 2000-01-03 | 2002-06-28 | 651d | finish no earlier than 2002-06-28 | GP | 5200h | 5200h | Rel-5 | Paolo |  |  |  |  |  |
| 1837 | 86.3.4 | Receiver performance in TS 45.005 | 325d | 2001-04-02 A | 2002-06-28 A |  | 100% | 2001-04-02 | 2002-06-28 | 325d | finish no earlier than 2002-06-28 | GP | 2600h | 2600h | Rel-5 | Paolo |  |  |  |  |  |
| 1838 | 86.3.5 | Link Adaptation in 45.009 | 330d | 2001-03-26 A | 2002-06-28 A |  | 100% | 2001-03-26 | 2002-06-28 | 330d | finish no earlier than 2002-06-28 | GP | 2640h | 2640h | Rel-5 | Paolo |  |  |  |  |  |
| 1839 | 86.4 | **Deleted - GERAN MS conformance test for AMR-WB** | 1036d | 2000-01-03 A | 2003-12-19 A |  | 100% | 2000-01-03 | 2003-12-19 | 1036d |  | GP | 16568h | 16568h | Rel-5 | Paolo |  |  |  |  |  |
| 1840 | 86.4.1 | Deleted - MS test for AMR-WB | 1036d | 2000-01-03 A | 2003-12-19 A |  | 100% | 2000-01-03 | 2003-12-19 | 1036d | finish no earlier than 2003-12-19 | GP | 8280h | 8280h | Rel-5 | Paolo |  |  | GP-17 |  |  |
| 1841 | 86.5 | **GERAN BTS conformance test for AMR-WB** | 762d | 2000-01-03 A | 2002-12-02 A |  | 100% | 2000-01-03 | 2002-12-02 | 762d |  | GP | 12184h | 12184h | Rel-5 | Paolo |  |  |  |  |  |
| 1842 | 86.5.1 | BTS test | 762d | 2000-01-03 A | 2002-12-02 A |  | 100% | 2000-01-03 | 2002-12-02 | 762d | finish no earlier than 2002-12-02 | GP | 6088h | 6088h | Rel-5 | Paolo |  |  |  |  |  |

Notes:
- 1818: -
- 1819: -
- 1820: -
- 1821: -
- 1822: -
- 1823: ANSI C-Code , Test Sequences, Speech Transcoding Functions, Error Concealment of lost frames, Source Controlled Bit-Rate Operation, Voice Activity Detector, Frame Structure
- 1824: -
- 1825: -
- 1826: -
- 1827: -
- 1828: -
- 1829: -
- 1830: -
- 1831: -
- 1832: -
- 1833: -
- 1834: 50098 -> 50298
- 1835: -
- 1836: -
- 1837: -
- 1838: -
- 1839: Not started 02/2003. Marked as stopped 12/2008
- 1840: Marked as stopped 12/2008
- 1841: -
- 1842: -

| ID | WBS | Task | Duration | Start | Finish | Complete | Baseline start | Baseline finish | Baseline duration | Constraint | Resources | Work | Actual work | Text1 | Text6 | Text8 | Text3 | Text4 | Text5 |
| --- | --- | --- | --- | --- | --- | --- | --- | --- | --- | --- | --- | --- | --- | --- | --- | --- | --- | --- | --- |
| 1843 | 11 | **Terminal interfaces** | 223d | 2001-05-14 A | 2002-03-20 A | 100% | 2001-05-14 | 2002-03-20 | 223d |  | T2 | 3568h | 3568h | TI | Rel-5 | Kimmo |  |  |  |
| 1844 | 87 | Terminal local model enhancements | 223d | 2001-05-14 A | 2002-03-20 A | 100% | 2001-05-14 | 2002-03-20 | 223d | finish no earlier than 2002-03-20 | T2 | 1784h | 1784h | TLM5 | Rel-5 |  | 23.227 |  |  |
| 1845 | 88 | **Rel-5 Location Services enhancements** | 845d | 2000-04-03 A | 2003-06-27 A | 100% | 2000-04-03 | 2003-06-27 | 845d |  | S2,S5 | 86804h | 86804h | LCS1 | Rel-5 | Maurice |  | Nokia | Jan Kall |
| 1846 | 88.1 | **UE positioning** | 315d | 2001-01-15 A | 2002-03-29 A | 100% | 2001-01-15 | 2002-03-29 | 315d |  | RP | 5560h | 5560h | LCS1-UEpos | Rel-5 | Issam |  |  |  |
| 1847 | 88.1.1 | UE positioning enhancements for 1.28 Mcps TDD | 255d | 2001-04-09 A | 2002-03-29 A | 100% | 2001-04-09 | 2002-03-29 | 255d | finish no earlier than 2002-03-29 | R2 | 2040h | 2040h | LCS-128Pos | Rel-5 | Joern |  | CATT | Xiaohua Mei |
| 1848 | 88.1.2 | Open SMLC-SRNC Interface within the UTRAN to support A-GPS Positioning | 195d | 2001-01-15 A | 2001-10-12 A | 100% | 2001-01-15 | 2001-10-12 | 195d |  | R2 | 1560h | 1560h | LCS-INTF | Rel-5 | Joern |  | Qualcomm Europe | Kirk Burroughs |
| 1849 | 88.2 | **Event based and Periodic LCS** | 535d | 2000-05-22 A | 2002-06-07 A | 100% | 2000-05-22 | 2002-06-07 | 535d |  | S1 | 6288h | 6288h | LCS1-EBP | Rel-5 | Alain |  |  |  |
| 1850 | 88.2.1 | Stage 1 | 130d | 2000-05-22 A | 2000-11-17 A | 100% | 2000-05-22 | 2000-11-17 | 130d | finish no earlier than 2000-07-21 | S1 | 1040h | 1040h |  | Rel-5 | Alain | 22.071 | Pacific Bell Wireless | Randolph Wohlert (rwohlert@tri.sbc.com) |
| 1851 | 88.2.2 | Stage 2 specification | 60d | 2000-11-06 A | 2001-01-26 A | 100% | 2000-11-06 | 2001-01-26 | 60d | finish no earlier than 2001-01-26 | S2 | 480h | 480h |  | Rel-5 | Maurice |  |  |  |
| 1852 | 88.2.3 | Impact on MAP | 61d | 2002-03-15 A | 2002-06-07 A | 100% | 2002-03-15 | 2002-06-07 | 61d | finish no earlier than 2002-06-07 | N4 | 488h | 488h |  | Rel-5 | Kimmo |  |  |  |
| 1853 | 88.3 | **Location Services for GERAN in A/Gb Mode** | 485d | 2000-04-03 A | 2002-02-08 A | 100% | 2000-04-03 | 2002-02-08 | 485d |  | GP | 14760h | 14760h | LCS-GERAN | Rel-5 | Paolo |  |  |  |
| 1854 | 88.3.1 | GERAN LCS Stage 2 (first release) | 485d | 2000-04-03 A | 2002-02-08 A | 100% | 2000-04-03 | 2002-02-08 | 485d | finish no earlier than 2002-02-08 | GP,S2,G1,G2 | 3880h | 3880h |  | Rel-5 | Paolo |  |  |  |
| 1855 | 88.3.2 | Gb interface support for LCS | 370d | 2000-04-03 A | 2001-08-31 A | 100% | 2000-04-03 | 2001-08-31 | 370d | finish no earlier than 2001-08-31 | GP | 2960h | 2960h |  | Rel-5 | Paolo |  |  |  |
| 1856 | 88.3.3 | L3 protocol support for LCS | 305d | 2000-04-03 A | 2001-06-01 A | 100% | 2000-04-03 | 2001-06-01 | 305d | finish no earlier than 2001-06-01 | GP | 2440h | 2440h |  | Rel-5 | Paolo |  |  |  |
| 1857 | 88.3.4 | Stage 3 specifications | 305d | 2000-04-03 A | 2001-06-01 A | 100% | 2000-04-03 | 2001-06-01 | 305d | finish no earlier than 2001-06-01 | GP | 2440h | 2440h |  | Rel-5 | Paolo |  |  |  |
| 1858 | 88.4 | **Location Services for GERAN in Iu Mode** | 585d | 2000-04-03 A | 2002-06-28 A | 100% | 2000-04-03 | 2002-06-28 | 585d |  | S2,G1,G2,R2,R3 | 20996h | 20996h |  | Rel-5 | Paolo |  |  |  |
| 1859 | 88.4.1 | GERAN LCS Stage 2 | 585d | 2000-04-03 A | 2002-06-28 A | 100% | 2000-04-03 | 2002-06-28 | 585d | finish no earlier than 2002-06-28 | S2,G1,G2 | 4680h | 4680h |  | Rel-5 | Paolo |  |  |  |
| 1860 | 88.4.2 | Iu-ps interface support for LCS | 585d | 2000-04-03 A | 2002-06-28 A | 100% | 2000-04-03 | 2002-06-28 | 585d | finish no earlier than 2002-06-28 | R2,R3 | 4680h | 4680h |  | Rel-5 | Paolo |  |  |  |
| 1861 | 88.4.3 | Iu-cs interface support for LCS | 585d | 2000-04-03 A | 2002-06-28 A | 100% | 2000-04-03 | 2002-06-28 | 585d | finish no earlier than 2002-06-28 | R2,R3 | 4680h | 4680h |  | Rel-5 | Paolo |  |  |  |
| 1862 | 88.4.4 | Iur-g interface support for LCS | 62.5d | 2002-01-23 A | 2002-04-19 A | 100% | 2002-01-23 | 2002-04-19 | 62.5d | finish no earlier than 2002-04-19 | G1,G2 | 500h | 500h |  | Rel-5 | Paolo |  |  |  |
| 1863 | 88.4.5 | RRC protocol support for LCS | 75d | 2001-08-20 A | 2001-11-30 A | 100% | 2001-08-20 | 2001-11-30 | 75d | finish no earlier than 2001-11-30 | G1,G2,R2,R3 | 600h | 600h |  | Rel-5 | Paolo |  |  |  |
| 1864 | 88.4.6 | Additional impacts on Broadcast of LCS data on packet channels | 77.5d | 2001-08-20 A | 2001-12-05 A | 100% | 2001-08-20 | 2001-12-05 | 77.5d | finish no earlier than 2001-12-05 | G1,G2,R2,R3 | 620h | 620h |  | Rel-5 | Paolo |  |  |  |
| 1865 | 88.4.7 | Stage 3 specifications | 69.5d | 2002-03-25 A | 2002-06-28 A | 100% | 2002-03-25 | 2002-06-28 | 69.5d | finish no earlier than 2002-06-28 | G1,G2,R2,R3 | 556h | 556h |  | Rel-5 | Paolo |  |  |  |
| 1866 | 88.5 | **GERAN MS Conformance test for LCS** | 280d | 2002-06-03 A | 2003-06-27 A | 100% | 2002-06-03 | 2003-06-27 | 280d |  | GP | 6720h | 6720h | LCS-GERAN-MSconf | Rel-5 | Paolo |  |  |  |
| 1867 | 88.5.1 | Develop LCS MS test case work plan (Release 98/99/4) | 280d | 2002-06-03 A | 2003-06-27 A | 100% | 2002-06-03 | 2003-06-27 | 280d | finish no earlier than 2003-06-27 | G4,G5 | 2240h | 2240h |  | Rel-5 | Paolo |  |  |  |
| 1868 | 88.5.2 | Develop LCS MS test cases | 280d | 2002-06-03 A | 2003-06-27 A | 100% | 2002-06-03 | 2003-06-27 | 280d | finish no earlier than 2003-06-27 | G4,G5 | 2240h | 2240h |  | Rel-5 | Paolo |  |  |  |

Notes:
- 1843: -
- 1844: -
- 1845: -
- 1846: -
- 1847: -
- 1848: Finished at RP#13
- 1849: -
- 1850: Evaluate Event based and Periodic LCS to be included in R00, corresponding Stage 1 description
- 1851: Marked as closed 12/2008 (was marked 51% complete)
- 1852: Possible impact on UTRAN of LCS quality level request / 17 May No stage 2 for event-based & periodic LCS. Work 100% completefor current stage 2
- 1853: -
- 1854: -
- 1855: -
- 1856: -
- 1857: -
- 1858: -
- 1859: -
- 1860: -
- 1861: -
- 1862: FFS
- 1863: -
- 1864: -
- 1865: -
- 1866: -
- 1867: Marked as closed 12/2008 (was marked 60% complete)
- 1868: Marked as closed 12/2008 (was marked 60% complete)

| ID | WBS | Task | Duration | Start | Finish | Predecessors | Complete | Baseline start | Baseline finish | Baseline duration | Constraint | Resources | Work | Actual work | Text1 | Text6 | Text8 | Text12 | Text3 | Text4 | Text5 |
| --- | --- | --- | --- | --- | --- | --- | --- | --- | --- | --- | --- | --- | --- | --- | --- | --- | --- | --- | --- | --- | --- |
| 1869 | 88.6 | **Deleted - GERAN BTS Conformance test for LCS** | 280d | 2002-06-03 A | 2003-06-27 A |  | 100% | 2002-06-03 | 2003-06-27 | 280d |  | GP | 6720h | 6720h | LCS-GERAN-BTSconf | Rel-5 | Paolo | GP-15 |  |  |  |
| 1870 | 88.6.1 | Deleted - Develop LCS BTS test case work plan (Release 98/99/4) | 280d | 2002-06-03 A | 2003-06-27 A |  | 100% | 2002-06-03 | 2003-06-27 | 280d | finish no earlier than 2003-06-27 | G4,G5 | 2240h | 2240h |  | Rel-5 | Paolo | GP-15 |  |  |  |
| 1871 | 88.6.2 | Deleted - Develop LCS BTS test cases | 280d | 2002-06-03 A | 2003-06-27 A |  | 100% | 2002-06-03 | 2003-06-27 | 280d | finish no earlier than 2003-06-27 | G4,G5 | 2240h | 2240h |  | Rel-5 | Paolo | GP-15 |  |  |  |
| 1872 | 88.7 | LCS interoperation stage 2 aspects | 480d | 2000-08-28 A | 2002-06-28 A |  | 100% | 2000-08-28 | 2002-06-28 | 480d |  | S2 | 3840h | 3840h |  | Rel-5 | Maurice |  |  |  |  |
| 1873 | 88.8 | **LCS interoperability aspects to GERAN** | 480d | 2000-08-28 A | 2002-06-28 A |  | 100% | 2000-08-28 | 2002-06-28 | 480d |  | GP,S5 | 7680h | 7680h | LCS-GERAN | Rel-5 | Paolo |  |  |  |  |
| 1874 | 88.8.1 | Co-ordinated development of GSM LCS Phase 2 and UMTS LCS, S2 and GERAN | 480d | 2000-08-28 A | 2002-06-28 A |  | 100% | 2000-08-28 | 2002-06-28 | 480d | finish no earlier than 2002-06-28 | GP,S2,S5,R2,R3,G2,G1 | 3840h | 3840h | LCS-GERAN | Rel-5 | Paolo |  |  |  |  |
| 1875 | 88.9 | FS on LCS support in the IMS | 90d | 2001-02-12 A | 2002-01-18 A |  | 100% | 2001-02-12 | 2002-01-18 | 90d | start no earlier than 2001-02-12 | S1 | 720h | 720h |  | Rel-5 | Alain |  |  |  |  |
| 1876 | 88.10 | Charging and OAM&P for LCS enhancements | 201d | 2001-09-21 A | 2002-06-28 A |  | 100% | 2001-09-21 | 2002-06-28 | 201d | finish no earlier than 2002-06-28 | S5 | 1608h | 1608h | LCS1-OAM | Rel-5 | Dionisio |  | 32-series | VoiceStream, Motorola |  |
| 1877 | 88.11 | New security aspects of LCS (not identified) | 446d | 2000-04-14 A | 2001-12-28 A |  | 100% | 2000-04-14 | 2001-12-28 | 446d | finish no earlier than 2001-12-28 | S3 | 3568h | 3568h | LCS1-SEC | Rel-5 | Dionisio |  |  | Nokia | valtteri.niemi@nokia.com |
| 1878 | 88.12 | Specification for the Le Interface | 45d | 2002-01-14 A | 2002-03-15 A |  | 100% | 2002-01-14 | 2002-03-15 | 45d | start no earlier than 2002-01-14 | S2 | 360h | 360h | LCS1-Le | Rel-5 | Maurice |  |  |  |  |
| 1879 | 88.13 | Deleted - CHECK STATUS - Inter-GMLC interface | 153d | 2002-05-30 A | 2002-12-30 A |  | 100% | 2002-05-30 | 2002-12-30 | 153d | finish no earlier than 2002-12-30 | S2 | 1224h | 1224h |  | Rel-5 | Maurice | SP-10 |  |  |  |
| 1880 | 89 | **Rel-5 Security enhancements** | 615d | 2000-02-21 A | 2002-06-28 A |  | 100% | 2000-02-21 | 2002-06-28 | 615d |  | S3 | 29974.9h | 29974.9h |  | Rel-5 | Dionisio |  |  | Vodafone | Peter.Howard@vodafone.com |
| 1881 | 89.1 | **Network domain security** | 615d | 2000-02-21 A | 2002-06-28 A |  | 100% | 2000-02-21 | 2002-06-28 | 615d |  | S3 | 25054.9h | 25054.9h | SEC1-NDS | Rel-5 | Dionisio |  |  | Telenor | Geir-myrdahl.koien@telenor.com |
| 1882 | 89.1.1 | **Deleted -Control plane protection in core network (e.g., GTP, CAP, MAP/IP, provided by IPsec)** | 541d | 2000-05-12 A | 2002-06-07 A |  | 100% | 2000-05-12 | 2002-06-07 | 541d |  | S3 | 7118.9h | 7118.9h |  | Rel-5 | Dionisio | SP-16 |  |  |  |
| 1883 | 89.1.1.1 | Deleted - Main aspects | 290d | 2000-05-12 A | 2001-06-21 A |  | 100% | 2000-05-12 | 2001-06-21 | 290d | finish no earlier than 2001-06-21 | S3 | 2320h | 2320h |  | Rel-5 | Dionisio | SP-12 |  |  |  |
| 1884 | 89.1.1.2 | Deleted -Integration of GTP signalling security architecture | 191d | 2001-09-14 A | 2002-06-07 A |  | 100% | 2001-09-14 | 2002-06-07 | 191d | finish no earlier than 2002-06-07 | N4 | 1528h | 1528h |  | Rel-5 | Kimmo | NP-16 |  |  |  |
| 1885 | 89.1.2 | **Deleted -User plane protection in core network (e.g., provided by IPsec)** | 615d | 2000-02-21 A | 2002-06-28 A |  | 100% | 2000-02-21 | 2002-06-28 | 615d |  | S3 | 9360h | 9360h |  | Rel-5 | Dionisio | SP-16 |  |  |  |
| 1886 | 89.1.2.1 | Deleted -Main aspects | 349d | 2000-02-21 A | 2001-06-21 A |  | 100% | 2000-02-21 | 2001-06-21 | 349d | finish no earlier than 2001-06-21 | S3 | 2792h | 2792h |  | Rel-5 | Dionisio | SP-12 |  |  |  |
| 1887 | 89.1.2.2 | Deleted -Integration of GTP signalling security architecture | 206d | 2001-09-14 A | 2002-06-28 A |  | 100% | 2001-09-14 | 2002-06-28 | 206d | finish no earlier than 2002-06-28 | N4 | 1648h | 1648h |  | Rel-5 | Kimmo | NP-16 |  |  |  |
| 1888 | 89.1.3 | IP network layer security (NDS/IP) | 457d | 2000-06-15 A | 2002-03-15 A |  | 100% | 2000-06-15 | 2002-03-15 | 457d | finish no earlier than 2002-03-15 | S3 | 3656h | 3656h | SEC1-NDS-IP | Rel-5 | Dionisio |  | 33.210 | Telenor | Geir-myrdahl.koien@telenor.com |
| 1889 | 90 | **Intra Domain Connection of RAN Nodes to Multiple CN Nodes** | 455d | 2000-10-02 A | 2002-06-28 A |  | 100% | 2000-10-02 | 2002-06-28 | 455d |  | S2 | 15136h | 15136h | IUFLEX | Rel-5 | Alain |  | 23.236 | Ericsson | stephen.terrill@ericsson.com |
| 1890 | 90.1 | Overall System Architecture | 188d | 2001-01-03 A | 2001-09-21 A |  | 100% | 2001-01-03 | 2001-09-21 | 188d | finish no earlier than 2001-06-01 | S2 | 1504h | 1504h |  | Rel-5 | Maurice |  |  |  |  |
| 1891 | 90.2 | Stage 3: RAN node selecting CN node | 130d | 2001-09-24 A | 2002-03-22 A | 1890 | 100% | 2001-09-24 | 2002-03-22 | 130d | finish no earlier than 2002-03-22 | R3 | 1040h | 1040h |  | Rel-5 | Juha |  |  | Vodafone | Brendan.McWilliams@gb.vodafone.co.uk |
| 1892 | 90.3 | N1 work | 205d | 2001-09-17 A | 2002-06-28 A |  | 100% | 2001-09-17 | 2002-06-28 | 205d | start no earlier than 2001-09-17 | N1 | 1640h | 1640h |  | Rel-5 | Frederic |  | 24.008 and check 29.018 |  |  |
| 1893 | 90.4 | N4 work | 375d | 2000-10-02 A | 2002-03-08 A |  | 100% | 2000-10-02 | 2002-03-08 | 375d | finish no earlier than 2002-03-15 | N4 | 3000h | 3000h |  | Rel-5 | Kimmo |  |  |  |  |

Notes:
- 1869: Not started 02/3003. Marked as stopped 12/2008
- 1870: Marked as stopped 12/2008
- 1871: Marked as stopped 12/2008
- 1872: Marked as closed 12/2008 (was marked 17% complete)
- 1873: -
- 1874: -
- 1875: Marked as closed 12/2008 (was marked 75% complete)
- 1876: -
- 1877: 14/09/00: WI may need to be split to improve on this date. S3#17 15% complete. No progress since S3#17
- 1878: -
- 1879: Marked as stopped 12/2008
- 1880: Added BB UE authentication and rapporteur added. TO BE DELETED
- 1881: S3#17: All due in Rel5. (WI Update at S3#18). Replaced by NDS-IP and NDS-MAP. TO BE DELETED OR MOVED TO HISTORY FILE
- 1882: Marked as stopped 12/2008
- 1883: TO BE DELETED. Marked as stopped 12/2008
- 1884: Waiting for input from SA3!.... Marked as stopped 12/2008
- 1885: TO BE DELETED. Marked as stopped 12/2008
- 1886: -
- 1887: 14/02/2002 requirements are not clear/not received...Marked as closed 12/2008 (was marked 95 complete)
- 1888: 2002/12: All IPsec RFCs are stable STD Track RFCs. WID updated SP#17
- 1889: No clear indication on the end date. Put to Rel5 by AS.
- 1890: -
- 1891: Not identified
- 1892: -
- 1893: DAB 12.12.01 - % complete to 66% / 14/02/02 Work completed

| ID | WBS | Task | Duration | Start | Finish | Complete | Baseline start | Baseline finish | Baseline duration | Constraint | Resources | Work | Actual work | Text1 | Text4 | Text5 | Text6 | Text8 | Text12 | Text3 |
| --- | --- | --- | --- | --- | --- | --- | --- | --- | --- | --- | --- | --- | --- | --- | --- | --- | --- | --- | --- | --- |
| 1894 | 90.5 | **GERAN work for Intra Domain Connection of RAN Nodes to Multiple CN Nodes** | 101d | 2002-02-08 A | 2002-06-28 A | 100% | 2002-02-08 | 2002-06-28 | 101d |  | GP | 4848h | 4848h | IDCRAN-GERAN | Ericsson | ingemar.backlund@era.ericsson.se | Rel-5 | Paolo |  |  |
| 1895 | 90.5.1 | Stage 2 (changes to ) | 101d | 2002-02-08 A | 2002-06-28 A | 100% | 2002-02-08 | 2002-06-28 | 101d | finish no earlier than 2002-06-28 | G1 | 808h | 808h |  |  |  | Rel-5 |  |  |  |
| 1896 | 90.5.2 | 43.051 Introduction of support for IDNNS in GERAN Iu mode | 101d | 2002-02-08 A | 2002-06-28 A | 100% | 2002-02-08 | 2002-06-28 | 101d | finish no earlier than 2002-06-28 | G1 | 808h | 808h |  |  |  | Rel-5 |  |  |  |
| 1897 | 90.5.3 | Stage 3 (changes to ) | 101d | 2002-02-08 A | 2002-06-28 A | 100% | 2002-02-08 | 2002-06-28 | 101d | finish no earlier than 2002-06-28 | G2 | 808h | 808h |  |  |  | Rel-5 | Gert |  |  |
| 1898 | 90.5.4 | 48.016 Use of Gb interface concepts when a network applies IDNNS | 101d | 2002-02-08 A | 2002-06-28 A | 100% | 2002-02-08 | 2002-06-28 | 101d | finish no earlier than 2002-06-28 | G2 | 808h | 808h |  |  |  | Rel-5 | Gert |  |  |
| 1899 | 90.5.5 | 48.018 Include MSC/VLR identity in CS IMSI paging | 101d | 2002-02-08 A | 2002-06-28 A | 100% | 2002-02-08 | 2002-06-28 | 101d | finish no earlier than 2002-06-28 | G2 | 808h | 808h |  |  |  | Rel-5 | Gert |  |  |
| 1900 | 91 | **Deleted - GERAN improvements 3 (new transport layer on interface A)** | 446d | 2001-04-06 A | 2002-12-20 A | 100% | 2001-04-06 | 2002-12-20 | 446d |  | GP | 14272h | 14272h | GEIMP3 |  |  | Rel-5 | Paolo |  |  |
| 1901 | 91.1 | **Deleted - Evolution of the transport for A** | 446d | 2001-04-06 A | 2002-12-20 A | 100% | 2001-04-06 | 2002-12-20 | 446d |  | GP | 10704h | 10704h | GEIMP3-EtA |  |  | Rel-5 | Paolo | GP-12 |  |
| 1902 | 91.1.1 | Deleted - Definition of a new A/Ater interface Transport Layer option based on the Iu Interface Transport Layer | 446d | 2001-04-06 A | 2002-12-20 A | 100% | 2001-04-06 | 2002-12-20 | 446d | finish no earlier than 2002-12-20 | GP | 3568h | 3568h |  |  |  | Rel-5 | Paolo | GP-12 |  |
| 1903 | 91.1.2 | Deleted - Adaptation of the Layer 3 BSSMAP procedures as required | 446d | 2001-04-06 A | 2002-12-20 A | 100% | 2001-04-06 | 2002-12-20 | 446d | finish no earlier than 2002-12-20 | GP | 3568h | 3568h |  |  |  | Rel-5 | Paolo | GP-12 |  |
| 1904 | 92 | **Rel-5 Charging and OAM&P** | 264d | 2001-09-10 A | 2002-09-12 A | 100% | 2001-09-10 | 2002-09-12 | 264d |  | S5 | 9976h | 9976h | OAM | VoiceStream, Motorola |  | Rel-5 | Dionisio |  |  |
| 1905 | 92.1 | Rel5 Principles, high level Requirements and Architecture | 205d | 2001-09-17 A | 2002-06-28 A | 100% | 2001-09-17 | 2002-06-28 | 205d | finish no earlier than 2002-06-28 | S5 | 1640h | 1640h | OAM-AR/PR | Motorola |  | Rel-5 | Dionisio |  | 32.101, 32.102 |
| 1906 | 92.2 | Rel5 Performance Management | 259d | 2001-09-17 A | 2002-09-12 A | 100% | 2001-09-17 | 2002-09-12 | 259d | finish no earlier than 2002-09-12 | S5 | 2072h | 2072h | OAM-PM | Nortel |  | Rel-5 | Dionisio |  | 32.4xy, 52.402 |
| 1907 | 92.3 | Rel5 Charging Management | 264d | 2001-09-10 A | 2002-09-12 A | 100% | 2001-09-10 | 2002-09-12 | 264d | finish no earlier than 2002-09-12 | S5 | 2112h | 2112h | OAM-CH | T-Mobile | Karl-Heinz.Nenner@T-MOBILE.DE | Rel-5 | Dionisio |  | 32.200, 32.205, 32.215, 32.225, 32.235 |
| 1908 | 92.4 | Rel5 Network Infrastructure Management | 255d | 2001-09-21 A | 2002-09-12 A | 100% | 2001-09-21 | 2002-09-12 | 255d | finish no earlier than 2002-09-12 | S5 | 2040h | 2040h | OAM-NIM | Ericsson | thomas.tovinger@ericsson.com | Rel-5 | Dionisio |  | 32.6xy, 32.3xy |
| 1909 | 93 | **GERAN enhancements for streaming services 1 (RLC enhancements)** | 430d | 2000-11-06 A | 2002-06-28 A | 100% | 2000-11-06 | 2002-06-28 | 430d |  | GP | 8944h | 8944h |  |  |  | Rel-5 | Paolo |  |  |
| 1910 | 93.1 | Concept | 258d | 2000-11-06 A | 2001-10-31 A | 100% | 2000-11-06 | 2001-10-31 | 258d | finish no earlier than 2001-10-31 | GP | 2064h | 2064h |  |  |  | Rel-5 | Paolo |  |  |
| 1911 | 93.2 | RLC protocol enhancement (SDU Discard) | 430d | 2000-11-06 A | 2002-06-28 A | 100% | 2000-11-06 | 2002-06-28 | 430d | finish no earlier than 2002-06-28 | GP | 3440h | 3440h |  |  |  | Rel-5 | Paolo |  |  |
| 1912 | 94 | **GERAN enhancements for streaming services 2 (usage of ECSD)** | 430d | 2000-11-06 A | 2002-06-28 A | 100% | 2000-11-06 | 2002-06-28 | 430d |  | GP | 19840h | 19840h |  | Ericsson | Frank Muller | Rel-5 | Paolo |  |  |
| 1913 | 94.1 | Usage of ECSD Concept | 380d | 2000-11-06 A | 2002-04-19 A | 100% | 2000-11-06 | 2002-04-19 | 380d | finish no earlier than 2002-04-19 | GP | 3040h | 3040h |  |  |  | Rel-5 | Paolo |  |  |
| 1914 | 94.2 | Stage 2 | 380d | 2000-11-06 A | 2002-04-19 A | 100% | 2000-11-06 | 2002-04-19 | 380d | finish no earlier than 2002-04-19 | GP | 3040h | 3040h |  |  |  | Rel-5 | Paolo |  |  |
| 1915 | 94.3 | Stage 3 | 430d | 2000-11-06 A | 2002-06-28 A | 100% | 2000-11-06 | 2002-06-28 | 430d | finish no earlier than 2002-06-28 | GP | 3440h | 3440h |  |  |  | Rel-5 | Paolo |  |  |
| 1916 | 94.4 | RLC PDU formats | 430d | 2000-11-06 A | 2002-06-28 A | 100% | 2000-11-06 | 2002-06-28 | 430d | finish no earlier than 2002-06-28 | GP | 3440h | 3440h |  |  |  | Rel-5 | Paolo |  |  |
| 1917 | 94.5 | MAC header | 430d | 2000-11-06 A | 2002-06-28 A | 100% | 2000-11-06 | 2002-06-28 | 430d | finish no earlier than 2002-06-28 | GP | 3440h | 3440h |  |  |  | Rel-5 | Paolo |  |  |

Notes:
- 1894: Accept changes Gb over IP
- 1895: -
- 1896: -
- 1897: -
- 1898: Closed, accept changes for Gb over IP
- 1899: -
- 1900: Terminated - not standardized. Marked as stopped 12/2008
- 1901: TERMINATED - NOT STANDARDIZED. Marked as stopped 12/2008
- 1902: TERMINATED - NOT STANDARDIZED. Marked as stopped 12/2008
- 1903: TERMINATED - NOT STANDARDIZED. Marked as stopped 12/2008
- 1904: -
- 1905: -
- 1906: -
- 1907: -
- 1908: -
- 1909: -
- 1910: -
- 1911: -
- 1912: AWS, Nokia, Ericsson, Nortel, Siemens, Motorola, Vodafone
- 1913: -
- 1914: -
- 1915: -
- 1916: -
- 1917: -

| ID | WBS | Task | Duration | Start | Finish | Predecessors | Complete | Baseline start | Baseline finish | Baseline duration | Constraint | Resources | Work | Actual work | Text1 | Text4 | Text5 | Text6 | Text8 |
| --- | --- | --- | --- | --- | --- | --- | --- | --- | --- | --- | --- | --- | --- | --- | --- | --- | --- | --- | --- |
| 1918 | 95 | **GERAN/UTRAN interface evolution 1 (evolution of Iu PS)** | 476d | 2000-09-01 A | 2002-06-28 A |  | 100% | 2000-09-01 | 2002-06-28 | 476d |  | GP,R3 | 10688h | 10688h | GERUEV1 | SBC | Marc Grant | Rel-5 | Paolo |
| 1919 | 95.1 | **Evolution of Iu ps** | 476d | 2000-09-01 A | 2002-06-28 A |  | 100% | 2000-09-01 | 2002-06-28 | 476d |  | GP,R3 | 7248h | 7248h | GERUEV1-IuPS |  |  | Rel-5 | Paolo |
| 1920 | 95.1.1 | Identification of GERAN requirements on Iu ps | 326d | 2000-09-01 A | 2001-11-30 A |  | 100% | 2000-09-01 | 2001-11-30 | 326d | finish no earlier than 2001-11-30 | GP,R3 | 2608h | 2608h |  |  |  | Rel-5 | Paolo |
| 1921 | 95.1.2 | Update of specifications | 150d | 2001-12-03 A | 2002-06-28 A | 1920 | 100% | 2001-12-03 | 2002-06-28 | 150d | finish no earlier than 2002-06-28 | GP,R3 | 1200h | 1200h |  |  |  | Rel-5 | Paolo |
| 1922 | 96 | **GERAN/UTRAN interface evolution 2 (evolution of Iu CS)** | 476d | 2000-09-01 A | 2002-06-28 A |  | 100% | 2000-09-01 | 2002-06-28 | 476d |  | GP,R3 | 12816h | 12816h | GERUEV2 |  |  | Rel-5 | Paolo |
| 1923 | 96.1 | **Evolution of Iu cs** | 476d | 2000-09-01 A | 2002-06-28 A |  | 100% | 2000-09-01 | 2002-06-28 | 476d |  | GP,R3 | 10016h | 10016h | GERUEV2-IuCS | Lucent | Krishna Balachandran | Rel-5 | Paolo |
| 1924 | 96.1.1 | Identification of GERAN requirements on Iu cs | 426d | 2000-09-01 A | 2002-06-24 A |  | 100% | 2000-09-01 | 2002-06-24 | 426d | finish no earlier than 2002-04-19 | GP,R3 | 3408h | 3408h |  |  |  | Rel-5 | Paolo |
| 1925 | 96.1.2 | Update of specifications | 476d | 2000-09-01 A | 2002-06-28 A |  | 100% | 2000-09-01 | 2002-06-28 | 476d | finish no earlier than 2002-06-28 | GP,R3 | 3808h | 3808h |  |  |  | Rel-5 | Paolo |
| 1926 | 97 | **End to End QoS for PS Domain including IMS** | 480d | 2000-08-28 A | 2002-06-28 A |  | 100% | 2000-08-28 | 2002-06-28 | 480d |  | S2 | 9856h | 9856h | E2EQoS | Ericsson | Johnson.oyama@era.ericcson.se | Rel-5 | Maurice |
| 1927 | 97.1 | E2E QoSConcept and Architecture | 178d | 2001-01-03 A | 2001-09-07 A |  | 100% | 2001-01-03 | 2001-09-07 | 178d | finish no earlier than 2001-09-07 | S2 | 1424h | 1424h |  |  |  | Rel-5 | Maurice |
| 1928 | 97.2 | E2E QoS interworking | 465d | 2000-08-28 A | 2002-06-07 A |  | 100% | 2000-08-28 | 2002-06-07 | 465d | finish no earlier than 2002-06-07 | N3 | 3720h | 3720h | E2EQoS-IW | Lucent | Daisuke Yokota (yokota@lucent.com) | Rel-5 | Gwiho |
| 1929 | 97.3 | QoS Management (Provisioning and Monitoring) | 201d | 2001-09-21 A | 2002-06-28 A |  | 100% | 2001-09-21 | 2002-06-28 | 201d | finish no earlier than 2002-06-28 | S5 | 1608h | 1608h | E2EQoS-OAM | VoiceStream, Motorola |  | Rel-5 | Dionisio |
| 1930 | 98 | **Messaging enhancements Rel-5** | 467d | 2001-06-15 A | 2003-03-31 A |  | 100% | 2001-06-15 | 2003-03-31 | 467d |  | T2 | 19000h | 19000h | MESS5 |  |  | Rel-5 | Kimmo |
| 1931 | 98.1 | **Multimedia Messaging (MMS) enhancements** | 467d | 2001-06-15 A | 2003-03-31 A |  | 100% | 2001-06-15 | 2003-03-31 | 467d |  | T2 | 11688h | 11688h | MESS5-MMS | Siemens | Josef.Laumen@SAL.SIEMENS.DE | Rel-5 | Alain |
| 1932 | 98.1.1 | Definition of service requirements | 196d | 2001-06-15 A | 2002-03-15 A |  | 100% | 2001-06-15 | 2002-03-15 | 196d | finish no earlier than 2002-03-15 | S1 | 1568h | 1568h | MESS5-SR | Siemens | Josef.Laumen@SAL.SIEMENS.DE | Rel-5 |  |
| 1933 | 98.1.2 | Technical realization | 256d | 2001-06-15 A | 2002-06-07 A |  | 100% | 2001-06-15 | 2002-06-07 | 256d | finish no earlier than 2002-06-07 | T2 | 2048h | 2048h |  | Siemens | Josef.Laumen@SAL.SIEMENS.DE | Rel-5 |  |
| 1934 | 98.1.3 | WAP Forum dependency: MM1 stage 3 | 467d | 2001-06-15 A | 2003-03-31 A |  | 100% | 2001-06-15 | 2003-03-31 | 467d | finish no earlier than 2003-03-31 | T2 | 3736h | 3736h |  |  |  | Rel-5 |  |
| 1935 | 98.1.4 | MMS formats and codecs | 75d | 2001-12-03 A | 2002-03-15 A |  | 100% | 2001-12-03 | 2002-03-15 | 75d | finish no earlier than 2002-03-15 | S4 | 600h | 600h |  |  |  | Rel-5 | Paolo |
| 1936 | 98.2 | **Enhanced Messaging Service (EMS) enhancements** | 191d | 2001-06-15 A | 2002-03-08 A |  | 100% | 2001-06-15 | 2002-03-08 | 191d |  | T2 | 3584h | 3584h | MESS5-EMS | Ericsson | Alan.Baldwin@EML.ERICSSON.SE | Rel-5 |  |
| 1937 | 98.2.1 | Definition of service requirements | 66d | 2001-06-15 A | 2001-09-14 A |  | 100% | 2001-06-15 | 2001-09-14 | 66d | finish no earlier than 2001-09-14 | S1 | 528h | 528h |  | Ericsson | Alan.Baldwin@EML.ERICSSON.SE | Rel-5 | Alain |
| 1938 | 98.2.2 | Technical realization | 191d | 2001-06-15 A | 2002-03-08 A |  | 100% | 2001-06-15 | 2002-03-08 | 191d | finish no earlier than 2002-03-08 | T2 | 1528h | 1528h |  | Ericsson | Alan.Baldwin@EML.ERICSSON.SE | Rel-5 |  |
| 1939 | 99 | **GERAN Inter BSC NACC improvements over the Gb Interface** | 215d | 2001-09-03 A | 2002-06-28 A |  | 100% | 2001-09-03 | 2002-06-28 | 215d |  | GP | 8200h | 8200h | GERNACC |  |  | Rel-5 | Paolo |
| 1940 | 99.1 | **Modification of core network protocols for GERAN Inter BSC NACC over Gb Interface** | 165d | 2001-09-03 A | 2002-04-19 A |  | 100% | 2001-09-03 | 2002-04-19 | 165d |  | N4,S2 | 4064h | 4064h | GERNACC-Cnmod |  |  | Rel-5 | Kimmo |
| 1941 | 99.1.1 | Stage 2 - Concept | 43d | 2001-09-03 A | 2001-10-31 A |  | 100% | 2001-09-03 | 2001-10-31 | 43d | finish no earlier than 2001-10-31 | N4,S2 | 344h | 344h |  |  |  | Rel-5 | Kimmo |
| 1942 | 99.1.2 | Stage 2 - 23.060 change - Definition of Inter BSC NACC | 165d | 2001-09-03 A | 2002-04-19 A |  | 100% | 2001-09-03 | 2002-04-19 | 165d | finish no earlier than 2002-04-19 | N4,S2 | 1320h | 1320h |  |  |  | Rel-5 | Kimmo |
| 1943 | 99.1.3 | Stage 3 (changes to TS 29.060) | 135d | 2001-09-03 A | 2002-03-08 A |  | 100% | 2001-09-03 | 2002-03-08 | 135d | finish no earlier than 2002-03-08 | N4 | 1080h | 1080h |  |  |  | Rel-5 | Kimmo |

Notes:
- 1918: SBC, Motorola, Nokia, Ericsson, Nortel
- 1919: -
- 1920: -
- 1921: -
- 1922: -
- 1923: Lucent, Ericsson, AWS, Nortel
- 1924: -
- 1925: -
- 1926: -
- 1927: - / Text3: 23.207
- 1928: [DAB - 30/07/02] - % complete to 95% (if we exclude Diffserv). Marked as closed 12/2008 (was marked 95% complete) / Text3: 29.208, 29.207, 27.060, 29.061, 24.008, 24.228, , 24.229, 29.060, 29.163
- 1929: - / Text3: 32-series
- 1930: support of UAProf, so this in my opinion is 100% complete
- 1931: -
- 1932: - / Text3: 22.140
- 1933: stage 3 MM7 is missing / Text3: 23.140
- 1934: Marked as closed 12/2008 (was marked 80% complete)
- 1935: - / Text3: 26.140
- 1936: - / Text3: 23.040
- 1937: -
- 1938: - / Text3: 23.040
- 1939: -
- 1940: -
- 1941: -
- 1942: -
- 1943: IP 30/11/01: Input awaited from GERAN2 to CN4 / 17 May Work complete 100%

| ID | WBS | Task | Duration | Start | Finish | Complete | Baseline start | Baseline finish | Baseline duration | Constraint | Resources | Work | Actual work | Text1 | Text6 | Text8 | Text12 | Text3 | Text4 | Text5 |
| --- | --- | --- | --- | --- | --- | --- | --- | --- | --- | --- | --- | --- | --- | --- | --- | --- | --- | --- | --- | --- |
| 1944 | 99.2 | **Modification of Gb protocols for GERAN Inter BSC NACC over Gb Interface** | 151d | 2001-11-30 A | 2002-06-28 A | 100% | 2001-11-30 | 2002-06-28 | 151d |  | GP | 2416h | 2416h | GERNACC-Gbmod | Rel-5 | Paolo |  |  |  |  |
| 1945 | 99.2.1 | Stage 3 (changes to TS 48.018) | 151d | 2001-11-30 A | 2002-06-28 A | 100% | 2001-11-30 | 2002-06-28 | 151d | finish no earlier than 2002-06-28 | GP | 1208h | 1208h |  | Rel-5 | Paolo |  |  |  |  |
| 1946 | 100 | **Enhanced Power Control** | 540d | 2001-11-26 A | 2003-12-19 A | 100% | 2001-11-26 | 2003-12-19 | 540d |  | GP | 12840h | 12840h | EPC | Rel-5 | Paolo |  |  |  |  |
| 1947 | 100.1 | Realization of Enhanced power control and signalling support | 5d | 2001-11-26 A | 2001-11-30 A | 100% | 2001-11-26 | 2001-11-30 | 5d | finish no earlier than 2001-11-30 | GP | 40h | 40h |  | Rel-5 | Paolo |  |  |  |  |
| 1948 | 100.2 | Deleted - GERAN MS Conformance test for Enhanced Power Control | 530d | 2001-12-10 A | 2003-12-19 A | 100% | 2001-12-10 | 2003-12-19 | 530d | finish no earlier than 2003-12-19 | GP | 4240h | 4240h |  | Rel-5 | Paolo | GP-17 |  |  |  |
| 1949 | 100.3 | Deleted - GERAN BTS Conformance test for Enhanced Power Control | 530d | 2001-12-10 A | 2003-12-19 A | 100% | 2001-12-10 | 2003-12-19 | 530d | finish no earlier than 2003-12-19 | GP | 4240h | 4240h |  | Rel-5 | Paolo | GP-17 |  |  |  |
| 1950 | 101 | **8PSK AMR HR** | 530d | 2001-12-10 A | 2003-12-19 A | 100% | 2001-12-10 | 2003-12-19 | 530d |  | GP | 21080h | 21080h | 8PSK-AH | Rel-5 | Paolo |  |  |  |  |
| 1951 | 101.1 | **Definition of channel coding, performance requirements and signalling support** | 145d | 2001-12-10 A | 2002-06-28 A | 100% | 2001-12-10 | 2002-06-28 | 145d |  | GP | 10440h | 10440h |  | Rel-5 | Paolo |  |  |  |  |
| 1952 | 101.1.1 | Concept | 145d | 2001-12-10 A | 2002-06-28 A | 100% | 2001-12-10 | 2002-06-28 | 145d | finish no earlier than 2002-06-28 | GP | 1160h | 1160h |  | Rel-5 | Paolo |  |  |  |  |
| 1953 | 101.1.2 | Changes to 44.018 | 145d | 2001-12-10 A | 2002-06-28 A | 100% | 2001-12-10 | 2002-06-28 | 145d | finish no earlier than 2002-06-28 | G2 | 1160h | 1160h |  | Rel-5 | Gert |  |  |  |  |
| 1954 | 101.1.3 | Changes to 45.001 | 145d | 2001-12-10 A | 2002-06-28 A | 100% | 2001-12-10 | 2002-06-28 | 145d | finish no earlier than 2002-06-28 | G1 | 1160h | 1160h |  | Rel-5 |  |  |  |  |  |
| 1955 | 101.1.4 | Changes to 45.002 | 145d | 2001-12-10 A | 2002-06-28 A | 100% | 2001-12-10 | 2002-06-28 | 145d | finish no earlier than 2002-06-28 | G1 | 1160h | 1160h |  | Rel-5 |  |  |  |  |  |
| 1956 | 101.1.5 | Changes to 45.003 | 145d | 2001-12-10 A | 2002-06-28 A | 100% | 2001-12-10 | 2002-06-28 | 145d | finish no earlier than 2002-06-28 | G1 | 1160h | 1160h |  | Rel-5 |  |  |  |  |  |
| 1957 | 101.1.6 | Changes to 45.005 | 145d | 2001-12-10 A | 2002-06-28 A | 100% | 2001-12-10 | 2002-06-28 | 145d | finish no earlier than 2002-06-28 | G1 | 1160h | 1160h |  | Rel-5 |  |  |  |  |  |
| 1958 | 101.1.7 | Changes to 24.008 | 145d | 2001-12-10 A | 2002-06-28 A | 100% | 2001-12-10 | 2002-06-28 | 145d | finish no earlier than 2002-06-28 | G2 | 1160h | 1160h |  | Rel-5 | Gert |  |  |  |  |
| 1959 | 101.1.8 | Changes to 48.058 | 145d | 2001-12-10 A | 2002-06-28 A | 100% | 2001-12-10 | 2002-06-28 | 145d | finish no earlier than 2002-06-28 | G2 | 1160h | 1160h |  | Rel-5 | Gert |  |  |  |  |
| 1960 | 101.2 | Deleted - GERAN MS Conformance test for 8PSK HR | 530d | 2001-12-10 A | 2003-12-19 A | 100% | 2001-12-10 | 2003-12-19 | 530d | finish no earlier than 2003-12-19 | GP | 4240h | 4240h |  | Rel-5 | Paolo |  |  |  |  |
| 1961 | 101.3 | GERAN BTS Conformance test for 8PSK HR | 270d | 2001-12-10 A | 2002-12-20 A | 100% | 2001-12-10 | 2002-12-20 | 270d | finish no earlier than 2002-12-20 | GP | 2160h | 2160h |  | Rel-5 | Paolo |  |  |  |  |
| 1962 | 102 | Service Change and UDI Fallback | 175d | 2001-10-08 A | 2002-06-07 A | 100% | 2001-10-08 | 2002-06-07 | 175d | finish no earlier than 2002-06-07 | N3 | 1400h | 1400h | SCUDIF | Rel-5 | Gwiho |  | 29.007, 27.001, 24.008 | Ericsson | Rune.Werner.Wiik@ericsson.no |
| 1963 | 103 | **Rel-5 USIM toolkit enhancements** | 865d | 2000-06-05 A | 2003-09-26 A | 100% | 2000-06-05 | 2003-09-26 | 865d |  | T3 | 24352h | 24352h | USAT1-Interpr | Rel-5 | Xavier |  |  | G & D | Michael Meyer |
| 1964 | 103.1 | Deleted - Test specification for USIM toolkit security mechanisms | 349d | 2002-05-28 A | 2003-09-26 A | 100% | 2002-05-28 | 2003-09-26 | 349d | finish no earlier than 2003-09-26 | T3 | 2792h | 2792h |  | Rel-5 |  | TP-21 |  | Gemplus | Sophie Viallet |
| 1965 | 103.2 | **Protocol Standardisation of a SIM Toolkit Interpreter** | 688d | 2000-06-05 A | 2003-01-22 A | 100% | 2000-06-05 | 2003-01-22 | 688d |  | T3 | 12512h | 12512h | USAT1-Interpr | Rel-5 | Xavier |  | 27.103 | G & D | Michael Meyer |
| 1966 | 103.2.1 | Stage 1 | 205d | 2000-06-05 A | 2001-03-16 A | 100% | 2000-06-05 | 2001-03-16 | 205d | finish no earlier than 2001-03-16 | T3 | 1640h | 1640h | USAT1-Interpr | Rel-5 | Xavier |  |  |  |  |
| 1967 | 103.2.2 | Stage 2 and 3 | 308d | 2001-01-03 A | 2002-03-08 A | 100% | 2001-01-03 | 2002-03-08 | 308d | finish no earlier than 2002-03-08 | T3 | 2464h | 2464h | USAT1-Interpr | Rel-5 | Xavier |  |  |  |  |
| 1968 | 103.2.3 | Test specification | 363d | 2001-09-03 A | 2003-01-22 A | 100% | 2001-09-03 | 2003-01-22 | 363d | finish no earlier than 2003-01-22 | T3 | 2904h | 2904h | USAT1-Interpr | Rel-5 | Xavier |  |  | Gemplus | Gérald MAUNIER |

Notes:
- 1944: -
- 1945: -
- 1946: -
- 1947: Completed 11/2001
- 1948: Not started. Marked as stopped 12/2008
- 1949: Not started. Marked as stopped 12/2008
- 1950: Completed for Rel-5
- 1951: -
- 1952: -
- 1953: -
- 1954: -
- 1955: -
- 1956: -
- 1957: -
- 1958: -
- 1959: -
- 1960: Marked as stopped 12/2008
- 1961: -
- 1962: -
- 1963: -
- 1964: Marked as stopped 12/2008
- 1965: 28/5/2001: T3-19 proposed that since the stage 2 and 3 will not be presented to TP-12 for approval as expected, the WI will be moved to rel-5, with completion expected at TP-13.
- 1966: 5/10/2001: Stage one comepeted at TP-12.
- 1967: 5/10/2001: TS 31.112 and 31.113 approved at TP-13. TS 31.114 to be presented to TP-14.
- 1968: 5/10/2001: Work started on test specification. Marked as closed 12/2008 (was marked 12% complete)

| ID | WBS | Task | Duration | Start | Finish | Complete | Baseline start | Baseline finish | Baseline duration | Constraint | Resources | Work | Actual work | Text1 | Text4 | Text5 | Text6 | Text8 | Text12 |
| --- | --- | --- | --- | --- | --- | --- | --- | --- | --- | --- | --- | --- | --- | --- | --- | --- | --- | --- | --- |
| 1969 | 103.4 | **(U)SIM API** | 133d | 2002-03-20 A | 2002-09-20 A | 100% | 2002-03-20 | 2002-09-20 | 133d |  | T3 | 2128h | 2128h | USAT1-API | Microelectrónica Española | Mario Pérez | Rel-5 | Xavier |  |
| 1970 | 103.4.1 | Java API Test specification | 133d | 2002-03-20 A | 2002-09-20 A | 100% | 2002-03-20 | 2002-09-20 | 133d | finish no earlier than 2002-09-20 | T3 | 1064h | 1064h | USAT1-API | Microelectrónica Española | Mario Pérez | Rel-5 | Xavier |  |
| 1971 | 104 | **small Technical Enhancements and Improvements for Rel5** | 2349d? | 2000-01-03 A | 2008-12-31 A | 100% | 2000-01-03 | 2008-12-31 | 2349d? |  | All | 18792h | 18792h | TEI5 |  |  | Rel-5 |  |  |
| 1972 | 511.1 | Small Technical Enhancements and Improvements for Rel-5 Conformance Testing | 2349d? | 2000-01-03 A | 2008-12-31 A | 100% | 2000-01-03 | 2008-12-31 | 2349d? | finish no earlier than 2008-12-31 | R5,T1 | 18792h | 18792h | TEI5_Test |  |  | Rel-5 | Ingbert |  |
| 1973 | 105 | Deleted - Technical Report on UE Functionality Split | 87d | 2000-01-03 A | 2000-05-01 A | 100% | 2000-01-03 | 2000-05-01 | 87d |  | S1 | 688h | 688h | UESPLIT | Motorola | sanjay.gupta@motorola.com | Rel-5 | Alain | SP-08 |
| 1974 | 106 | **User Equipment Management** | 267d | 2001-06-21 A | 2002-06-28 A | 100% | 2001-06-21 | 2002-06-28 | 267d |  | S5 | 3752h | 3752h | UEM | Vodafone | john.mudge@vf.vodafone.co.uk | Rel-5 | Dionisio |  |
| 1975 | 106.1 | FS on User Equipment (UE) Management | 267d | 2001-06-21 A | 2002-06-28 A | 100% | 2001-06-21 | 2002-06-28 | 267d | finish no earlier than 2002-06-28 | S5 | 2136h | 2136h | OAM-UEM | Vodafone | john.mudge@vf.vodafone.co.uk | Rel-5 | Dionisio |  |
| 1976 | 107 | **Flow control supporting an MS with multiple data flows with different QoS over the Gb interface** | 50d | 2002-06-24 A | 2002-08-30 A | 100% | 2002-06-24 | 2002-08-30 | 50d |  | GP | 1288h | 1288h | FlowCon | Ericsson | ingemar.backlund@era.ericsson.se | Rel-5 | Paolo |  |
| 1977 | 107.1 | **Update of stage 2 specifications** | 50d | 2002-06-24 A | 2002-08-30 A | 100% | 2002-06-24 | 2002-08-30 | 50d |  | GP | 808h | 808h |  |  |  | Rel-5 | Paolo |  |
| 1978 | 107.1.1 | Concept document 23.060 (changes to) | 46d | 2002-06-28 A | 2002-08-30 A | 100% | 2002-06-28 | 2002-08-30 | 46d | finish no earlier than 2002-08-30 | S2 | 368h | 368h |  |  |  | Rel-5 | Maurice |  |
| 1979 | 107.1.2 | Flow Control | 5d | 2002-06-24 A | 2002-06-28 A | 100% | 2002-06-24 | 2002-06-28 | 5d | finish no earlier than 2002-06-28 | GP | 40h | 40h |  |  |  | Rel-5 | Paolo |  |
| 1980 | 107.2 | **Modification of BSSGP protocol** | 5d | 2002-06-24 A | 2002-06-28 A | 100% | 2002-06-24 | 2002-06-28 | 5d |  | GP | 80h | 80h |  | Ericsson | ingemar.backlund@era.ericsson.se | Rel-5 | Paolo |  |
| 1981 | 107.2.1 | Stage 3 (changes to 48.018) | 5d | 2002-06-24 A | 2002-06-28 A | 100% | 2002-06-24 | 2002-06-28 | 5d | finish no earlier than 2002-06-28 | G2 | 40h | 40h |  |  |  | Rel-5 | Gert |  |
| 1982 | 108 | **Deleted - Multiple TBF in A/Gb mode - Phase 1** | 421d | 2002-04-19 A | 2003-11-28 A | 100% | 2002-04-19 | 2003-11-28 | 421d |  | GP | 17480h | 17480h | MULTBF | Ericsson | gunnar.mildh@era.ericsson.se | Rel-5 | Paolo | GP-17 |
| 1983 | 108.1 | **Deleted - Multiple TBF in A/Gb mode - Phase 1** | 351d | 2002-04-19 A | 2003-08-22 A | 100% | 2002-04-19 | 2003-08-22 | 351d |  | GP | 8112h | 8112h | MULTBF-Agbmode |  |  | Rel-5 | Paolo | GP-17 |
| 1984 | 108.1.1 | Deleted - Multiple TBF Concept paper | 351d | 2002-04-19 A | 2003-08-22 A | 100% | 2002-04-19 | 2003-08-22 | 351d | finish no earlier than 2003-08-22 | GP | 2808h | 2808h | MULTBF-Agbmode |  |  | Rel-5 | Paolo | GP-17 |
| 1985 | 108.1.2 | Deleted - Multiple TBF Stage 2 (43.064) CRs | 156d | 2002-04-19 A | 2002-11-22 A | 100% | 2002-04-19 | 2002-11-22 | 156d | finish no earlier than 2002-11-22 | G1 | 1248h | 1248h | MULTBF-Agbmode |  |  | Rel-5 | Paolo | GP-12 |
| 1986 | 108.1.3 | Deleted - Multiple TBF Stage 3 (44.060) CRs | 156d | 2002-04-19 A | 2002-11-22 A | 100% | 2002-04-19 | 2002-11-22 | 156d | finish no earlier than 2002-11-22 | G2 | 1248h | 1248h | MULTBF-Agbmode |  |  | Rel-5 | Gert | GP-12 |
| 1987 | 108.2 | **Deleted - Multiple TBF in A/Gb mode – MS testing** | 375d | 2002-06-24 A | 2003-11-28 A | 100% | 2002-06-24 | 2003-11-28 | 375d |  | GP | 6000h | 6000h |  | Ericsson | ingemar.backlund@era.ericsson.se | Rel-5 | Paolo | GP-17 |
| 1988 | 108.2.1 | Deleted - MS conformance tests | 375d | 2002-06-24 A | 2003-11-28 A | 100% | 2002-06-24 | 2003-11-28 | 375d | finish no earlier than 2003-11-28 | G4 | 3000h | 3000h |  |  |  | Rel-5 | Paolo | GP-17 |
| 1989 | 109 | **Alignment of 3G functional split and Iu** | 922d | 2000-06-08 A | 2003-12-19 A | 100% | 2000-06-08 | 2003-12-19 | 922d |  | GP | 126664h | 126664h | GER3GAL | Ericsson | Frank Muller | Rel-5 | Paolo |  |
| 1990 | 109.1 | **GERAN user / control plane** | 540d | 2000-08-07 A | 2002-08-30 A | 100% | 2000-08-07 | 2002-08-30 | 540d |  | GP | 36232h | 36232h | GER3GAL-GUCOPL | Ericsson | Frank Muller | Rel-5 | Paolo |  |
| 1991 | 109.1.1 | **Alignment with UMTS bearer concept** | 540d | 2000-08-07 A | 2002-08-30 A | 100% | 2000-08-07 | 2002-08-30 | 540d |  | GP | 24952h | 24952h |  |  |  | Rel-5 | Paolo |  |
| 1992 | 109.1.1.1 | Enhanced power control | 1d | 2001-08-31 A | 2001-08-31 A | 100% | 2001-08-31 | 2001-08-31 | 1d | finish no earlier than 2001-08-31 | GP | 8h | 8h |  |  |  | Rel-5 | Paolo |  |
| 1993 | 109.1.1.2 | Stage 2 | 235d | 2000-08-07 A | 2001-06-29 A | 100% | 2000-08-07 | 2001-06-29 | 235d | finish no earlier than 2001-06-29 | GP | 1880h | 1880h |  |  |  | Rel-5 | Paolo |  |
| 1994 | 109.1.1.3 | Adoption of the UTRAN PDCP | 295d | 2000-11-06 A | 2001-12-21 A | 100% | 2000-11-06 | 2001-12-21 | 295d | finish no earlier than 2001-12-21 | GP | 2360h | 2360h |  |  |  | Rel-5 | Paolo |  |
| 1995 | 109.1.1.4 | Development of RLC / MAC | 261d | 2001-08-31 A | 2002-08-30 A | 100% | 2001-08-31 | 2002-08-30 | 261d | finish no earlier than 2002-08-30 | GP | 2088h | 2088h |  |  |  | Rel-5 | Paolo |  |
| 1996 | 109.1.1.5 | Development of GERAN RRC | 266d | 2001-06-22 A | 2002-06-28 A | 100% | 2001-06-22 | 2002-06-28 | 266d | finish no earlier than 2002-06-28 | GP | 2128h | 2128h |  |  |  | Rel-5 | Paolo |  |
| 1997 | 109.1.1.6 | Ciphering and integrity protection concept paper | 166d | 2001-08-31 A | 2002-04-19 A | 100% | 2001-08-31 | 2002-04-19 | 166d | finish no earlier than 2002-04-19 | GP | 1328h | 1328h |  |  |  | Rel-5 | Paolo |  |
| 1998 | 109.1.1.7 | Multiple TBF or equivalent Concept paper | 116d | 2001-08-31 A | 2002-02-08 A | 100% | 2001-08-31 | 2002-02-08 | 116d | finish no earlier than 2002-02-08 | GP | 928h | 928h |  |  |  | Rel-5 | Paolo |  |
| 1999 | 109.1.1.8 | Paging concept | 166d | 2001-08-31 A | 2002-04-19 A | 100% | 2001-08-31 | 2002-04-19 | 166d | finish no earlier than 2002-04-19 | GP | 1328h | 1328h |  |  |  | Rel-5 | Paolo |  |
| 2000 | 109.1.1.9 | Dedicated Physical subchannels, includes traffic and control channels | 66d | 2001-08-31 A | 2001-11-30 A | 100% | 2001-08-31 | 2001-11-30 | 66d | finish no earlier than 2001-11-30 | GP | 528h | 528h |  |  |  | Rel-5 | Paolo |  |
| 2001 | 109.1.1.10 | Iu support and broadcast concept | 166d | 2001-08-31 A | 2002-04-19 A | 100% | 2001-08-31 | 2002-04-19 | 166d | finish no earlier than 2002-04-19 | GP | 1328h | 1328h |  |  |  | Rel-5 | Paolo |  |
| 2002 | 109.1.1.11 | Impact of using RLC instead of LAPDm concept | 116d | 2001-08-31 A | 2002-02-08 A | 100% | 2001-08-31 | 2002-02-08 | 116d | finish no earlier than 2002-02-08 | GP | 928h | 928h |  |  |  | Rel-5 | Paolo |  |
| 2003 | 109.1.1.12 | Contention resolution, mobile station identity, and access concept | 66d | 2001-08-31 A | 2001-11-30 A | 100% | 2001-08-31 | 2001-11-30 | 66d | finish no earlier than 2001-11-30 | GP | 528h | 528h |  |  |  | Rel-5 | Paolo |  |
| 2004 | 109.1.1.13 | PDCP concept | 166d | 2001-08-31 A | 2002-04-19 A | 100% | 2001-08-31 | 2002-04-19 | 166d | finish no earlier than 2002-04-19 | GP | 1328h | 1328h |  |  |  | Rel-5 | Paolo |  |
| 2005 | 109.1.1.14 | Downlink delayed TBF release | 261d | 2001-08-31 A | 2002-08-30 A | 100% | 2001-08-31 | 2002-08-30 | 261d | finish no earlier than 2002-08-30 | GP | 2088h | 2088h |  |  |  | Rel-5 | Paolo |  |
| 2006 | 109.1.1.15 | Add transparent RLC Concept | 116d | 2001-08-31 A | 2002-02-08 A | 100% | 2001-08-31 | 2002-02-08 | 116d | finish no earlier than 2002-02-08 | GP | 928h | 928h |  |  |  | Rel-5 | Paolo |  |
| 2007 | 109.1.1.16 | Handover concept | 116d | 2001-08-31 A | 2002-02-08 A | 100% | 2001-08-31 | 2002-02-08 | 116d | finish no earlier than 2002-02-08 | GP | 928h | 928h |  |  |  | Rel-5 | Paolo |  |

Notes:
- 1969: 8/3/2001: test spec is based on R99 core spec, so deleted from Workplan
- 1970: -
- 1971: "Joker" WI, to be used for a Rel 5 CR not related to any feature and with very limited impact on the system
- 1972: "Joker" WI, to be used for small modifications applicable to Rel 5 conformance testing. Moved in from Stoyan/testing WP. / Text3: 34.108, 34.109, 34.121-1, 34.121-2, 34.122, 34.123-1, 34.123-2, 34.123-3, 34.171, 34.229-1, 34.229-2, 34.229-3
- 1973: -
- 1974: - / Text3: 32.802
- 1975: - / Text3: 32.802
- 1976: 50101 -> 50201
- 1977: 50102 -> 50202
- 1978: -
- 1979: 50103 -> 50203
- 1980: -
- 1981: -
- 1982: GP#17 Nov 2003 Moved to Rel-6 as UID_50600 MULTBF (Only Multiple TBF Concept paper produced in Rel-5)
- 1983: Marked as closed 12/2008 (was marked 26% complete)
- 1984: Marked as closed 12/2008 (was marked 50% complete)
- 1985: Marked as stopped 12/2008
- 1986: Marked as stopped 12/2008
- 1987: 08/08: duplicate UID_50106=-> 50206. Marked as stopped 12/2008
- 1988: Not started. Marked as stopped 12/2008
- 1989: AWS, Nokia, Ericsson, Nortel, Siemens, Vodafone
- 1990: AWS, Nokia, Ericsson, Nortel, Siemens, Vodafone
- 1991: -
- 1992: -
- 1993: -
- 1994: Responsible is GERAN; RAN WG2 help may be needed.
- 1995: -
- 1996: -
- 1997: -
- 1998: -
- 1999: -
- 2000: -
- 2001: -
- 2002: -
- 2003: -
- 2004: -
- 2005: -
- 2006: -
- 2007: -

| ID | WBS | Task | Duration | Start | Finish | Complete | Baseline start | Baseline finish | Baseline duration | Constraint | Resources | Work | Actual work | Text6 | Text8 | Text1 | Text4 | Text5 |
| --- | --- | --- | --- | --- | --- | --- | --- | --- | --- | --- | --- | --- | --- | --- | --- | --- | --- | --- |
| 2008 | 109.1.2 | **Physical layer alignment with UMTS bearer concept** | 280d | 2000-11-06 A | 2001-11-30 A | 100% | 2000-11-06 | 2001-11-30 | 280d |  | GP | 6960h | 6960h | Rel-5 | Paolo |  |  |  |
| 2009 | 109.1.2.1 | PDTCH/TCH in 45.003 | 155d | 2000-11-06 A | 2001-06-08 A | 100% | 2000-11-06 | 2001-06-08 | 155d | finish no earlier than 2001-06-08 | GP | 1240h | 1240h | Rel-5 | Paolo |  |  |  |
| 2010 | 109.1.2.2 | Control channels in 45.003 | 155d | 2000-11-06 A | 2001-06-08 A | 100% | 2000-11-06 | 2001-06-08 | 155d | finish no earlier than 2001-06-08 | GP | 1240h | 1240h | Rel-5 | Paolo |  |  |  |
| 2011 | 109.1.2.3 | Receiver performance in 45.005 for PDTCH/TCH and control channels | 280d | 2000-11-06 A | 2001-11-30 A | 100% | 2000-11-06 | 2001-11-30 | 280d | finish no earlier than 2001-11-30 | GP | 2240h | 2240h | Rel-5 | Paolo |  |  |  |
| 2012 | 109.2 | **Iu rg interface** | 430d | 2000-11-06 A | 2002-06-28 A | 100% | 2000-11-06 | 2002-06-28 | 430d |  | GP,RP | 39560h | 39560h | Rel-5 | Paolo | GER3GAL-Iurg | Ericsson | Frank Muller |
| 2013 | 109.2.1 | **Inter BSS interface** | 430d | 2000-11-06 A | 2002-06-28 A | 100% | 2000-11-06 | 2002-06-28 | 430d |  | GP,RP | 20640h | 20640h | Rel-5 | Paolo |  |  |  |
| 2014 | 109.2.1.1 | Identification of requirements | 430d | 2000-11-06 A | 2002-06-28 A | 100% | 2000-11-06 | 2002-06-28 | 430d | finish no earlier than 2002-06-28 | GP | 3440h | 3440h | Rel-5 | Paolo |  |  |  |
| 2015 | 109.2.1.2 | Stage 2 | 430d | 2000-11-06 A | 2002-06-28 A | 100% | 2000-11-06 | 2002-06-28 | 430d | finish no earlier than 2002-06-28 | GP | 3440h | 3440h | Rel-5 | Paolo |  |  |  |
| 2016 | 109.2.1.3 | Adoption of relevant parts from Iur | 430d | 2000-11-06 A | 2002-06-28 A | 100% | 2000-11-06 | 2002-06-28 | 430d | finish no earlier than 2002-06-28 | GP | 3440h | 3440h | Rel-5 | Paolo |  |  |  |
| 2017 | 109.2.1.4 | Complementation with GERAN specifics | 430d | 2000-11-06 A | 2002-06-28 A | 100% | 2000-11-06 | 2002-06-28 | 430d | finish no earlier than 2002-06-28 | GP | 3440h | 3440h | Rel-5 | Paolo |  |  |  |
| 2018 | 109.2.1.5 | Stage 3 | 430d | 2000-11-06 A | 2002-06-28 A | 100% | 2000-11-06 | 2002-06-28 | 430d | finish no earlier than 2002-06-28 | GP | 3440h | 3440h | Rel-5 | Paolo |  |  |  |
| 2019 | 109.2.2 | **Inter BSS-RNS interface** | 430d | 2000-11-06 A | 2002-06-28 A | 100% | 2000-11-06 | 2002-06-28 | 430d |  | GP,RP | 15480h | 15480h | Rel-5 | Paolo |  |  |  |
| 2020 | 109.2.2.1 | Identification of requirements | 430d | 2000-11-06 A | 2002-06-28 A | 100% | 2000-11-06 | 2002-06-28 | 430d | start no earlier than 2000-11-06 | GP,R3 | 3440h | 3440h | Rel-5 | Paolo |  |  |  |
| 2021 | 109.2.2.2 | Stage 2 | 430d | 2000-11-06 A | 2002-06-28 A | 100% | 2000-11-06 | 2002-06-28 | 430d | finish no earlier than 2002-06-28 | GP,R3 | 3440h | 3440h | Rel-5 | Paolo |  |  |  |
| 2022 | 109.2.2.3 | Adoption of relevant parts from Iur | 430d | 2000-11-06 A | 2002-06-28 A | 100% | 2000-11-06 | 2002-06-28 | 430d | finish no earlier than 2002-06-28 | GP,R3 | 3440h | 3440h | Rel-5 | Paolo |  |  |  |
| 2023 | 109.2.2.4 | Complementation with GERAN specifics | 107.5d | 2002-01-30 A | 2002-06-28 A | 100% | 2002-01-30 | 2002-06-28 | 107.5d | finish no earlier than 2002-06-28 | GP,R3 | 860h | 860h | Rel-5 | Paolo |  |  |  |
| 2024 | 109.2.2.5 | Stage 3 | 107.5d | 2002-01-30 A | 2002-06-28 A | 100% | 2002-01-30 | 2002-06-28 | 107.5d | finish no earlier than 2002-06-28 | GP,R3 | 860h | 860h | Rel-5 | Paolo |  |  |  |
| 2025 | 109.3 | **Voice over GERAN PS and CS concept** | 430d | 2000-11-06 A | 2002-06-28 A | 100% | 2000-11-06 | 2002-06-28 | 430d |  | GP,R3 | 18520h | 18520h | Rel-5 | Paolo |  |  |  |
| 2026 | 109.3.1 | Architecture for A, Iu cs and Iu ps | 430d | 2000-11-06 A | 2002-06-28 A | 100% | 2000-11-06 | 2002-06-28 | 430d | finish no earlier than 2002-06-28 | GP,R3 | 3440h | 3440h | Rel-5 | Paolo |  |  |  |
| 2027 | 109.3.2 | Transcoder position/operation | 115d | 2000-11-06 A | 2001-04-13 A | 100% | 2000-11-06 | 2001-04-13 | 115d | finish no earlier than 2001-04-13 | GP | 920h | 920h | Rel-5 | Paolo |  |  |  |
| 2028 | 109.3.3 | Handover | 430d | 2000-11-06 A | 2002-06-28 A | 100% | 2000-11-06 | 2002-06-28 | 430d | finish no earlier than 2002-06-28 | GP,R3 | 3440h | 3440h | Rel-5 | Paolo |  |  |  |
| 2029 | 109.3.4 | RTP payload | 430d | 2000-11-06 A | 2002-06-28 A | 100% | 2000-11-06 | 2002-06-28 | 430d | finish no earlier than 2002-06-28 | GP,R3 | 3440h | 3440h | Rel-5 | Paolo |  |  |  |
| 2030 | 109.3.5 | Codec renegotiation concept | 365d | 2000-11-06 A | 2002-03-29 A | 100% | 2000-11-06 | 2002-03-29 | 365d | finish no earlier than 2002-03-29 | GP,R3 | 2920h | 2920h | Rel-5 | Paolo |  |  |  |
| 2031 | 109.3.6 | LA | 115d | 2000-11-06 A | 2001-04-13 A | 100% | 2000-11-06 | 2001-04-13 | 115d | finish no earlier than 2001-04-13 | GP | 920h | 920h | Rel-5 | Paolo |  |  |  |

Notes:
- 2008: -
- 2009: -
- 2010: -
- 2011: -
- 2012: AWS, Nokia, Ericsson, Nortel, Siemens, Vodafone
- 2013: -
- 2014: -
- 2015: -
- 2016: -
- 2017: -
- 2018: -
- 2019: -
- 2020: -
- 2021: -
- 2022: -
- 2023: -
- 2024: -
- 2025: -
- 2026: -
- 2027: -
- 2028: -
- 2029: -
- 2030: -
- 2031: -

| ID | WBS | Task | Duration | Start | Finish | Complete | Baseline start | Baseline finish | Baseline duration | Total slack | Constraint | Resources | Work | Actual work | Text6 | Text8 | Text12 | Text1 | Text4 | Text5 |
| --- | --- | --- | --- | --- | --- | --- | --- | --- | --- | --- | --- | --- | --- | --- | --- | --- | --- | --- | --- | --- |
| 2032 | 109.4 | **Deleted - GERAN MS Conformance test for GERAN interface evolution** | 660d | 2001-06-11 A | 2003-12-19 A | 100% | 2001-06-11 | 2003-12-19 | 660d |  |  | GP | 10560h | 10560h | Rel-5 | Paolo | GP-17 |  |  |  |
| 2033 | 109.4.1 | Deleted - MS test | 660d | 2001-06-11 A | 2003-12-19 A | 100% | 2001-06-11 | 2003-12-19 | 660d |  | finish no earlier than 2003-12-19 | GP | 5280h | 5280h | Rel-5 | Paolo | GP-17 |  |  |  |
| 2034 | 109.5 | **GERAN BSS Conformance test for GERAN interface evolution** | 922d | 2000-06-08 A | 2003-12-19 A | 100% | 2000-06-08 | 2003-12-19 | 922d |  |  | GP | 14752h | 14752h | Rel-5 | Paolo |  |  |  |  |
| 2035 | 109.5.1 | Deleted - BSS test | 922d | 2000-06-08 A | 2003-12-19 A | 100% | 2000-06-08 | 2003-12-19 | 922d |  | finish no earlier than 2003-12-19 | GP | 7376h | 7376h | Rel-5 | Paolo | GP-17 |  |  |  |
| 2036 | 110 | **GERAN support for IMS** | 690d | 2000-05-01 A | 2002-12-20 A | 100% | 2000-05-01 | 2002-12-20 | 690d |  |  | GP | 39198.4h | 39198.4h | Rel-5 | Paolo |  | GERIMS | Nokia | Shkumbin Hamiti |
| 2037 | 110.1 | **GERAN Header adaptation** | 690d | 2000-05-01 A | 2002-12-20 A | 100% | 2000-05-01 | 2002-12-20 | 690d |  |  | GP,S2,RP | 12302.8h | 12302.8h | Rel-5 | Paolo |  | GERIMS-HEADAPT | Nokia | Shkumbin Hamiti |
| 2038 | 110.1.1 | Definition of compression and removal modes for PDCP protocol | 15.05d | 2000-05-01 A | 2000-06-09 A | 100% | 2000-05-01 | 2000-06-09 | 15.05d |  | finish no earlier than 2000-09-01 | GP,S2,RP | 120.4h | 120.4h | Rel-5 | Paolo |  |  |  |  |
| 2039 | 110.1.2 | Conceptual description in stage 2 | 393d | 2000-05-01 A | 2001-10-31 A | 100% | 2000-05-01 | 2001-10-31 | 393d |  | finish no earlier than 2001-10-31 | GP,S2,RP | 3144h | 3144h | Rel-5 | Paolo |  |  |  |  |
| 2040 | 110.1.3 | Necessary changes on stage 3 regarding header removal | 439.8d | 2000-11-06 A | 2002-12-20 A | 100% | 2000-11-06 | 2002-12-20 | 439.8d |  | finish no earlier than 2002-12-20 | GP,S2,RP | 3518.4h | 3518.4h | Rel-5 | Paolo |  |  |  |  |
| 2041 | 110.2 | **Deleted - GERAN Radio access bearer design for IMS** | 430d | 2000-11-06 A | 2002-06-28 A | 100% | 2000-11-06 | 2002-06-28 | 430d |  |  | GP,S2,RP | 9287.6h | 9287.6h | Rel-5 | Paolo | GP-10 | GERIMS-RABDES | Nokia | Shkumbin Hamiti |
| 2042 | 110.2.1 | **Deleted - MuM control signalling for conversational multimedia services** | 430d | 2000-11-06 A | 2002-06-28 A | 100% | 2000-11-06 | 2002-06-28 | 430d |  |  | GP,S2,RP | 5847.6h | 5847.6h | Rel-5 | Paolo | GP-10 |  |  |  |
| 2043 | 110.2.1.1 | Deleted - Identification of requirements | 330d | 2000-11-06 A | 2002-02-08 A | 100% | 2000-11-06 | 2002-02-08 | 330d |  | finish no earlier than 2002-02-08 | GP,S2,RP | 2640h | 2640h | Rel-5 | Paolo | GP-08 |  |  |  |
| 2044 | 110.2.1.2 | Deleted - Necessary modifications due to SIP | 40d | 2002-05-06 A | 2002-06-28 A | 100% | 2002-05-06 | 2002-06-28 | 40d |  | finish no earlier than 2002-06-28 | GP,S2,RP | 320h | 320h | Rel-5 | Paolo | GP-10 |  |  |  |
| 2045 | 110.3 | **Deleted - GERAN MS Conformance test for support of IMS** | 400d | 2001-06-11 A | 2002-12-20 A | 100% | 2001-06-11 | 2002-12-20 | 400d |  |  | GP | 6400h | 6400h | Rel-5 | Paolo | GP-12 | GERIMS-MSconf | Nokia | Shkumbin Hamiti |
| 2046 | 110.3.1 | Deleted - MS test | 400d | 2001-06-11 A | 2002-12-20 A | 100% | 2001-06-11 | 2002-12-20 | 400d |  | finish no earlier than 2002-12-20 | G4 | 3200h | 3200h | Rel-5 | Paolo | GP-12 |  |  |  |
| 2047 | 110.4 | **Deleted - GERAN BTS Conformance test for support of IMS** | 400d | 2001-06-11 A | 2002-12-20 A | 100% | 2001-06-11 | 2002-12-20 | 400d |  |  | GP | 6400h | 6400h | Rel-5 | Paolo | GP-12 | GERIMS-BTSconf | Nokia | Shkumbin Hamiti |
| 2048 | 110.4.1 | Deleted - BTS test | 400d | 2001-06-11 A | 2002-12-20 A | 100% | 2001-06-11 | 2002-12-20 | 400d |  | finish no earlier than 2002-12-20 | G3new | 3200h | 3200h | Rel-5 | Ingbert | GP-12 |  |  |  |
| 2049 | 518 | MS Conformance Testing of Dual Transfer Mode | 65d? | 2002-11-11 A | 2003-02-07 A | 100% | 2002-11-11 | 2003-02-07 | 65d? |  | finish no earlier than 2003-02-07 | G4,G5 | 520h | 520h | Rel-5 | Paolo |  | MSCTDTM | Vodafone | Dave Fox |
| 2050 | 519 | **Handling of early UEs** | 911d? | 2000-01-03 A | 2003-06-27 A | 100% | 2000-01-03 | 2003-06-27 | 911d? |  |  | S2 | 4480h | 4480h | Rel-5 | Maurice |  | LATE_UE |  |  |
| 2051 | 519.1 | Feasibility Study | 50d? | 2002-10-07 A | 2002-12-13 A | 100% | 2002-10-07 | 2002-12-13 | 50d? |  | finish no earlier than 2002-12-13 | S2 | 400h | 400h | Rel-5 | Maurice |  |  |  |  |
| 2052 | 519.2 | Stage 2 | 125d? | 2003-01-06 A | 2003-06-27 A | 100% | 2003-01-06 | 2003-06-27 | 125d? |  | start no earlier than 2003-01-06 | S2 | 1000h | 1000h | Rel-5 | Maurice |  |  |  |  |
| 2053 | 519.3 | FS for the Early Mobile Handling in UTRAN | 195d | 2002-09-09 A | 2003-06-06 A | 100% | 2002-09-09 | 2003-06-06 | 195d |  | finish no earlier than 2003-06-06 | R2 | 1560h | 1560h | Rel-5 | Joern |  | FSEarlyUE | Vodafone | Alan Law |
| 2054 | 519.4 | Note: Stage 3 RAN part not shown | 1d | 2000-01-03 A | 2000-01-03 A | 100% | 2000-01-03 | 2000-01-03 | 1d |  |  |  |  |  | Rel-5 |  |  |  |  |  |
| 2055 | 520 | Release 4 Features | 1d? | 2000-01-03 | 2000-01-03 |  | 2000-01-03 | 2000-01-03 | 1d? | 3317d |  | NP,GP, RP,SP,TP | 8h |  | Rel-4 |  |  |  |  |  |

Notes:
- 2032: Not started. Marked as stopped 12/2008
- 2033: Not started. Marked as stopped 12/2008
- 2034: Not started. Marked as stopped 12/2008
- 2035: Not started. Marked as stopped 12/2008
- 2036: AWS, Nokia, Ericsson, Nortel, Siemens, Motorola
- 2037: AWS, Nokia, Ericsson, Nortel, Siemens, Motorola
- 2038: -
- 2039: -
- 2040: -
- 2041: TERMINATED - NOT STANDARDIZED. Marked as stopped 12/2008
- 2042: TERMINATED - NOT STANDARDIZED. Marked as stopped 12/2008
- 2043: TERMINATED - NOT STANDARDIZED
- 2044: TERMINATED - NOT STANDARDIZED
- 2045: TERMINATED - NOT STANDARDIZED. Marked as stopped 12/2008
- 2046: TERMINATED - NOT STANDARDIZED. Marked as stopped 12/2008
- 2047: TERMINATED - NOT STANDARDIZED. Marked as stopped 12/2008
- 2048: TERMINATED - NOT STANDARDIZED. Marked as stopped 12/2008
- 2049: Needed to complete DTM (R99)
- 2050: -
- 2051: -
- 2052: -
- 2053: -
- 2054: -
- 2055: -

| ID | WBS | Task | Duration | Start | Finish | Predecessors | Complete | Baseline start | Baseline finish | Baseline duration | Constraint | Resources | Work | Actual work | Text1 | Text6 | Text8 | Text3 | Text12 | Text4 | Text5 |
| --- | --- | --- | --- | --- | --- | --- | --- | --- | --- | --- | --- | --- | --- | --- | --- | --- | --- | --- | --- | --- | --- |
| 2056 | 15 | **Miscellaneous UE Conformance Testing Activities** | 958d | 2001-04-02 A | 2004-12-01 A |  | 100% | 2001-04-02 | 2004-12-01 | 958d |  | T1 | 36360h | 36360h | MISTST1 | Rel-4 | Ingbert |  |  |  |  |
| 2057 | 15.1 | Optimization of Test Time, RF Aspects (FDD) | 508d | 2001-09-24 A | 2003-09-03 A |  | 100% | 2001-09-24 | 2003-09-03 | 508d | finish no earlier than 2003-09-03 | T1 | 4064h | 4064h | MISTST1-OpFDD | Rel-4 | Ingbert | 34.121 |  |  |  |
| 2058 | 15.2 | Optimization of Test Time, RF Aspects (TDD) | 508d | 2001-09-24 A | 2003-09-03 A |  | 100% | 2001-09-24 | 2003-09-03 | 508d | finish no earlier than 2003-09-03 | T1 | 4064h | 4064h | MISTST1-OpTDD | Rel-4 | Ingbert | 34.122 |  |  |  |
| 2059 | 15.3 | Extensions to R99 Test cases | 139.4w | 2001-04-02 A | 2003-12-02 A |  | 100% | 2001-04-02 | 2003-12-02 | 139.4w | finish no earlier than 2003-12-02 | T1 | 5576h | 5576h | MISTST1-Ext | Rel-4 | Ingbert | 34.123 p 1,2 |  |  |  |
| 2060 | 15.4 | Extension to R99 Test cases - TTCN | 439d | 2002-06-28 A | 2004-03-03 A |  | 100% | 2002-06-28 | 2004-03-03 | 439d | finish no earlier than 2004-03-03 | T1 | 3512h | 3512h |  | Rel-4 | Ingbert |  |  |  |  |
| 2061 | 15.5 | Creation of R99 TCs for TDD - prose | 719d | 2001-10-01 A | 2004-07-01 A |  | 100% | 2001-10-01 | 2004-07-01 | 719d | finish no earlier than 2004-07-01 | T1 | 5752h | 5752h | MISTST1-TDD | Rel-4 | Ingbert | 34.123-1 |  |  |  |
| 2062 | 15.6 | Deleted - Creation of R99 TCs for TDD - TTCN | 587d | 2002-09-03 A | 2004-12-01 A |  | 100% | 2002-09-03 | 2004-12-01 | 587d | finish no earlier than 2004-12-01 | T1 | 4696h | 4696h |  | Rel-4 | Ingbert |  | TP-26 |  |  |
| 2063 | 15.7 | Deleted - Review all other work items for impact on new or exiting 34 series specs. | 25.8w | 2002-07-02 A | 2002-12-27 A |  | 100% | 2002-07-02 | 2002-12-27 | 25.8w | finish no earlier than 2002-12-27 | T1 | 1032h | 1032h | MISTST1 | Rel-4 | Ingbert | 34.121,122,123,125 | TP-18 |  |  |
| 2064 | 46 | **Facsimile** | 89d | 2000-02-22 A | 2000-06-23 A |  | 100% | 2000-02-22 | 2000-06-23 | 89d |  | S1 | 4376h | 4376h | FAX | Rel-4 | Alain |  |  |  |  |
| 2065 | 46.1 | **Real Time Fax** | 89d | 2000-02-22 A | 2000-06-23 A |  | 100% | 2000-02-22 | 2000-06-23 | 89d |  | S2 | 3664h | 3664h | FAX-RT | Rel-4 | Maurice |  |  |  |  |
| 2066 | 46.1.1 | Terminal capabilities, AT commands | 89d | 2000-02-22 A | 2000-06-23 A |  | 100% | 2000-02-22 | 2000-06-23 | 89d | finish no earlier than 2000-06-23 | T2 | 712h | 712h |  | Rel-4 |  | 21.904, 27.007 |  |  |  |
| 2067 | 46.1.2 | Signalling aspects (e.g. ICM) | 89d | 2000-02-22 A | 2000-06-23 A |  | 100% | 2000-02-22 | 2000-06-23 | 89d | start no earlier than 2000-02-22 | N1 | 712h | 712h |  | Rel-4 | Frederic |  |  |  |  |
| 2068 | 46.1.3 | Service provision | 89d | 2000-02-22 A | 2000-06-23 A |  | 100% | 2000-02-22 | 2000-06-23 | 89d | finish no earlier than 2000-06-23 | N3 | 712h | 712h |  | Rel-4 | Gwiho | 23.146 |  |  |  |
| 2069 | 46.1.4 | Review whether service/stage 1 aspects need to be aligned | 51d | 2000-04-14 A | 2000-06-23 A |  | 100% | 2000-04-14 | 2000-06-23 | 51d | finish no earlier than 2000-12-14 | S1 | 408h | 408h |  | Rel-4 | Alain |  |  |  |  |
| 2070 | 46.1.5 | Review whether architecture/stage 2 aspects need to be aligned | 51d | 2000-04-14 A | 2000-06-23 A |  | 100% | 2000-04-14 | 2000-06-23 | 51d | finish no earlier than 2000-12-14 | S2 | 408h | 408h |  | Rel-4 | Maurice |  |  |  |  |
| 2071 | 47 | Transparent End-to-End PS mobile streaming application | 253d | 2000-04-03 A | 2001-03-21 A |  | 100% | 2000-04-03 | 2001-03-21 | 253d | finish no earlier than 2000-12-29 | S4 | 2024h | 2024h | PSTREAM | Rel-4 | Paolo | 26.233, 26.234 |  |  |  |
| 2072 | 48 | **Multimedia Messaging** | 277d | 2000-02-22 A | 2001-03-14 A |  | 100% | 2000-02-22 | 2001-03-14 | 277d |  | T2,S1 | 9992h | 9992h | MMS | Rel-4 | Kimmo | 22.140, 23.140 |  | Siemens | Josef.Laumen@SAL.SIEMENS.DE |
| 2073 | 48.1 | Definition of service requirements | 72d | 2000-02-22 A | 2000-05-31 A |  | 100% | 2000-02-22 | 2000-05-31 | 72d | start no earlier than 2000-02-22 | S1 | 576h | 576h | MMS | Rel-4 | Alain |  |  |  |  |
| 2074 | 48.2 | Review of definition of service requirements | 205d | 2000-06-01 A | 2001-03-14 A | 2073 | 100% | 2000-06-01 | 2001-03-14 | 205d | finish no earlier than 2000-09-08 | T2 | 1640h | 1640h | MMS | Rel-4 | Kimmo | 22.140, 23.140 |  | Siemens |  |
| 2075 | 48.3 | **Technical Realisation** | 243d | 2000-04-10 A | 2001-03-14 A |  | 100% | 2000-04-10 | 2001-03-14 | 243d |  | T2 | 7776h | 7776h | MMS | Rel-4 | Kimmo | 22.140, 23.140 |  | Siemens | Josef.Laumen@SAL.SIEMENS.DE |
| 2076 | 48.3.1 | Review of definition of reference Achitecture model | 243d | 2000-04-10 A | 2001-03-14 A |  | 100% | 2000-04-10 | 2001-03-14 | 243d | finish no earlier than 2001-03-14 | T2 | 1944h | 1944h | MMS | Rel-4 | Kimmo | 22.140, 23.140 |  | Siemens | Josef.Laumen@SAL.SIEMENS.DE |
| 2077 | 48.3.2 | "Fulfill Requirements of Stage 1" | 243d | 2000-04-10 A | 2001-03-14 A |  | 100% | 2000-04-10 | 2001-03-14 | 243d | finish no earlier than 2001-03-14 | T2 | 1944h | 1944h | MMS | Rel-4 | Kimmo | 22.140, 23.140 |  | Siemens | Josef.Laumen@SAL.SIEMENS.DE |
| 2078 | 48.3.3 | Definition of MMS primitives in Stage 2 | 243d | 2000-04-10 A | 2001-03-14 A |  | 100% | 2000-04-10 | 2001-03-14 | 243d | finish no earlier than 2001-03-14 | T2 | 1944h | 1944h | MMS | Rel-4 | Kimmo | 22.140, 23.140 |  | Siemens | Josef.Laumen@SAL.SIEMENS.DE |
| 2079 | 49 | **Transcoder-Free Operation** | 326d | 2000-01-03 A | 2001-03-30 A |  | 100% | 2000-01-03 | 2001-03-30 | 326d |  | N4,S2,N1 | 10448h | 10448h | TrFO | Rel-4 | Kimmo |  |  |  |  |
| 2080 | 49.1 | **Out-of-Band Transcoder Control solution** | 326d | 2000-01-03 A | 2001-03-30 A |  | 100% | 2000-01-03 | 2001-03-30 | 326d |  | N4 | 8448h | 8448h | TrFO-OoBTC | Rel-4 | Kimmo |  |  | NEC | Toshiyuki Tamura (tamurato@aj.jp.nec.com) |
| 2081 | 49.1.1 | implementation in UTRAN | 145d | 2000-09-11 A | 2001-03-30 A |  | 100% | 2000-09-11 | 2001-03-30 | 145d | finish no earlier than 2001-03-30 | R3 | 1160h | 1160h | TrFO-OoBTC-UTRAN | Rel-4 | Juha | 25.401, 25.410, 25.413, 25.415, 23.153 |  | Siemens | Alexander Vesely |
| 2082 | 49.1.2 | Impact on architecture, Principles and Terminology | 211d | 2000-01-03 A | 2000-10-20 A |  | 100% | 2000-01-03 | 2000-10-20 | 211d | finish no earlier than 2000-10-20 | S2 | 1680h | 1680h | TrFO-OoBTC | Rel-4 | Maurice |  |  |  |  |
| 2083 | 49.1.3 | Codec Negotiation between UE and MSC | 125d | 2000-08-14 A | 2001-02-02 A |  | 100% | 2000-08-14 | 2001-02-02 | 125d | finish no earlier than 2001-02-02 | N1 | 1000h | 1000h | TrFO-OoBTC | Rel-4 | Frederic | 24.008, 23.009, 23.108, (29.002) |  | Motorola | Andrew Howell |
| 2084 | 49.1.4 | Codec Negotiation inter MSC | 125d | 2000-07-03 A | 2000-12-22 A |  | 100% | 2000-07-03 | 2000-12-22 | 125d | finish no earlier than 2000-12-22 | N4 | 1000h | 1000h | TrFO-OoBTC | Rel-4 | Kimmo |  |  |  |  |
| 2085 | 49.1.5 | Bearer establishment inter MSC | 125d | 2000-07-03 A | 2000-12-22 A |  | 100% | 2000-07-03 | 2000-12-22 | 125d | finish no earlier than 2000-12-22 | N4 | 1000h | 1000h | TrFO-OoBTC | Rel-4 | Kimmo | 23.153 |  |  |  |

Notes:
- 2056: -
- 2057: It is believed that the current R99 test spec. can be optimised for faster overall test times. Marked as stopped 12/2008 (was 70% complete)
- 2058: It is believed that the current R99 test spec. can be optimised for faster overall test times
- 2059: Further test coverage of the R99 specification to cover supplementry services. Marked as stopped 12/2008 (was 70% complete)
- 2060: Marked as closed 12/2008 (was marked 50% complete)
- 2061: Marked as closed 12/2008 (was marked 50% complete)
- 2062: Marked as stopped 12/2008
- 2063: Marked as stopped 12/2008
- 2064: -
- 2065: postponed from R99 to R00, SP-000169
- 2066: -
- 2067: -
- 2068: -
- 2069: -
- 2070: -
- 2071: -
- 2072: -
- 2073: -
- 2074: -
- 2075: -
- 2076: -
- 2077: e.g. minimum set of media formats, media format conversion, personalization of MMS.
- 2078: -
- 2079: Lead given to CN4 from CN / [DAB 28/11/00]
- 2080: -
- 2081: moved according to NP-000575
- 2082: e.g. study cascading TrFO/TFO/TrFO
- 2083: the link to NP-000085has been deleted because refering to a R99 status sheet / One common set of codec negotiation procedures will be specified as in ID1656.
- 2084: Bearer establishment inter MSC. TS 23.153 R99 part complete. capabilities moved to annex + list of open issues
- 2085: Bearer establishment inter MSC. TS 23.153 R99 part complete. capabilities moved to annex. / See NP-000127 / Open issues: / Handling of Conference Calls; / Handling of Multi Party Supplementary Services; / Handling of Handover UMTS to GSM; / Handling of Sending a ...

| ID | WBS | Task | Duration | Start | Finish | Complete | Baseline start | Baseline finish | Baseline duration | Constraint | Resources | Work | Actual work | Text1 | Text6 | Text8 | Text4 | Text5 |
| --- | --- | --- | --- | --- | --- | --- | --- | --- | --- | --- | --- | --- | --- | --- | --- | --- | --- | --- |
| 2086 | 49.2 | **Speech Transcoder: Location and Control at the UMTS Core Network Border** | 125d | 2000-04-10 A | 2000-09-29 A | 100% | 2000-04-10 | 2000-09-29 | 125d |  | S2 | 2000h | 2000h | TrFO-STLC | Rel-4 | Maurice |  |  |
| 2087 | 49.2.1 | Transcoder at Edge | 125d | 2000-04-10 A | 2000-09-29 A | 100% | 2000-04-10 | 2000-09-29 | 125d | finish no earlier than 2000-09-29 | NP | 1000h | 1000h | TrFO-STLC | Rel-4 |  |  |  |
| 2088 | 50 | **GERAN improvements 1 (Gb over IP)** | 225d | 2000-05-09 A | 2001-03-19 A | 100% | 2000-05-09 | 2001-03-19 | 225d |  | GP | 6472h | 6472h | GEIMP1 | Rel-4 | Paolo |  |  |
| 2089 | 50.1 | **Gb over IP (Ip-fication of Gb)** | 225d | 2000-05-09 A | 2001-03-19 A | 100% | 2000-05-09 | 2001-03-19 | 225d |  | GP | 4672h | 4672h | GbIP | Rel-4 | Paolo |  |  |
| 2090 | 50.1.1 | Concept | 134d | 2000-05-09 A | 2000-11-10 A | 100% | 2000-05-09 | 2000-11-10 | 134d |  | GP | 1072h | 1072h |  | Rel-4 | Paolo |  |  |
| 2091 | 50.1.2 | Changes to 08.16, 08.18 | 225d | 2000-05-09 A | 2001-03-19 A | 100% | 2000-05-09 | 2001-03-19 | 225d |  | GP | 1800h | 1800h |  | Rel-4 | Paolo |  |  |
| 2092 | 51 | **GERAN improvements 2 (NACC)** | 677d | 2000-11-06 A | 2003-06-10 A | 100% | 2000-11-06 | 2003-06-10 | 677d |  | GP | 19224h | 19224h | GEIMP2 | Rel-4 | Paolo |  |  |
| 2093 | 51.1 | **Gb enhancements** | 155d | 2000-11-06 A | 2001-06-08 A | 100% | 2000-11-06 | 2001-06-08 | 155d |  | GP | 7440h | 7440h | Gben | Rel-4 | Paolo |  |  |
| 2094 | 51.1.1 | **Intra BSC NACC (Network Assisted Cell Change)** | 155d | 2000-11-06 A | 2001-06-08 A | 100% | 2000-11-06 | 2001-06-08 | 155d |  | GP | 6200h | 6200h |  | Rel-4 | Paolo |  |  |
| 2095 | 51.1.1.1 | Concept | 155d | 2000-11-06 A | 2001-06-08 A | 100% | 2000-11-06 | 2001-06-08 | 155d | finish no earlier than 2001-06-08 | GP | 1240h | 1240h |  | Rel-4 | Paolo |  |  |
| 2096 | 51.1.1.2 | Changes in 03.64 | 155d | 2000-11-06 A | 2001-06-08 A | 100% | 2000-11-06 | 2001-06-08 | 155d | finish no earlier than 2001-06-08 | GP | 1240h | 1240h |  | Rel-4 | Paolo |  |  |
| 2097 | 51.1.1.3 | Changes in 04.60 | 155d | 2000-11-06 A | 2001-06-08 A | 100% | 2000-11-06 | 2001-06-08 | 155d | finish no earlier than 2001-06-08 | GP | 1240h | 1240h |  | Rel-4 | Paolo |  |  |
| 2098 | 51.1.1.4 | Changes in 44.008 | 155d | 2000-11-06 A | 2001-06-08 A | 100% | 2000-11-06 | 2001-06-08 | 155d | finish no earlier than 2001-06-08 | GP | 1240h | 1240h |  | Rel-4 | Paolo |  |  |
| 2099 | 51.3 | **MS conformance test for Intra BSC NACC** | 398d | 2001-11-30 A | 2003-06-10 A | 100% | 2001-11-30 | 2003-06-10 | 398d |  | GP | 6368h | 6368h | GEIMP2-Msconf | Rel-4 | Paolo |  |  |
| 2100 | 51.3.1 | Changes in 51.010 | 398d | 2001-11-30 A | 2003-06-10 A | 100% | 2001-11-30 | 2003-06-10 | 398d | finish no earlier than 2003-12-19 | G5,G4 | 3184h | 3184h |  | Rel-4 | Paolo |  |  |
| 2101 | 52 | **GERAN improvements 4 (Delayed TBF)** | 105d | 2001-01-15 A | 2001-06-08 A | 100% | 2001-01-15 | 2001-06-08 | 105d |  | GP | 3960h | 3960h | GEIMP4 | Rel-4 | Paolo |  |  |
| 2102 | 52.1 | **Gb enhancements 2** | 105d | 2001-01-15 A | 2001-06-08 A | 100% | 2001-01-15 | 2001-06-08 | 105d |  | GP | 3120h | 3120h | GEIMP4-Gben2 | Rel-4 | Paolo |  |  |
| 2103 | 52.1.1 | stage 2 | 105d | 2001-01-15 A | 2001-06-08 A | 100% | 2001-01-15 | 2001-06-08 | 105d | finish no earlier than 2001-06-08 | GP | 840h | 840h |  | Rel-4 | Paolo |  |  |
| 2104 | 52.1.2 | **Stage 3 (changes in 44.060)** | 60d | 2001-01-15 A | 2001-04-06 A | 100% | 2001-01-15 | 2001-04-06 | 60d |  | G2 | 1440h | 1440h |  | Rel-4 | Gert |  |  |
| 2105 | 52.1.2.1 | Definition of enhanced countdown procedure | 60d | 2001-01-15 A | 2001-04-06 A | 100% | 2001-01-15 | 2001-04-06 | 60d | finish no earlier than 2001-04-06 | G2 | 480h | 480h |  | Rel-4 | Gert |  |  |
| 2106 | 52.1.2.2 | Definition of enhanced TBF release procedure | 60d | 2001-01-15 A | 2001-04-06 A | 100% | 2001-01-15 | 2001-04-06 | 60d | finish no earlier than 2001-04-06 | G2 | 480h | 480h |  | Rel-4 | Gert |  |  |
| 2107 | 52.1.2.3 | Definition of USF=FREE type polling mechanism on PDCH | 60d | 2001-01-15 A | 2001-04-06 A | 100% | 2001-01-15 | 2001-04-06 | 60d | finish no earlier than 2001-04-06 | G2 | 480h | 480h |  | Rel-4 | Gert |  |  |
| 2108 | 53 | **Low Chip Rate TDD option** | 880d | 2000-07-19 A | 2003-12-02 A | 100% | 2000-07-19 | 2003-12-02 | 880d |  | R1 | 25872h | 25872h | LCRTDD | Rel-4 | Patrick | CWTS | G. Yang |
| 2109 | 53.1 | Physical layer | 183d | 2000-07-19 A | 2001-03-30 A | 100% | 2000-07-19 | 2001-03-30 | 183d | finish no earlier than 2001-03-30 | R1 | 1464h | 1464h | LCRTDD-Phys | Rel-4 | Patrick | CWTS | G. Yang |
| 2110 | 53.2 | Layer 2 and layer 3 protocol aspects | 183d | 2000-07-19 A | 2001-03-30 A | 100% | 2000-07-19 | 2001-03-30 | 183d | finish no earlier than 2001-03-30 | R2 | 1464h | 1464h | LCRTDD-L23 | Rel-4 | Joern | CWTS | Y. Liu |
| 2111 | 53.3 | RF radio transmission/reception, system performance requirements and conformance testing | 165d | 2000-08-14 A | 2001-03-30 A | 100% | 2000-08-14 | 2001-03-30 | 165d | finish no earlier than 2001-03-30 | R4 | 1320h | 1320h | LCRTDD-RF | Rel-4 | Issam | CWTS | D. Zhang |
| 2112 | 53.4 | UE radio access capability | 165d | 2000-08-14 A | 2001-03-30 A | 100% | 2000-08-14 | 2001-03-30 | 165d | finish no earlier than 2001-03-30 | R2 | 1320h | 1320h | LCRTDD-UErac | Rel-4 | Joern | CWTS | Y. Liu |
| 2113 | 53.5 | Iub/Iur protocol aspects | 165d | 2000-08-14 A | 2001-03-30 A | 100% | 2000-08-14 | 2001-03-30 | 165d | finish no earlier than 2001-03-30 | R3 | 1320h | 1320h | LCRTDD-IubIur | Rel-4 | Juha | CWTS | Y. Liu |

Notes:
- 2086: WI description and Tdoc S2-99352 / Speech Transcoder: Location and Control at the UMTS Core Network Border
- 2087: WI description and Tdoc S2-99352...
- 2088: -
- 2089: -
- 2090: -
- 2091: -
- 2092: -
- 2093: -
- 2094: -
- 2095: -
- 2096: -
- 2097: -
- 2098: -
- 2099: -
- 2100: az 05/08: duplicated UID_50099 => 50299. Marked as closed 12/2008 (was marked 50% complete)
- 2101: -
- 2102: -
- 2103: -
- 2104: -
- 2105: -
- 2106: -
- 2107: -
- 2108: -
- 2109: -
- 2110: -
- 2111: -
- 2112: -
- 2113: -

| ID | WBS | Task | Duration | Start | Finish | Predecessors | Complete | Baseline start | Baseline finish | Baseline duration | Constraint | Resources | Work | Actual work | Text6 | Text8 | Text3 | Text12 | Text1 | Text4 | Text5 |
| --- | --- | --- | --- | --- | --- | --- | --- | --- | --- | --- | --- | --- | --- | --- | --- | --- | --- | --- | --- | --- | --- |
| 2114 | 53.6 | **Low chiprate TDD interworking with GERAN** | 101d | 2000-09-01 A | 2001-01-19 A | 2113 | 100% | 2000-09-01 | 2001-01-19 | 101d |  |  |  |  | Rel-4 | Paolo |  |  |  |  |  |
| 2115 | 53.6.1 | Handover and Cell Selection / Reselection to UTRA 1.28 Mcps TDD | 101d | 2000-09-01 A | 2001-01-19 A |  | 100% | 2000-09-01 | 2001-01-19 | 101d | finish no earlier than 2001-01-19 |  |  |  | Rel-4 |  |  |  |  |  |  |
| 2116 | 53.8 | **Conformance Test Aspects - Low Chip Rate TDD** | 577d | 2001-09-17 A | 2003-12-02 A | 2114 | 100% | 2001-09-17 | 2003-12-02 | 577d |  | T1 | 12088h | 12088h | Rel-4 | Ingbert |  |  |  |  |  |
| 2117 | 53.8.1 | Testing Layer 2 and layer 3 protocol aspects | 468d | 2001-09-17 A | 2003-07-02 A |  | 100% | 2001-09-17 | 2003-07-02 | 468d | finish no earlier than 2003-07-02 | T1 | 3744h | 3744h | Rel-4 | Ingbert | 34.123-1, 34.123-2 |  |  |  |  |
| 2118 | 53.8.2 | Deleted - Testing Layer 2 and layer 3 protocol aspects - TTCN | 261d | 2002-12-03 A | 2003-12-02 A |  | 100% | 2002-12-03 | 2003-12-02 | 261d | finish no earlier than 2003-12-02 | T1 | 2088h | 2088h | Rel-4 | Ingbert | 34.123-3 | TP-22 |  |  |  |
| 2119 | 53.8.3 | Testing RF Radio Transmission and Reception | 205d | 2001-09-17 A | 2002-06-28 A |  | 100% | 2001-09-17 | 2002-06-28 | 205d | finish no earlier than 2002-06-28 | T1 | 1640h | 1640h | Rel-4 | Ingbert |  |  |  |  |  |
| 2120 | 54 | **Enable bearer independent CS architecture** | 566d | 2000-01-03 A | 2002-03-01 A |  | 100% | 2000-01-03 | 2002-03-01 | 566d |  | S2 | 20192h | 20192h | Rel-4 | Maurice |  |  | CSSPLIT | Siemens | Alexander Milinski |
| 2121 | 54.1 | **Enable bearer-independent call control** | 425d | 2000-01-03 A | 2001-08-16 A |  | 100% | 2000-01-03 | 2001-08-16 | 425d |  | N4 | 12344h | 12344h | Rel-4 | Kimmo |  |  |  | Ericsson | Heinz-Peter.Keutmann@eed.ericsson.se |
| 2122 | 54.1.1 | Architecture and Stage 2 description | 181d | 2000-01-03 A | 2000-09-08 A |  | 100% | 2000-01-03 | 2000-09-08 | 181d | finish no earlier than 2000-09-08 | S2 | 1440h | 1440h | Rel-4 | Maurice | 23.002 |  |  |  |  |
| 2123 | 54.1.2 | Standardisation of protocols (control & user planes) over Nb interface | 64d | 2001-01-02 A | 2001-03-30 A |  | 100% | 2001-01-02 | 2001-03-30 | 64d | finish no earlier than 2001-03-30 | N3 | 512h | 512h | Rel-4 | Gwiho |  |  |  |  |  |
| 2124 | 54.1.3 | Standardisation of protocols over reference points between MSC server and Gateway MSC server | 130d | 2000-09-25 A | 2001-03-23 A |  | 100% | 2000-09-25 | 2001-03-23 | 130d | finish no earlier than 2001-03-23 | N4 | 1040h | 1040h | Rel-4 | Kimmo |  |  |  |  |  |
| 2125 | 54.1.4 | Standardisation of detailed stage 2 description | 180d | 2000-07-17 A | 2001-03-23 A |  | 100% | 2000-07-17 | 2001-03-23 | 180d | finish no earlier than 2001-03-23 | N4 | 1440h | 1440h | Rel-4 | Kimmo |  |  |  |  |  |
| 2126 | 54.1.5 | **Bearer control between MSC server and MGW** | 250d | 2000-09-01 A | 2001-08-16 A |  | 100% | 2000-09-01 | 2001-08-16 | 250d |  | N4 | 4512h | 4512h | Rel-4 | Kimmo |  |  |  |  |  |
| 2127 | 54.1.5.1 | stage 3 - protocol issues | 250d | 2000-09-01 A | 2001-08-16 A |  | 100% | 2000-09-01 | 2001-08-16 | 250d | finish no earlier than 2001-08-16 | N4 | 2000h | 2000h | Rel-4 | Kimmo |  |  |  |  |  |
| 2128 | 54.1.5.2 | stage 3 - parameter value issues | 64d | 2001-01-02 A | 2001-03-30 A |  | 100% | 2001-01-02 | 2001-03-30 | 64d | finish no earlier than 2001-03-30 | N3 | 512h | 512h | Rel-4 | Gwiho |  |  |  |  |  |
| 2129 | 54.2 | Lawful interception | 155d | 2000-08-21 A | 2001-03-23 A |  | 100% | 2000-08-21 | 2001-03-23 | 155d | finish no earlier than 2001-03-23 | S3 | 1240h | 1240h | Rel-4 | Dionisio |  |  |  |  |  |
| 2130 | 54.4 | Deleted - Conformance Test Aspects - Enable bearer independent CS architecture | 260d | 2001-03-05 A | 2002-03-01 A |  | 100% | 2001-03-05 | 2002-03-01 | 260d |  | T1 | 2080h | 2080h | Rel-4 | Ingbert |  | TP-15 | CSSPLIT-TEST |  |  |
| 2131 | 55 | **MExE enhancements Rel-4** | 511d | 2000-01-03 A | 2001-12-14 A |  | 100% | 2000-01-03 | 2001-12-14 | 511d |  | T2 | 19032h | 19032h | Rel-4 | Kimmo |  |  | MEXE |  |  |
| 2132 | 55.1 | **MExE Security Analysis Activity** | 474d | 2000-02-22 A | 2001-12-14 A |  | 100% | 2000-02-22 | 2001-12-14 | 474d |  | S3 | 8464h | 8464h | Rel-4 | Dionisio |  |  | MEXE-SEC | BT | colin.blanchard@bt.com |
| 2133 | 55.1.1 | Stage 3 | 370d | 2000-07-17 A | 2001-12-14 A |  | 100% | 2000-07-17 | 2001-12-14 | 370d | finish no earlier than 2001-12-14 | S3 | 2960h | 2960h | Rel-4 | Dionisio |  |  | MEXE1-SEC |  |  |
| 2134 | 55.1.2 | Terminal aspects | 214d | 2000-02-22 A | 2000-12-15 A |  | 100% | 2000-02-22 | 2000-12-15 | 214d | finish no earlier than 2000-12-15 | T2 | 1712h | 1712h | Rel-4 |  |  |  |  |  |  |
| 2135 | 55.2 | **MExE Rel4 Improvements and Investigations** | 251d | 2000-01-03 A | 2000-12-15 A |  | 100% | 2000-01-03 | 2000-12-15 | 251d |  | T2 | 6480h | 6480h | Rel-4 |  | 22.057, 23.057 |  | MEXE-ENHANC | Motorola | Mark Cataldo |
| 2136 | 55.2.1 | 3rd MExE classmark | 251d | 2000-01-03 A | 2000-12-15 A |  | 100% | 2000-01-03 | 2000-12-15 | 251d | finish no earlier than 2000-12-15 | T2 | 2000h | 2000h | Rel-4 |  | 22.057, 23.057 |  |  | Motorola | Mark Cataldo |
| 2137 | 55.2.2 | FS on Secure download mechanism and capabilities to support SDR concepts | 225d | 2000-02-07 A | 2000-12-15 A |  | 100% | 2000-02-07 | 2000-12-15 | 225d | finish no earlier than 2000-12-15 | T2 | 1800h | 1800h | Rel-4 |  | 22.057, 23.057 |  |  | Motorola | Mark Cataldo |
| 2138 | 55.2.3 | FS on Support of MP3/MPEG4 content | 225d | 2000-02-07 A | 2000-12-15 A |  | 100% | 2000-02-07 | 2000-12-15 | 225d | finish no earlier than 2000-12-15 | T2 | 1800h | 1800h | Rel-4 |  | 22.057, 23.057 |  |  | Motorola | Mark Cataldo |

Notes:
- 2114: -
- 2115: -
- 2116: -
- 2117: Marked as closed 12/2008 (was marked 60% complete)
- 2118: Marked as stopped 12/2008
- 2119: duration set to 6 months (was 0), finish date set
- 2120: -
- 2121: DAB 12.12.01 should be 100% hence closed
- 2122: R00 stage 2 at least 80 % complete in TSGS #8 21.-23.6.2000
- 2123: -
- 2124: -
- 2125: -
- 2126: -
- 2127: -
- 2128: -
- 2129: Requirements capture: S3#14 (Aug 00), Feature specification: S3#15 (Sep 00), Definition of architecture. Should be included in general LI work mentioned above.
- 2130: Marked as stopped 12/2008
- 2131: -
- 2132: Presentation to S3 of threats and countermeasures analysis: S3#15, Feature specification: S3#16. S3#18: WID updated
- 2133: Analysis undertaken by T2. No additional analysis needed for Rel-4
- 2134: -
- 2135: -
- 2136: Additional features for MExE R2000
- 2137: -
- 2138: -

| ID | WBS | Task | Duration | Start | Finish | Complete | Baseline start | Baseline finish | Baseline duration | Constraint | Resources | Work | Actual work | Text1 | Text6 | Text8 | Text3 | Text4 | Text5 |
| --- | --- | --- | --- | --- | --- | --- | --- | --- | --- | --- | --- | --- | --- | --- | --- | --- | --- | --- | --- |
| 2139 | 56 | **Tandem Free aspects for 3G and between 2G and 3G systems** | 344d | 2000-02-22 A | 2001-06-15 A | 100% | 2000-02-22 | 2001-06-15 | 344d |  | S4 | 9696h | 9696h | TFO | Rel-4 | Paolo |  |  |  |
| 2140 | 56.1 | **Tandem Free AMR** | 344d | 2000-02-22 A | 2001-06-15 A | 100% | 2000-02-22 | 2001-06-15 | 344d |  | S4 | 6944h | 6944h | TFO-AMR | Rel-4 | Paolo |  |  |  |
| 2141 | 56.1.1 | Specification | 284d | 2000-02-22 A | 2001-03-23 A | 100% | 2000-02-22 | 2001-03-23 | 284d | start no earlier than 2000-02-22 | S4 | 2272h | 2272h |  | Rel-4 | Paolo | 28.062 |  |  |
| 2142 | 56.1.2 | **Impact on:** | 115d | 2001-01-08 A | 2001-06-15 A | 100% | 2001-01-08 | 2001-06-15 | 115d |  | NP | 1920h | 1920h |  | Rel-4 | Kimmo |  |  |  |
| 2143 | 56.1.2.1 | CN | 60d | 2001-03-26 A | 2001-06-15 A | 100% | 2001-03-26 | 2001-06-15 | 60d | finish no earlier than 2001-06-15 | NP | 480h | 480h |  | Rel-4 | Kimmo |  |  |  |
| 2144 | 56.1.2.2 | GERAN | 65d | 2001-01-08 A | 2001-04-06 A | 100% | 2001-01-08 | 2001-04-06 | 65d | finish no earlier than 2001-04-06 | GP | 520h | 520h |  | Rel-4 | Paolo |  |  |  |
| 2145 | 57 | **Advanced Speech Call Items enhancements_REL-4** | 334d | 2000-12-03 A | 2002-03-14 A | 100% | 2000-12-03 | 2002-03-14 | 334d |  | N1 | 5925.6h | 5925.6h | ASCI | Rel-4 | Frederic |  | Nortel | sonia.garapaty@nortelnetworks.com |
| 2146 | 57.1 | Stage 2 | 326.7d | 2000-12-03 A | 2002-03-14 A | 100% | 2000-12-03 | 2002-03-14 | 326.7d | finish no earlier than 2002-03-14 | N4 | 2613.6h | 2613.6h |  | Rel-4 | Kimmo | 23.067, 24.067 | Sagem | Vivien Perlic |
| 2147 | 57.2 | Stages 2 and 3 on A interface | 80d | 2000-12-03 A | 2001-03-23 A | 100% | 2000-12-03 | 2001-03-23 | 80d | finish no earlier than 2001-03-23 | N1 | 640h | 640h |  | Rel-4 | Frederic | 44.068, 44.069, 24.008 | Nortel | sonia.garapaty@nortelnetworks.com |
| 2148 | 58 | **700 MHz spectrum support** | 776d | 2000-01-03 A | 2002-12-20 A | 100% | 2000-01-03 | 2002-12-20 | 776d |  | GP | 25016h | 25016h | 700SS | Rel-4 | Paolo |  |  |  |
| 2149 | 58.1 | **GERAN support for the 700 MHz band** | 276d | 2000-01-03 A | 2001-01-19 A | 100% | 2000-01-03 | 2001-01-19 | 276d |  | GP | 8808h | 8808h |  | Rel-4 | Paolo |  |  |  |
| 2150 | 58.1.1 | Signalling support | 276d | 2000-01-03 A | 2001-01-19 A | 100% | 2000-01-03 | 2001-01-19 | 276d | finish no earlier than 2001-01-19 | GP | 2200h | 2200h |  | Rel-4 | Paolo |  |  |  |
| 2151 | 58.1.2 | Physical layer definitions | 276d | 2000-01-03 A | 2001-01-19 A | 100% | 2000-01-03 | 2001-01-19 | 276d | finish no earlier than 2001-01-19 | GP | 2200h | 2200h |  | Rel-4 | Paolo |  |  |  |
| 2152 | 58.1.3 | Receiver performance and RF budget | 276d | 2000-01-03 A | 2001-01-19 A | 100% | 2000-01-03 | 2001-01-19 | 276d | finish no earlier than 2001-01-19 | GP | 2200h | 2200h |  | Rel-4 | Paolo |  |  |  |
| 2153 | 58.2 | **GERAN MS Conformance test for 700 MHz band** | 175d | 2001-04-02 A | 2001-11-30 A | 100% | 2001-04-02 | 2001-11-30 | 175d |  | GP | 2800h | 2800h |  | Rel-4 | Paolo |  |  |  |
| 2154 | 58.2.1 | MS test | 175d | 2001-04-02 A | 2001-11-30 A | 100% | 2001-04-02 | 2001-11-30 | 175d | finish no earlier than 2001-11-30 | GP | 1400h | 1400h |  | Rel-4 | Paolo |  |  |  |
| 2155 | 58.3 | **GERAN BTS Conformance test for 700 MHz band** | 450d | 2001-04-02 A | 2002-12-20 A | 100% | 2001-04-02 | 2002-12-20 | 450d |  | GP | 7200h | 7200h |  | Rel-4 | Paolo |  |  |  |
| 2156 | 58.3.1 | BTS test | 450d | 2001-04-02 A | 2002-12-20 A | 100% | 2001-04-02 | 2002-12-20 | 450d | finish no earlier than 2002-12-20 | GP | 3600h | 3600h |  | Rel-4 | Paolo |  |  |  |
| 2157 | 59 | Operator Determined Barring for Packet Oriented Services | 208d | 2000-06-01 A | 2001-03-19 A | 100% | 2000-06-01 | 2001-03-19 | 208d | finish no earlier than 2001-03-19 | NP | 1664h | 1664h | ODB | Rel-4 |  |  | NEC | Toshiyuki Tamura (tamurato@aj.jp.nec.com) |
| 2158 | 60 | **UMTS QoS Architecture for PS Domain** | 759d | 2000-01-03 A | 2002-11-27 A | 100% | 2000-01-03 | 2002-11-27 | 759d |  | S2 | 41312h | 41312h | QoSPS | Rel-4 | Maurice |  | Ericsson | Ina.widegren@era.ericsson.se |
| 2159 | 60.1 | Architecture | 153d | 2000-06-05 A | 2001-01-03 A | 100% | 2000-06-05 | 2001-01-03 | 153d | finish no earlier than 2001-01-03 | S2 | 1224h | 1224h |  | Rel-4 | Maurice | 23.107 |  |  |
| 2160 | 60.2 | Charging and OAM&P for QoS Management | 201d | 2001-09-21 A | 2002-06-28 A | 100% | 2001-09-21 | 2002-06-28 | 201d | finish no earlier than 2002-06-28 | S5 | 1608h | 1608h | QoSPS-OAM | Rel-4 | Dionisio | 32-series | VoiceStream, Motorola |  |
| 2161 | 60.3 | **RAB Quality of Service (re)Negotiation over Iu** | 155d | 2000-08-21 A | 2001-03-23 A | 100% | 2000-08-21 | 2001-03-23 | 155d |  | R3 | 3648h | 3648h | QoSPS-MAPEND-RABQoS | Rel-4 | Juha | 25.413 | Ericsson | A. Molander |
| 2162 | 60.3.1 | RAB Quality of Service Negotiation over Iu | 155d | 2000-08-21 A | 2001-03-23 A | 100% | 2000-08-21 | 2001-03-23 | 155d | finish no earlier than 2001-03-23 | R3 | 1240h | 1240h | QoSPS-MAPEND-RABQoS-Negot | Rel-4 | Juha |  | Ericsson | A. Molander |
| 2163 | 60.3.2 | RAB Quality of Service Negotiation over Iu during relocation | 16d | 2001-03-02 A | 2001-03-23 A | 100% | 2001-03-02 | 2001-03-23 | 16d | start no earlier than 2001-03-02 | R3 | 128h | 128h | QoSPS-MAPEND-RABQoS-NegotReloc | Rel-4 | Juha |  |  |  |
| 2164 | 60.3.3 | RAB Quality of Service Re-Negotiation over Iu | 130d | 2000-09-25 A | 2001-03-23 A | 100% | 2000-09-25 | 2001-03-23 | 130d | finish no earlier than 2001-03-23 | R3 | 1040h | 1040h | QoSPS-MAPEND-RABQoS-ReNegot | Rel-4 | Juha |  | Motorola | S. Irwin |

Notes:
- 2139: RAN and CN to verify no problems for GSM terminals roaming in 3G R99
- 2140: RAN and CN to verify UMTS_AMR_2 support
- 2141: -
- 2142: "Implementation" changed to "Impact on:" by A. Sultan (for better wording)
- 2143: RAN and CN to verify UMTS_AMR_2 support
- 2144: End date Modified from June to March to have it in Rel4
- 2145: Approved at CN#10
- 2146: CN4#11 30/11/02: no inputs received in CN4
- 2147: -
- 2148: -
- 2149: -
- 2150: -
- 2151: -
- 2152: -
- 2153: -
- 2154: -
- 2155: -
- 2156: -
- 2157: Completed WI missing from the P-plan Added for tracking
- 2158: -
- 2159: -
- 2160: -
- 2161: -
- 2162: -
- 2163: -
- 2164: -

| ID | WBS | Task | Duration | Start | Finish | Complete | Baseline start | Baseline finish | Baseline duration | Constraint | Resources | Work | Actual work | Text1 | Text6 | Text8 | Text12 | Text4 | Text5 | Text3 |
| --- | --- | --- | --- | --- | --- | --- | --- | --- | --- | --- | --- | --- | --- | --- | --- | --- | --- | --- | --- | --- |
| 2165 | 60.4 | **GERAN QoS Aspects - Handovers: maintenance of real-time QoS while moving between cells in the PLMN including inter-SGSN and SRNS relocation or possibly other mechanisms** | 501d | 2000-01-03 A | 2001-11-30 A | 100% | 2000-01-03 | 2001-11-30 | 501d |  | GP | 14456h | 14456h | GERQoS | Rel-4 | Paolo |  |  |  |  |
| 2166 | 60.4.1 | **Handover Concept for the PS domain** | 501d | 2000-01-03 A | 2001-11-30 A | 100% | 2000-01-03 | 2001-11-30 | 501d |  | GP | 10448h | 10448h |  | Rel-4 | Paolo |  |  |  |  |
| 2167 | 60.4.1.1 | Stable RT handover report 25.936 including header removal | 14d | 2000-01-03 A | 2000-01-19 A | 100% | 2000-01-03 | 2000-01-19 | 14d | start no earlier than 2000-01-03 | GP [92.9%] | 104h | 104h |  | Rel-4 | Paolo |  |  |  |  |
| 2168 | 60.4.1.2 | Update of stage 2 | 293d | 2000-01-03 A | 2001-02-13 A | 100% | 2000-01-03 | 2001-02-13 | 293d | finish no earlier than 2001-02-13 | GP | 2336h | 2336h |  | Rel-4 | Paolo |  |  |  |  |
| 2169 | 60.4.1.3 | Update of relevant stage 3 specs -> RRC | 501d | 2000-01-03 A | 2001-11-30 A | 100% | 2000-01-03 | 2001-11-30 | 501d | finish no earlier than 2001-11-30 | G2 | 4000h | 4000h |  | Rel-4 | Gert |  |  |  |  |
| 2170 | 60.5 | **Deleted - GERAN MS Conformance test for inter-system and intra-system Packet data real-time Handover** | 324d | 2001-08-31 A | 2002-11-27 A | 100% | 2001-08-31 | 2002-11-27 | 324d |  | G4,R3 | 12960h | 12960h | GERQoS-Mstest | Rel-4 | Paolo | GP-12 |  |  |  |
| 2171 | 60.5.1 | **Deleted - Handover for the PS domain** | 324d | 2001-08-31 A | 2002-11-27 A | 100% | 2001-08-31 | 2002-11-27 | 324d |  | G4,R3 | 10368h | 10368h |  | Rel-4 | Paolo | GP-12 |  |  |  |
| 2172 | 60.5.1.1 | Deleted - Stable RT handover report 25.936 including header removal | 324d | 2001-08-31 A | 2002-11-27 A | 100% | 2001-08-31 | 2002-11-27 | 324d | finish no earlier than 2002-11-27 | G4,R3 | 2592h | 2592h |  | Rel-4 | Paolo | GP-12 |  |  |  |
| 2173 | 60.5.1.2 | Deleted - Update of stage 2 | 324d | 2001-08-31 A | 2002-11-27 A | 100% | 2001-08-31 | 2002-11-27 | 324d | finish no earlier than 2002-11-27 | G4,R3 | 2592h | 2592h |  | Rel-4 | Paolo | GP-12 |  |  |  |
| 2174 | 60.5.1.3 | Deleted - Update of relevant stage 3 specs | 324d | 2001-08-31 A | 2002-11-27 A | 100% | 2001-08-31 | 2002-11-27 | 324d | finish no earlier than 2002-11-27 | G4,R3 | 2592h | 2592h |  | Rel-4 | Paolo | GP-12 |  |  |  |
| 2175 | 60.6 | PS-domain handover for real-time services | 155d | 2000-08-28 A | 2001-03-30 A | 100% | 2000-08-28 | 2001-03-30 | 155d | finish no earlier than 2001-03-30 | R3 | 1240h | 1240h | QoSPS-PSdoRTS | Rel-4 | Juha |  | Nokia | A. Lansisalmi |  |
| 2176 | 60.7 | Deleted - RAB QoS Renegotiation at Relocation | 58d | 2001-01-03 A | 2001-03-23 A | 100% | 2001-01-03 | 2001-03-23 | 58d | finish no earlier than 2001-03-23 | R3 | 464h | 464h |  | Rel-4 | Juha | RP-11 |  |  | 25.851, 25.946 |
| 2177 | 61 | **small Technical Enhancements and Improvements for Rel4** | 2178d? | 2000-01-03 A | 2008-05-06 A | 100% | 2000-01-03 | 2008-05-06 | 2178d? |  | All | 17424h | 17424h | TEI4 | Rel-4 |  |  |  |  |  |
| 2178 | 537.1 | Small Technical Enhancements and Improvements for Rel-4 Conformance Testing | 2178d? | 2000-01-03 A | 2008-05-06 A | 100% | 2000-01-03 | 2008-05-06 | 2178d? | finish no earlier than 2008-12-31 | R5,T1 | 17424h | 17424h | TEI4_Test | Rel-4 | Ingbert |  |  |  |  |
| 2179 | 62 | **Rel-4 Evolutions of the transport in the UTRAN** | 525d | 2000-08-21 A | 2002-08-23 A | 100% | 2000-08-21 | 2002-08-23 | 525d |  | RP | 8600h | 8600h | ETRAN | Rel-4 | Issam |  | Alcatel | Francois Courau |  |
| 2180 | 62.1 | QoS optimization for AAL2 connections over Iub and Iur interfaces | 160d | 2000-08-21 A | 2001-03-30 A | 100% | 2000-08-21 | 2001-03-30 | 160d | finish no earlier than 2001-03-30 | R3 | 1280h | 1280h | ETRAN-QoSAAL2 | Rel-4 | Juha |  | Japan Telecom | T. Yoshimura |  |
| 2181 | 62.2 | Transport bearer modification procedure on Iub, Iur, and Iu | 130d | 2000-10-02 A | 2001-03-30 A | 100% | 2000-10-02 | 2001-03-30 | 130d | finish no earlier than 2001-03-30 | R3 | 1040h | 1040h | ETRAN-MigrMod | Rel-4 | Juha |  | Japan Telecom | T. Yoshimura |  |
| 2182 | 62.3 | **Deleted - Conformance Test Aspects of Rel-4 evolutions of the transport in UTRAN** | 130d | 2002-02-25 A | 2002-08-23 A | 100% | 2002-02-25 | 2002-08-23 | 130d |  | T1 | 2080h | 2080h |  | Rel-4 | Ingbert |  |  |  |  |
| 2183 | 62.3.1 | Deleted - Testing RAB support enhancements | 130d | 2002-02-25 A | 2002-08-23 A | 100% | 2002-02-25 | 2002-08-23 | 130d | finish no earlier than 2002-08-23 | T1 | 1040h | 1040h | CT-RABS? | Rel-4 | Ingbert |  |  |  | 34.108, 34. 121, 34.122, 34.123 p 1,2, 34.123 pt 3 |
| 2184 | 63 | **Rel-4 Evolutions of the transport in the CN** | 215d | 2000-05-29 A | 2001-03-23 A | 100% | 2000-05-29 | 2001-03-23 | 215d |  | N4,N1,N2,S2 | 7968h | 7968h | CNTRSP | Rel-4 | Kimmo |  |  |  |  |
| 2185 | 63.1 | **IP Transport of CN protocols (e.g., CAP, MAP)** | 77d | 2000-12-07 A | 2001-03-23 A | 100% | 2000-12-07 | 2001-03-23 | 77d |  | N4 | 2808h | 2808h | SS7IP | Rel-4 | Kimmo |  |  |  |  |
| 2186 | 63.1.1 | **Stage 3** | 77d | 2000-12-07 A | 2001-03-23 A | 100% | 2000-12-07 | 2001-03-23 | 77d |  | N4 | 2192h | 2192h |  | Rel-4 | Kimmo |  |  |  |  |
| 2187 | 63.1.1.1 | CAP | 77d | 2000-12-07 A | 2001-03-23 A | 100% | 2000-12-07 | 2001-03-23 | 77d | finish no earlier than 2001-03-23 | N2 | 616h | 616h |  | Rel-4 | Kimmo |  |  |  |  |
| 2188 | 63.1.1.2 | MAP | 77d | 2000-12-07 A | 2001-03-23 A | 100% | 2000-12-07 | 2001-03-23 | 77d | finish no earlier than 2001-03-23 | N4 | 616h | 616h |  | Rel-4 | Kimmo |  |  |  |  |
| 2189 | 63.1.1.3 | BSSAP+ | 43d | 2001-01-15 A | 2001-03-14 A | 100% | 2001-01-15 | 2001-03-14 | 43d | finish no earlier than 2001-03-14 | N1 | 344h | 344h | SS7IP-BSSAP+ | Rel-4 | Frederic |  |  |  |  |

Notes:
- 2165: -
- 2166: -
- 2167: -
- 2168: -
- 2169: -
- 2170: Still exist? To be clarified by GERAN4/5. Marked as stopped 12/2008
- 2171: Marked as stopped 12/2008
- 2172: Marked as stopped 12/2008
- 2173: Marked as stopped 12/2008
- 2174: Marked as stopped 12/2008
- 2175: -
- 2176: Marked as stopped 12/2008
- 2177: "Joker" WI, to be used for a Rel 4 CR not related to any feature and with very limited impact on the system
- 2178: "Joker" WI, to be used for small modifications applicable to Rel 4 conformance testing. Moved in from the Stoyan/Testing WP
- 2179: -
- 2180: -
- 2181: -
- 2182: Marked as stopped 12/2008
- 2183: Marked as stopped 12/2008
- 2184: -
- 2185: -
- 2186: -
- 2187: -
- 2188: -
- 2189: -

| ID | WBS | Task | Duration | Start | Finish | Complete | Baseline start | Baseline finish | Baseline duration | Constraint | Resources | Work | Actual work | Text4 | Text5 | Text6 | Text8 | Text1 | Text3 | Text12 |
| --- | --- | --- | --- | --- | --- | --- | --- | --- | --- | --- | --- | --- | --- | --- | --- | --- | --- | --- | --- | --- |
| 2190 | 63.2 | **FS on Transport and control separation in the PS CN domain** | 215d | 2000-05-29 A | 2001-03-23 A | 100% | 2000-05-29 | 2001-03-23 | 215d |  | S2 | 3440h | 3440h | Ericsson | Juan-Antonio.Ibanez@eed.ericsson.se | Rel-4 | Maurice |  |  |  |
| 2191 | 63.2.1 | Architectural impacts | 215d | 2000-05-29 A | 2001-03-23 A | 100% | 2000-05-29 | 2001-03-23 | 215d | finish no earlier than 2001-03-23 | S2 | 1720h | 1720h |  |  | Rel-4 | Maurice |  |  |  |
| 2192 | 64 | **Rel-4 Improvements of Radio Interface** | 700d | 2000-07-10 A | 2003-03-14 A | 100% | 2000-07-10 | 2003-03-14 | 700d |  | RP | 28624h | 28624h |  |  | Rel-4 |  | RInImp |  |  |
| 2193 | 64.1 | UTRA repeater specification (master) | 183d | 2000-07-10 A | 2001-03-21 A | 100% | 2000-07-10 | 2001-03-21 | 183d | finish no earlier than 2001-03-21 | R4 | 1464h | 1464h | Mikom, Allgon | T. Kummetz, Mikom; Alf Ahlström, Allgon | Rel-4 | Issam | RInImp-REP |  |  |
| 2194 | 64.2 | DSCH power control improvement in soft handover | 140d | 2000-09-11 A | 2001-03-23 A | 100% | 2000-09-11 | 2001-03-23 | 140d | finish no earlier than 2001-03-23 | R1 | 1120h | 1120h | Nokia | antti.toskala@nokia.com | Rel-4 | Patrick | RInImp-DSCHsho |  |  |
| 2195 | 64.3 | UMTS 1800 | 320d | 2000-09-25 A | 2001-12-14 A | 100% | 2000-09-25 | 2001-12-14 | 320d | finish no earlier than 2001-12-14 | R4 | 2560h | 2560h | Motorola | Howard Benn | Rel-4 | Issam | RInImp-UMTS18 |  |  |
| 2196 | 64.4 | UMTS 1900 | 195d | 2001-03-19 A | 2001-12-14 A | 100% | 2001-03-19 | 2001-12-14 | 195d | finish no earlier than 2001-12-14 | R4 | 1560h | 1560h | Motorola | Howard Benn | Rel-4 | Issam | RInImp-UMTS19 | 25.101 |  |
| 2197 | 64.5 | FS on High Speed downlink packet access | 155d | 2000-08-21 A | 2001-03-23 A | 100% | 2000-08-21 | 2001-03-23 | 155d | finish no earlier than 2001-03-23 | R2 | 1240h | 1240h | Motorola | A. Ghosh | Rel-4 | Joern | RInImp-HSDPA |  |  |
| 2198 | 64.6 | Deleted - FS on improved common DL channel for Cell-FACH state | 340d | 2000-09-11 A | 2001-12-28 A | 100% | 2000-09-11 | 2001-12-28 | 340d | finish no earlier than 2001-12-28 | R2 | 2720h | 2720h | GBT | J. Kwak | Rel-4 | Joern | RInImp-DLCFACH |  | RP-14 |
| 2199 | 64.7 | **Conformance Test Spec. Rel-4 improvements in Radio Interface** | 375d | 2001-10-08 A | 2003-03-14 A | 100% | 2001-10-08 | 2003-03-14 | 375d |  | T1 | 12360h | 12360h |  |  | Rel-4 | Ingbert |  |  |  |
| 2200 | 64.7.1 | Deleted - Testing Improved usage of downlink resource in FDD for CCTrCHs of dedicated type | 140d | 2002-02-18 A | 2002-08-30 A | 100% | 2002-02-18 | 2002-08-30 | 140d | finish no earlier than 2002-08-30 | T1 | 1120h | 1120h |  |  | Rel-4 | Ingbert |  |  | TP-17 |
| 2201 | 64.7.2 | Deleted - Testing Terminal Power saving features | 140d | 2002-02-18 A | 2002-08-30 A | 100% | 2002-02-18 | 2002-08-30 | 140d | finish no earlier than 2002-08-30 | T1 | 1120h | 1120h |  |  | Rel-4 | Ingbert |  |  | TP-17 |
| 2202 | 64.7.3 | Deleted - Testing DSCH power control improvement in soft handover | 140d | 2002-02-18 A | 2002-08-30 A | 100% | 2002-02-18 | 2002-08-30 | 140d | finish no earlier than 2002-08-30 | T1 | 1120h | 1120h |  |  | Rel-4 | Ingbert |  |  | TP-17 |
| 2203 | 64.7.4 | Testing UMTS 1800 | 180d | 2001-10-08 A | 2002-06-14 A | 100% | 2001-10-08 | 2002-06-14 | 180d | finish no earlier than 2002-06-14 | T1 | 1440h | 1440h |  |  | Rel-4 | Ingbert |  | 34.108, 34,121, 34.122, 34.123-1 |  |
| 2204 | 64.7.5 | Testing UMTS 1900 | 180d | 2001-10-08 A | 2002-06-14 A | 100% | 2001-10-08 | 2002-06-14 | 180d | finish no earlier than 2002-06-14 | T1 | 1440h | 1440h |  |  | Rel-4 | Ingbert |  | 34.108, 34,121, 34.122, 34.123-1 |  |
| 2205 | 64.7.6 | Testing UMTS 1800 - TTCN | 195d | 2002-06-17 A | 2003-03-14 A | 100% | 2002-06-17 | 2003-03-14 | 195d | finish no earlier than 2003-03-14 | T1 | 1560h | 1560h |  |  | Rel-4 | Ingbert |  | 34.123-3 |  |
| 2206 | 64.7.7 | Testing UMTS 1900 - TTCN | 195d | 2002-06-17 A | 2003-03-14 A | 100% | 2002-06-17 | 2003-03-14 | 195d | finish no earlier than 2003-03-14 | T1 | 1560h | 1560h |  |  | Rel-4 | Ingbert |  | 34.123-3 |  |
| 2207 | 65 | **Rel-4 RAN improvements** | 938d? | 2000-08-14 A | 2004-03-17 A | 100% | 2000-08-14 | 2004-03-17 | 938d? |  | RP | 29336h | 29336h |  |  | Rel-4 |  | RANimp |  |  |
| 2208 | 65.1 | Node B synchronization for TDD | 160d | 2000-08-14 A | 2001-03-23 A | 100% | 2000-08-14 | 2001-03-23 | 160d | finish no earlier than 2001-03-23 | R1 | 1280h | 1280h | Siemens | S. Oestreich | Rel-4 | Patrick | RANimp-NBsync |  |  |
| 2209 | 65.2 | RAB support enhancement for Rel-4 | 155d | 2000-08-21 A | 2001-03-23 A | 100% | 2000-08-21 | 2001-03-23 | 155d | finish no earlier than 2001-03-23 | R2 | 1240h | 1240h | Ericsson | M. Israelsson, A. Krishnarajah | Rel-4 | Joern | RANimp-RABSE |  |  |
| 2210 | 65.4 | **Deleted - Conformance Test Aspects - Rel-4 RAN Improvements** | 577d? | 2002-01-01 A | 2004-03-17 A | 100% | 2002-01-01 | 2004-03-17 | 577d? |  | T1 | 19312h | 19312h |  |  | Rel-4 | Ingbert |  |  |  |
| 2211 | 65.4.1 | Deleted - Testing Radio access bearer support enhancments | 175d | 2002-01-01 A | 2002-09-02 A | 100% | 2002-01-01 | 2002-09-02 | 175d | finish no earlier than 2002-09-02 | T1 | 1400h | 1400h |  |  | Rel-4 | Ingbert |  |  | TP-17 |
| 2212 | 65.4.2 | Deleted - Testing RAB support enhancements-Robust Header Compression | 332d | 2002-05-28 A | 2003-09-03 A | 100% | 2002-05-28 | 2003-09-03 | 332d | finish no earlier than 2003-09-03 | T1 | 2656h | 2656h |  |  | Rel-4 | Ingbert | RABimp-RoCH | 34.123-1, -2 | TP-21 |
| 2213 | 65.4.3 | Deleted - Testing RAB support enhancements-Robust Header Compression - TTCN | 472d | 2002-05-28 A | 2004-03-17 A | 100% | 2002-05-28 | 2004-03-17 | 472d | finish no earlier than 2004-03-17 | T1 | 3776h | 3776h |  |  | Rel-4 | Ingbert |  | 34.123-3 | TP-23 |
| 2214 | 65.4.4 | Testing of Extended Robut Header Compression | 270d | 2002-09-18 A | 2003-09-30 A | 100% | 2002-09-18 | 2003-09-30 | 270d | finish no earlier than 2003-09-30 | T1 | 2160h | 2160h |  |  | Rel-4 | Ingbert | Ext-RoHC | 34.123-1, -2 |  |
| 2215 | 65.4.5 | Deleted - Testing of Extended Robut Header Compression - TTCN | 325d | 2002-09-18 A | 2003-12-16 A | 100% | 2002-09-18 | 2003-12-16 | 325d | finish no earlier than 2003-12-16 | T1 | 2600h | 2600h |  |  | Rel-4 | Ingbert |  | 34.123-3 | TP-22 |
| 2216 | 541.3.6 | Deleted - General changes to TS34.121 corresponding to release 4 | 263d? | 2003-03-03 A | 2004-03-03 A | 100% | 2003-03-03 | 2004-03-03 | 263d? | finish no earlier than 2004-03-03 | T1 | 2104h | 2104h |  |  | Rel-4 | Ingbert | RANimp-test | 34.108, 34.121 | TP-23 |

Notes:
- 2190: -
- 2191: -
- 2192: -
- 2193: -
- 2194: -
- 2195: -
- 2196: -
- 2197: -
- 2198: Stopped at RP#14
- 2199: -
- 2200: Marked as stopped 12/2008
- 2201: Marked as stopped 12/2008
- 2202: Marked as stopped 12/2008
- 2203: -
- 2204: -
- 2205: -
- 2206: -
- 2207: -
- 2208: -
- 2209: 29 Nov 2000: split into ROHC and non-ROHC part; 5 Mar 2001: splitting off of ROHC for Rel-4 agreed by R2
- 2210: Marked as stopped 12/2008
- 2211: Marked as stopped 12/2008
- 2212: UID changed. Marked as stopped 12/2008
- 2213: UID changed. Marked as stopped 12/2008
- 2214: Marked as closed 12/2008 (was marked 15% complete)
- 2215: Marked as stopped 12/2008
- 2216: Marked as stopped 12/2008

| ID | WBS | Task | Duration | Start | Finish | Complete | Baseline start | Baseline finish | Baseline duration | Constraint | Resources | Work | Actual work | Text1 | Text4 | Text6 | Text8 | Text12 | Text3 | Text5 |
| --- | --- | --- | --- | --- | --- | --- | --- | --- | --- | --- | --- | --- | --- | --- | --- | --- | --- | --- | --- | --- |
| 2217 | 66 | **Rel-4 Emergency call enhancements** | 628d | 2000-01-03 A | 2002-05-28 A | 100% | 2000-01-03 | 2002-05-28 | 628d |  | N1,S1,T1 | 3600h | 3600h | EMC1 | Ericsson | Rel-4 | Frederic |  |  |  |
| 2218 | 66.1 | **For CS based calls** | 628d | 2000-01-03 A | 2002-05-28 A | 100% | 2000-01-03 | 2002-05-28 | 628d |  | N1 | 3600h | 3600h | EMC1-CS | Ericsson | Rel-4 | Frederic |  |  |  |
| 2219 | 66.1.1 | Distinction in CS domain of emergency call types to different emergency services | 40d | 2000-05-01 A | 2000-06-23 A | 100% | 2000-05-01 | 2000-06-23 | 40d | finish no earlier than 2000-06-23 | S1 | 320h | 320h | EMC1-CS |  | Rel-4 | Alain |  |  |  |
| 2220 | 66.1.2 | Distinction in CS domain of emergency calls to different emergency types | 22d | 2000-08-24 A | 2000-09-22 A | 100% | 2000-08-24 | 2000-09-22 | 22d | finish no earlier than 2000-09-22 | N1 | 176h | 176h | EMC1-CS |  | Rel-4 | Frederic |  |  |  |
| 2221 | 66.1.3 | Deleted - Conformance Test Aspects - Emergency call enhancements | 151d | 2000-01-03 A | 2000-07-28 A | 100% | 2000-01-03 | 2000-07-28 | 151d |  | T1 | 1200h | 1200h | EMC1-CS |  | Rel-4 | Ingbert | TP-08 |  |  |
| 2222 | 66.1.4 | Testing CS based emergency calls | 67d | 2002-02-25 A | 2002-05-28 A | 100% | 2002-02-25 | 2002-05-28 | 67d | finish no earlier than 2002-05-28 | T1 | 536h | 536h | EMC1-CS |  | Rel-4 | Ingbert |  | 34.123-1 |  |
| 2223 | 66.1.5 | Testing CS based emergency calls - TTCN | 134d | 2001-11-22 A | 2002-05-28 A | 100% | 2001-11-22 | 2002-05-28 | 134d | finish no earlier than 2002-05-28 | T1 | 1072h | 1072h | EMC1-CS |  | Rel-4 | Ingbert |  | 34.123-3 |  |
| 2224 | 67 | **Rel-4 Terminal interfaces** | 315d | 2000-01-03 A | 2001-03-15 A | 100% | 2000-01-03 | 2001-03-15 | 315d |  | T2 | 14296h | 14296h | TI |  | Rel-4 | Kimmo |  |  |  |
| 2225 | 67.1 | **AT commands enhancements** | 314d | 2000-01-03 A | 2001-03-14 A | 100% | 2000-01-03 | 2001-03-14 | 314d |  | T2 | 5016h | 5016h | TI-ATC |  | Rel-4 |  |  | 27.007 |  |
| 2226 | 67.1.1 | Specification of AT commands for new services | 314d | 2000-01-03 A | 2001-03-14 A | 100% | 2000-01-03 | 2001-03-14 | 314d | finish no earlier than 2001-03-14 | T2 | 2504h | 2504h |  |  | Rel-4 |  |  | 27.007 |  |
| 2227 | 67.2 | **Wide Area Data Synchronization** | 314d | 2000-01-03 A | 2001-03-14 A | 100% | 2000-01-03 | 2001-03-14 | 314d |  | T2 | 5016h | 5016h | TI-WADS |  | Rel-4 |  |  |  |  |
| 2228 | 67.2.1 | Continues evolution of Synchronization protocol | 314d | 2000-01-03 A | 2001-03-14 A | 100% | 2000-01-03 | 2001-03-14 | 314d | finish no earlier than 2001-03-14 | T2 | 2504h | 2504h | TI-SYNC-EVOL |  | Rel-4 |  |  | 27.903, 27.103 |  |
| 2229 | 67.3 | Terminal local model | 218d | 2000-05-16 A | 2001-03-15 A | 100% | 2000-05-16 | 2001-03-15 | 218d | finish no earlier than 2001-03-15 | T2 | 1744h | 1744h | TLM | Ericsson | Rel-4 |  |  | 23.227 | Olga.Tome@ECS.ERICSSON.SE |
| 2230 | 68 | **Rel-4 Location Services enhancements** | 455d | 2000-04-03 A | 2001-12-28 A | 100% | 2000-04-03 | 2001-12-28 | 455d |  | S2 | 26799.2h | 26799.2h | LCS1 | Nokia | Rel-4 | Maurice |  |  | Jan Kall |
| 2231 | 68.1 | CBS interactions | 455d | 2000-04-03 A | 2001-12-28 A | 100% | 2000-04-03 | 2001-12-28 | 455d | finish no earlier than 2001-12-28 | T2 | 3640h | 3640h | LCS1-CBS |  | Rel-4 |  |  | 23.041 |  |
| 2232 | 68.2 | LCS support in the CS domain | 180d | 2000-05-15 A | 2001-01-19 A | 100% | 2000-05-15 | 2001-01-19 | 180d | finish no earlier than 2001-01-19 | S2 | 1440h | 1440h | LCS1-CS |  | Rel-4 | Maurice |  |  |  |
| 2233 | 68.3 | **LCS support in the PS domain** | 435d | 2000-05-01 A | 2001-12-28 A | 100% | 2000-05-01 | 2001-12-28 | 435d |  | S2 | 13560h | 13560h | LCS1-PS |  | Rel-4 | Maurice |  |  |  |
| 2234 | 68.3.1 | Stage 1 | 40d | 2000-07-03 A | 2000-08-25 A | 100% | 2000-07-03 | 2000-08-25 | 40d | start no earlier than 2000-07-03 | S1 | 320h | 320h |  | Pacific Bell Wireless | Rel-4 | Alain |  | 22.071 | Randolph Wohlert (rwohlert@tri.sbc.com) |
| 2235 | 68.3.2 | Stage 2 | 190d | 2000-05-01 A | 2001-01-19 A | 100% | 2000-05-01 | 2001-01-19 | 190d | finish no earlier than 2001-01-19 | S2 | 1520h | 1520h |  |  | Rel-4 | Maurice |  | 23.271 |  |
| 2236 | 68.3.3 | **Stage 3** | 355d | 2000-08-21 A | 2001-12-28 A | 100% | 2000-08-21 | 2001-12-28 | 355d |  | N1 | 8240h | 8240h |  |  | Rel-4 | Frederic |  |  |  |
| 2237 | 68.3.3.1 | Layer 3 LCS signalling UE (MS) -SGSN (UMTS PS and and GSM-GPRS) | 355d | 2000-08-21 A | 2001-12-28 A | 100% | 2000-08-21 | 2001-12-28 | 355d | finish no earlier than 2001-12-28 | N1 | 2840h | 2840h |  | Nokia | Rel-4 | Frederic |  |  | Janne Muhonen |
| 2238 | 68.3.3.2 | MAP impacts of LCS | 160d | 2000-08-21 A | 2001-03-30 A | 100% | 2000-08-21 | 2001-03-30 | 160d | finish no earlier than 2001-03-30 | N4 | 1280h | 1280h |  |  | Rel-4 | Kimmo |  |  |  |
| 2239 | 68.3.3.3 | GTP signalling for LCS | 160d | 2000-08-21 A | 2001-03-30 A | 100% | 2000-08-21 | 2001-03-30 | 160d | finish no earlier than 2001-03-30 | N4 | 1280h | 1280h |  |  | Rel-4 | Kimmo |  |  |  |
| 2240 | 68.4 | **UE positioning Rel-4** | 260d | 2000-04-03 A | 2001-03-30 A | 100% | 2000-04-03 | 2001-03-30 | 260d |  | RP | 4591.2h | 4591.2h | LCS1-UEpos |  | Rel-4 | Issam |  |  |  |
| 2241 | 68.4.1 | Iub/Iur interfaces for methods Rel 99 | 233.9d | 2000-04-03 A | 2001-03-30 A | 100% | 2000-04-03 | 2001-03-30 | 233.9d | finish no earlier than 2001-03-30 | R3 | 1871.2h | 1871.2h | LCS1-UEpos-IubIur | Ericsson | Rel-4 | Juha |  |  | Yun-Chao Hu |
| 2242 | 68.4.2 | UE positioning enhancements - IPDL for TDD | 150d | 2000-08-28 A | 2001-03-23 A | 100% | 2000-08-28 | 2001-03-23 | 150d | finish no earlier than 2001-03-23 | R2 | 1200h | 1200h | LCS1-UEpos-enh | Siemens | Rel-4 | Joern |  |  | M. Beckmann |

Notes:
- 2217: -
- 2218: WI approved in TSG_10
- 2219: -
- 2220: Calls to different emergency services such as ambulance, fire brigade, police, etc. can be routed to respective different emergency centres. / NP-000447 is the stage 3 changes for CS call control protocol.
- 2221: UID changed. Marked as stopped 12/2008
- 2222: -
- 2223: -
- 2224: -
- 2225: -
- 2226: goal not completely achieved because of missing input
- 2227: AS: Rel5 changed to Rel4 according to SP#10 decision, milestone on testing added
- 2228: -
- 2229: -
- 2230: -
- 2231: -
- 2232: Only MAP impact foreseen so far. To be further split if needed.
- 2233: -
- 2234: To be also considered: External LCS client identity, and Privacy options when PDP-context and when no PDP-context is established
- 2235: AS: 23.271 completed at SP#10
- 2236: -
- 2237: -
- 2238: Missing work task
- 2239: -
- 2240: UID changed
- 2241: 27/11: WG corrected; rapporteur corrected
- 2242: 5 Mar 2001: splitting off of IPDL for TDD for Rel-4 agreed by R2

| ID | WBS | Task | Duration | Start | Finish | Complete | Baseline start | Baseline finish | Baseline duration | Constraint | Resources | Work | Actual work | Text1 | Text6 | Text8 | Text3 | Text4 | Text5 | Text12 |
| --- | --- | --- | --- | --- | --- | --- | --- | --- | --- | --- | --- | --- | --- | --- | --- | --- | --- | --- | --- | --- |
| 2243 | 69 | **Rel-4 UICC/(U)SIM enhancements and interworking** | 175d | 2000-07-24 A | 2001-03-23 A | 100% | 2000-07-24 | 2001-03-23 | 175d |  | T3 | 2800h | 2800h | UICC1 | Rel-4 | Xavier |  |  |  |  |
| 2244 | 69.1 | Common PCN Handset Specification (CPHS) | 175d | 2000-07-24 A | 2001-03-23 A | 100% | 2000-07-24 | 2001-03-23 | 175d | finish no earlier than 2001-03-23 | T3 | 1400h | 1400h | UICC1-CPHS | Rel-4 |  | 27.103 | One2One |  |  |
| 2245 | 70 | **Rel-4 (U)SIM toolkit enhancements** | 210d | 2000-06-05 A | 2001-03-23 A | 100% | 2000-06-05 | 2001-03-23 | 210d |  | T3 | 3360h | 3360h | USAT1-LocLnk | Rel-4 | Xavier |  | Gemplus | Jean-Francois Rubon |  |
| 2246 | 70.1 | USAT local link | 210d | 2000-06-05 A | 2001-03-23 A | 100% | 2000-06-05 | 2001-03-23 | 210d | finish no earlier than 2001-03-23 | T3 | 1680h | 1680h | USAT1-LocLnk | Rel-4 | Xavier |  | Gemplus | Jean-Francois Rubon |  |
| 2247 | 71 | **Rel-4 Security enhancements** | 576d | 2000-01-03 A | 2002-03-15 A | 100% | 2000-01-03 | 2002-03-15 | 576d |  | S3 | 24152h | 24152h |  | Rel-4 | Dionisio |  | Vodafone | Peter.Howard@vodafone.com |  |
| 2248 | 71.1 | Evolution of GSM CS algorithms (e.g. A5/3 development and deployment) | 272d | 2000-01-03 A | 2001-01-15 A | 100% | 2000-01-03 | 2001-01-15 | 272d | finish no earlier than 2001-01-15 | S3 | 2168h | 2168h | SEC1-CSALGO1 | Rel-4 | Dionisio |  |  |  |  |
| 2249 | 71.2 | **Evolution of GSM PS algorithms (e.g. GEA 2 deployment)** | 219d | 2000-02-22 A | 2000-12-22 A | 100% | 2000-02-22 | 2000-12-22 | 219d |  | S3 | 6024h | 6024h | SEC1-PSALGO1 | Rel-4 | Dionisio |  |  |  |  |
| 2250 | 71.2.1 | Main aspects | 199d | 2000-02-22 A | 2000-11-24 A | 100% | 2000-02-22 | 2000-11-24 | 199d | finish no earlier than 2000-11-24 | S3 | 1592h | 1592h | SEC1-PSALGO1 | Rel-4 | Dionisio |  |  |  |  |
| 2251 | 71.2.2 | Impact on GTP | 200d | 2000-03-20 A | 2000-12-22 A | 100% | 2000-03-20 | 2000-12-22 | 200d | finish no earlier than 2000-12-22 | N4 | 1600h | 1600h | SEC1-PSALGO1 | Rel-4 | Kimmo |  |  |  |  |
| 2252 | 71.2.3 | GEA capability indication in MS CM | 135d | 2000-06-19 A | 2000-12-22 A | 100% | 2000-06-19 | 2000-12-22 | 135d | finish no earlier than 2000-12-22 | N1 | 1080h | 1080h | SEC1-PSALGO1-GEACAP | Rel-4 | Frederic |  | Vodafone Airtouch | Duncan Mills |  |
| 2253 | 71.3 | **Deleted - MAP application layer security** | 576d | 2000-01-03 A | 2002-03-15 A | 100% | 2000-01-03 | 2002-03-15 | 576d |  | S3 | 11352h | 11352h | SEC1-MAPAL | Rel-4 | Dionisio |  |  |  | SP-15 |
| 2254 | 71.3.1 | Deleted - Main aspects | 199d | 2000-02-21 A | 2001-03-29 A | 100% | 2000-02-21 | 2001-03-29 | 199d | start no earlier than 2000-02-21 | S3 | 1592h | 1592h |  | Rel-4 | Dionisio |  |  |  | SP-11 |
| 2255 | 71.3.2 | Deleted - Other stage 3 aspects | 199d | 2000-02-22 A | 2000-11-24 A | 100% | 2000-02-22 | 2000-11-24 | 199d | finish no earlier than 2000-11-24 | N4 | 1592h | 1592h |  | Rel-4 | Kimmo |  |  |  | CP-10 |
| 2256 | 71.3.3 | Deleted - Visibility and Configurability of security | 576d | 2000-01-03 A | 2002-03-15 A | 100% | 2000-01-03 | 2002-03-15 | 576d | finish no earlier than 2002-03-15 | S3 | 4600h | 4600h | SEC1-VCS | Rel-4 | Dionisio |  | France Telecom | Sebastien.nguyenngoc@rd.francetelecom.com | SP-15 |
| 2257 | 72 | **Rel-4 Charging and OAM&P** | 221d | 2000-12-01 A | 2001-10-05 A | 100% | 2000-12-01 | 2001-10-05 | 221d |  | S5 | 10472h | 10472h | OAM | Rel-4 | Dionisio |  | VoiceStream, Motorola |  |  |
| 2258 | 72.1 | Rel4 Principles, high level Requirements and Architecture | 145d | 2000-12-01 A | 2001-06-21 A | 100% | 2000-12-01 | 2001-06-21 | 145d | finish no earlier than 2001-06-21 | S5 | 1160h | 1160h | OAM-AR/PR | Rel-4 | Dionisio | 32.101, 32.102 | Motorola, Telia | Michael.Truss@MOTOROLA.COM; Tommy.R.Berggren@TELIA.SE |  |
| 2259 | 72.2 | Rel4 Performance Management | 216d | 2000-12-01 A | 2001-09-28 A | 100% | 2000-12-01 | 2001-09-28 | 216d | finish no earlier than 2001-06-21 | S5 | 1728h | 1728h |  | Rel-4 | Dionisio | 32.4xy, 52.402 | T-Mobile | karl-heinz.nenner@t-mobile.de |  |
| 2260 | 72.3 | Fault Management | 221d | 2000-12-01 A | 2001-10-05 A | 100% | 2000-12-01 | 2001-10-05 | 221d | finish no earlier than 2001-06-21 | S5 | 1768h | 1768h |  | Rel-4 | Dionisio | 32.111-1/4 | Lucent |  |  |
| 2261 | 72.4 | Configuration Management | 145d | 2000-12-01 A | 2001-06-21 A | 100% | 2000-12-01 | 2001-06-21 | 145d | finish no earlier than 2001-06-21 | S5 | 1160h | 1160h | OAM-CM | Rel-4 | Dionisio | 32.106-1/8 | Ericsson | thomas.tovinger@ericsson.com |  |
| 2262 | 72.5 | Rel4 Charging Management | 216d | 2000-12-01 A | 2001-09-28 A | 100% | 2000-12-01 | 2001-09-28 | 216d | finish no earlier than 2001-06-21 | S5 | 1728h | 1728h | OAM-CH | Rel-4 | Dionisio | 32.200, 32.205, 32.215, 32.235 | T-Mobile | karl-heinz.nenner@t-mobile.de |  |
| 2263 | 72.6 | UTRAN Operations and Maintenance procedures | 145d | 2000-12-01 A | 2001-06-21 A | 100% | 2000-12-01 | 2001-06-21 | 145d | finish no earlier than 2001-06-21 | S5 | 1160h | 1160h | UOAM | Rel-4 | Dionisio | 32.800 | Mannesmann Mobilfunk | bert.boden@d2mannesmann.de |  |
| 2264 | 73 | **Global Text Telephony** | 2537d? | 2000-01-03 A | 2009-09-18 A | 100% | 2000-01-03 | 2009-09-18 | 2537d? |  | S1,S2,S4,T1,R5 | 44928h | 44928h | GTT | Rel-4 | Maurice |  | Ericsson | gunnar.hellstrom@omnitor.se |  |
| 2265 | 73.1 | Stage 1 | 188d | 2000-04-05 A | 2000-12-22 A | 100% | 2000-04-05 | 2000-12-22 | 188d | finish no earlier than 2000-12-22 | S1 | 1504h | 1504h | GTT | Rel-4 | Alain | 22.976, 22.226 |  |  |  |
| 2266 | 73.2 | Stage 2 | 206d | 2000-01-03 A | 2000-10-13 A | 100% | 2000-01-03 | 2000-10-13 | 206d |  | S2 | 1640h | 1640h | GTT | Rel-4 | Maurice | 23.226 |  |  |  |

Notes:
- 2243: -
- 2244: 28/5/2001: CRs approved at TP-11. WI complete.
- 2245: -
- 2246: 25/5/2001:CR was approved at TP-11. WI is complete
- 2247: Added BB UE authentication and rapporteur added. TO BE DELETED
- 2248: Approved SP#17
- 2249: A5/3 development will consider new GEA algorithm based on Kasumi
- 2250: Complete TSG#09 (09/2000). S3#17: Proposed for deletion. TO BE DELETED
- 2251: -
- 2252: -
- 2253: REPLACED BY NDS-MAP and NDS-IP. Completed Auto Key Management -> Rel-6. Marked as stopped 12/2008
- 2254: UID changed. Marked as stopped 12/2008
- 2255: UID changed. Marked as stopped 12/2008
- 2256: CR approved at SA3#21 awaiting comments from CN1. Marked as stopped 12/2008
- 2257: SP#13 approved WID
- 2258: -
- 2259: -
- 2260: -
- 2261: -
- 2262: -
- 2263: -
- 2264: SP#12 updated WID SP-000162=>SP-010340
- 2265: -
- 2266: -

| ID | WBS | Task | Type | Duration | Start | Finish | Complete | Baseline start | Baseline finish | Baseline duration | Total slack | Constraint | Resources | Work | Actual work | Text1 | Text6 | Text8 | Text9 | Text12 |
| --- | --- | --- | --- | --- | --- | --- | --- | --- | --- | --- | --- | --- | --- | --- | --- | --- | --- | --- | --- | --- |
| 2267 | 73.3 | **Specification of Cellular Text telephone Modem** |  | 136d | 2000-09-11 A | 2001-03-19 A | 100% | 2000-09-11 | 2001-03-19 | 136d |  |  | S4 | 2704h | 2704h | GTT-CTM | Rel-4 | Paolo |  |  |
| 2268 | 73.3.1 | General description and C-code |  | 66d | 2000-09-11 A | 2000-12-11 A | 100% | 2000-09-11 | 2000-12-11 | 66d |  | finish no earlier than 2000-12-11 | S4 | 528h | 528h | GTT-CTM | Rel-4 | Paolo |  |  |
| 2269 | 73.3.2 | Minimum Performance requirements |  | 136d | 2000-09-11 A | 2001-03-19 A | 100% | 2000-09-11 | 2001-03-19 | 136d |  | finish no earlier than 2001-03-19 | S4 | 1088h | 1088h | GTT-CTM | Rel-4 | Paolo |  |  |
| 2270 | 73.5 | Deleted - Conformance Test Aspects - Global Text Telephony |  | 2348d? | 2000-09-21 A | 2009-09-18 A | 100% | 2000-09-21 | 2009-09-18 | 2348d? |  | finish no earlier than 2009-09-18 | R5,T1 | 18784h | 18784h | GTT_Test | Rel-4 | Ingbert | PCG-23 | RP-45 |
| 2271 | 550 | Release 1999 Features | milestone | 0d? | 2000-01-01 | 2000-01-01 |  | 2000-01-01 | 2000-01-01 | 0d? | 3318d |  | NP,SP,TP,SMG |  |  |  | R99 |  |  |  |
| 2272 | 551 | **UMTS Features** |  | 261d? | 1999-01-01 A | 1999-12-31 A | 100% | 1999-01-01 | 1999-12-31 | 261d? |  |  | S1,S2,S4,SMG,N3,N4,RP | 25056h | 25056h |  | R99 |  |  |  |
| 2273 | 551.1 | UMTS_SERVICES |  | 261d? | 1999-01-01 A | 1999-12-31 A | 100% | 1999-01-01 | 1999-12-31 | 261d? |  | start no earlier than 1999-01-01 | S1 | 2088h | 2088h | UMTS_SERVICES | R99 |  |  |  |
| 2274 | 551.2 | UMTS phase 1 |  | 261d? | 1999-01-01 A | 1999-12-31 A | 100% | 1999-01-01 | 1999-12-31 | 261d? |  | start no earlier than 1999-01-01 | S1 | 2088h | 2088h | UMTS1 | R99 |  |  |  |
| 2275 | 551.3 | UMTS Capabilities |  | 261d? | 1999-01-01 A | 1999-12-31 A | 100% | 1999-01-01 | 1999-12-31 | 261d? |  | start no earlier than 1999-01-01 | S1 | 2088h | 2088h | UMTS_Capabil | R99 |  |  |  |
| 2276 | 551.4 | Architecture of the GSM-UMTS platform |  | 261d? | 1999-01-01 A | 1999-12-31 A | 100% | 1999-01-01 | 1999-12-31 | 261d? |  | start no earlier than 1999-01-01 | S2,N4 | 2088h | 2088h |  | R99 |  |  |  |
| 2277 | 551.5 | UMTS Terrestrial Radio Access Network |  | 261d? | 1999-01-01 A | 1999-12-31 A | 100% | 1999-01-01 | 1999-12-31 | 261d? |  | start no earlier than 1999-01-01 | RP | 2088h | 2088h | UTRAN | R99 |  |  |  |
| 2278 | 551.6 | UMTS 1800, UMTS 1900 |  | 261d? | 1999-01-01 A | 1999-12-31 A | 100% | 1999-01-01 | 1999-12-31 | 261d? |  | start no earlier than 1999-01-01 | R2 | 2088h | 2088h | Rlnlmp19, Rlnlmp18 | R99 |  |  |  |
| 2279 | 551.7 | Mandatory speech codec for narrowband telephony service |  | 261d? | 1999-01-01 A | 1999-12-31 A | 100% | 1999-01-01 | 1999-12-31 | 261d? |  | start no earlier than 1999-01-01 | S4 | 2088h | 2088h | Mandatory_Speech_Codec, AMR-NB, AMR | R99 | Paolo |  |  |
| 2280 | 551.8 | Codec for low bitrate multimedia telephony service |  | 261d? | 1999-01-01 A | 1999-12-31 A | 100% | 1999-01-01 | 1999-12-31 | 261d? |  | start no earlier than 1999-01-01 | S4 | 2088h | 2088h | Low_bit_rate_codec_for_MM_Tel., H.324M | R99 | Paolo |  |  |
| 2281 | 551.9 | 3G Audio-Visual Terminal characteristics |  | 261d? | 1999-01-01 A | 1999-12-31 A | 100% | 1999-01-01 | 1999-12-31 | 261d? |  | start no earlier than 1999-01-01 | S4 | 2088h | 2088h | WI5TAC, 3G-AVT, Terminal_Acoustic_Characteristics | R99 |  |  |  |
| 2282 | 551.10 | Updates_for_UMTS |  | 261d? | 1999-01-01 A | 1999-12-31 A | 100% | 1999-01-01 | 1999-12-31 | 261d? |  | start no earlier than 1999-01-01 | N3 | 2088h | 2088h | Updates_for_UMTS | R99 |  |  |  |
| 2283 | 551.11 | UMTS |  | 261d? | 1999-01-01 A | 1999-12-31 A | 100% | 1999-01-01 | 1999-12-31 | 261d? |  | start no earlier than 1999-01-01 | N3 | 2088h | 2088h | UMTS | R99 |  |  |  |
| 2284 | 552 | **UMTS and GSM Features** |  | 261d? | 1999-01-01 A | 1999-12-31 A | 100% | 1999-01-01 | 1999-12-31 | 261d? |  |  | S1,S2,SMG,T2,N1,N2,N3,N4,R2,R3 | 114840h | 114840h |  | R99 |  |  |  |
| 2285 | 552.1 | Multimedia Messaging Service |  | 261d? | 1999-01-01 A | 1999-12-31 A | 100% | 1999-01-01 | 1999-12-31 | 261d? |  | start no earlier than 1999-01-01 | T2 | 2088h | 2088h | MMS | R99 |  |  |  |
| 2286 | 552.2 | Location Services |  | 261d? | 1999-01-01 A | 1999-12-31 A | 100% | 1999-01-01 | 1999-12-31 | 261d? |  | start no earlier than 1999-01-01 | S1,S2,S3,SMG1,SMG2,SMG12,N1,N2,N4,R2,R3 | 2088h | 2088h | LCS | R99 |  |  |  |
| 2287 | 552.3 | **Customised Application for Mobile network Enhanced Logic Phase 3** |  | 261d? | 1999-01-01 A | 1999-12-31 A | 100% | 1999-01-01 | 1999-12-31 | 261d? |  |  | S1,S2,N2,N4 | 6264h | 6264h | CAMEL3 | R99 |  |  |  |
| 2288 | 552.3.1 | Global view |  | 261d? | 1999-01-01 A | 1999-12-31 A | 100% | 1999-01-01 | 1999-12-31 | 261d? |  | start no earlier than 1999-01-01 | S1,S2,N2,N4 | 2088h | 2088h | CAMEL3 | R99 |  |  |  |
| 2289 | 552.3.2 | Multiple Subscriber Profile (MSP) based on CAMEL phase 3 |  | 261d? | 1999-01-01 A | 1999-12-31 A | 100% | 1999-01-01 | 1999-12-31 | 261d? |  | start no earlier than 1999-01-01 | S1 | 2088h | 2088h | CAMEL3 | R99 |  |  |  |
| 2290 | 552.4 | Short Message Service enhancements / Enhanced Messaging Service (EMS) |  | 261d? | 1999-01-01 A | 1999-12-31 A | 100% | 1999-01-01 | 1999-12-31 | 261d? |  | start no earlier than 1999-01-01 | T2 | 2088h | 2088h | EMS | R99 |  |  |  |
| 2291 | 552.5 | Mobile Station Execution Environment |  | 261d? | 1999-01-01 A | 1999-12-31 A | 100% | 1999-01-01 | 1999-12-31 | 261d? |  | start no earlier than 1999-01-01 | S1,SMG1,T2 | 2088h | 2088h | MExE | R99 |  |  |  |
| 2292 | 552.6 | MS_Classmark |  | 261d? | 1999-01-01 A | 1999-12-31 A | 100% | 1999-01-01 | 1999-12-31 | 261d? |  | start no earlier than 1999-01-01 | N1 | 2088h | 2088h | MS_Classmark | R99 |  |  |  |

Notes:
- 2267: -
- 2268: - / Text3: 26.226, 26.230
- 2269: - / Text3: 26.231
- 2270: RP#45 work item abandoned/closed (it was never really started)
- 2271: -
- 2272: -
- 2273: - / Text3: 22.101
- 2274: - / Text3: 22.100
- 2275: Requirement for high quality speech in UMTS Phase 1 but not in R99 / Text3: 22.105
- 2276: wid Architecture overview of the GSM-UMTS System, Architecture the GSM-UMTS Platform and New Access Network to Core Network (BSS-NSS) interface / Text3: 23.002, 23.008, 23.060, 23.101, 23.110
- 2277: - / Text3: 22.011, 22.038, 22.060, 22.078, 22.100, 22.101, 22.105, 22.115, 22.129, 23.002, 23.060, 24.007, 24.008, 25.101, 25.102, 25.104, 25.105, 25.113, 25.123, 25.133, 25.141, 25.142, 25.201, 25.211, 25.212, 25.213, 25.214, 25.215, 25.221, 25.222, 25.223, 25.224,
- 2278: - / Text3: 25.307 CR#0002, 0003 Inclusion of release independent RF related information
- 2279: Define the default speech codec for UMTS (both for FDD and TDD). Definition limited to selection of one codec among several existing ones/proposed codecs: GSM AMR, IS127 EVRC, ITU G.729 and MPEG-4 speech codec. / Text3: 04.08, 05.01, 05.02, 05.03, 05.05, 05.08, 05.09, 05.09, 05.50, 08.60, 08.61, 11.21, 26.071, 26.073, 26.074, 26.090, 26.091, 26.092, 26.093, 26.094, 26.101, 26.102, 26.103, 26.104, 26.975
- 2280: - / Text3: 26.104, 26.110, 26.111, 26.911, 26.912, 26.915
- 2281: - / Text3: 26.131, 26.132
- 2282: - / Text3: 24.022, 27.001, 29.007
- 2283: - / Text3: 27.060, 29.061
- 2284: -
- 2285: MMS allows users to send/receive messages e.g. almost unlimited text length, images, audio and video clips and new content types. R99 only includes the concept. MMS stage 3 is not included in 23.140. Rel-4 adds detailed architecture and protocols. / Text3: 22.140, 23.040, 23.140
- 2286: LCS provide ability to localize a terminal. Location data is used to provide services to end-user (e.g. local map indicating closest restaurants), for emergency services or for a UMTS network entity (RNC to direct beam when space diversity is used) / Text3: 02.07, 03.71, 04.31, 04.35, 04.71, 05.05, 08.08, 08.31, 08.71, 09.31, 22.071, 23.002, 23.003, 23.007, 23.008, 23.016, 23.018, 23.032, 23.171, 24.007, 24.008, 24.030, 24.080, 25.305, 25.306, 25.331, 25.413, 25.423, 29.002, 29.010
- 2287: CAMEL is a network feature providing mechanisms to support services of operators which are not covered by standardised services, even when roaming outside the HPLMN. / Text3: 22.101, 23.008, 23.012, 23.016, 23.018, 23.060, 23.072, 23.078, 23.079, 23.082, 23.093, 29.002, 29.078
- 2288: - / Text3: 22.078, 23.078, 29.078
- 2289: MSP is an optional service enabling mobile subscribers to have several profiles associated with a single IMSI, with each profile being a subscription option. Each profile may be used for mobile originated and mobile terminated calls. / Text3: 22.097 (Advanced Addressing)
- 2290: SMS for 3G terminals compatible with GSM SMS. Added Enhanced Messaging Service (EMS) allowing small pictures, sounds, animations to be transferred via SMS. / Text3: 23.038, 23.039, 23.040, 23.042
- 2291: MExE provides a standardized MS execution environment and ability to negotiate its supported capabilities with a MExE SP. R99 enhances SIM MExE certificate management, security clarifications, QoS and defines two MExE classmarks WAP/Personal-Java based. / Text3: 02.57, 22.057, 22.101, 23.057
- 2292: MExE classmark identifies a category of MExE UE supporting MExE functionality with a minimum level of processing, memory, display, and interactive capabilities. Several MExE classmarks may be defined. / Text3: 24.008

| ID | WBS | Task | Duration | Start | Finish | Complete | Baseline start | Baseline finish | Baseline duration | Constraint | Resources | Work | Actual work | Text1 | Text6 |
| --- | --- | --- | --- | --- | --- | --- | --- | --- | --- | --- | --- | --- | --- | --- | --- |
| 2293 | 552.7 | **MultiCall** | 261d? | 1999-01-01 A | 1999-12-31 A | 100% | 1999-01-01 | 1999-12-31 | 261d? |  | S1,N1,N2,N4 | 4176h | 4176h | Multicall | R99 |
| 2294 | 552.7.1 | Multicall | 261d? | 1999-01-01 A | 1999-12-31 A | 100% | 1999-01-01 | 1999-12-31 | 261d? | start no earlier than 1999-01-01 | S1 | 2088h | 2088h | Multicall | R99 |
| 2295 | 552.8 | Virtual Home Environment | 261d? | 1999-01-01 A | 1999-12-31 A | 100% | 1999-01-01 | 1999-12-31 | 261d? | start no earlier than 1999-01-01 | S1,SMG1,S2 | 2088h | 2088h | VHE | R99 |
| 2296 | 552.9 | Open Service Access | 261d? | 1999-01-01 A | 1999-12-31 A | 100% | 1999-01-01 | 1999-12-31 | 261d? | start no earlier than 1999-01-01 | S1,S2,N5 | 2088h | 2088h | OSA | R99 |
| 2297 | 552.10 | Super Charger mechanism for signalling traffic associated with mobility | 261d? | 1999-01-01 A | 1999-12-31 A | 100% | 1999-01-01 | 1999-12-31 | 261d? | start no earlier than 1999-01-01 | N2,N4 | 2088h | 2088h | Super_Charger | R99 |
| 2298 | 552.11 | Follow_Me service | 261d? | 1999-01-01 A | 1999-12-31 A | 100% | 1999-01-01 | 1999-12-31 | 261d? | start no earlier than 1999-01-01 | S1,N2,N4 | 2088h | 2088h | Follow_Me | R99 |
| 2299 | 552.12 | Wide area network Synchronization and object exchange | 261d? | 1999-01-01 A | 1999-12-31 A | 100% | 1999-01-01 | 1999-12-31 | 261d? | start no earlier than 1999-01-01 | T2 | 2088h | 2088h | SYNC | R99 |
| 2300 | 552.13 | **Terminal Interfaces** | 261d? | 1999-01-01 A | 1999-12-31 A | 100% | 1999-01-01 | 1999-12-31 | 261d? |  | T2 | 8352h | 8352h |  | R99 |
| 2301 | 552.13.1 | AT commands for 3GPP | 261d? | 1999-01-01 A | 1999-12-31 A | 100% | 1999-01-01 | 1999-12-31 | 261d? | start no earlier than 1999-01-01 | T2 | 2088h | 2088h |  | R99 |
| 2302 | 552.13.2 | Physical interfaces | 261d? | 1999-01-01 A | 1999-12-31 A | 100% | 1999-01-01 | 1999-12-31 | 261d? | start no earlier than 1999-01-01 | T2 | 2088h | 2088h |  | R99 |
| 2303 | 552.13.3 | Multiplexer | 261d? | 1999-01-01 A | 1999-12-31 A | 100% | 1999-01-01 | 1999-12-31 | 261d? | start no earlier than 1999-01-01 | T2 | 2088h | 2088h | MUX MS-TE | R99 |
| 2304 | 552.14 | **Bearer Services** | 261d? | 1999-01-01 A | 1999-12-31 A | 100% | 1999-01-01 | 1999-12-31 | 261d? |  | S1,T2,N1,N3 | 27144h | 27144h |  | R99 |
| 2305 | 552.14.1 | **Circuit Switched Bearer Services** | 261d? | 1999-01-01 A | 1999-12-31 A | 100% | 1999-01-01 | 1999-12-31 | 261d? |  | S1,N3 | 14616h | 14616h | Circuit_switched_Bearer_Services | R99 |
| 2306 | 552.14.1.1 | Circuit Switched Bearer Services | 261d? | 1999-01-01 A | 1999-12-31 A | 100% | 1999-01-01 | 1999-12-31 | 261d? | start no earlier than 1999-01-01 | S1,N3 | 2088h | 2088h | CS_Bearerss_in_UMTS | R99 |
| 2307 | 552.14.1.2 | CS_Bearers | 261d? | 1999-01-01 A | 1999-12-31 A | 100% | 1999-01-01 | 1999-12-31 | 261d? | start no earlier than 1999-01-01 | N3 | 2088h | 2088h | CS_Bearers | R99 |
| 2308 | 552.14.1.3 | CS_Bearerss | 261d? | 1999-01-01 A | 1999-12-31 A | 100% | 1999-01-01 | 1999-12-31 | 261d? | start no earlier than 1999-01-01 | N3 | 2088h | 2088h | CS_Bearerss | R99 |
| 2309 | 552.14.1.4 | CS_Data | 261d? | 1999-01-01 A | 1999-12-31 A | 100% | 1999-01-01 | 1999-12-31 | 261d? | start no earlier than 1999-01-01 | N3 | 2088h | 2088h | CS_Data | R99 |
| 2310 | 552.14.1.5 | CS_Data_Bearers | 261d? | 1999-01-01 A | 1999-12-31 A | 100% | 1999-01-01 | 1999-12-31 | 261d? | start no earlier than 1999-01-01 | N3 | 2088h | 2088h | CS_Data_Bearers | R99 |
| 2311 | 552.14.1.6 | Deleted - Circuit Switched Bearer Services | 261d? | 1999-01-01 A | 1999-12-31 A | 100% | 1999-01-01 | 1999-12-31 | 261d? | start no earlier than 1999-01-01 | N3 | 2088h | 2088h | CSBS | R99 |
| 2312 | 552.14.2 | Frame Tunnelling Mode | 261d? | 1999-01-01 A | 1999-12-31 A | 100% | 1999-01-01 | 1999-12-31 | 261d? | start no earlier than 1999-01-01 | T2,N1,N3 | 2088h | 2088h | FTM | R99 |
| 2313 | 552.14.3 | Access to ISPs and Intranets – Wireless/Remote access to LANs | 261d? | 1999-01-01 A | 1999-12-31 A | 100% | 1999-01-01 | 1999-12-31 | 261d? | start no earlier than 1999-01-01 | N3 | 2088h | 2088h | Interworking with PDN (DHCP) | R99 |
| 2314 | 552.14.4 | **PHS Internet Access Forum Specification** | 261d? | 1999-01-01 A | 1999-12-31 A | 100% | 1999-01-01 | 1999-12-31 | 261d? |  | S1,N3 | 6264h | 6264h | PIAFS | R99 |
| 2315 | 552.14.4.1 | Personal Handyphone System Internet Access Forum Standard (PIAFS) | 261d? | 1999-01-01 A | 1999-12-31 A | 100% | 1999-01-01 | 1999-12-31 | 261d? | start no earlier than 1999-01-01 | S1 | 2088h | 2088h | PIAFS | R99 |
| 2316 | 552.14.4.2 | Support_of_PIAFS_in_UMTS | 261d? | 1999-01-01 A | 1999-12-31 A | 100% | 1999-01-01 | 1999-12-31 | 261d? | start no earlier than 1999-01-01 | N3 | 2088h | 2088h | Support_of_PIAFS_in_UMTS | R99 |

Notes:
- 2293: Multicall allows several simultaneous CS calls with dedicated bearers of independent traffic and performance characteristics. R99 Multicall was defined as a supplementary service limited to one CS bearer to be used for speech at any time. / Text3: 22.030, 22.083, 22.087, 23.008, 23.009, 23.016, 23.018, 23.108, 23.135, 24.008, 24.080, 24.135, 29.002, 29.010
- 2294: - / Text3: 22.030, 22.083, 22.087
- 2295: Information exists in SP#5-8 reports & in SP-99416,SP-000095,SP 000155. OSA allows service development by operators and 3rd parties by making use of network functionality through open, standardised, secure, extensible and scalable interfaces. / Text3: 02.01, 22.105, 22.121,23.127
- 2296: Open Service Architecture became in later Releases Open Service Access. Produced by Parlay, ETSI SPAN (TISPAN), 3GPP SA1 (Stage 1), SA2 (Stage 2) and CN5 (Stage 3), resulting in a single set of standard OSA APIs for the whole development community. / Text3: 22.121, 23.127, 29.198, 29.998
- 2297: Super Charger reduces mobility management cost by reducing the volume of location update signalling. It changes subscriber data management associated with inter-VLR and SGSN location updates. It also applies to packet services (SGSN replaces VLR and … / Text3: 21.905, 23.007, 23.008, 23.012, 23.016, 23.018, 23.040, 23.060, 23.116, 23.912, 29.002
- 2298: Follow Me enables a mobile subscriber A to manipulate the Follow Me data of a party B in such a way that - under certain conditions - subsequent calls directed to party B will be forwarded to subscriber A. It is PLMN-specific and control based on USSD / Text3: 21.905, 22.004, 22.030, 22.082, 22.090, 22.094, 23.090, 24.090, 22.094, 23.011, 23.015, 23.082, 29.002
- 2299: Allows data stored in ME/USIM to be synchronized with the outside world. TS 27.103 defines protocols based upon IrMC level 4 and will evaluate new technologies (XML) for inclusion. From Rel-4 IrMC was replaced by SyncML in 27.103. / Text3: 27.103, 27.903
- 2300: -
- 2301: AT commands to control a 3G ME via an external Terminal Equipment (TE), fully compatible with GSM AT commands. R99 adds new AT commands e.g. to control Advanced Speech Call Items (ASCI) services. / Text3: 27.005, 27.007
- 2302: Conclusion: 3GPP should not produce any technical specification for terminal interfaces other than radio interface and USIM interface. SDOs could develop own optional physical connector specification based on market requirements / Text3: 27.901
- 2303: Multiplexing protocol allowing a number of simultaneous sessions between a MS and a terminal; used to send any data (voice, SMS, USSD, fax etc.). 27.010 describes the protocol, but not the commands or data transported with it. / Text3: 27.010
- 2304: -
- 2305: CS and real-time data services provided for interworking with PSTN/ISDN so that user is unaware of access network used (UMTS, GSM or handover between ANs). Transparent(constant delay) & non-transparent(zero error with flow control) services are supported / Text3: 22.002, 23.910, 27.001, 29.007
- 2306: CS and real-time data services provided for interworking with PSTN/ISDN so that user is unaware of access network used (UMTS, GSM or handover between ANs). Transparent(constant delay) & non-transparent(zero error with flow control) services are supported / Text3: 22.002, 23.910, 27.001, 29.007
- 2307: - / Text3: 29.007
- 2308: - / Text3: 04.21, 23.910, 27.001, 29.007
- 2309: - / Text3: 27.001, 27.002, 27.003, 29.007
- 2310: - / Text3: 23.910, 27.001, 29.007
- 2311: No CR or new TS/TR approved under this WI / Text3: 29.007
- 2312: FTM is a type of async non-transparent CS bearer service (22.002). Generic term for HDLC and HDLC-related transmission protocols. Converts async non-transp data stream towards mobile side & sync data stream using X.31 flag stuffing on fixed network side. / Text3: 22.002, 27.001, 27.007, 29.007
- 2313: Access to an Intranet or ISP by running DHCP between the TE and a server in the Intranet/ISP domain. / Text3: 29.061
- 2314: PIAFS is one type of CS bearer data service (22.002). It refers to async CS tx protocol over ISDN 64 kbit/s unrestricted digital line. Facilitates interworking between PHS-MS and UMTS-UE & UMTS-UE and existing PIAFS TA (Terminal Adapter). / Text3: 22.002, 27.001, 27.007, 29.007
- 2315: PIAFS was originally standardised by the PHS Internet Access Forum in Japan. More information can be found at: http://www.infopro.or.jp/piaf / Text3: 22.002
- 2316: - / Text3: 27.001, 27.007, 29.007

| ID | WBS | Task | Duration | Start | Finish | Complete | Baseline start | Baseline finish | Baseline duration | Constraint | Resources | Work | Actual work | Text1 | Text6 |
| --- | --- | --- | --- | --- | --- | --- | --- | --- | --- | --- | --- | --- | --- | --- | --- |
| 2317 | 552.15 | **Universal Integrated Circuit Card (UICC) and Universal Subscriber Identity Module (USIM)** | 261d? | 1999-01-01 A | 1999-12-31 A | 100% | 1999-01-01 | 1999-12-31 | 261d? |  | T3 | 27144h | 27144h | UICC, USIM | R99 |
| 2318 | 552.15.1 | UICC / Terminal interface; Physical and logical characteristics | 261d? | 1999-01-01 A | 1999-12-31 A | 100% | 1999-01-01 | 1999-12-31 | 261d? | start no earlier than 1999-01-01 | T3 | 2088h | 2088h | UICC | R99 |
| 2319 | 552.15.2 | UICC/(U)SIM enhancements and interworking | 261d? | 1999-01-01 A | 1999-12-31 A | 100% | 1999-01-01 | 1999-12-31 | 261d? | start no earlier than 1999-01-01 | T3 | 2088h | 2088h | UICC1 | R99 |
| 2320 | 552.15.3 | Characteristics of the USIM application | 261d? | 1999-01-01 A | 1999-12-31 A | 100% | 1999-01-01 | 1999-12-31 | 261d? | start no earlier than 1999-01-01 | T3 | 2088h | 2088h | USIM | R99 |
| 2321 | 552.15.4 | UICC Application Identifiers | 261d? | 1999-01-01 A | 1999-12-31 A | 100% | 1999-01-01 | 1999-12-31 | 261d? | start no earlier than 1999-01-01 | T3 | 2088h | 2088h | AID, Application_Identifiers | R99 |
| 2322 | 552.15.5 | SIM Application Toolkit | 261d? | 1999-01-01 A | 1999-12-31 A | 100% | 1999-01-01 | 1999-12-31 | 261d? | start no earlier than 1999-01-01 | S1,T3 | 2088h | 2088h | SAT | R99 |
| 2323 | 552.15.6 | USIM Application Toolkit | 261d? | 1999-01-01 A | 1999-12-31 A | 100% | 1999-01-01 | 1999-12-31 | 261d? | start no earlier than 1999-01-01 | T3 | 2088h | 2088h | USAT | R99 |
| 2324 | 552.15.7 | Bearer Independent Protocol for SAT applications to exchange data over the GSM network | 261d? | 1999-01-01 A | 1999-12-31 A | 100% | 1999-01-01 | 1999-12-31 | 261d? | start no earlier than 1999-01-01 | T3 | 2088h | 2088h | BIP | R99 |
| 2325 | 552.15.8 | Administrative commands and functions for IC cards | 261d? | 1999-01-01 A | 1999-12-31 A | 100% | 1999-01-01 | 1999-12-31 | 261d? | start no earlier than 1999-01-01 | T3 | 2088h | 2088h |  | R99 |
| 2326 | 552.15.9 | USIM and UICC requirements | 261d? | 1999-01-01 A | 1999-12-31 A | 100% | 1999-01-01 | 1999-12-31 | 261d? | start no earlier than 1999-01-01 | T3 | 2088h | 2088h |  | R99 |
| 2327 | 552.15.10 | SIM_API | 261d? | 1999-01-01 A | 1999-12-31 A | 100% | 1999-01-01 | 1999-12-31 | 261d? | start no earlier than 1999-01-01 | T3 | 2088h | 2088h | SIM_API | R99 |
| 2328 | 552.15.11 | SIM_toolkit_API | 261d? | 1999-01-01 A | 1999-12-31 A | 100% | 1999-01-01 | 1999-12-31 | 261d? | start no earlier than 1999-01-01 | SMG9,T3 | 2088h | 2088h | SIM_toolkit | R99 |
| 2329 | 552.15.12 | Deleted - 1.8 Volt SIM ME interface | 261d? | 1999-01-01 A | 1999-12-31 A | 100% | 1999-01-01 | 1999-12-31 | 261d? | start no earlier than 1999-01-01 | SMG9 | 2088h | 2088h | SMIME_1.8V | R99 |
| 2330 | 552.16 | **USIM/UICC Testing** | 261d? | 1999-01-01 A | 1999-12-31 A | 100% | 1999-01-01 | 1999-12-31 | 261d? |  | T3 | 10440h | 10440h |  | R99 |
| 2331 | 552.16.1 | Terminal tests for the UICC Interface | 261d? | 1999-01-01 A | 1999-12-31 A | 100% | 1999-01-01 | 1999-12-31 | 261d? | start no earlier than 1999-01-01 | T3 | 2088h | 2088h |  | R99 |
| 2332 | 552.16.2 | USIM application test specification | 261d? | 1999-01-01 A | 1999-12-31 A | 100% | 1999-01-01 | 1999-12-31 | 261d? | start no earlier than 1999-01-01 | T3 | 2088h | 2088h |  | R99 |
| 2333 | 552.16.3 | USIM conformance test specification | 261d? | 1999-01-01 A | 1999-12-31 A | 100% | 1999-01-01 | 1999-12-31 | 261d? | start no earlier than 1999-01-01 | T3 | 2088h | 2088h |  | R99 |
| 2334 | 552.16.4 | SIM toolkit test specification | 261d? | 1999-01-01 A | 1999-12-31 A | 100% | 1999-01-01 | 1999-12-31 | 261d? | start no earlier than 1999-01-01 | T3 | 2088h | 2088h |  | R99 |
| 2335 | 552.17 | **Security** | 261d? | 1999-01-01 A | 1999-12-31 A | 100% | 1999-01-01 | 1999-12-31 | 261d? |  | S3,N2,N4 | 8352h | 8352h | Security | R99 |
| 2336 | 552.17.1 | Fraud Information Gathering Service (for connection-orientated services) | 261d? | 1999-01-01 A | 1999-12-31 A | 100% | 1999-01-01 | 1999-12-31 | 261d? | start no earlier than 1999-01-01 | S3 | 2088h | 2088h | FIGS | R99 |
| 2337 | 552.17.2 | Immediate Service Termination / SECurity Immediate Service Termination | 261d? | 1999-01-01 A | 1999-12-31 A | 100% | 1999-01-01 | 1999-12-31 | 261d? | start no earlier than 1999-01-01 | S3,N2,N4 | 2088h | 2088h | IST, SECIST | R99 |
| 2338 | 552.17.3 | Core_Network_Security | 261d? | 1999-01-01 A | 1999-12-31 A | 100% | 1999-01-01 | 1999-12-31 | 261d? | start no earlier than 1999-01-01 | N4 | 2088h | 2088h | Core_Network_Security | R99 |
| 2339 | 553 | **GSM Features** | 261d? | 1999-01-01 A | 1999-12-31 A | 100% | 1999-01-01 | 1999-12-31 | 261d? |  | S1,S2,SMG,T2,N1,N2,N3,N4 | 50112h | 50112h |  | R99 |
| 2340 | 553.1 | **Dual Transfer Mode within GSM and GPRS** | 261d? | 1999-01-01 A | 1999-12-31 A | 100% | 1999-01-01 | 1999-12-31 | 261d? |  | SMG,N1 | 6264h | 6264h | DTM | R99 |
| 2341 | 553.1.1 | Class A Dual Transfer Mode | 261d? | 1999-01-01 A | 1999-12-31 A | 100% | 1999-01-01 | 1999-12-31 | 261d? | start no earlier than 1999-01-01 | SMG | 2088h | 2088h | Class_A_Dual_Transfer_Mode_(DTM) | R99 |
| 2342 | 553.1.2 | Dual Transfer Mode | 261d? | 1999-01-01 A | 1999-12-31 A | 100% | 1999-01-01 | 1999-12-31 | 261d? | start no earlier than 1999-01-01 | SMG,N1 | 2088h | 2088h | DTM | R99 |

Notes:
- 2317: For 3G, GSM 11.11 was divided into two parts: a platform comprised of basic physical, electrical and logical specification (31.101) and an application specification (31.102)
- 2318: Defines a generic Terminal/Integrated Circuit Card (ICC) interface. Is independent of 3G USIM application => platform for any IC card application. Ensures interoperability between ICC and terminal independently of manufacturer, card issuer or operator. / Text3: 31.101 (Since 10/2000, ETSI EP SCP is responsible for the generic Terminal/Integrated Circuit Card (ICC) interface TS 102 221)
- 2319: - / Text3: 31.102, 31.900
- 2320: Defines Universal Subscriber Identity Module (USIM) application for 3G telecom network operation & resides on UICC, an IC card specified in 31.101. UICC can be used as a multi-application card: several USIMs and/or other applications can co-exist / Text3: 31.102
- 2321: Defines and administers Application IDentifiers (AID) for UICC. AID is used to address an application in the card. Consists of Registered application provider ID (RID) & Proprietary application ID eXtension (PIX - according to ISO/IEC 7816-5). / Text3: 21.111, 31.110
- 2322: - / Text3: 11.14, 22.030, 22.100, 22.101
- 2323: Defines UICC - ME interface, and mandatory ME procedures for USAT. Based on GSM 11.14 (SIM Application Toolkit). Commands and procedures defined in USIM and 3G Terminal for using USAT. Service and security requirements defined in 22.100 and 22.101. / Text3: 31.111
- 2324: Defines at SIM-ME interface a basic protocol allowing SIM Toolkit applications to determine available bearers and to exchange data by selecting using the most appropriate bearer available (CS data, GPRS, SMS, Unstructured Supplementary Service Data (USSD) / Text3: 03.48, 11.10, 11.14
- 2325: Defines function and syntax of administrative commands for telecommunication IC Card used during installation, activation and de-activation of applications. Compliant to ISO/IEC 7816 series. Handed over to ETSI Project Smart Card Platform (SCP) in 2000. / Text3: ETSI TS 102 222
- 2326: High level requirements for 3GPP IC card and its interface to 3GPP terminal (USIM&UICC reqs). Service&security reqs in 322.01,22.00. USIM is a 3GPP application on an IC card. Inter-operates with 3GPP terminals and provides access to 3GPP services / Text3: 21.111
- 2327: - / Text3: 03.19
- 2328: - / Text3: 03.48, 11.11, 11.14
- 2329: No CR or new TS/TR approved under this WI / Text3: 11.18
- 2330: -
- 2331: Test spec for the interface between UICC and terminal (originally based GSM 11.10-1 clause 27). Ensures UICC - terminal interoperability independently of manufacturer, card issuer or operator. Tests for applications residing on UICC are in 31.121 / Text3: 31.120
- 2332: Application test spec originally based on GSM 11.17. Aspects related to UICC administrative management phase are not defined. Any internal technical realisation of either UICC or terminal is only specified where these are reflected over the interface. / Text3: 31.121
- 2333: Conformance Test specification for UICC defined in 31.101 with USIM defined in 31.102. / Text3: 31.122
- 2334: SIM Application Toolkit (SAT) has major impact on ME design and enhances SIM/ME interface. Contains tests for SIM/ME interface optional features (no network related signalling issues involved). Doesn't form basis for any type approval or regulatory tests. / Text3: 11.10-4
- 2335: - / Text3: 02.09, 03.20, 21.133, 22.022, 23.003, 23.007, 23.008, 23.012, 23.018, 24.007, 24.008, 24.010, 24.011, 29.002, 29.060, 33.102, 33.103, 33.105, 33.107, 35.201
- 2336: HPLMN can monitor its subscribers in VPLMN, which collects info on a defined set of monitored subscribers activities & sends it to HPLMN, which can perform service limitation control eg Operator Determined Barring (ODB) and IST to limit financial exposure / Text3: 22.031, 23.031
- 2337: HPLMN can terminate all activities of its subscriber in VPLMN, if decides (based on info via eg FIGS) that a roaming subscriber is behaving in fraudulent/suspicious way. HPLMN can terminate all subscriber activities including calls in progress. / Text3: 03.35, 22.032, 23.008, 23.016, 23.035, 29.002
- 2338: - / Text3: 29.002
- 2339: -
- 2340: WID on BSS co-ordination of Radio Resource allocation for class A GPRS services - GSM Radio Access (R99) / Text3: 03.55, 03.64, 04.18, 04.60, 05.01, 05.02, 05.08, 08.08, 23.060, 24.007, 24.008
- 2341: - / Text3: 05.10
- 2342: - / Text3: 03.55, 03.64, 04.18, 05.01, 05.02, 05.08, 24.008

| ID | WBS | Task | Duration | Start | Finish | Complete | Baseline start | Baseline finish | Baseline duration | Constraint | Resources | Work | Actual work | Text1 | Text6 |
| --- | --- | --- | --- | --- | --- | --- | --- | --- | --- | --- | --- | --- | --- | --- | --- |
| 2343 | 553.2 | **General Packet Radio Service enahancements** | 261d? | 1999-01-01 A | 1999-12-31 A | 100% | 1999-01-01 | 1999-12-31 | 261d? |  | S1,S2,SMG1,SMG2,SMG7,N1,N2,N3,N4,T2 | 8352h | 8352h | GPRS enhancements | R99 |
| 2344 | 553.2.1 | General Packet Radio Service | 261d? | 1999-01-01 A | 1999-12-31 A | 100% | 1999-01-01 | 1999-12-31 | 261d? | start no earlier than 1999-01-01 | S1,S2,SMG1,SMG2,SMG7,N1,N2,N3,N4,T2 | 2088h | 2088h | GPRS | R99 |
| 2345 | 553.2.2 | GPRS2 | 261d? | 1999-01-01 A | 1999-12-31 A | 100% | 1999-01-01 | 1999-12-31 | 261d? | start no earlier than 1999-01-01 | SMG1,N2 | 2088h | 2088h | GPRS2 | R99 |
| 2346 | 553.2.3 | GPRS Tunnelling Protocol enhancement | 261d? | 1999-01-01 A | 1999-12-31 A | 100% | 1999-01-01 | 1999-12-31 | 261d? | start no earlier than 1999-01-01 | N4,N2 | 2088h | 2088h | GTP_enhancement | R99 |
| 2347 | 553.3 | **Enhanced Data rates for GSM Evolution - Phase 1** | 261d? | 1999-01-01 A | 1999-12-31 A | 100% | 1999-01-01 | 1999-12-31 | 261d? |  | SMG2,SMG1,SMG3,SMG4,SMG7,SMG9,SMG10,N1,N3,T2 | 25056h | 25056h | EDGE - Phase 1 | R99 |
| 2348 | 553.3.1 | Enhanced Data rates for GSM Evolution | 261d? | 1999-01-01 A | 1999-12-31 A | 100% | 1999-01-01 | 1999-12-31 | 261d? | start no earlier than 1999-01-01 | SMG2,SMG1,SMG3,SMG4,SMG7,SMG9,SMG10,N1,N3,T2 | 2088h | 2088h | EDGE | R99 |
| 2349 | 553.3.2 | EDGE-Layer1 | 261d? | 1999-01-01 A | 1999-12-31 A | 100% | 1999-01-01 | 1999-12-31 | 261d? | start no earlier than 1999-01-01 | SMG2 | 2088h | 2088h | EDGE-Layer1 | R99 |
| 2350 | 553.3.3 | High Speed Circuit Switched Data | 261d? | 1999-01-01 A | 1999-12-31 A | 100% | 1999-01-01 | 1999-12-31 | 261d? | start no earlier than 1999-01-01 | SMG1,SMG2,SMG7 | 2088h | 2088h | HSCSD | R99 |
| 2351 | 553.3.4 | Enhanced Circuit Switched Data - Phase 1 | 261d? | 1999-01-01 A | 1999-12-31 A | 100% | 1999-01-01 | 1999-12-31 | 261d? | start no earlier than 1999-01-01 | S1,SMG | 2088h | 2088h | ECSD | R99 |
| 2352 | 553.3.5 | EDGE-Enhanced Circuit Switched Data | 261d? | 1999-01-01 A | 1999-12-31 A | 100% | 1999-01-01 | 1999-12-31 | 261d? | start no earlier than 1999-01-01 | SMG2 | 2088h | 2088h | EDGE-ECSD | R99 |
| 2353 | 553.3.6 | Enhanced GPRS - Phase 1 | 261d? | 1999-01-01 A | 1999-12-31 A | 100% | 1999-01-01 | 1999-12-31 | 261d? | start no earlier than 1999-01-01 | SMG,N1 | 2088h | 2088h | EGPRS | R99 |
| 2354 | 553.3.7 | EDGE-EGPRS | 261d? | 1999-01-01 A | 1999-12-31 A | 100% | 1999-01-01 | 1999-12-31 | 261d? | start no earlier than 1999-01-01 | SMG2 | 2088h | 2088h | EDGE-EGPRS | R99 |
| 2355 | 553.3.8 | Packet Flow Context (PFC) | 261d? | 1999-01-01 A | 1999-12-31 A | 100% | 1999-01-01 | 1999-12-31 | 261d? | start no earlier than 1999-01-01 | SMG2 | 2088h | 2088h | PFC | R99 |
| 2356 | 553.3.9 | Support for EGPRS in ANSI-136 networks and EDGE COMPACT | 261d? | 1999-01-01 A | 1999-12-31 A | 100% | 1999-01-01 | 1999-12-31 | 261d? | start no earlier than 1999-01-01 | SMG | 2088h | 2088h | EDGE-Compact | R99 |
| 2357 | 553.3.10 | EGPRS COMPACT | 261d? | 1999-01-01 A | 1999-12-31 A | 100% | 1999-01-01 | 1999-12-31 | 261d? | start no earlier than 1999-01-01 | SMG | 2088h | 2088h | EGPRS-Compact | R99 |
| 2358 | 553.3.11 | COMPACT | 261d? | 1999-01-01 A | 1999-12-31 A | 100% | 1999-01-01 | 1999-12-31 | 261d? | start no earlier than 1999-01-01 | SMG,N1 | 2088h | 2088h | COMPACT | R99 |
| 2359 | 553.4 | GSM_400 | 261d? | 1999-01-01 A | 1999-12-31 A | 100% | 1999-01-01 | 1999-12-31 | 261d? | start no earlier than 1999-01-01 | SMG2,SMG7,T2 | 2088h | 2088h | GSM_400 | R99 |
| 2360 | 553.5 | GSM_450 | 261d? | 1999-01-01 A | 1999-12-31 A | 100% | 1999-01-01 | 1999-12-31 | 261d? | start no earlier than 1999-01-01 | SMG2 | 2088h | 2088h | GSM_450 | R99 |
| 2361 | 553.6 | GSM_700 | 261d? | 1999-01-01 A | 1999-12-31 A | 100% | 1999-01-01 | 1999-12-31 | 261d? | start no earlier than 1999-01-01 | SMG2 | 2088h | 2088h | GSM_700 | R99 |
| 2362 | 553.7 | Deleted - GERAN | 261d? | 1999-01-01 A | 1999-12-31 A | 100% | 1999-01-01 | 1999-12-31 | 261d? | start no earlier than 1999-01-01 | SMG2,S2 | 2088h | 2088h | GERAN | R99 |
| 2363 | 554 | **GSM Features transposed to UMTS** | 261d? | 1999-01-01 A | 1999-12-31 A | 100% | 1999-01-01 | 1999-12-31 | 261d? |  | S1,S3,T2,N2,N4 | 16704h | 16704h |  | R99 |
| 2364 | 554.1 | Cell Broadcast Service | 261d? | 1999-01-01 A | 1999-12-31 A | 100% | 1999-01-01 | 1999-12-31 | 261d? | start no earlier than 1999-01-01 | T2 | 2088h | 2088h | CBS | R99 |
| 2365 | 554.2 | **GSM mobile number portability euro MNP / North American MNP** | 261d? | 1999-01-01 A | 1999-12-31 A | 100% | 1999-01-01 | 1999-12-31 | 261d? |  | S1,N2,N4 | 4176h | 4176h | MNP | R99 |
| 2366 | 554.2.1 | Mobile Number Portability | 261d? | 1999-01-01 A | 1999-12-31 A | 100% | 1999-01-01 | 1999-12-31 | 261d? | start no earlier than 1999-01-01 | N2,N4 | 2088h | 2088h | MNP | R99 |
| 2367 | 554.3 | Automatic establishment of roaming relations | 261d? | 1999-01-01 A | 1999-12-31 A | 100% | 1999-01-01 | 1999-12-31 | 261d? | start no earlier than 1999-01-01 | S1 | 2088h | 2088h |  | R99 |
| 2368 | 554.4 | Advanced addressing | 261d? | 1999-01-01 A | 1999-12-31 A | 100% | 1999-01-01 | 1999-12-31 | 261d? | start no earlier than 1999-01-01 | S1 | 2088h | 2088h |  | R99 |
| 2369 | 554.5 | UMTS numbering, addressing and identities | 261d? | 1999-01-01 A | 1999-12-31 A | 100% | 1999-01-01 | 1999-12-31 | 261d? | start no earlier than 1999-01-01 | S1 | 2088h | 2088h |  | R99 |
| 2370 | 554.6 | Lawful Interception | 261d? | 1999-01-01 A | 1999-12-31 A | 100% | 1999-01-01 | 1999-12-31 | 261d? | start no earlier than 1999-01-01 | S3 | 2088h | 2088h | LI | R99 |

Notes:
- 2343: GPRS was introduced in Release 97. Release 99 brings a number of essential corrections e.g. on Downlink Power Control, Timing Advance procedure, Cell reselection delay time, PBCCH scheduling, PTCCH mapping, etc. / Text3: 05.02, 05.05, 05.08, 05.10, 05.50, 11.21, 23.064, 24.008, 24.060
- 2344: - / Text3: 02.60, 03.22, 03.64, 04.18, 04.60, 04.64, 04.65, 05.01, 05.02, 05.05, 05.08, 05.10, 08.08, 08.18, 11.10-1, 11.21, 22.041, 22.060, 23.003, 23.007, 23.060, 23.107, 23.122, 24.007, 24.008, 27.007, 27.060, 29.002, 29.016, 29.018, 29.060, 29.061
- 2345: Introduction of EGPRS (S1) + Introduction of Reserved Service Labels in the APN (N2) / Text3: 02.60, 23.003
- 2346: - / Text3: 23.003, 23.008, 29.060
- 2347: EDGE is independent of the frequency bands, so it can be deployed e.g. in 900 and 1900 MHz bands. The new physical layer based on 8-PSK modulation is introduced and EGPRS and ECSD facilitate the new modulation in single and multi slot constellation. / Text3: 10.59, 02.34, 02.60, 03.30, 05.10, 05.50, 11.26
- 2348: - / Text3: 02.34, 03.10, 03.20, 03.64, 04.03, 04.04, 04.06, 04.08, 04.18, 04.21, 04.22, 04.60, 04.64, 05.01, 05.02, 05.03, 05.04, 05.05, 05.08, 05.10, 05.50, 07.01, 07.02, 07.03, 08.08, 08.20, 08.58, 08.60, 09.07, 09.18, 11.10-1, 11.11, 11.21, 11.26, 23.034, 24.008,
- 2349: - / Text3: 05.05, 05.10, 05.50
- 2350: No additional features for R99. / Text3: 02.34, 04.18, 11.10-1
- 2351: ECSD supports both transparent and non-transparent services, up to 64 kbit/s and 57.6 kbit/s respectively. See Tdoc SMG2 670/99 ECSD Concept Evaluation for more info / Text3: 05.02, 08.58, 22.034
- 2352: - / Text3: 05.03
- 2353: - / Text3: 02.07, 03.64, 04.14, 04.18, 04.60, 05.05, 05.08, 24.008
- 2354: - / Text3: 05.03, 05.05, 05.08
- 2355: - / Text3: 04.18
- 2356: Support for EGPRS in ANSI-136 networks and EDGE Compact (for ANSI-136 networks only). COMPACT = Deployment of services in spectrum below 1 MHz / Text3: 03.22, 03.30, 03.64, 05.01, 05.02, 05.03, 05.05, 05.08, 05.10
- 2357: COMPACT = Deployment of services in spectrum below 1 MHz / Text3: 04.18, 05.02
- 2358: COMPACT = Deployment of services in spectrum below 1 MHz / Text3: 03.22, 04.18, 04.60, 05.08, 23.122, 24.008
- 2359: - / Text3: 02.17, 03.22, 03.30, 04.04, 04.18, 04.60, 05.01, 05.02, 05.05, 05.08, 05.10, 05.50, 08.18, 08.58, 11.21, 24.008, 27.007 / Text8: GSM in the 400 MHz bands allows to deploy GSM within frequency bands in the range 450 to 500 MHz, previously used for analogue cellular systems. See Tdoc SMG2 190/99 and 595/99 for further info.
- 2360: - / Text3: 03.22, 03.30, 05.01, 05.05, 05.08
- 2361: - / Text3: 05.05
- 2362: No CR or new TS/TR approved under this WI / Text3: G2: 04.18 CR#A248 , 04.60 CR#B090
- 2363: -
- 2364: Moved to CT1 at TSG-T closure. Applicability of the Cell Broadcast Service (as defined for GSM network) to 3G networks / Text3: 23.041
- 2365: R98 MNP: mobile subscriber ability to change PLMN operator within the same country whilst retaining its original MS ISDN number (MSISDN). IMSI is changed, only MSISDN is kept. R99 adds requirements for North American Service Provider Number Portability. / Text3: 22.066
- 2366: - / Text3: 23.018, 23.066, 29.002
- 2367: framework for commercial and technical interworking between UMTS Home Environments and Serving Networks who have no direct prior commercial agreements with each other. / Text3: 22.101, 22.971
- 2368: - / Text3: 22.101, 22.75U, 22.975
- 2369: Also new requirements for Single and Multiple Numbering scheme was added (CR#20 and 21). Deleted the term International Mobile User Identifier (IMUI) and changed IMSI (International Mobile Station Identifier=>International Mobile Subscriber Identity. / Text3: 22.101
- 2370: Defines an interception system in UMTS that supports a number of regional interception regulations. Regional interception requirements shall be met in using specific (regional) mediation functions allowing only required information to be transported. / Text3: 33.106, 33.107

| ID | WBS | Task | Duration | Start | Finish | Complete | Baseline start | Baseline finish | Baseline duration | Constraint | Resources | Work | Actual work | Text1 | Text6 |
| --- | --- | --- | --- | --- | --- | --- | --- | --- | --- | --- | --- | --- | --- | --- | --- |
| 2371 | 555 | **Charging** | 261d? | 1999-01-01 A | 1999-12-31 A | 100% | 1999-01-01 | 1999-12-31 | 261d? |  | S1,S5 | 6264h | 6264h | CH | R99 |
| 2372 | 555.1 | Charging | 261d? | 1999-01-01 A | 1999-12-31 A | 100% | 1999-01-01 | 1999-12-31 | 261d? | start no earlier than 1999-01-01 | S1 | 2088h | 2088h | Charging | R99 |
| 2373 | 555.2 | OAM Charging Management | 261d? | 1999-01-01 A | 1999-12-31 A | 100% | 1999-01-01 | 1999-12-31 | 261d? | start no earlier than 1999-01-01 | S5 | 2088h | 2088h | OAMCH, CH | R99 |
| 2374 | 556 | **Operations, Administration, Maintenance and Provisioning (OAM&P)** | 261d? | 1999-01-01 A | 1999-12-31 A | 100% | 1999-01-01 | 1999-12-31 | 261d? |  | S5 | 12528h | 12528h | OAM | R99 |
| 2375 | 556.1 | OAM Principles and High-level Requirements | 261d? | 1999-01-01 A | 1999-12-31 A | 100% | 1999-01-01 | 1999-12-31 | 261d? | start no earlier than 1999-01-01 | S5 | 2088h | 2088h | PR, Princs_&_Reqs_(PR) | R99 |
| 2376 | 556.2 | OAM Architecture | 261d? | 1999-01-01 A | 1999-12-31 A | 100% | 1999-01-01 | 1999-12-31 | 261d? | start no earlier than 1999-01-01 | S5 | 2088h | 2088h | OAMAR, AR, Telecom_Management_Arch_(AR) | R99 |
| 2377 | 556.3 | OAM Configuration Management | 261d? | 1999-01-01 A | 1999-12-31 A | 100% | 1999-01-01 | 1999-12-31 | 261d? | start no earlier than 1999-01-01 | S5 | 2088h | 2088h | OAMCM, CM | R99 |
| 2378 | 556.4 | OAM Fault Management | 261d? | 1999-01-01 A | 1999-12-31 A | 100% | 1999-01-01 | 1999-12-31 | 261d? | start no earlier than 1999-01-01 | S5 | 2088h | 2088h | OAMFM | R99 |
| 2379 | 556.5 | OAM Performance Management | 261d? | 1999-01-01 A | 1999-12-31 A | 100% | 1999-01-01 | 1999-12-31 | 261d? | start no earlier than 1999-01-01 | S5 | 2088h | 2088h | OAMPM, PM | R99 |
| 2380 | 557 | Vocabulary | 261d? | 1999-01-01 A | 1999-12-31 A | 100% | 1999-01-01 | 1999-12-31 | 261d? | start no earlier than 1999-01-01 | S1 | 2088h | 2088h | Vocabulary | R99 |
| 2381 | 558 | Emergency | 261d? | 1999-01-01 A | 1999-12-31 A | 100% | 1999-01-01 | 1999-12-31 | 261d? | start no earlier than 1999-01-01 | S1 | 2088h | 2088h | Emergency | R99 |
| 2382 | 559 | GSM General Bearer Services (GBS) and interworking scenarios support in UMTS | 261d? | 1999-01-01 A | 1999-12-31 A | 100% | 1999-01-01 | 1999-12-31 | 261d? | start no earlier than 1999-01-01 | S1 | 2088h | 2088h | GSM_to_UMTS_Evol | R99 |
| 2383 | 560 | GPRS_Mobile_IP_interworking | 261d? | 1999-01-01 A | 1999-12-31 A | 100% | 1999-01-01 | 1999-12-31 | 261d? | start no earlier than 1999-01-01 | N3 | 2088h | 2088h | GPRS_Mobile_IP_interworking | R99 |
| 2384 | 561 | GSM/UMTS interworking | 261d? | 1999-01-01 A | 1999-12-31 A | 100% | 1999-01-01 | 1999-12-31 | 261d? | start no earlier than 1999-01-01 | N1,N2,N4,R3,S1,SMG | 2088h | 2088h | 2G3Ginterworking | R99 |
| 2385 | 562 | Handover | 261d? | 1999-01-01 A | 1999-12-31 A | 100% | 1999-01-01 | 1999-12-31 | 261d? | start no earlier than 1999-01-01 | S1,SMG2,N1,N2,N4 | 2088h | 2088h | Handover | R99 |
| 2386 | 563 | 2G3Ghandover | 261d? | 1999-01-01 A | 1999-12-31 A | 100% | 1999-01-01 | 1999-12-31 | 261d? | start no earlier than 1999-01-01 | SMG2 | 2088h | 2088h | 2G3Ghandover | R99 |
| 2387 | 564 | Service Provider Name Indication | 261d? | 1999-01-01 A | 1999-12-31 A | 100% | 1999-01-01 | 1999-12-31 | 261d? | start no earlier than 1999-01-01 | S1 | 2088h | 2088h | SPANME | R99 |
| 2388 | 565 | Data & Data_CleanUp | 261d? | 1999-01-01 A | 1999-12-31 A | 100% | 1999-01-01 | 1999-12-31 | 261d? | start no earlier than 1999-01-01 | SMG1 | 2088h | 2088h | Data, Data_CleanUp | R99 |
| 2389 | 566 | Unstructured Supplementary Service Data | 261d? | 1999-01-01 A | 1999-12-31 A | 100% | 1999-01-01 | 1999-12-31 | 261d? | start no earlier than 1999-01-01 | SMG1,N4 | 2088h | 2088h | USSD | R99 |
| 2390 | 567 | Man-Machine Interface (MMI) of the User Equipment (UE) | 261d? | 1999-01-01 A | 1999-12-31 A | 100% | 1999-01-01 | 1999-12-31 | 261d? | start no earlier than 1999-01-01 | S1 | 2088h | 2088h | MMI | R99 |
| 2391 | 568 | Network Identity and Timezone (NITZ) | 261d? | 1999-01-01 A | 1999-12-31 A | 100% | 1999-01-01 | 1999-12-31 | 261d? | start no earlier than 1999-01-01 | SMG1,SMG3 | 2088h | 2088h | NITZ | R99 |
| 2392 | 569 | Operator Determined Barring for Packet Oriented Services | 261d? | 1999-01-01 A | 1999-12-31 A | 100% | 1999-01-01 | 1999-12-31 | 261d? | start no earlier than 1999-01-01 | S1 | 2088h | 2088h | ODB_Enh. | R99 |
| 2393 | 570 | Packet Flow Management | 261d? | 1999-01-01 A | 1999-12-31 A | 100% | 1999-01-01 | 1999-12-31 | 261d? | start no earlier than 1999-01-01 | SMG2 | 2088h | 2088h | Packet_Flow_Management | R99 |
| 2394 | 571 | GPRS_Point-To-Multipoint Group call | 261d? | 1999-01-01 A | 1999-12-31 A | 100% | 1999-01-01 | 1999-12-31 | 261d? | start no earlier than 1999-01-01 | SMG1 | 2088h | 2088h | GPRS_PTMG | R99 |

Notes:
- 2371: -
- 2372: WID SP-99271 Charging and accounting / Text3: 22.115, 23.121
- 2373: WID SP-99581 SA5 Year 2000 Work plan / Text3: 32.005, 32.015
- 2374: WID SP-99581 SA5 Year 2000 Work plan
- 2375: WID SP-99581 SA5 Year 2000 Work plan / Text3: 32.101
- 2376: WID SP-99581 SA5 Year 2000 Work plan / Text3: 32.101, 32.102
- 2377: WID SP-99273 Configuration management / Text3: 32.106, 32.106-1, 32.106-2, 32.106-3, 32.106-4, 32.106-5, 32.106-6, 32.106-7, 32.106-8
- 2378: WID SP-99272 Fault management / Text3: 32.111, 32.111-1, 32.111-2, 32.111-3, 32.111-4
- 2379: WID SP-99274 Performance management / Text3: 12.04, 32.104
- 2380: - / Text3: 21.905
- 2381: - / Text3: 22.101
- 2382: UMTS shall support GSM General Bearer Services (GBS) and interworking scenarios as specified in 02.02 / Text3: 22.105
- 2383: - / Text3: 29.061
- 2384: - / Text3: 03.22, 04.18, 04.60, 05.02, 05.08, 05.10, 08.08, 08.18, 08.58, 09.08, 22.011, 23.003, 23.009, 23.014, 23.034, 23.122, 24.007, 24.008, 24.011, 24.080, 29.108
- 2385: - / Text3: 04.18, 08.08, 08.58, 22.129, 23.009, 29.002, 29.010
- 2386: - / Text3: 04.18, 04.60, 05.02, 05.08, 05.10, 08.08, 29.010
- 2387: Service Provider Name Indication included in R98 (02.07) was not carried into R99 (22.101), but is in the SIM/USIM specification for R99 / Text3: 22.101
- 2388: - / Text3: 02.01, 02.02, 02.04, 02.34
- 2389: No additional features for R99. / Text3: 02.04, 02.90, 23.090, 29.002
- 2390: Data services streamlining + Support for Anonymous Call Rejection / Text3: 22.030
- 2391: - / Text3: 02.42, 04.08
- 2392: Remove ODB for Packet Oriented Services from R99 / Text3: 22.041
- 2393: - / Text3: 08.18
- 2394: - / Text3: 02.60

| ID | WBS | Task | Duration | Start | Finish | Complete | Baseline start | Baseline finish | Baseline duration | Constraint | Resources | Work | Actual work | Text6 | Text8 |
| --- | --- | --- | --- | --- | --- | --- | --- | --- | --- | --- | --- | --- | --- | --- | --- |
| 2395 | 572 | **Call Forwarding** | 261d? | 1999-01-01 A | 1999-12-31 A | 100% | 1999-01-01 | 1999-12-31 | 261d? |  | SMG1,N2,N4 | 8352h | 8352h | R99 |  |
| 2396 | 572.1 | Call Forwarding enhancements | 261d? | 1999-01-01 A | 1999-12-31 A | 100% | 1999-01-01 | 1999-12-31 | 261d? | start no earlier than 1999-01-01 | N4,N2 | 2088h | 2088h | R99 |  |
| 2397 | 572.2 | Call_Forwarding | 261d? | 1999-01-01 A | 1999-12-31 A | 100% | 1999-01-01 | 1999-12-31 | 261d? | start no earlier than 1999-01-01 | SMG1,N2 | 2088h | 2088h | R99 |  |
| 2398 | 572.3 | Call_Forwarding_Enhancements | 261d? | 1999-01-01 A | 1999-12-31 A | 100% | 1999-01-01 | 1999-12-31 | 261d? | start no earlier than 1999-01-01 | N4 | 2088h | 2088h | R99 |  |
| 2399 | 573 | **Quality of Service** | 261d? | 1999-01-01 A | 1999-12-31 A | 100% | 1999-01-01 | 1999-12-31 | 261d? |  | S2,T2,N1,N2,N4 | 10440h | 10440h | R99 |  |
| 2400 | 573.1 | End-to-end UMTS Quality of Service management | 261d? | 1999-01-01 A | 1999-12-31 A | 100% | 1999-01-01 | 1999-12-31 | 261d? | start no earlier than 1999-01-01 | S2,T2,N1,N2,N4 | 2088h | 2088h | R99 |  |
| 2401 | 573.2 | End-to-end QoS for PS Domain including IMS | 261d? | 1999-01-01 A | 1999-12-31 A | 100% | 1999-01-01 | 1999-12-31 | 261d? | start no earlier than 1999-01-01 | S2 | 2088h | 2088h | R99 |  |
| 2402 | 573.3 | GPRS-enhanced_QoS | 261d? | 1999-01-01 A | 1999-12-31 A | 100% | 1999-01-01 | 1999-12-31 | 261d? | start no earlier than 1999-01-01 | T2 | 2088h | 2088h | R99 |  |
| 2403 | 573.4 | QoS_enhancements | 261d? | 1999-01-01 A | 1999-12-31 A | 100% | 1999-01-01 | 1999-12-31 | 261d? | start no earlier than 1999-01-01 | N2,N1,N4 | 2088h | 2088h | R99 |  |
| 2404 | 574 | Support of Localised Service Area | 261d? | 1999-01-01 A | 1999-12-31 A | 100% | 1999-01-01 | 1999-12-31 | 261d? | start no earlier than 1999-01-01 | SMG2,SMG3,SMG7,N2 | 2088h | 2088h | R99 |  |
| 2405 | 575 | Transcoder_location | 261d? | 1999-01-01 A | 1999-12-31 A | 100% | 1999-01-01 | 1999-12-31 | 261d? | start no earlier than 1999-01-01 | S2 | 2088h | 2088h | R99 |  |
| 2406 | 576 | Antenna_test_methods | 261d? | 1999-01-01 A | 1999-12-31 A | 100% | 1999-01-01 | 1999-12-31 | 261d? | start no earlier than 1999-01-01 | SMG2 | 2088h | 2088h | R99 |  |
| 2407 | 577 | WBAMR / high quality speech in UMTS Phase 1 but not in R99 | 261d? | 1999-01-01 A | 1999-12-31 A | 100% | 1999-01-01 | 1999-12-31 | 261d? | start no earlier than 1999-01-01 | S1 | 2088h | 2088h | R99 |  |
| 2408 | 578 | **Codec** | 261d? | 1999-01-01 A | 1999-12-31 A | 100% | 1999-01-01 | 1999-12-31 | 261d? |  | S4 | 14616h | 14616h | R99 | Paolo |
| 2409 | 578.1 | Codec(s)_for_Multimedia_Telephony_Service | 261d? | 1999-01-01 A | 1999-12-31 A | 100% | 1999-01-01 | 1999-12-31 | 261d? | start no earlier than 1999-01-01 | S4 | 2088h | 2088h | R99 | Paolo |
| 2410 | 578.2 | QoS for Speech and Multimedia Codec | 261d? | 1999-01-01 A | 1999-12-31 A | 100% | 1999-01-01 | 1999-12-31 | 261d? | start no earlier than 1999-01-01 | S4 | 2088h | 2088h | R99 | Paolo |
| 2411 | 578.3 | Tandem Free Operation - Adaptive Multi-Rate codec types | 261d? | 1999-01-01 A | 1999-12-31 A | 100% | 1999-01-01 | 1999-12-31 | 261d? | start no earlier than 1999-01-01 | S4 | 2088h | 2088h | R99 | Paolo |
| 2412 | 578.4 | Noise Suppression for AMR | 261d? | 1999-01-01 A | 1999-12-31 A | 100% | 1999-01-01 | 1999-12-31 | 261d? | start no earlier than 1999-01-01 | S4 | 2088h | 2088h | R99 | Paolo |
| 2413 | 578.5 | Out-of-Band Transcoder | 261d? | 1999-01-01 A | 1999-12-31 A | 100% | 1999-01-01 | 1999-12-31 | 261d? | start no earlier than 1999-01-01 | N1 | 2088h | 2088h | R99 |  |
| 2414 | 578.6 | Out-of-Band Transcoder Control | 261d? | 1999-01-01 A | 1999-12-31 A | 100% | 1999-01-01 | 1999-12-31 | 261d? | start no earlier than 1999-01-01 | N1 | 2088h | 2088h | R99 |  |
| 2415 | 579 | Advanced Speech Call Items enhancements | 261d? | 1999-01-01 A | 1999-12-31 A | 100% | 1999-01-01 | 1999-12-31 | 261d? | start no earlier than 1999-01-01 | SMG1,SMG2,SMG3,SMG7,SMG9,N1,C1,N4,S1,T2 | 2088h | 2088h | R99 |  |
| 2416 | 580 | Call Control improvements | 261d? | 1999-01-01 A | 1999-12-31 A | 100% | 1999-01-01 | 1999-12-31 | 261d? | start no earlier than 1999-01-01 | N1 | 2088h | 2088h | R99 |  |
| 2417 | 581 | Multimedia | 261d? | 1999-01-01 A | 1999-12-31 A | 100% | 1999-01-01 | 1999-12-31 | 261d? | start no earlier than 1999-01-01 | N1,N3 | 2088h | 2088h | R99 |  |
| 2418 | 582 | Sub-System Number allocation for RANAP, RNSAP | 261d? | 1999-01-01 A | 1999-12-31 A | 100% | 1999-01-01 | 1999-12-31 | 261d? | start no earlier than 1999-01-01 | N2 | 2088h | 2088h | R99 |  |
| 2419 | 583 | Intranet / ISP access with DHCP end-to-end | 261d? | 1999-01-01 A | 1999-12-31 A | 100% | 1999-01-01 | 1999-12-31 | 261d? | start no earlier than 1999-01-01 | N3 | 2088h | 2088h | R99 |  |
| 2420 | 584 | Point_to_Multipoint_Services | 261d? | 1999-01-01 A | 1999-12-31 A | 100% | 1999-01-01 | 1999-12-31 | 261d? | start no earlier than 1999-01-01 | N3 | 2088h | 2088h | R99 |  |
| 2421 | 585 | Facsimile | 261d? | 1999-01-01 A | 1999-12-31 A | 100% | 1999-01-01 | 1999-12-31 | 261d? | start no earlier than 1999-01-01 | S1 | 2088h | 2088h | R99 |  |
| 2422 | 586 | Realtime_NT_FAX_in_UMTS | 261d? | 1999-01-01 A | 1999-12-31 A | 100% | 1999-01-01 | 1999-12-31 | 261d? | start no earlier than 1999-01-01 | N3 | 2088h | 2088h | R99 |  |
| 2423 | 587 | Gateway Location Register (GLR) - Mobile Application Part (MAP) specification | 261d? | 1999-01-01 A | 1999-12-31 A | 100% | 1999-01-01 | 1999-12-31 | 261d? | start no earlier than 1999-01-01 | N4 | 2088h | 2088h | R99 |  |
| 2424 | 588 | Multiple Subscriber Profile phase 2 | 261d? | 1999-01-01 A | 1999-12-31 A | 100% | 1999-01-01 | 1999-12-31 | 261d? | start no earlier than 1999-01-01 | S1,N4 | 2088h | 2088h | R99 |  |
| 2425 | 589 | Prepaging | 261d? | 1999-01-01 A | 1999-12-31 A | 100% | 1999-01-01 | 1999-12-31 | 261d? | start no earlier than 1999-01-01 | N2,N4 | 2088h | 2088h | R99 |  |
| 2426 | 590 | Downlink Advanced Receiver Performance | 261d? | 1999-01-01 A | 1999-12-31 A | 100% | 1999-01-01 | 1999-12-31 | 261d? | start no earlier than 1999-01-01 | SMG | 2088h | 2088h | R99 |  |
| 2427 | 591 | Harmonized Standard | 261d? | 1999-01-01 A | 1999-12-31 A | 100% | 1999-01-01 | 1999-12-31 | 261d? | start no earlier than 1999-01-01 | SMG2 | 2088h | 2088h | R99 |  |
| 2428 | 592 | Streamlining of specifications | 261d? | 1999-01-01 A | 1999-12-31 A | 100% | 1999-01-01 | 1999-12-31 | 261d? | start no earlier than 1999-01-01 | N3 | 2088h | 2088h | R99 |  |
| 2429 | 593 | R99_Service_Clean_up | 261d? | 1999-01-01 A | 1999-12-31 A | 100% | 1999-01-01 | 1999-12-31 | 261d? | start no earlier than 1999-01-01 | N3 | 2088h | 2088h | R99 |  |

Notes:
- 2395: -
- 2396: No additional features for R99. / Text1: CF_enhancements / Text3: 23.078, 23.079, 23.082, 29.002, 29.078
- 2397: - / Text1: Call_Forwarding / Text3: 02.82, 29.002
- 2398: - / Text1: Call_Forwarding_Enhancements / Text3: 23.082
- 2399: WID SMG 98-0781 End To End UMTS QoS Management
- 2400: WID SMG 98-0781 End To End UMTS QoS Management / Text1: QoS / Text3: 23.107, 23.907, 24.008
- 2401: - / Text1: E2EQoS / Text3: 23.060, 23.170
- 2402: AT-commands for Enhanced QoS Support management / Text1: GPRS-enhanced_QoS / Text3: 27.007
- 2403: - / Text1: QoS_enhancements / Text3: 23.008, 23.016, 24.008, 29.002, 29.060
- 2404: Mechanism which can be used as a platform for providing special tariffs and/or special set of service features for certain subscribers within a regionally restricted area or areas. No additional features for R99. / Text1: SoLSA / Text3: 04.08, 04.18, 08.08, 11.10-1, 29.002
- 2405: UE location identification: background information and associated primitives 2. Transcoder location at the core network and source depending coding belonging to the non-access stratum. / Text1: Transcoder_location / Text3: 23.110
- 2406: - / Text1: Antenna_test_methods / Text3: 03.30
- 2407: Add requirement for high quality speech in UMTS Phase 1 but not in R99 / Text1: WBAMR / Text3: 22.105
- 2408: -
- 2409: - / Text1: Multimedia_Codec, CSM, WI2MMC, Codec(s)_for_CS_MM_Tel._Serv, Codec(s)_for_MM_Tel_Service, Codec_for_Multimedia_Telephony / Text3: 26.911, 26.104, 26.111
- 2410: - / Text1: QoS_for_Speech_&_MM_Codecs_/_AMR / Text3: 26.102, 26.912
- 2411: UMTS_AMR2 is default Codec Type in R99 dual_mode terminals / Text1: TFOAMR / Text3: 26.103
- 2412: Combination of the AMR speech codec and the Noise Suppression function. TS 06.77 and TR 06.78 only apply to GSM. They apply to UMTS from Rel-4 onwards, when they were converted to TS 26.077 and TR 26.078. / Text1: AMRNS / Text3: 06.77, 06.78
- 2413: Transcoder handling in the CN at inter-system handover and relocation + Introduction of UMTS AMR / Text1: OoBT / Text3: 23.009, 24.008
- 2414: 24.008 CR#0572 in NP-020220 was approved under this WI / Text1: OoBTC / Text3: 24.008 CR#0572 in NP-020220
- 2415: - / Text1: ASCI / Text3: 02.30, 02.68, 03.68, 03.69, 04.18, 08.08, 11.10-1, 11.11, 23.067, 23.094, 24.008, 24.067, 27.007, 29.002
- 2416: Minor improvements to 24.007 and 24.008 to increase the number of simultaneous calls/sessions from the present 7: the TI value is increased (NP-99441). / Text1: CC_Related_items / Text3: 24.007, 24.008
- 2417: - / Text1: Multimedia / Text3: 24.008, 27.001, 29.007
- 2418: Sub-System Number allocation for Radio Access Network Application Part, Radio Network Subsystem Application Part / Text1: SSN_allocation / Text3: 23.003
- 2419: Access to an Intranet/ISP with DHCP end to end / Text1: ISPaccess / Text3: 29.061
- 2420: Support for the IP-Multicast protocol / Text1: Point_to_Multipoint_Services / Text3: 29.061
- 2421: - / Text1: FAX / Text3: 22.003, 22.100
- 2422: Asynchronous Interface for real-time NT Fax + Introduction of Asynchronous interface for Real-time non-transparent FAX / Text1: Realtime_NT_FAX_in_UMTS / Text3: 27.001, 27.003
- 2423: - / Text1: GLR / Text3: 29.120
- 2424: - / Text1: MSP2 / Text3: 22.097, 23.072, 23.083, 23.084, 23.091, 23.093, 23.097
- 2425: - / Text1: Prepaging / Text3: 23.018, 23.082, 29.002
- 2426: Re-definition of channel quality measure used for AMR link adaptation for DARP MS / Text3: 05.09
- 2427: - / Text1: HS / Text3: 13.21
- 2428: - / Text1: Streamlining / Text3: 27.060, 29.061
- 2429: - / Text1: R99_Service_Clean_up / Text3: 03.10, 27.001, 27.002, 27.003, 27.060, 29.007, 29.061

| ID | WBS | Task | Type | Duration | Start | Finish | Complete | Baseline start | Baseline finish | Baseline duration | Total slack | Constraint | Resources | Work | Actual work | Text1 | Text6 | Text3 |
| --- | --- | --- | --- | --- | --- | --- | --- | --- | --- | --- | --- | --- | --- | --- | --- | --- | --- | --- |
| 2430 | 594 | **small Technical Enhancements and Improvements for R99** |  | 261d? | 1999-01-01 A | 1999-12-31 A | 100% | 1999-01-01 | 1999-12-31 | 261d? |  |  | N3 | 6264h | 6264h | TEI | R99 |  |
| 2431 | 594.1 | TEI_[CS_Data] |  | 261d? | 1999-01-01 A | 1999-12-31 A | 100% | 1999-01-01 | 1999-12-31 | 261d? |  | start no earlier than 1999-01-01 | N3 | 2088h | 2088h | TEI_[CS_Data] | R99 |  |
| 2432 | 594.2 | TEI_[GPRS] |  | 261d? | 1999-01-01 A | 1999-12-31 A | 100% | 1999-01-01 | 1999-12-31 | 261d? |  | start no earlier than 1999-01-01 | N3 | 2088h | 2088h | TEI_[GPRS] | R99 |  |
| 2433 | 595 | **R99 UE Conformance Testing** |  | 261d? | 1999-01-01 A | 1999-12-31 A | 100% | 1999-01-01 | 1999-12-31 | 261d? |  |  | R5,T1 | 4176h | 4176h | TEI_Test | R99 | 34.108, 34.121, 34.122, 34.123-1, 34.123-2, 34.123-3 |
| 2434 | 595.1 | Deleted - RTEI |  | 261d? | 1999-01-01 A | 1999-12-31 A | 100% | 1999-01-01 | 1999-12-31 | 261d? |  | start no earlier than 1999-01-01 | T1 | 2088h | 2088h | RTEI | R99 | 34.123-1 CR#0650, 0651, 34.123-3 CR#0148, 0149, 0150 |
| 2435 | 595.2 | Common test environments for User Equipment (UE); Conformance testing | milestone | 0d? | 1999-01-01 A | 1999-01-01 A | 100% | 1999-01-01 | 1999-01-01 | 0d? |  | start no earlier than 1999-01-01 | R5,T1 |  |  | TEI_Test | R99 | 34.108 |
| 2436 | 595.3 | Terminal conformance specification, Radio transmission and reception (FDD) | milestone | 0d? | 1999-01-01 A | 1999-01-01 A | 100% | 1999-01-01 | 1999-01-01 | 0d? |  | start no earlier than 1999-01-01 | R5,T1 |  |  | TEI_Test | R99 | 34.121 |
| 2437 | 595.4 | Terminal conformance specification, Radio transmission and reception (TDD) | milestone | 0d? | 1999-01-01 A | 1999-01-01 A | 100% | 1999-01-01 | 1999-01-01 | 0d? |  | start no earlier than 1999-01-01 | R5,T1 |  |  | TEI_Test | R99 | 34.122 |
| 2438 | 595.5 | UE conformance specification; Part 1: Protocol conformance specification | milestone | 0d? | 1999-01-01 A | 1999-01-01 A | 100% | 1999-01-01 | 1999-01-01 | 0d? |  | start no earlier than 1999-01-01 | R5,T1 |  |  | TEI_Test | R99 | 34.123-1 |
| 2439 | 595.6 | UE conformance specification; Part 2: Implementation Conformance Statement (ICS) specification | milestone | 0d? | 1999-01-01 A | 1999-01-01 A | 100% | 1999-01-01 | 1999-01-01 | 0d? |  | start no earlier than 1999-01-01 | R5,T1 |  |  | TEI_Test | R99 | 34.123-2 |
| 2440 | 595.7 | UE conformance specification; Part 3: Abstract test suites (ATSs) | milestone | 0d? | 1999-01-01 A | 1999-01-01 A | 100% | 1999-01-01 | 1999-01-01 | 0d? |  | start no earlier than 1999-01-01 | R5,T1 |  |  | TEI_Test | R99 | 34.123-3 |
| 2441 | 596 | Deleted - Dual Tone Multi-Frequency signalling : Support in the whole 3GPP system |  | 261d? | 1999-01-01 A | 1999-12-31 A | 100% | 1999-01-01 | 1999-12-31 | 261d? |  | start no earlier than 1999-01-01 | N1 | 2088h | 2088h | DTMF | R99 | 23.014 CR#0004 |
| 2442 | 597 | Deleted - Intersystem_Change |  | 261d? | 1999-01-01 A | 1999-12-31 A | 100% | 1999-01-01 | 1999-12-31 | 261d? |  | start no earlier than 1999-01-01 | G3new | 2088h | 2088h | Intersystem_Change | R99 | 04.18 CR#A243 |
| 2443 | 598 | Deleted - Long_Forwardedto_Numbers |  | 261d? | 1999-01-01 A | 1999-12-31 A | 100% | 1999-01-01 | 1999-12-31 | 261d? |  | start no earlier than 1999-01-01 | N2 | 2088h | 2088h | Long_Forwardedto_Numbers | R99 | 29.002 |
| 2444 | 599 | Deleted - RANimp-FSEarlyUE |  | 261d? | 1999-01-01 A | 1999-12-31 A | 100% | 1999-01-01 | 1999-12-31 | 261d? |  | start no earlier than 1999-01-01 | R3 | 2088h | 2088h | RANimp-FSEarlyUE | R99 | 25.413 CR#0520, 0538, 0565, 0563, 0541, 0540, 0539, 0547 |
| 2445 | 600 | Release 1999 Studies |  | 1d? | 2000-01-03 | 2000-01-03 |  | 2000-01-03 | 2000-01-03 | 1d? | 3317d |  | S1,T2 | 8h |  |  | R99 |  |
| 2446 | 601 | Advanced Addressing/Numbering |  | 261d? | 1999-01-01 A | 1999-12-31 A | 100% | 1999-01-01 | 1999-12-31 | 261d? |  | start no earlier than 1999-01-01 | S1 | 2088h | 2088h | Numbering | R99 | 22.975 |
| 2447 | 602 | Combined GSM and Mobile IP mobility handling in UMTS IP CN |  | 261d? | 1999-01-01 A | 1999-12-31 A | 100% | 1999-01-01 | 1999-12-31 | 261d? |  | start no earlier than 1999-01-01 | S2 | 2088h | 2088h |  | R99 | 23.923 |
| 2448 | 603 | UE Capabilities Requirements |  | 261d? | 1999-01-01 A | 1999-12-31 A | 100% | 1999-01-01 | 1999-12-31 | 261d? |  | start no earlier than 1999-01-01 | T2 | 2088h | 2088h | UCR | R99 | 21.904 |
| 2449 | 604 | Electrical safety requirements and regulations |  | 261d? | 1999-01-01 A | 1999-12-31 A | 100% | 1999-01-01 | 1999-12-31 | 261d? |  | start no earlier than 1999-01-01 | T2 | 2088h | 2088h |  | R99 | 34.907 |
| 2450 | 605 | Specific Absorbtion Rate (SAR) requirements and regulations in different regions |  | 261d? | 1999-01-01 A | 1999-12-31 A | 100% | 1999-01-01 | 1999-12-31 | 261d? |  | start no earlier than 1999-01-01 | T2 | 2088h | 2088h |  | R99 | 34.925 |
| 2451 | 606 | Multi-mode UE issues |  | 261d? | 1999-01-01 A | 1999-12-31 A | 100% | 1999-01-01 | 1999-12-31 | 261d? |  | start no earlier than 1999-01-01 | T2 | 2088h | 2088h |  | R99 | 21.810, 21.910 |
| 2452 | 607 | Provision of fax service in GSM and UMTS |  | 261d? | 1999-01-01 A | 1999-12-31 A | 100% | 1999-01-01 | 1999-12-31 | 261d? |  | start no earlier than 1999-01-01 | T2 | 2088h | 2088h |  | R99 | 22.945 |
| 2453 | 608 | Separating Radio Resources and Mobility Management specific parts of the MS Classmark |  | 261d? | 1999-01-01 A | 1999-12-31 A | 100% | 1999-01-01 | 1999-12-31 | 261d? |  | start no earlier than 1999-01-01 | T2 | 2088h | 2088h |  | R99 | 23.814 |

Notes:
- 2430: -
- 2431: -
- 2432: -
- 2433: Specifies Conformance Tests for a 3G UE to be recognised as 3GPP-standard compliant. A 3GPP-external body, GCF (Global Certification Forum), delivers certificates to prove that a UE has correctly passed tests and is then conform to the 3GPP standard.
- 2434: No CR or new TS/TR approved under this WI
- 2435: -
- 2436: measurement procedures for the conformance test of the UE that contain transmitting characteristics, receiving characteristics and performance requirements in addition to requirements for support of RRM (Radio Resource Management) in FDD mode.
- 2437: measurement procedures for the conformance test of the UE that contain transmitting characteristics, receiving characteristics and performance requirements in addition to requirements for support of RRM (Radio Resource Management) in TDD mode.
- 2438: TS 34.123, composed of three parts, actually specifies the protocol conformance testing for the 3G UE. Part 1 describes the overall test structure.
- 2439: Part 2 contains the applicability of each test case defined as the Implementation Conformance Statement (ICS) proforma, in compliance with the relevant requirements, and in accordance with the relevant guidance given in ISO/IEC 9646-7 and ETS 300 406.
- 2440: Part 3 specifies the protocol conformance testing in TTCN for the 3G UE at the Uu interface. It defines the TTCN test specification and design considerations in Abstract Test Suites based on the test cases specified in prose in part 1.
- 2441: No CR or new TS/TR approved under this WI
- 2442: No CR or new TS/TR approved under this WI
- 2443: -
- 2444: No CR or new TS/TR approved under this WI
- 2445: -
- 2446: Study on requirements for numbering and addressing for UMTS
- 2447: -
- 2448: Moved to CT1 at TSG-T closure
- 2449: Moved to RAN4 at TSG-T closure. TR summarizes differences between international and national standards relevant to IEC60950 and refers to regulations for conformity assessment due to different regulatory environments in different countries / regions.
- 2450: Moved to RAN4 at TSG-T closure.
- 2451: Moved to CT1 at TSG-T closure. Consequences on roaming capabilities and service availability (e.g. handover) of multi-mode UEs while roaming in various regions with various network configurations. Case studies for each of the possible scenarios in specs
- 2452: CP#27: Moved to C1 on closure of T2; see TP-050062. CP#28: C1->C3
- 2453: CP#27: change of WG as a result of closure of CN and T.
